# 3GPP_Release-2000

Schedule from MS Project, 1999-01-01 to 2017-06-14, A marks actual dates.

## Calendars

- Standard: Mon-Fri 08:00-12:00, 13:00-17:00; Sat-Sun off. Exceptions (off unless hours are given): 2000-01-15 08:00-12:00, 13:00-17:00, 2009-05-30 08:00-12:00, 13:00-17:00, 2011-08-27 to 2011-08-28 08:00-12:00, 13:00-17:00, 2011-09-24 08:00-12:00, 13:00-17:00, 2012-06-02 08:00-12:00, 13:00-17:00, 2012-09-01 08:00-12:00, 13:00-17:00, 2012-11-18 08:00-12:00, 13:00-17:00, 2012-11-24 08:00-12:00, 13:00-17:00, 2013-02-16 08:00-12:00, 13:00-17:00, 2013-06-02 08:00-12:00, 13:00-17:00, 2013-08-10 to 2013-08-11 08:00-12:00, 13:00-17:00, 2013-09-14 08:00-12:00, 13:00-17:00, 2014-03-01 08:00-12:00, 13:00-17:00, 2014-08-24 08:00-12:00, 13:00-17:00, 2014-09-21 08:00-12:00, 13:00-17:00, 2014-10-05 08:00-12:00, 13:00-17:00, 2016-06-18 08:00-12:00, 13:00-17:00.

## Resources

| Resource |
| --- |
| NP |
| N1 |
| N2 |
| N3 |
| N4 |
| N5 |
| TP |
| T1 |
| T2 |
| T3 |
| RP |
| R1 |
| R2 |
| R3 |
| R4 |
| SP |
| S1 |
| S2 |
| S3 |
| S4 |
| S5 |
| PCG |
| GP |
| No |
| CN4 |
| ? |
| WG G2 |
| G2 |
| G1 |
| G4 |
| G3 |
| All |
| Generic |
| MLST |
| G5 |
| S3, G2 |
| WG T2 |
| GP,G1 |
| G4,G5 |
| OMA |
| GP-G2 |
| Yes |
| GP, |
| N4, |
| GP, N1 |
| CT5 |
| C5 |
| C1 |
| C4 |
| C3 |
| C6 |
| G1, |
| 4 |
| ct |
| c,s,r |
| CT,RAN,SA |
| G2, |
| G1, G3 |
| CT6 |
| CT1 |
| CT1, CT3, CT4 |
| C1, C3, C4 |
| CP |
| R5 |
| C |
| Rel-8 |
| GP, G2 |
| R1,R4 |
| S5,C1 |
| CT,RAN,SA,GERAN |
| S3,C1,C4 |
| 5 |
| S1,C1,C3,C4,S5 |
| S1,C1,C3,C5 |
| S1,C1,C3,C4 |
| S1,S5 |
| S2,S3 |
| RAN,SA |
| RP,S5 |
| S2,CT |
| S1,CT |
| S1,CT,GERAN |
| S1,C5 |
| S3,CT |
| S4,CT |
| C1,SA |
| S1,S2 |
| S1,S4 |
| S2,S2,S3,CT |
| S2,S3,CT |
| S1,CT,GX |
| S1,S4,CT |
| S2,S2,S3,S5,CT |
| S1,S2,CT |
| S1,S2,S3,CT |
| S1,S2,S3,S5CT |
| S1,S2,S3,S5,CT |
| S2,S5,CT |
| S4,S3 |
| S1,C1 |
| CP,C1 |
| C1,C3 |
| C1,C3,C4 |
| S1,S5,CT |
| C4,C3 |
| CP,RAN,SA,GERAN |
| S1,S2,S3,S5,CP |
| S2,S3,CP |
| S2,CP |
| S1,CP,GX |
| S1,CP |
| S1,S4,CP |
| S1,S2,CP |
| S1,S2,S3,CP |
| S2,S5,CP |
| S3,CP |
| S1,S5,CP |
| RAN,SA,GERAN |
| S1,S2,S3,S5,C1,C3,C4,C6 |
| S2,S3,C1,C3,C4 |
| S2,C4 |
| S2,C1,C3,C4 |
| S2,C1,C4 |
| S2,S3,C1,C4 |
| S1,C1,C4,G2 |
| C1,C4 |
| S1,C1,C3 |
| S1,S4,C1,C3,C4 |
| S1,S2,S3,C1,C3,C4 |
| S2,S5,C3 |
| S1,S2,C1,C4 |
| S2,C1 |
| S2,C1,C3 |
| S3,C1,C3,C4 |
| S1,S5,C1,C3,C4 |
| S2,C3,C4 |
| C3,C1 |
| R2,R4 |
| R2,R5 |
| RP,R5 |
| RP,S5,R5 |
| R1,R5 |
| S1,C1,R5 |
| S1,C1,S4,R5 |
| GERAN |
| G3new |
| G1, G3new |
| C4,C1,C3 |
| R1.R4 |
| R1, R4 |
| R2,R3 |
| C3,C4 |
| S4,C3 |
| S4,C3,C1,C4 |
| S1,S2,C1 |
| S1,S2<C1,C3,C4 |
| S1,S2,C1,C3,C4 |
| S5,C1,C3,C4 |
| GP,C4 |
| C4,C1 |
| S2,S1 |
| RP,SP,GP |
| RP,SP,CP,GP |
| CP,GP,RP,SP |
| GP,C4,S4 |
| S1,C1,C4 |
| S1,S2,C3,C1 |
| R2,R4,R3 |
| CP,GP, RP,SP |
| S2,S1,C1,S5 |
| S2,S1,C1 |
| S1,C1,S4 |
| S1,S2,GP,C4,R2 |
| S1,GP,R2 |
| S1,C6 |
| S1,S2,C1,S4 |
| S2,S3,S5,C1,C3,C4 |
| S2,S5,C1 |
| S2,S3,S5 |
| CP,GP, RP,SP,TP |
| S2,C4,C1 |
| S1,C1,C4,S3 |
| S2,S5 |
| S3,C1 |
| S3,C4 |
| S1,C4 |
| S2,S5,C3,C1 |
| S2,S1,S5,C1,C4 |
| S1,R1,C3 |
| S1,C1,R2 |
| S2,S1,C1,C4 |
| S1,C1,C6 |
| GP,S4,C4,C1,C3 |
| C3,C1,C4 |
| S1,C4,C1 |
| S1,S3 |
| S1,S2,S5,C3,C4 |
| R4,G1 |
| G1,R4 |
| RP,GP |
| R4,GP |
| R3,R2 |
| C6,RP,SP |
| R5,C6 |
| CP,RP,SP |
| RP,SP,CP |
| R3,S5 |
| S1,S2,RP |
| S1,S2,S5,RP |
| S2,S1,RP |
| Rel-9 |
| S3,C6 |
| S1,S2,S3,S5,RP |
| S2,S1,S3 |
| S1,S2,S3 |
| S1,S2,S3,S5 |
| C6,R5 |
| S1,S2,RP,GP |
| S1,S2,S4,S5,RP,GP |
| GP,G2 |
| GP,GP, N1 |
| GP,S2,G1,G2 |
| GP,R2,R3,S2,G1,G2 |
| GP,S2,S5,R2,R3,G2,G1 |
| GP,R3 |
| N4,S2 |
| GP,RP |
| GP,S2,RP |
| G5,G4 |
| G4,R3 |
| S2,R2,R4 |
| S1,S2,R2,R4 |
| GP,S5 |
| S1,S2,S5 |
| R4,R5 |
| R4,R2,R3,R5 |
| S2,S5,N4,RP |
| S1,S2,S3,S5,NP |
| S2,S4,S5 |
| T2,S1,S4,S5 |
| SP,RP |
| S2,RP |
| S1,S2,CP,G2 |
| CP,SP |
| S1,G2 |
| SP,CP |
| S1,S2,S5,C3 |
| S1,C1,S3 |
| G1,G3new |
| C4, C3, C1C4 |
| C4,C3,C1 |
| S1,S2,S3,S5,R2,R3,R4 |
| S1,S2,S3,R2 |
| S2,S3,S5,C4,R2 |
| S1,S5,C1 |
| S1,S2,S3,C1,C3,C4,R2 |
| Ggp |
| S3,S2,C1,C4,G2 G3new |
| R1,R2,R3,R4 |
| R4,R1,R2,R3 |
| R4,R2,R3 |
| S1,C1,C4,R2 |
| R4,R2 |
| S2,C4,R2,R4 |
| S2,C4,R2 |
| S2,S3,S5,C3,C4,R2 |
| S1,S2,S4,T2 |
| S1,S2,S4 |
| S1,S2,S4,R5 |
| S3,S2,C1,C4,G2,G3new |
| GP,C1 |
| S1,S5,C4 |
| S1,S2,S3,S5,R2,R3,R4,GP |
| GP,C4,C3,C1 |
| SMG9 |
| SMG1 |
| SMG2 |
| N3,R5 |
| N1, N2, N4, G1, G2, R3, S1, SMG2 |
| S1,SMG1 |
| SMG1,N4 |
| N1,C1,N4,S1,T2,G2,SMG1,SMG2,SMG3,SMG7,SMG9 |
| SMG1,N2 |
| S1,S2,N2,N4 |
| N4,N2 |
| G1,G2 |
| G1,G2,C1 |
| G1,G2,N1 |
| SMG2, SMG1, SMG3, SMG4, SMG7, SMG9, SMG10, G1, G2, G3, N1, N3, T2 |
| SMG2,G1 |
| S1,G1,G2 |
| SMG1,N1,G1,G2 |
| G2,G1 |
| G1,G2,G3,S1,S2,SMG1,SMG2,SMG7,N1,N2,N3,N4,T2 |
| 23.003, 23.008, 29.060 |
| S1, S2, SMG1, SMG2, SMG12, G2, N1, N2, N4 |
| S1,S2,SMG1,SMG2,SMG12,G2,N1,N2,N4 |
| S1,SMG2,N1,N2,N4 |
| SMG1,T2 |
| S1,N1,N2,N4 |
| S1,S2,N5 |
| SMG2,SMG7,G2,T2 |
| S3,N1,N2,N3 |
| S3,N1,N2,N4 |
| SMG9,T3 |
| SMG2,SMG3,SMG7,G2,N2 |
| SMG2,N1,G1,G2 |
| S1,N2 |
| N1,N3 |
| S2,N1 |
| N1,N2,N4 |
| N2,N1,N4 |
| N2,N4 |
| S1,T3 |
| T2,N3 |
| S3,N2 |
| T2,S1 |
| S1,N4 |
| SMG1,SMG2,SMG7 |
| N1,S1,T1 |
| SMG1,SMG3 |
| N4,S2,N1 |
| S1,S2,SMG1,SMG2,SMG7,G1,G2,G3,N1,N2,N3,N4,T2 |
| SMG1,N3 |
| S1,N3 |
| CP,SP,SMG |
| CP,SP,TP,GP,SMG |
| NP,SP,TP,GP,SMG |
| NP,GP, RP,SP,TP |
| SMG2,SMG1,SMG3,SMG4,SMG7,SMG9,SMG10,G1,G2,G3,N1,N3,T2 |
| S1,N2,N4 |
| S1,S2,S3,C1,C3,C4,R2,R3 |
| R2,R3,R1,R4 |
| R2,R3,R4 |
| R2,R1,R3,R4 |
| S2,C4,R2,R3,R4 |
| S2,C4,R2,R1,R3,R4 |
| S2,S3,S5,C3,C4,R2,R3,R4 |
| R1,R2,R4 |
| R3,R1,R4 |
| S2, |
| S2,G2, |
| S1,S2,G2, |
| S1,S2,G2,R2,R3, |
| S1,S2,C4,G2,R2,R3 |
| S1,S2,N4,G2,R2,R3 |
| S1,S2,SMG1,SMG2,SMG12,G2,N1,N2,N4,R2,R3 |
| S1,SMG1,T2 |
| S1,SMG1,S2 |
| S1,N4,N2 |
| T2,N1,N3 |
| S3,N2,N4 |
| SMG1,SMG2,SMG3,SMG7,SMG9,N1,C1,N4,S1,T2,G2 |
| SMG1,N2,N4 |
| S2,T2,N1,N2,N4 |
| S1,T2 |
| S1,S2,C4 |
| S1,S2,N4,RP |
| S2,N4 |
| S1,S2,N3,N4,RP |
| S1,S2,SMG1,SMG2,SMG12,T2,G2,N1,N2,N4,R2,R3 |
| S1,T2,N1,N3 |
| S1,S2,SMG1,SMG2,SMG12,T2,G2,N1,N2,N3,N4,R2,R3 |
| S1,S2,S3,SMG1,SMG2,SMG12,G2,N1,N2,N4,R2,R3 |
| S1,S2,SMG,G1,G2,G3,N1,N2,N3,N4,T2 |
| S1,S2,SMG,T2,G2,N1,N2,N3,N4,R2,R3 |
| S1,S3,SMG,G1,G2,G3,N1,N2,N3,N4,T2 |
| S1,S3,T2,N2,N4 |
| S1,S2,SMG,T2,G1,G2,G3,N1,N2,N3,N4 |
| G2,S2 |
| T1,R5 |
| R5,T1 |
| S1,S2,S4,T1,R5 |
| S1,S2,S4,S5,T1,RP,GP |
| S1,S2,S3,S5,R2,R3,R4,GP,C1 |
| S1,S2,S3,SMG1,SMG2,SMG12,N1,N2,N4,R2,R3 |
| S1,S2,SMG,T2,N1,N2,N3,N4,R2,R3 |
| NP,SP,TP,SMG |
| S1,S2,SMG,T2,N1,N2,N3,N4 |
| SMG,N1 |
| SMG |
| S1,S2,SMG1,SMG2,SMG7,N1,N2,N3,N4,T2 |
| SMG2,SMG1,SMG3,SMG4,SMG7,SMG9,SMG10,N1,N3,T2 |
| S1,SMG |
| SMG2,SMG7,T2 |
| SMG2,S2 |
| N1,N2,N4,R3,S1,SMG |
| SMG2,SMG3,SMG7,N2 |
| SMG1,SMG2,SMG3,SMG7,SMG9,N1,C1,N4,S1,T2 |
| S1,S2,SMG,N3,N4,RP |
| S1,S2,S4,SMG,N3,N4,RP |
| S2,C1,C4,R2,R1,R3,R4 |
| R2,S2,S4 |
| G3new,R5 |
| GP,R4 |
| S2,S4,R2 |
| SP,GP |
| RP,SP |
| S2,S1,S3,S5 |
| S3,S1 |
| N4,N1,N2,S2 |
| S2,G1,G2,R2,R3 |
| S2,G1,G2 |
| G1,G2,R2,R3 |
| N4,T3 |
| S3,S2,N1,N4,T3,OMA |
| T2,S1,S4,S5,OMA |
| S2,N3 |
| S4,S1 |
| N4,N3,S1 |
| R5,G3new |
| R4,R2,R1 |
| S2,R2 |
| C3, C4,C1 |
| S3,C1,C4,C3 |
| C1,C4,C3 |
| S2,C1,C4,C3 |
| R3,R5 |
| S1,S2,C3 |
| R1,R2 |
| S3,C1,C4,G2,G3new |
| R1,R3 |
| GP,N1 |
| R1,R2,R3 |
| R3,R2,R4 |
| R4,R3 |
| S1,S2,R2,R3 |
| S1,S2,S3,C1,C3,C4,R2,R3,R5 |
| S2,S1,S5 |
| C4, C1 |
| C3, C1, C4 |
| S2,S1,S3,S5,C4,C1 |
| S2,C3,C1,C4 |
| S2,S1,S5,C3 |
| GP,S2,C1 |
| GP,S2,C1,G2 |
| G2,S2,C1 |
| v |
| G3new,G1,G2 |
| G1,G2,C1,G3new |
| S2,S1,S5,C1,C3 |
| C1,C3,C4,R5 |
| R2,R1 |
| S1<S2,N1,R2,R5 |
| S1,S2,N1,R2,R5 |
| S2,R5 |
| S1,S2,S5,R5 |
| S2,C1,C4,R2,R1,R3,R4,R5 |
| S1,S2,S3,S5,NP,R5 |
| S1,S2,S4,S5,RP,R5,GP |
| S1,S2,S3,S5,C1,C6,R2,R3,R4 |
| S1,S2,S3,S5,C1,C6,R2,R3,R4,GP |
| S4,R2 |
| S1,S2,C1,C4,G2 |
| S4,C3,C4 |
| S5,C1,C4 |
| S2,C4,C3,C1 |
| C4, C3, C1 |
| S2,S4,R2,C4,C3,C1 |
| GP1,GP2 |
| GP,GP1,GP2 |
| GP,G1,G2 |
| G2,R3 |
| S1,S2,S3,C1,C3,C4,G2 |
| GP,G1,C1 |
| S1,S2,C4,C3,C1 |
| - |
| GP,G1,G2,G3new |
| S1,S2,S3,C1,C3,C4,G2,R2,R3 |
| S1,S2,C1,C3,C4,G2,R2,R3 |
| C1,C6 |
| GP,G2,C4 |
| S2,C3 |
| R5,R4 |
| C4,GP,G2 |
| S1,S2,C1,C4,G2,R2,R3 |
| R1,R2,R4,S3 |
| S2,S5,C3,C1,C4 |
| S2,S4,C4,C3,C1 |
| S2,S4 |
| S3,S1,S2 |
| S1,S2,S3,C1,R2 |
| S3,S1,S2,C1,R2 |
| S2,C3,S5 |
| S1,S2,C1,C4,C3,G2,R2,R3 |
| S5,C4 |
| S2,S1,C3 |
| C1,C4,C3,C6 |
| S1,S2,C1,C4,C3,C6,G2,R2,R3 |
| R1,R2,R4,S3,C4,C6 |
| R4,R1,R4,R1,R2,R3,R3 |
| S2,R3,R2 |
| S1,S2,S5,CP |
| S1,S3,CP |
| C6,C1 |
| R4,R2,R1,R3 |
| R3,R1,R2 |
| R1,R4,R2,R3 |
| S2,C4,C1,C3 |
| R3,R1,R2,R4 |
| C4,S1 |
| S2,S5,R3,GP, |
| S2,S5,R3,GP |
| S1,S2,S3,S5,C1,C3,C4 |
| S2,S3,S5,C1,C3,C4,C6 |
| S5,S1 |
| 03.06.2011 |
| CT1 CT3, CT4 |
| CT3, |
| CT4 |
| CT3 |
| GP,G2,G1 |
| S5,S1,C1 |
| SP,RP,CP |
| SP,CP,GP,RP |
| R1,R2,R4,R3 |
| R4,R2,R5 |
| R2,R4,R5 |
| R1,R2,R4,S2,S3,C4,C6 |
| C1-IETF |
| S4-IETF |
| C1-IETF, C3-IETF, C4-IETF |
| S3-IETF |
| C4-IETF |
| C1-IETF, C3-IETF |
| S2,S4,C1,R2 |
| S2,S4,C3,C4 |
| S2,S4,C1,C3,R2 |
| S1,S2,C1,IETF |
| S4,IETF |
| C1,C4,IETF |
| S2,S4,C1,C3,R2,IETF |
| S3,C1,C4,C3,IETF |
| S3,C4,IETF |
| C1,IETF |
| S1,S2,S3,S5,C1,C3,C4,C6,IETF |
| S2,S3,C1,C4,IETF |
| S1,S2,C1,C3,C4,IETF |
| C1,C3,C4,IETF |
| S1,S5,C1,C3,C4,IETF |
| C1,C3,IETF |
| S2,C1,C3,C4,IETF |
| S2,S4,C3,C4,IETF |
| S5,C1,C4,IETF |
| S5,C1,C3,C4,IETF |
| S2,S3,S5,C1,C3,C4,IETF |
| S2,IETF |
| S3,C1,C3,C4,IETF |
| S2,S3,C1,C3,C4,IETF |
| S3,S2 |
| S3,S2,C1 |
| S3,S1,S2,C1 |
| S2,S5,N3 |
| S1,S2,S3,S5,N1,N3,N4,T3 |
| S5,N4,R3 |
| S1,S2,S5,C1,C4,C3,C6,G2,R2,R3 |
| S2,N1,N4,R3,GP |
| T2,S3 |
| S3,N4,N1 |
| S2,N3,N4 |
| S3,T2 |
| S2,S1,S3,S5,RP,GP |
| S1,S2,S3,S5,R5 |
| S1,S2,S3,S5,NP,T3,T1,R5 |
| S3,T3 |
| GP,S3 |
| S1,S2,S3,S4,S5,RP,R5,GP |
| N1,N4 |
| S1,S2,S3,S4,N1,N3,N4,OMA |
| S2,C1,C3,C4,G2,R2,R3 |
| S1,C4,C3 |
| S2,S1,C1,C4,IETF |
| C1,C3,C4,C6 |
| C4,C1,C6 |
| S1,S2,S3,C1,C3,C4,C6 |
| S2,S1,C1,C3,C4 |
| S1,S2,C1,C3 |
| C1.IETF |
| C1-IETF,C4-IETF |
| G1,C1 |
| G1,S2,C4 |
| G2,S2,C4 |
| R1,R2,R3,R4,R5 |
| R2,R4,R3,R5 |
| R3,R2,R5 |
| R2,R3,C1,C6 |
| S1,S2,S3,C1,C3,C4,C6,R2,R3 |
| R4,R1 |
| S2,S4,C4,C3,C1,IETF |
| S2,C4,C3 |
| S3.C4,C1 |
| G2,C4 |
| R4,G1,G3new |
| C4,G2 |
| S3,C4,C1 |
| R2,R3,R5 |
| R1,R2,R4,R5 |
| S1,S2,S3,S5,C1,C6,R2,R3,R4,R5,GP |
| S1,C1,C4,R2,R5 |
| S2,S3,S5,C3,C4,R2,R3,R4,R5 |
| R2,R1,R3,R4,R5 |
| S3-IETF, C1-IETF |
| S3-IETF,C1-IETF |
| C1-IETF,C3-IETF |
| S2-IETF |
| S2,S1,C1,C3,C4,IETF |
| 25.101, 25.104, 25.141, 25.317 |
| S1,G2,S2,C1 |
| S1,C1,C4,R2,R3,R5 |
| S5,S2 |
| S4,C3,C4,IETF |
| S4,S3,C3,C4,IETF |
| S4,S3,C3,C4 |
| S4,S3,IETF |
| S1,S2,S3,S5,C1,C3,C4,C6,R2,R3 |
| C1,C4,C6 |
| S1,S2,S5,C1,C4,C6,G2,R2,R3 |
| GP,G1,C1,G3new |
| S2,S5,C1,C3 |
| C4,C3,G2 |
| S2,S1,S5,C3,C1,C4 |
| C3,C4,C1 |
| S2,S1,S5,C3,C4,C1 |
| RAN1 |
| RAN2 |
| RAN3 |
| RAN4 |
| R4,R2,R3, |
| Feasibility Study on LTE Device to Device Communications – Radio Aspects |
| SMG1,SMG2,SMG3,SMG7,SMG9,N1,N4,S1,T2 |
| C3-IETF, C4-IETF |
| S3-IETF,C1-IETF,C3-IETF |
| C3-IETF |
| C3,IETF |
| S2,C1,C4,C3,IETF |
| S1,S2,S3,C1,C3,C4,R2,R3,R5,IETF |
| C1-IETF,C3-IETF,C4-IETF |
| C4,C1,C3,IETF |
| S2,C4,C1,C3,IETF |
| C1,C4,C3,IETF |
| S2,S1,T2,N1,N4,R3,R2 |
| S2,S1,S2,S1,N1,N4 |
| S2,S1,N1,N4 |
| S2,R2,G1 |
| S2,S1,S3,S5,N4,R2,R3,GP |
| S1,S2,N4 |
| S2,OMA |
| S2,N4,OMA |
| S2,S5,N4,R2,R4 |
| S2,S5,N4,R2,R4,OMA |
| GP,R2 |
| S1,S2,GP,R2 |
| G1,G3 |
| S1,G2,R2 |
| S2,S5,N4,R2,R4,R5,OMA |
| SR5 |
| S3,C4,C1,R5 |
| S3,S1,C1 |
| S2,C4,C3,G2 |
| SP,CP,RP |
| S3,R5 |
| GP,G2,G3new |
| S1,S2,S3,S4,S5,N1,N3,RP,R5,GP |
| S1,S2,S3,S4,S5,N1,N3,RP,R5,T1,GP |
| S1,S2,S3,S4,S5,N1,N3,RP,R5,T1,GP,G2,G3new |
| S1,S2,S3,S4,S5,N1,N3,R2,R4,R5,T1,GP,G2,G3new |
| S1,S2,S5,C1,C4,C6,G2,R2,R3,G3new |
| SP,CP,RP,GP |
| G2,G1,G3new |
| G2,G1,C1,G3new |
| RAN |
| R |
| S2,S1,S3,S5,R2 |
| S2,S1,S3,S5,R2,R3 |
| S1,S2,S5,C1,C4,C6,G2,R2,R3,R5,G3new |
| C1,C4,R5,IETF |
| C1,R5 |
| R3,R1 |
| R3,GP |
| S3,IETF |
| S1,S2,S5,C1,C3,C4,C6,R2,R3 |
| S3,C4,C1,C3 |
| C1,C4,S1 |
| C1,C4,R3 |
| R2,R1,R3 |
| R1,R4,R2,R3,R5 |
| RAN5 |
| S2,C4,C1,R3 |
| G1,G2,G3new |
| S4,C1 |
| S4,C4,C1,C3 |
| 14/06/2013 08:00 |
| S2,C1,C3,IETF |
| C3, C1 |
| R3,C4 |
| S2,S1,C1,C3 |
| R3,S2,C4 |
| R% |
| G1,C1,G3new |
| R3,S2,C4,G2 |
| S1,S3,N4 |
| S1,OMA |
| S1,S2,S4,OMA |
| S5,S2,N3 |
| S3,C4,C1,C3,IETF |
| S1,S2,S5,C1,C3,C4,C6,R2,R3,R5 |
| S2,S1,S5<c3 |
| S2,C1,C4,C6 |
| S2,S1,S3,C1,C4,C6 |
| S2,S1,S3,C1 |
| R2,R3,R4,G2,G1,G3new |
| C1,C3,R5 |
| ,C4,C6 |
| S2,S1,S3,C1,C4,C6,R2 |
| S2,S1,S3,C1,C4,C6,R2,R3 |
| S2,S1,S3,C1,C3,C4,C6,R2,R3 |
| S1,S2,S3,IETF |
| S1,S2,S3,C1,C3 |
| S1,S2,S3,C4,C1,C3 |
| C1,S1 |
| C34 |
| S1,S2,S3,C1,C4,IETF |
| IETF |
| SMG12 |
| SMG7 |
| SMG3 |
| SMG4 |
| SMG10 |
| C3-IETF,C4-IETF |
| NP,GP,RP,SP,TP |
| S3,G2 |
| R2,S2 |
| R2,S2,C1 |
| R2,C1 |
| S1` |
| R2,S1,C1 |
| C1-IET |
| 18/06/2014 08:00 |
| C4-IET |
| RAN1 (primary) |
| C3.S2 |
| C3-IET |

## Schedule

| ID | WBS | Task | Duration | Start | Finish | Complete | Remaining | Baseline start | Baseline finish | Baseline duration | Total slack | Constraint | Resources | Work | Actual work | Release | Acronym | PCG approved | Impacted TSs and TRs | WI rapporteur name | WI rapporteur e-mail | TSG approved | MCC resp | Status Report | Acronym_3GU_Export | Special Focus Doc |
| --- | --- | --- | --- | --- | --- | --- | --- | --- | --- | --- | --- | --- | --- | --- | --- | --- | --- | --- | --- | --- | --- | --- | --- | --- | --- | --- |
| 1 | 1 | Release 14 Features | 655d? | 2014-12-12 | 2017-06-14 |  |  |  |  |  | 0d | start no earlier than 2014-12-12 | SP; RP; CP; GP | 20960h |  | Rel-14 |  |  |  |  |  |  |  |  |  |  |
| 2 | 2 | Release 14 Studies | 323d? | 2014-09-17 A | 2015-12-11 | 10% | 290.7d? |  |  |  | 394d | finish no earlier than 2015-12-11 | SP; RP; CP; GP | 10336h | 1033.6h | Rel-14 |  |  |  |  |  |  |  |  |  |  |
| 3 | 3 | Study on need for Multiple Access Point Names | 464d? | 2013-09-12 A | 2015-06-19 | 60% | 186.1d? | 2013-09-12 | 2014-12-10 | 327d? | 519d | finish no earlier than 2015-06-19 | S1 | 3704h | 2215.2h | Rel-14 | FS_MAPN | PCG-31 | 22.802 | Giesecke & Devrient | Ilario.macchi@gi-de.com | SP-61 | Alain | S1-143308 | FS_MAPN |  |
| 4 | 4 | Study on Multimedia Broadcast Supplement for Public Warning System (PWS) | 264d? | 2013-12-11 A | 2014-12-12 A | 100% |  | 2013-12-11 | 2014-09-17 | 202d? |  | finish no earlier than 2014-12-12 | S1 | 2104h | 2104h | Rel-14 | FS_MBSP | PCG-32 | 22.815 | Qualcomm | Eddy Hall (edhall@qti.qualcomm.com) | SP-62 | Alain | S1-143312 | FS_MBSP | Public Safety (I-A) |
| 5 | 5 | Study on service aspects for dealing with User Control over spoofed calls | 271d? | 2014-03-07 A | 2015-03-20 | 67% | 90.1d? | 2014-03-07 | 2014-12-10 | 199d? | 584d | finish no earlier than 2015-03-20 | S1 | 2168h | 1447.2h | Rel-14 | FS_UC_SPOOF | PCG-32 | 22.898 | Sprint | Gregory.schumacher@sprint.com | SP-63 | Alain | S1-143314 | FS_UC_SPOOF |  |
| 6 | 6 | Study on User Location Reporting Support enhancements | 261d? | 2014-06-19 A | 2015-06-17 | 70% | 78.3d? | 2014-06-18 | 2015-06-17 | 261d? | 521d | finish no earlier than 2015-06-17 | S1 | 2088h | 1461.6h | Rel-14 | FS_eULRS | PCG-33 | 22.899 | China Unicom | Zhuoyun Zhang ( zhangzy910@chinaunicom.cn) | SP-64 |  | S1-143315 | FS_eULRS |  |
| 7 | 7 | Study on Control of Applications when Third party Servers encounter difficulties | 196d? | 2014-06-19 A | 2015-03-18 | 60% | 78.4d? | 2014-06-18 | 2014-12-10 | 126d? | 586d | finish no earlier than 2015-03-18 | S1 | 1568h | 940.8h | Rel-14 | FS_CATS | PCG-33 | 22.818 | KDDI | Eriko Yoshida (er-yoshida@kddi.com) | SP-64 |  | S1-143316 | FS_CATS |  |
| 8 | 8 | Release 13 Features | 183.25d? | 2013-09-12 A | 2015-12-25 | 25% | 137.44d? | 2015-04-14 | 2015-12-25 | 183.25d? | 384d | finish no earlier than 2015-12-25 | SP; RP; CP; GP | 5864h | 1466h | Rel-13 |  |  |  |  |  |  |  |  |  |  |
| 9 | 9 | **Service Exposure and Enablement Support** | 268d? | 2013-09-12 A | 2014-09-17 A | 100% |  | 2013-09-12 | 2014-09-17 | 267d? |  |  | S1 | 5880h | 5880h | Rel-13 | SEES | PCG-31 | Stage 1 | KPN | toon.norp@tno.nl | SP-61 | Alain | S1-143301 | SEES | MTC, M2M |
| 10 | 9.1 | TR on Stage 1 for Service Exposure and Enablement Support | 202d? | 2013-09-12 A | 2014-06-18 A | 100% |  | 2013-09-12 | 2014-06-18 | 202d? |  | finish no earlier than 2014-06-18 | S1 | 1608h | 1608h | Rel-13 | SEES-ST1TR | PCG-31 | New TR 22.853 | KPN | toon.norp@tno.nl | SP-61 | Alain | S1-143301 |  | MTC, M2M |
| 11 | 9.2 | Stage 1 for Service Exposure and Enablement Support | 266d? | 2013-09-12 A | 2014-09-17 A | 100% |  | 2013-09-12 | 2014-09-17 | 266d? |  | finish no earlier than 2014-09-17 | S1 | 2128h | 2128h | Rel-13 | SEES-ST1 | PCG-31 | 22.101, 22.115, 22.368, TBD | KPN | toon.norp@tno.nl | SP-61 | Alain | S1-143301 |  | MTC, M2M |
| 12 | 10 | Service Requirements Maintenance for Machine-Type Communications (MTC) | 201d? | 2013-12-13 A | 2014-09-17 A | 100% |  | 2013-12-12 | 2014-12-10 | 261d? |  | finish no earlier than 2014-09-17 | S1 | 1608h | 1608h | Rel-13 | SRMMTC | PCG-32 | 22.368 | KPN | toon.norp@tno.nl | SP-62 | Alain |  | SRMMTC | MTC, M2M |
| 13 | 11 | Isolated E-UTRAN Operation for Public Safety | 140d? | 2014-03-07 A | 2014-09-17 A | 100% |  | 2014-03-07 | 2014-09-17 | 139d? |  | finish no earlier than 2014-09-17 | S1 | 1120h | 1120h | Rel-13 | IOPS | PCG-32 | New TS 22.346 | General Dynamics | paul.piggin@gd-broadband.com | SP-63 | Alain | S1-143304 | IOPS | Public Safety (A-A) |
| 14 | 12 | Service Requirements Maintenance for Group Communication System Enablers for LTE | 67d? | 2014-06-18 A | 2014-09-17 A | 100% |  | 2014-06-18 | 2014-09-17 | 66d? |  | finish no earlier than 2014-09-17 | S1 | 536h | 536h | Rel-13 | SRM_GCSE_LTE | PCG-33 | 22.468 | Nokia Networks | Juergen.Merkel@nsn.com | SP-64 |  | S1-143307 | SRM_GCSE_LTE | Public Safety (A-A) |
| 15 | 13 | **Co-ordinated packet data network gateway (P-GW) change for SIPTO** | 264d? | 2014-06-18 A | 2015-06-17 | 32% | 179.83d? | 2014-06-18 | 2014-09-17 | 66d? | 521d |  | S1 | 3768h | 1056h | Rel-13 | CSIPTO | PCG-33 | 22.101 | Intel | Eric.siow@intel.com | SP-64 |  | S1-143306 | CSIPTO |  |
| 16 | 13.1 | Stage 1 for Co-ordinated packet data network gateway (P-GW) change for SIPTO | 66d? | 2014-06-18 A | 2014-09-16 A | 100% |  | 2014-06-18 | 2014-09-17 | 66d? |  | finish no earlier than 2014-09-17 | S1 | 528h | 528h | Rel-13 | CSIPTO-ST1 | PCG-33 | 22.101 | Intel | Eric.siow@intel.com | SP-64 |  | S1-143306 | CSIPTO |  |
| 17 | 13.2 | Feasibility Study on Co-ordinated P-GW Change for SIPTO - Stage 2 | 141d? | 2014-12-03 | 2015-06-17 |  |  |  |  |  | 521d | finish no earlier than 2015-06-17 | S2 | 1128h |  | Rel-13 | FS_CSIPTO_SA2 |  |  |  |  | SP-66 |  |  |  |  |
| 18 | 14 | **Application specific Congestion control for Data Communication** | 261d? | 2014-06-18 A | 2015-06-12 | 33% | 175.28d? | 2014-06-18 | 2014-09-17 | 66d? | 524d |  | S1 | 3720h | 1064.12h | Rel-13 | ACDC | PCG-33 | 22.011 | NTT DOCOMO | Atsushi Minokuchi (minokuchi@nttdocomo.co.jp) | SP-64 |  | S1-143305 | ACDC |  |
| 19 | 14.1 | Stage 1 for Application specific Congestion control for Data Communication | 67d? | 2014-06-18 A | 2014-09-17 A | 100% |  | 2014-06-18 | 2014-09-17 | 66d? |  | finish no earlier than 2014-09-17 | S1 | 536h | 536h | Rel-13 | ACDC-ST1 | PCG-33 | 22.011 | NTT DOCOMO | Atsushi Minokuchi (minokuchi@nttdocomo.co.jp) | SP-64 |  | S1-143305 | ACDC |  |
| 20 | 14.2 | Stage 3 for Application specific Congestion control for Data Communication | 137d? | 2014-12-04 | 2015-06-12 |  |  |  |  |  | 524d | finish no earlier than 2015-06-12 | C1 | 1096h |  | Rel-13 | ACDC-CT |  | TS 24.105, 24.301, 24.008, 27.007, 31.102 | LGE |  | CT-66 |  |  |  |  |
| 21 | 15 | Enhanced Calling Information Presentation | 2d? | 2014-09-15 A | 2014-09-16 A | 100% |  | 2013-12-11 | 2014-09-17 | 201d? |  | finish no earlier than 2015-06-16 | S1 | 16h | 16h | Rel-13 | ECIP | PCG-32 | 22.182 (CAT), 22.183 (CRS) | China Mobile | LI Xiaofan (lixiaofan@chinamobile.com | SP-62 | Alain | S1-143311 | ECIP |  |
| 22 | 16 | **Flexible Mobile Service Steering** | 200d? | 2014-09-15 A | 2015-06-17 | 9% | 182.96d? | 2013-12-11 | 2014-09-17 | 202d? | 521d |  | S1 | 3767.76h | 320.86h | Rel-13 | FMSS | PCG-33 | 22.101 | China Mobile | Lu Lu (lulu@chinamobile.com) | SP-65 | Alain | S1-143310 | FMSS |  |
| 23 | 16.1 | Stage 1 for Flexible Mobile Service Steering | 3d? | 2014-09-15 A | 2014-09-17 A | 100% |  | 2013-12-11 | 2014-09-17 | 202d? |  | start no earlier than 2014-09-15 | S1 | 23.85h | 23.85h | Rel-13 | FMSS-ST1 | PCG-33 | 22.101 | China Mobile | Lu Lu (lulu@chinamobile.com) | SP-65 | Alain | S1-143310 | FMSS |  |
| 24 | 16.2 | Flexible Mobile Service Steering TR Phase | 134d? | 2014-12-12 A | 2015-06-17 | 15% | 113.9d? |  |  |  | 521d | finish no earlier than 2015-06-17 | S2 | 1072h | 160.8h | Rel-13 | FMSS-SA2TR |  |  | China Mobile |  | SP-66 |  |  |  |  |
| 25 | 16.3 | Flexible Mobile Service Steering - Stage 2 | 134d? | 2014-12-12 | 2015-06-17 |  |  |  |  |  | 521d | start no earlier than 2014-12-12 | S2 | 1072h |  | Rel-13 | FMSS-SA2 |  |  | China Mobile |  | SP-66 |  |  |  |  |
| 26 | 17 | GERAN UTRAN Sharing Enhancements | 63d? | 2014-09-19 A | 2014-12-12 A | 100% |  |  |  |  |  | finish no earlier than 2014-12-12 | S1 | 504h | 504h | Rel-13 | GUSH | PCG-33 | 22.101 | Telefónica | chris.friel@telefonica.com | SP-65 |  | SP-140515 | GUSH |  |

Notes:
- 1: -
- 2: -
- 3: SP#65 moved to Rel-14. Completion 12/14=>03/15. Triggered by S1-133134 LS on GSMA Connected Living Programme Request for APN Storage in the SIM. LM: 50->70%, CD: 03/15->06/15
- 4: SP#65 completion 09/14=>12/14. Moved to Rel-14. TR 22.815v100 for Information. Linked to Rel-9 Feature PWS. LM:70->100%
- 5: SP#65 moved to Rel-14. TR 22.898v100 for Information. Linked to SA3 Rel-11 TR 33.838 PUCI and Rel-12 ongoing study TR 33.831 (FS_SPOOF). LM: 70->90, CD: 12/14->03/15
- 6: SP#65 moved to Rel-14. Linked to Rel-12 SA2 TR 23.843 Study on Core Network Overload solutions (FS_CNO) and Rel-13 Feature Service Exposure and Enablement Support (SEES). LM: 30->70
- 7: SP#65 completion 12/14=>03/15. Moved to Rel-14. Linked to Rel-13 Feature SEES and Rel-13 TR 22.806 (FS_ACDC). LM: 30->60%, WID SP-140246->SP-140758, CD: 12/14->03/15
- 8: -
- 9: SP#62 completion 06/14=>09/14. Linked to Rel-12 Study TR 22.888 (FS_MTCe) and to Features Rel-11 SIMTC & Rel-12 MTCe and MOSAP
- 10: SP#64 completed. TR 22.853v200 for Approval. External requirements from oneM2M TR0001(oneM2M Use Case collection), TS0002 (M2M Requirements)
- 11: SP#65 completed
- 12: SP#65 completed. Linked to Rel-13 SEES, Rel-12 Support for Interworking with M2M Service Enablement (MTCe-SIMSE), Service Requirement Maintenance (MTCe-SRM). Decide which MTC reqs with no Stage 2 should be removed/maintained in Rel-13.
- 13: SP#65 completed. TS 22.346v100 for 1-step Approval. Triggered by Rel-13 TR 22.897 (FS_IOPS)
- 14: SP#65 completed. Some Rel-12 service reqs have no Stage 2/3 implementation
- 15: SP#65 completed. Updated WID SP-140235=>SP-140509. Triggered by Rel-13 Study TR 22.828 (FS_CSIPTO)
- 16: SP#65 completed. Updated WID SP-140235=>SP-140509. Triggered by Rel-13 Study TR 22.828 (FS_CSIPTO). LM: former S1-only feature split
- 18: SP#65 completed. Triggered by Rel-13 Study TR 22.806
- 19: Results from MCC Split of the SA1 feature into F+BB for stage 1
- 20: Presented at CT#66
- 21: SP#65 approved WID & completed. Triggered by Rel-13 TR 22.810. Linked to Multimedia Telephony Service for IMS (UID_7038), Customized Alerting Tone (CAT) UID_370028, Customized Ringing Signal (CRS) UID_380067
- 22: SP#65 WID approved & completed. Triggered by Rel-13 TR 22.808 (FS_FMSS)
- 23: SP#65 WID approved & completed. Triggered by Rel-13 TR 22.808 (FS_FMSS). LM: moved from Feature to S1 BB
- 24: proposed at SA#66
- 25: proposed at SA#66
- 26: SP#65 exception in SP-140515. Triggered by TR 22.852 (FS_RSE and FS_GUSH). Completed.

| ID | WBS | Task | Duration | Start | Finish | Complete | Remaining | Baseline start | Baseline finish | Baseline duration | Total slack | Constraint | Resources | Work | Actual work | Acronym | PCG approved | WI rapporteur name | WI rapporteur e-mail | Release | TSG approved | MCC resp | Acronym_3GU_Export | PCG stopped | TSG stopped | Special Focus Doc | Status Report |
| --- | --- | --- | --- | --- | --- | --- | --- | --- | --- | --- | --- | --- | --- | --- | --- | --- | --- | --- | --- | --- | --- | --- | --- | --- | --- | --- | --- |
| 27 | 18 | **User Plane Congestion management** | 828d? | 2012-02-02 A | 2015-03-18 | 85% | 125.66d? | 2012-02-02 | 2015-06-17 | 890d? | 586d |  | S1; S2; C3; C4 | 47936h | 25324.1h | UPCON | PCG-29 | KDDI | Eriko Yoshida (er-yoshida@kddi.com) | Rel-13 | SP-57 | Alain | UPCON |  |  |  |  |
| 28 | 18.1 | Stage 1 for User Plane Congestion management | 289d? | 2012-02-02 A | 2013-03-06 A | 100% |  | 2012-02-02 | 2013-03-06 | 289d? |  | finish no earlier than 2013-03-06 | S1 | 2304h | 2304h | UPCON-ST1 | PCG-29 | KDDI | Eriko Yoshida (er-yoshida@kddi.com) | Rel-13 | SP-57 | Alain |  |  |  |  |  |
| 29 | 18.2 | TR on Stage 2 for User Plane Congestion management | 595d? | 2012-12-12 A | 2015-03-18 | 98% | 11.9d? | 2012-12-12 | 2014-12-10 | 525d? | 586d | finish no earlier than 2015-03-18 | S2 | 4760h | 4664.8h | UPCON-SA2TR | PCG-30 | Allot | Alla Goldner (agoldner@allot.com) | Rel-13 | SP-58 | Maurice |  |  |  |  |  |
| 30 | 18.3 | Deleted - Stage 2 for User Plane Congestion management | 261d? | 2012-12-19 A | 2013-12-11 A | 100% |  | 2012-12-19 | 2013-12-11 | 261d? |  | finish no earlier than 2013-12-11 | S2 | 2088h | 2088h | UPCON-SA2Del | PCG-30 | NEC | andreas.maeder@neclab.eu | Rel-13 | SP-58 | Maurice |  | PCG-32 | SP-62 |  |  |
| 31 | 18.4 | **BB1: RAN Downlink Traffic Differentiation, Congestion Detection and Reporting** | 269d? | 2014-03-07 A | 2015-03-13 | 57% | 116.65d? | 2014-03-07 | 2015-06-17 | 334d? | 589d |  | S2 | 10048h | 4747.29h | UPCON-DOTCON | PCG-32 | Allot | Alla Goldner (agoldner@allot.com) | Rel-13 | SP-63 | Maurice | UPCON-DOTCON |  |  |  |  |
| 32 | 18.4.1 | Stage 2 for RAN Downlink Traffic Differentiation, Congestion Detection and Reporting | 201d? | 2014-03-07 A | 2014-12-12 A | 100% |  | 2014-03-07 | 2015-06-17 | 334d? |  | finish no earlier than 2014-12-12 | S2 | 1608h | 1608h | UPCON-DOTCON-SA2 | PCG-32 | Allot | Alla Goldner (agoldner@allot.com) | Rel-13 | SP-63 | Maurice |  |  |  |  |  |
| 33 | 18.4.2 | **CT aspects of User Plane Congestion Management for BB1** | 262d? | 2014-03-18 A | 2015-03-13 | 40% | 157.2d? |  |  |  | 589d |  | C3 | 6288h | 2515.2h | UPCON-DOTCON-CT | PCG-33 | Huawei | Xia Haitao (xiahaitao@huawei.com) | Rel-13 | CP-65 |  | UPCON-DOTCON-CT |  |  |  |  |
| 34 | 18.4.2.1 | CT3 part of CT aspects of User Plane Congestion Management for BB1 | 262d? | 2014-03-18 A | 2015-03-13 | 60% | 104.8d? |  |  |  | 589d | finish no earlier than 2015-03-13 | C3 | 2096h | 1257.6h | UPCON-DOTCON-CT3 | PCG-33 | Huawei | Xia Haitao (xiahaitao@huawei.com) | Rel-13 | CP-65 |  |  |  |  |  |  |
| 35 | 18.4.2.2 | CT4 part of CT aspects of User Plane Congestion Management for BB1 | 262d? | 2014-03-18 A | 2015-03-13 | 20% | 209.6d? |  |  |  | 589d | finish no earlier than 2015-03-13 | C4 | 2096h | 419.2h | UPCON-DOTCON-CT4 | PCG-33 | Huawei | Xia Haitao (xiahaitao@huawei.com) | Rel-13 | CP-65 |  |  |  |  |  |  |
| 36 | 18.5 | Deleted - BB2: Application and Content Prioritization | 140d? | 2014-03-07 A | 2014-09-17 A | 100% |  | 2014-03-07 | 2015-06-17 | 334d? |  | finish no earlier than 2014-09-17 | S2 | 1120h | 1120h | UPCON-CONDEL | PCG-32 | Allot | Alla Goldner (agoldner@allot.com) | Rel-13 | SP-63 | Maurice | UPCON-CON | PCG-33 | SP-65 |  |  |
| 37 | 18.6 | Deleted - BB3: Uplink traffic and attended/unattended traffic | 140d? | 2014-03-07 A | 2014-09-17 A | 100% |  | 2014-03-07 | 2015-06-17 | 334d? |  | finish no earlier than 2014-09-17 | S2 | 1120h | 1120h | UPCON-TRAFDEL | PCG-32 | Allot | Alla Goldner (agoldner@allot.com) | Rel-13 | SP-63 | Maurice | UPCON-TRAF | PCG-33 | SP-65 |  |  |
| 38 | 19 | **RAN Sharing Enhancements** | 526d? | 2013-06-19 A | 2015-06-15 | 48% | 271.27d? | 2013-06-19 | 2013-12-11 | 129d? | 523d |  | S1; R3 | 12632h | 3573.49h | RSE | PCG-31 | NEC | joerg.swetina@neclab.eu | Rel-13 | SP-60 | Alain | RSE |  |  |  |  |
| 39 | 19.1 | Stage 1 for RAN Sharing Enhancements | 129d? | 2013-06-19 A | 2013-12-11 A | 100% |  | 2013-06-19 | 2013-12-11 | 129d? |  |  | S1 | 1032h | 1032h | RSE-SA1 | PCG-31 | NEC | joerg.swetina@neclab.eu | Rel-13 | SP-60 | Alain |  |  |  |  |  |
| 40 | 19.2 | **RAN aspects of RAN Sharing Enhancements for LTE** | 199d? | 2014-09-12 A | 2015-06-15 | 15% | 169.16d? | 2014-06-13 | 2015-06-12 | 261d? | 523d |  | R3 | 3184h | 477.49h | RSE-RAN_LTE | PCG-33 | NEC | Siva.Vakeesar@emea.nec.com | Rel-13 | RP-65 |  | RSE-RAN_LTE |  |  |  |  |
| 41 | 19.2.1 | Core part: RAN aspects of RAN Sharing Enhancements for LTE | 199d? | 2014-09-12 A | 2015-06-15 | 15% | 169.15d? | 2014-06-13 | 2015-06-12 | 261d? | 523d | finish no earlier than 2015-06-15 | R3 | 1592h | 238.8h | RSE-RAN_LTE-Core | PCG-33 | NEC | Siva.Vakeesar@emea.nec.com | Rel-13 | RP-65 |  | RSE-RAN_LTE-Core |  |  |  |  |
| 42 | 20 | **Mission Critical Push To Talk over LTE** | 400d? | 2013-12-11 A | 2015-06-17 | 40% | 239.39d? | 2013-12-11 | 2015-06-17 | 397d? | 521d |  | S1; S2 | 11057.2h | 4439.76h | MCPTT | PCG-32 | NIST | david.cypher@nist.gov | Rel-13 | SP-62 | Alain | MCPTT |  |  | Public Safety (A-A) |  |
| 43 | 20.1 | Stage 1 for Mission Critical Push To Talk over LTE | 263d? | 2013-12-11 A | 2014-12-12 A | 100% |  | 2013-12-11 | 2014-12-10 | 261d? |  | finish no earlier than 2014-12-12 | S1 | 2104h | 2104h | MCPTT-SA1 | PCG-32 | NIST | david.cypher@nist.gov | Rel-13 | SP-62 | Alain |  |  |  | Public Safety (A-A) | SP-140502 |
| 44 | 20.2 | TR on Stage 2 for Mission Critical Push To Talk over LTE | 261d? | 2014-06-18 A | 2015-06-17 | 20% | 208.8d? | 2014-06-18 | 2014-12-10 | 126d? | 521d | finish no earlier than 2015-06-17 | S2 | 2088h | 417.6h | MCPTT-SA2TR | PCG-33 | U.S. Department of Commerce | Randy Bloomfield (randy@its.bldrdoc.gov) | Rel-13 | SP-64 |  |  |  |  | Public Safety (A-A) |  |
| 45 | 20.3 | Stage 2 for Mission Critical Push To Talk over LTE | 261d? | 2014-06-23 | 2015-06-17 |  |  | 2014-06-18 | 2015-06-17 | 261d? | 521d | finish no earlier than 2015-06-17 | S2 | 2088h |  | MCPTT-SA2 | PCG-33 | U.S. Department of Commerce | Randy Bloomfield (randy@its.bldrdoc.gov) | Rel-13 | SP-64 |  |  |  |  | Public Safety (A-A) |  |
| 46 | 21 | **Enhancements to WEBRTC interoperability** | 337d? | 2014-03-07 A | 2015-06-17 | 33% | 226.21d? | 2014-03-07 | 2015-06-17 | 334d? | 521d |  | S1; S2; S3 | 15424h | 4177.02h | eWebRTCi | PCG-32 | Alcatel-Lucent | betsy.covell@alcatel-lucent.com | Rel-13 | SP-63 | Alain | eWebRTCi |  |  |  |  |
| 47 | 21.1 | Stage 1 for Enhancements to WEBRTC interoperability | 139d? | 2014-03-07 A | 2014-09-17 A | 100% |  | 2014-03-07 | 2014-09-17 | 139d? |  | finish no earlier than 2014-09-17 | S1 | 1112h | 1112h | eWebRTCi-SA1 | PCG-32 | Alcatel-Lucent | betsy.covell@alcatel-lucent.com | Rel-13 | SP-63 | Alain |  |  |  |  | S1-143303 |
| 48 | 21.2 | TR on Stage 2 for Enhancements to WEBRTC interoperability | 196d? | 2014-06-19 A | 2015-03-18 | 55% | 88.2d? | 2014-06-18 | 2015-03-18 | 196d? | 586d | finish no earlier than 2015-03-18 | S2 | 1568h | 862.4h | eWebRTCi-SA2TR | PCG-33 | China Mobile | Yu Qing (yuqing@chinamobile.com) | Rel-13 | SP-64 |  |  |  |  |  |  |
| 49 | 21.3 | Stage 2 for Enhancements to WEBRTC interoperability | 261d? | 2014-06-23 | 2015-06-17 |  |  | 2014-06-18 | 2015-06-17 | 261d? | 521d | finish no earlier than 2015-06-17 | S2 | 2088h |  | eWebRTCi-SA2 | PCG-33 | China Mobile | Yu Qing (yuqing@chinamobile.com) | Rel-13 | SP-64 |  |  |  |  |  |  |
| 50 | 21.4 | TR on Security for Enhancements to WEBRTC interoperability | 197d? | 2014-09-17 A | 2015-06-16 | 20% | 157.6d? |  |  |  | 522d | start no earlier than 2014-09-17 | S3 | 1576h | 315.2h | eWebRTCi-SA3TR | PCG-33 | Ericsson | vesa.lehtovirta@ericsson.com | Rel-13 | SP-65 |  |  |  |  |  |  |
| 51 | 21.5 | Security for Enhancements to WEBRTC interoperability | 198d? | 2014-09-17 A | 2015-06-17 | 20% | 158.4d? |  |  |  | 521d | start no earlier than 2014-09-17 | S3 | 1584h | 316.8h | eWebRTCi-SA3 | PCG-33 | Ericsson | vesa.lehtovirta@ericsson.com | Rel-13 | SP-65 |  |  |  |  |  |  |

Notes:
- 27: SP#65 updated WID SP-140153=>SP-140631 (BBII & BBIII stopped). Triggered by Rel-12 TR 22.805 Study on User Plane Congestion management (FS_UPCON) / Impacted TSs and TRs: Stage 1/2/3
- 28: SP#63 moved to Rel-13 updated WID SP-120890=>SP-140153. SP#59 completed. Convert TR 22.805 clause 6 consolidated requirements to normative requirements in 22.101 / Impacted TSs and TRs: 22.101
- 29: SP#65 updated WID SP-140153=>SP-140631. TR 23.705v100 for Information. LM: 87->98% / Impacted TSs and TRs: new TR 23.705
- 30: SP#62 stopped at 0% completion / Impacted TSs and TRs: TBD
- 31: SP#65 updated WID SP-140153=>SP-140631. Includes: RAN Congestion Detection: , RAN Traffic Differentiation, RAN Congestion Reporting, CN Congestion Mitigation mechanisms, Dynamic Policy Control
- 32: SP#65 updated WID SP-140153=>S2-142850 (added impacted specs). LM: 70->100% only if RAN agrees to standardize the FPI / Impacted TSs and TRs: 23.060, 23.203, 23.401
- 33: Stage 3; WID: CP-140734->CP-140929 / Impacted TSs and TRs: Stage 3
- 34: LM: 0->60; WID: CP-140734->CP-140929 / Impacted TSs and TRs: 29.201, 29.212, 29.213, 29.214, 29.215, 29.219, New TS 29.217 (PCC over Np)
- 35: LM: 0->20; WID: CP-140734->CP-140929 / Impacted TSs and TRs: 23.003, 29.303, New TS 29.405 (UPCON over Nq)
- 36: SP#65 updated WID SP-140153=>SP-140631 (BBII & BBIII stopped). Includes: Content specific UP prioritization (Video), Application specific UP prioritization / Impacted TSs and TRs: TBD
- 37: SP#65 updated WID SP-140153=>SP-140631 (BBII & BBIII stopped). Includes: Uplink Congestion Management, Un/Attended UE Information / Impacted TSs and TRs: TBD
- 38: Triggered by Rel-12 TR 22.852 Study on RAN Sharing Enhancements (FS_RSE)
- 39: SP#62 completed / Impacted TSs and TRs: 22.101
- 40: Triggered by TR 36.856 Study on RAN aspects of RAN Sharing Enhancements for LTE (FS_RSE-RAN_LTE) & SA1 22.101 Stage 1 / Impacted TSs and TRs: LTE
- 41: CD:Tue 16/06/15->Mon 15/06/15; Compl:0%->15% / Impacted TSs and TRs: 36.300, 36.413, 36.423
- 42: SP#65 updated WID SP-140276=>SP-140435. Complements Rel-12 FS_ProSe/ProSe and GCSE_LTE. External requirements: FIRSTNET (US), UK Home Office, OMA, TCCA (TETRA and Critical Communications Association) / Impacted TSs and TRs: Stage 1/2
- 43: SP#65 completion 09/14=>12/14. Exception in SP-140502. TS 22.179v100 for Information. Completed. / Impacted TSs and TRs: New TS 22.179
- 44: SP#65 completion 12/14=>06/15. Updated WID SP-140276=>SP-140435. LM: 2->20% / Impacted TSs and TRs: New TR 23.779
- 45: SP#65 completion 12/14=>06/15. Updated WID SP-140276=>SP-140435 / Impacted TSs and TRs: New TS 23.179
- 46: SP#65 updated WID SP-14028=>SP-140630 (added SA3 part, SA1 change). Add enhanced interoperability support for WebRTC to Rel-12 Web Real Time Communication (WebRTC) Access to IMS. / Impacted TSs and TRs: Stage 1/2
- 47: SP#65 completed. Updated WID SP-140286=>SP-140630 / Impacted TSs and TRs: 22.228
- 48: SP#65 updated WID SP-14028=>SP-140630 (added SA3 part). LM: 9->55% / Impacted TSs and TRs: New TR 23.706
- 49: SP#65 updated WID SP-14028=>SP-140630 (added SA3 part) / Impacted TSs and TRs: 23.228
- 50: SP#65 updated WID SP-14028=>SP-140630 (added SA3 part). LM: 0->20%, TR number added / Impacted TSs and TRs: New TR 33.872
- 51: SP#65 updated WID SP-14028=>SP-140630 (added SA3 part). LM: 0->20% / Impacted TSs and TRs: 33.203, 33.328

| ID | WBS | Task | Duration | Start | Finish | Complete | Remaining | Baseline start | Baseline finish | Baseline duration | Total slack | Constraint | Resources | Work | Actual work | Acronym | PCG approved | Impacted TSs and TRs | WI rapporteur name | WI rapporteur e-mail | Release | TSG approved | MCC resp | Acronym_3GU_Export | Special Focus Doc |
| --- | --- | --- | --- | --- | --- | --- | --- | --- | --- | --- | --- | --- | --- | --- | --- | --- | --- | --- | --- | --- | --- | --- | --- | --- | --- |
| 52 | 22 | **Improvements to CS/PS coordination in UTRAN/GERAN Shared Networks** | 204d? | 2014-03-07 A | 2014-12-12 A | 100% |  | 2014-03-07 | 2014-12-10 | 199d? |  |  | S2 | 4360h | 4360h | CSPS_Coord | PCG-32 | Stage 2 | Ericsson | roland.gustafsson@ericsson.com | Rel-13 | SP-63 | Maurice | CSPS_Coord |  |
| 53 | 22.1 | TR on Stage 2 for Improvements to CS/PS coordination in UTRAN/GERAN Shared Networks | 140d? | 2014-03-07 A | 2014-09-17 A | 100% |  | 2014-03-07 | 2014-12-10 | 199d? |  | finish no earlier than 2014-09-17 | S2 | 1120h | 1120h | CSPS_Coord-SA2TR | PCG-32 | New TR 23.704 | Ericsson | roland.gustafsson@ericsson.com | Rel-13 |  | Maurice |  |  |
| 54 | 22.2 | Stage 2 for Improvements to CS/PS coordination in UTRAN/GERAN Shared Networks | 201d? | 2014-03-12 A | 2014-12-12 A | 100% |  | 2014-03-07 | 2014-12-10 | 199d? |  | finish no earlier than 2014-12-12 | S2 | 1608h | 1608h | CSPS_Coord-SA2 | PCG-32 | 23.216, 23.251, 23.272 | Ericsson | roland.gustafsson@ericsson.com | Rel-13 |  | Maurice |  |  |
| 55 | 23 | **Enhancements to Proximity-based Services** | 329d? | 2014-06-18 A | 2015-09-16 | 11% | 293.07d? | 2014-06-18 | 2015-06-12 | 258d? | 456d |  | S1; S2; S3 | 14136h | 1181.78h | eProSe | PCG-33 | Stage 1/2 | Qualcomm | Eddy Hall (edhall@qti.qualcomm.com) | Rel-13 | SP-64 |  | eProSe | Public Safety (A-A) |
| 56 | 23.1 | Stage 1 for Enhancements to Proximity-based Services | 66d? | 2014-06-19 A | 2014-09-17 A | 100% |  | 2014-06-18 | 2014-09-17 | 66d? |  | finish no earlier than 2014-09-17 | S1 | 528h | 528h | eProSe-SA1 | PCG-33 | 22.115, 22.278 | Qualcomm | Eddy Hall (edhall@qti.qualcomm.com) | Rel-13 | SP-64 |  |  | Public Safety (A-A) |
| 57 | 23.2 | Stage 2 for Enhancements to Proximity-based Services - Extensions | 261d? | 2014-06-23 | 2015-06-17 |  |  | 2014-06-18 | 2015-06-12 | 258d? | 521d | finish no earlier than 2015-06-17 | S2 | 2088h |  | eProSe-Ext-SA2 | PCG-33 | 23.303, TBD | Qualcomm | Haris Zisimopoulos (harisz@qti.qualcomm.com) | Rel-13 | SP-64 |  | eProSe-Ext | Public Safety (A-A) |
| 58 | 23.3 | TR on Stage 2 for Enhancements to Proximity-based Services - Extensions | 193d? | 2014-06-18 A | 2015-03-13 | 10% | 173.7d? | 2014-06-18 | 2015-03-13 | 193d? | 589d | finish no earlier than 2015-03-13 | S2 | 1544h | 154.4h | eProSe-Ex-SA2TRt | PCG-33 | New TR 23.713 | Qualcomm | Haris Zisimopoulos (harisz@qti.qualcomm.com) | Rel-13 | SP-64 |  |  | Public Safety (A-A) |
| 59 | 23.4 | Security for Enhancements to Proximity-based Services - Extensions | 261d? | 2014-09-19 | 2015-09-16 |  |  |  |  |  | 456d | finish no earlier than 2015-09-16 | S3 | 2088h |  | eProSe-Ex-SA3t | PCG-33 | 33.303 | Qualcomm | Adrian Escott (aescott@qti.qualcomm.com) | Rel-13 | SP-65 |  |  | Public Safety (A-A) |
| 60 | 24 | **voice over E-UTRAN Paging Policy Differentiation** | 133d? | 2014-06-16 A | 2014-12-12 | 51% | 65.46d? | 2014-06-16 | 2014-12-10 | 128d? | 654d |  | S1; S2; C4; C1; C3 | 9244.75h | 4178.79h | voE_UTRAN_PPD | PCG-33 | Stage 1/2 | Alcatel-Lucent | (betsy.covell@alcatel-lucent.com) | Rel-13 | SP-64 |  | voE_UTRAN_PPD |  |
| 61 | 24.1 | Stage 1 for voice over E-UTRAN Paging Policy Differentiation | 3d? | 2014-06-16 A | 2014-06-18 A | 100% |  | 2014-06-16 | 2014-06-18 | 3d? |  | finish no earlier than 2014-06-18 | S1 | 24h | 24h | voE_UTRA-N_PPD-SA1 | PCG-33 | 22.228, 22.278 | Alcatel-Lucent | betsy.covell@alcatel-lucent.com | Rel-13 | SP-64 |  |  |  |
| 62 | 24.2 | Stage 2 for voice over E-UTRAN Paging Policy Differentiation | 128d? | 2014-06-18 A | 2014-12-12 A | 100% |  | 2014-06-18 | 2014-12-10 | 126d? |  | finish no earlier than 2014-12-12 | S2 | 1024h | 1024h | voE_UTRAN_PPD-SA2 | PCG-33 | 23.228, 23.401 | Alcatel-Lucent | laurent.thiebaut@alcatel-lucent.com | Rel-13 | SP-64 |  |  |  |
| 63 | 24.3 | **CT aspects of voice over E-UTRAN Paging Policy Differentiation** | 63d? | 2014-09-16 A | 2014-12-09 | 17% | 52.5d? |  |  |  | 657d |  | C4; C1; C3 | 3024h | 504h | voE_UTRAN_PPD-CT | PCG-33 | Stage 3 | Alcatel-Lucent | bruno.landais@alcatel-lucent.com | Rel-13 | CP-65 |  |  |  |
| 64 | 24.3.1 | CT4 part of CT aspects of voice over E-UTRAN Paging Policy Differentiation | 63d? | 2014-09-16 | 2014-12-09 |  |  |  |  |  | 657d | finish no earlier than 2014-12-09 | C4 | 504h |  | voE_UTRAN_PPD-CT4 | PCG-33 | 29.274, 29.281 | Alcatel-Lucent | bruno.landais@alcatel-lucent.com | Rel-13 | CP-65 |  |  |  |
| 65 | 24.3.2 | CT1 part of CT aspects of voice over E-UTRAN Paging Policy Differentiation | 63d? | 2014-09-16 A | 2014-12-09 | 50% | 31.5d? |  |  |  | 657d | finish no earlier than 2014-12-09 | C1 | 504h | 252h | voE_UTRAN_PPD-CT1 | PCG-33 | 24.229 | Alcatel-Lucent | bruno.landais@alcatel-lucent.com | Rel-13 | CP-65 |  |  |  |
| 66 | 24.3.3 | CT3 part of CT aspects of voice over E-UTRAN Paging Policy Differentiation | 63d? | 2014-09-16 | 2014-12-09 |  |  |  |  |  | 657d | finish no earlier than 2014-12-09 | C3 | 504h |  | voE_UTRAN_PPD-CT3 | PCG-33 | 29.061 | Alcatel-Lucent | bruno.landais@alcatel-lucent.com | Rel-13 | CP-65 |  |  |  |
| 67 | 25 | **Dedicated Core Networks** | 199d? | 2014-06-18 A | 2015-03-18 | 40% | 120.38d? | 2014-06-18 | 2015-03-18 | 196d? | 586d |  | S2 | 4184h | 1652.94h | DECOR | PCG-33 | Stage 2 | NTT DOCOMO | Daisuke Fujishima (fujishimad@nttdocomo.co.jp) | Rel-13 | SP-64 |  | DECOR |  |
| 68 | 25.1 | TR for Dedicated Core Networks | 128d? | 2014-06-18 A | 2014-12-12 A | 100% |  | 2014-06-18 | 2014-12-10 | 126d? |  | finish no earlier than 2014-12-12 | S2 | 1024h | 1024h | DÉCOR-SA2TR | PCG-33 | New TR 23.707 | NTT DOCOMO | Daisuke Fujishima (fujishimad@nttdocomo.co.jp) | Rel-13 | SP-64 |  |  |  |
| 69 | 25.2 | Stage 2 for Dedicated Core Networks | 196d? | 2014-06-23 | 2015-03-18 |  |  | 2014-06-18 | 2015-03-18 | 196d? | 586d | finish no earlier than 2015-03-18 | S2 | 1568h |  | DECOR-SA2 | PCG-33 | 23.060, 23.401 | NTT DOCOMO | Daisuke Fujishima (fujishimad@nttdocomo.co.jp) | Rel-13 | SP-64 |  |  |  |
| 70 | 26 | **IP Flow Mobility support for S2a and S2b Interfaces** | 264d? | 2014-06-18 A | 2015-06-17 | 26% | 196.66d? | 2014-06-18 | 2015-06-17 | 261d? | 521d |  | S2 | 5744h | 1465.09h | NBIFOM | PCG-33 | Stage 2 | ZTE | Tricci So (tso@zteusa.com) | Rel-13 | SP-64 |  | NBIFOM |  |
| 71 | 26.1 | TR for IP Flow Mobility support for S2a and S2b Interfaces | 193d? | 2014-06-18 A | 2015-03-13 | 60% | 77.2d? | 2014-06-18 | 2015-03-13 | 193d? | 589d | finish no earlier than 2015-03-13 | S2 | 1544h | 926.4h | NBIFOM-SA2TR | PCG-33 | New TR 23.861 | ZTE | Tricci So (tso@zteusa.com) | Rel-13 | SP-64 |  |  |  |
| 72 | 26.2 | Stage 2 for IP Flow Mobility support for S2a and S2b Interfaces | 261d? | 2014-06-23 | 2015-06-17 |  |  | 2014-06-18 | 2015-06-17 | 261d? | 521d | finish no earlier than 2015-06-17 | S2 | 2088h |  | NBIFOM-SA2 | PCG-33 | 23.402, TBD | ZTE | Tricci So (tso@zteusa.com) | Rel-13 | SP-64 |  |  |  |
| 73 | 27 | **Architecture Enhancements for Service capability Exposure** | 329d? | 2014-06-18 A | 2015-09-16 | 22% | 257.08d? | 2014-06-18 | 2015-09-16 | 326d? | 456d |  | S2; S3 | 13459.2h | 2367.07h | AESE | PCG-33 | Stage 2 | Intel | puneet.jain@intel.com | Rel-13 | SP-64 |  | AESE |  |
| 74 | 27.1 | TR for Architecture Enhancements for Service capability Exposure | 196d? | 2014-06-18 A | 2015-03-18 | 65% | 68.6d? | 2014-06-18 | 2015-03-18 | 196d? | 586d | finish no earlier than 2015-03-18 | S2 | 1568h | 1019.2h | AESE-SA2TR | PCG-33 | New TR 23.708 | Intel | puneet.jain@intel.com | Rel-13 | SP-64 |  |  |  |
| 75 | 27.2 | Stage 2 for Architecture Enhancements for Service capability Exposure | 261d? | 2014-06-23 | 2015-06-17 |  |  | 2014-06-18 | 2015-06-17 | 261d? | 521d | finish no earlier than 2015-06-17 | S2 | 2088h |  | AESE-SA2 | PCG-33 | TBD | Intel | puneet.jain@intel.com | Rel-13 | SP-64 |  |  |  |
| 76 | 27.3 | TR on Security for Architecture Enhancements for Service capability Exposure | 241.4d? | 2014-06-23 A | 2015-06-17 | 40% | 144.84d? | 2014-06-18 | 2015-06-17 | 241.4d? | 521d | finish no earlier than 2015-06-17 | S3 | 1931.2h | 772.48h | AESE-SA3TR | PCG-33 | New TR 33.889 | Samsung | Rajavelsamy R (rajvel@samsung.com) | Rel-13 | SP-64 |  |  |  |
| 77 | 27.4 | Security for Architecture Enhancements for Service capability Exposure | 326d? | 2014-06-23 | 2015-09-16 |  |  | 2014-06-18 | 2015-09-16 | 326d? | 456d | finish no earlier than 2015-09-16 | S3 | 2608h |  | AESE-SA3 | PCG-33 | 33.187 | Samsung | Rajavelsamy R (rajvel@samsung.com) | Rel-13 | SP-64 |  |  |  |

Notes:
- 52: Provide improvements to the solutions for CS/PS coordination in TS 23.251 to ensure that CS/PS coordination can be achieved for all mobility scenarios
- 53: SP#65 completed. TR 23.704v200 for Approval
- 54: LM: 0->100%
- 55: -
- 56: SP#65 completed. Some Rel-12 ProSe service requirements have not been implemented at Stage 2/3 level. These are taken up in Rel-13 Stage 2/3 and need Stage 1 appropriate service requirements. No new service requirements are introduced.
- 57: SP#65 updated WID SP-140385=>SP-140573 (added SA3 part)
- 58: SP#65 updated WID SP-140385=>SP-140573 (added SA3 part)
- 59: SP#65 updated WID SP-140385=>SP-140573 (added SA3 part). Specify selected security solutions based on the outcome of SA3 study TR 33.833
- 60: -
- 61: SP#64 approved WID & completed
- 62: Architectural enhancements allowing a differentiated paging policy for IMS voice calls over E-UTRAN. LM: 25->100%
- 63: Stage 3
- 64: -
- 65: LM: 0->50%
- 66: -
- 67: Enable deployment of dedicated CNs to UEs sharing the same characteristics. The specific dedicated CN that serves a UE is selected based on subscription info and operator config, without requiring UEs to be modified.
- 68: LM: 30->100%
- 69: -
- 70: -
- 71: Revived the Rel-12 DRAFT TR 23.861 stopped at SP#59 (at 40% completion). LM: 20->60%
- 72: -
- 73: -
- 74: LM: 30->65%
- 75: -
- 76: TR 33.8xy will capture requirements, solution alternatives, evaluations and conclusions for the AESE, MONTE and GROUPE WIDs. LM: 0->40%
- 77: -

| ID | WBS | Task | Duration | Start | Finish | Complete | Remaining | Baseline start | Baseline finish | Baseline duration | Total slack | Constraint | Resources | Work | Actual work | Acronym | PCG approved | WI rapporteur name | Release | TSG approved | Acronym_3GU_Export | MCC resp |
| --- | --- | --- | --- | --- | --- | --- | --- | --- | --- | --- | --- | --- | --- | --- | --- | --- | --- | --- | --- | --- | --- | --- |
| 78 | 28 | **Monitoring Enhancements** | 329d? | 2014-06-18 A | 2015-09-16 | 18% | 271.23d? | 2014-06-18 | 2015-09-16 | 326d? | 456d |  | S2; S3 | 13380.8h | 2349.76h | MONTE | PCG-33 | Intel | Rel-13 | SP-64 | MONTE |  |
| 79 | 28.1 | TR for Monitoring Enhancements | 196d? | 2014-09-17 A | 2015-06-17 | 85% | 29.4d? | 2014-09-17 | 2015-06-17 | 196d? | 521d | finish no earlier than 2015-06-17 | S2 | 1568h | 1332.8h | MONTE-SA2TR | PCG-33 | Intel | Rel-13 | SP-64 |  |  |
| 80 | 28.2 | Stage 2 for Monitoring Enhancements | 261d? | 2014-06-23 | 2015-06-17 |  |  | 2014-06-18 | 2015-06-17 | 261d? | 521d | finish no earlier than 2015-06-17 | S2 | 2088h |  | MONTE-SA2 | PCG-33 | Intel | Rel-13 | SP-64 |  |  |
| 81 | 28.3 | TR on Security for Monitoring Enhancements | 231.6d? | 2014-06-18 A | 2015-06-12 | 5% | 220.02d? | 2014-06-18 | 2015-06-17 | 231.6d? | 524d | start no earlier than 2014-06-18 | S3 | 1852.8h | 92.64h | MONTE-SA3TR | PCG-33 | Samsung | Rel-13 | SP-64 |  |  |
| 82 | 28.4 | Security for Monitoring Enhancements | 326d? | 2014-06-23 | 2015-09-16 |  |  | 2014-06-18 | 2015-09-16 | 326d? | 456d | finish no earlier than 2015-09-16 | S3 | 2608h |  | MONTE-SA3 | PCG-33 | Samsung | Rel-13 | SP-64 |  |  |
| 83 | 29 | **Group based Enhancements** | 329d? | 2014-06-18 A | 2015-09-16 | 15% | 280.76d? | 2014-06-18 | 2015-09-16 | 326d? | 456d |  | S2; S3 | 13380.8h | 1576.14h | GROUPE | PCG-33 | Huawei | Rel-13 | SP-64 | GROUPE |  |
| 84 | 29.1 | TR for Group based Enhancements | 196d? | 2014-06-18 A | 2015-03-18 | 70% | 58.8d? | 2014-06-18 | 2015-03-18 | 196d? | 586d | finish no earlier than 2015-03-18 | S2 | 1568h | 1097.6h | GROUPE-SA2TR | PCG-33 | Huawei | Rel-13 | SP-64 |  |  |
| 85 | 29.2 | Stage 2 for Group based Enhancements | 261d? | 2014-06-23 | 2015-06-17 |  |  | 2014-06-18 | 2015-06-17 | 261d? | 521d | finish no earlier than 2015-06-17 | S2 | 2088h |  | GROUPE-SA2 | PCG-33 | Huawei | Rel-13 | SP-64 |  |  |
| 86 | 29.3 | TR on Security for Group based Enhancements | 231.6d? | 2014-06-18 A | 2015-06-12 | 5% | 220.02d? | 2014-06-18 | 2015-06-17 | 231.6d? | 524d | start no earlier than 2014-06-18 | S3 | 1852.8h | 92.64h | GROUPESA3TR | PCG-33 | Samsung | Rel-13 | SP-64 |  |  |
| 87 | 29.4 | Security for Group based Enhancements | 326d? | 2014-06-23 | 2015-09-16 |  |  | 2014-06-18 | 2015-09-16 | 326d? | 456d | finish no earlier than 2015-09-16 | S3 | 2608h |  | GROUPE-SA3 | PCG-33 | Samsung | Rel-13 | SP-64 |  |  |
| 88 | 30 | **Enhanced CS Fallback (CSFB)** | 196d? | 2014-06-18 A | 2015-03-13 | 34% | 129.77d? | 2014-06-18 | 2015-03-18 | 196d? | 589d |  | S2; S3 | 5712h | 1400.2h | eCSFB | PCG-33 | China Unicom | Rel-13 | SP-64 | eCSFB |  |
| 89 | 30.1 | TR for Enhanced CS Fallback (CSFB) | 128d? | 2014-06-18 A | 2014-12-12 | 85% | 19.2d? | 2014-06-18 | 2014-12-10 | 126d? | 654d | finish no earlier than 2014-12-12 | S2 | 1024h | 870.4h | eCSFB-SA2TR | PCG-33 | China Unicom | Rel-13 | SP-64 |  |  |
| 90 | 30.2 | Stage 2 for Enhanced CS Fallback (CSFB) | 193d? | 2014-06-23 | 2015-03-13 |  |  | 2014-06-18 | 2015-03-18 | 196d? | 589d | finish no earlier than 2015-03-13 | S2 | 1544h |  | eCSFBSA2 | PCG-33 | China Unicom | Rel-13 | SP-64 |  |  |
| 91 | 30.3 | Security for Enhanced CS Fallback (CSFB) | 1d? | 2014-09-17 | 2014-09-17 |  |  |  |  |  | 718d | start no earlier than 2014-09-17 | S3 | 8h |  | eCSFBSA3 | PCG-33 | China Unicom | Rel-13 | SP-65 |  |  |
| 92 | 31 | **Double Resource Reuse for Multiple Media Sessions** | 264d? | 2014-03-14 A | 2015-03-13 | 84% | 41.39d? | 2014-03-14 | 2015-03-13 | 261d? | 589d |  | S2 | 5952h | 4926.09h | DRuMS | PCG-33 | Ericsson | Rel-13 | SP-64 | DRuMS |  |
| 93 | 31.1 | Stage 2 for Double Resource Reuse for Multiple Media Sessions | 264d? | 2014-03-14 A | 2015-03-13 | 95% | 13.2d? | 2014-03-14 | 2015-03-13 | 261d? | 589d | finish no earlier than 2015-03-13 | S2 | 2088h | 2006.4h | DRuMS-SA2 | PCG-33 | Ericsson | Rel-13 | SP-64 |  |  |
| 94 | 31.2 | **CT aspects of Double Resource Reuse for Multiple Media Sessions** | 73d? | 2014-12-03 A | 2015-03-13 | 65% | 25.55d? |  |  |  | 589d |  | C3 | 1752h | 1138.81h | DRuMS-CT |  | Ericsson | Rel-13 | CT-66 |  |  |
| 95 | 31.2.1 | CT1 aspects of Double Resource Reuse for Multiple Media Sessions | 73d? | 2014-12-03 A | 2015-03-13 | 65% | 25.55d? |  |  |  | 589d | start no earlier than 2014-12-03 | C3 | 584h | 379.6h | DRuMS-CT-CT1 |  | Ericsson | Rel-13 | CT-66 |  |  |
| 96 | 31.2.2 | CT3 aspects of Double Resource Reuse for Multiple Media Sessions | 73d? | 2014-12-03 A | 2015-03-13 | 65% | 25.55d? |  |  |  | 589d | start no earlier than 2014-12-03 | C3 | 584h | 379.6h | DRuMS-CT-CT3 |  | Ericsson | Rel-13 | CT-66 |  |  |
| 97 | 32 | **SRVCC Enhancements for Transcoding Avoidance** | 196d? | 2014-09-19 A | 2015-06-17 | 28% | 141.8d? |  |  |  | 521d |  | S2 | 4160h | 1150.37h | SETA | PCG-33 | Ericsson | Rel-13 | SP-65 | SETA |  |
| 98 | 32.1 | TR for SRVCC Enhancements for Transcoding Avoidance | 128d? | 2014-09-19 A | 2015-03-13 | 70% | 38.4d? |  |  |  | 589d | finish no earlier than 2015-03-13 | S2 | 1024h | 716.8h | SETA-SA2TR | PCG-33 | Ericsson | Rel-13 | SP-65 |  |  |
| 99 | 32.2 | Stage 2 for SRVCC Enhancements for Transcoding Avoidance | 196d? | 2014-09-19 | 2015-06-17 |  |  |  |  |  | 521d | finish no earlier than 2015-06-17 | S2 | 1568h |  | SETA-SA2 | PCG-33 | Ericsson | Rel-13 | SP-65 |  |  |
| 100 | 33 | **Security Assurance Specification for 3GPP network products** | 337d? | 2013-12-09 A | 2015-03-18 | 48% | 176.37d? | 2013-12-09 | 2015-03-18 | 334d? | 586d |  | S3 | 9600h | 3934.91h | SCAS | PCG-32 | NTT DOCOMO | Rel-13 | SP-62 | SCAS | Mirko |
| 101 | 33.1 | TR on Pilot development of Security Assurance Specification for MME network product class | 266d? | 2013-12-09 A | 2014-12-12 | 70% | 79.8d? | 2013-12-09 | 2014-12-10 | 264d? | 654d | finish no earlier than 2014-12-12 | S3 | 2120h | 1481.6h | SCAS-SA3Pil_TR | PCG-32 | NTT DOCOMO | Rel-13 | SP-62 |  | Mirko |
| 102 | 33.2 | Security Assurance Specification for 3GPP network product classes | 333d? | 2013-12-13 | 2015-03-18 |  |  | 2013-12-10 | 2015-03-18 | 333d? | 586d | finish no earlier than 2015-03-18 | S3 | 2664h |  | SCAS-SA3 | PCG-32 | China Mobile | Rel-13 | SP-62 |  | Mirko |
| 103 | 33.3 | TR on Security Assurance scheme for 3GPP network products | 266d? | 2013-12-09 A | 2014-12-12 | 85% | 39.9d? | 2013-12-09 | 2014-12-10 | 264d? | 654d | finish no earlier than 2014-12-12 | S3 | 2120h | 1800.8h | SCAS-SA3TR | PCG-32 | NTT DOCOMO | Rel-13 | SP-62 |  | Mirko |
| 104 | 34 | Lawful Interception in the 3GPP Rel-13 | 386d? | 2014-06-18 | 2015-12-04 |  |  | 2014-06-18 | 2015-12-09 | 386d? | 399d | start no earlier than 2014-06-18 | S3 | 3088h |  | LI13 | PCG-33 | PIDS, Alcatel-Lucent | Rel-13 | SP-64 | LI13 |  |
| 105 | 35 | Video enhancements by Region-Of-Interest information signalling | 263d? | 2014-06-18 A | 2015-06-19 | 20% | 210.4d? | 2014-06-18 | 2015-06-17 | 261d? | 519d | finish no earlier than 2015-06-19 | S4 | 2104h | 420.8h | ROI | PCG-33 | Intel | Rel-13 | SP-64 | ROI |  |

Notes:
- 78: Linked to Rel-13 Feature Architecture Enhancements for Service Exposure (AESE). Although service requirements (TS 22.368 clause 7.2.8) are motivated by MTC, the solution may apply to normal UEs / Impacted TSs and TRs: Stage 2 / WI rapporteur e-mail: puneet.jain@intel.com
- 79: LM: 25->85% / Impacted TSs and TRs: New TR 23.789 / WI rapporteur e-mail: puneet.jain@intel.com
- 80: - / Impacted TSs and TRs: 23.682, TBD / WI rapporteur e-mail: puneet.jain@intel.com
- 81: TR 33.8xy will capture requirements, solution alternatives, evaluations and conclusions for the AESE, MONTE and GROUPE WIDs. / Impacted TSs and TRs: New TR 33.889 / WI rapporteur e-mail: Rajavelsamy R (rajvel@samsung.com)
- 82: - / Impacted TSs and TRs: 33.187 / WI rapporteur e-mail: Rajavelsamy R (rajvel@samsung.com)
- 83: - / Impacted TSs and TRs: Stage 2 / WI rapporteur e-mail: ZhangWanqiang@huawei.com
- 84: LM: 20->70% / Impacted TSs and TRs: New TR 23.769 / WI rapporteur e-mail: ZhangWanqiang@huawei.com
- 85: - / Impacted TSs and TRs: 23.682, TBD / WI rapporteur e-mail: ZhangWanqiang@huawei.com
- 86: TR 33.8xy will capture requirements, solution alternatives, evaluations and conclusions for the AESE, MONTE and GROUPE WIDs. / Impacted TSs and TRs: New TR 33.889 / WI rapporteur e-mail: Rajavelsamy R (rajvel@samsung.com)
- 87: - / Impacted TSs and TRs: 33.187 / WI rapporteur e-mail: Rajavelsamy R (rajvel@samsung.com)
- 88: SP#65 updated ID SP-140285=>SP-140579 (added SA3 part). Linked to Rel-8 WIs Single Radio Voice Call Continuity for 3GPP (SAES-SRVCC) and CS Fallback in EPS (SAES-CSFB) / Impacted TSs and TRs: Stage 2 / WI rapporteur e-mail: Yang Xu (xuyang49@chinaunicom.cn)
- 89: SP#65 updated ID SP-140285=>SP-140579 (added SA3 part). LM: 35->85% / Impacted TSs and TRs: New TR 23.772 / WI rapporteur e-mail: Yang Xu (xuyang49@chinaunicom.cn)
- 90: SP#65 updated ID SP-140285=>SP-140579 (added SA3 part) / Impacted TSs and TRs: 23.272 / WI rapporteur e-mail: Yang Xu (xuyang49@chinaunicom.cn)
- 91: SP#65 updated ID SP-140285=>SP-140579 / WI rapporteur e-mail: Feng Gao (gaofeng149@chinaunicom.cn)
- 92: - / Impacted TSs and TRs: Stage 2 / WI rapporteur e-mail: George.Foti@ericsson.com
- 93: LM: 49->95% / Impacted TSs and TRs: 23.203, 23.228 / WI rapporteur e-mail: George.Foti@ericsson.com
- 94: Proposed at TSG#66 / Impacted TSs and TRs: 24.229, 24.615, 24.610, 24.605, 29.212, 29.213, 29.214, 29.215
- 95: Proposed at TSG#66 / Impacted TSs and TRs: 24.229, 24.615, 24.610, 24.605
- 96: Proposed at TSG#66 / Impacted TSs and TRs: 29.212, 29.213, 29.214, 29.215
- 97: Enhance chances for end-to-end transcoder free operation (TrFo) where possible/ ensure proper CS radio resources are reserved for optimal RAN codec. Address TrFo of EVS codecs during SRVCC that are not covered by Rel-12 / Impacted TSs and TRs: Stage 2 / WI rapporteur e-mail: George.Foti@ericsson.com
- 98: LM: 0->70% / Impacted TSs and TRs: New TR 23.7xy / WI rapporteur e-mail: George.Foti@ericsson.com
- 99: - / Impacted TSs and TRs: 23.216, 23.237 / WI rapporteur e-mail: George.Foti@ericsson.com
- 100: Triggered by Rel-12 TR 33.805 Study on Security Assurance Methodology for 3GPP Network Elements (FS_SECAM) / WI rapporteur e-mail: Alf Zugenmaier (alf.zugenmaier@hm.edu)
- 101: This TR collects input for the new TS 33.116. LM: 55->70% / Impacted TSs and TRs: New TR 33.806 / WI rapporteur e-mail: Alf Zugenmaier (alf.zugenmaier@hm.edu)
- 102: This TS contains results of the first WID objective / Impacted TSs and TRs: New TS 33.116 / WI rapporteur e-mail: Judy Zhu (zhuhongru@chinamobile.com)
- 103: This TR contains results of the second WID objective. LM: 75->85% / Impacted TSs and TRs: New TR 33.916 / WI rapporteur e-mail: Alf Zugenmaier (alf.zugenmaier@hm.edu)
- 104: SP#65 updated WID SP-140400=>SP-140578 / Impacted TSs and TRs: 33.106, 33.107, 33.108 / WI rapporteur e-mail: Koen Jaspers (k.b.jaspers@minjus.nl), terry.jacobson@alcatel-lucent.com
- 105: LM: 5->20% / Impacted TSs and TRs: 26.114 / WI rapporteur e-mail: ozgur.oyman@intel.com

| ID | WBS | Task | Duration | Start | Finish | Complete | Remaining | Baseline start | Baseline finish | Baseline duration | Total slack | Constraint | Resources | Work | Actual work | Acronym | PCG approved | WI rapporteur name | Release | TSG approved | Acronym_3GU_Export | MCC resp | Special Focus Doc |
| --- | --- | --- | --- | --- | --- | --- | --- | --- | --- | --- | --- | --- | --- | --- | --- | --- | --- | --- | --- | --- | --- | --- | --- |
| 106 | 36 | **TV video profile** | 334d? | 2014-09-09 A | 2015-12-16 | 5% | 317.31d? |  |  |  | 391d |  | S4 | 8016h | 400.71h | TVProf | PCG-33 | Orange | Rel-13 | SP-65 | TVProf |  |  |
| 107 | 36.1 | TR on TV video profile | 334d? | 2014-09-09 A | 2015-12-16 | 5% | 317.3d? |  |  |  | 391d | finish no earlier than 2015-12-16 | S4 | 2672h | 133.6h | TVProf-SA4TR | PCG-33 | Orange | Rel-13 | SP-65 |  |  |  |
| 108 | 36.2 | Specification on TV video profile | 334d? | 2014-09-09 A | 2015-12-16 | 5% | 317.3d? |  |  |  | 391d | finish no earlier than 2015-12-16 | S4 | 2672h | 133.6h | TVProf-SA4 | PCG-33 | Orange | Rel-13 | SP-65 |  |  |  |
| 109 | 37 | Enhanced LTE UE Delay test methods and requirements | 334d? | 2014-09-09 | 2015-12-16 |  |  |  |  |  | 391d | finish no earlier than 2015-12-16 | S4 | 2672h |  | E_LTE_UED | PCG-33 | Orange | Rel-13 | SP-65 | E_LTE_UED |  |  |
| 110 | 38 | **Media Handling Aspects of IMS-based Telepresence** | 334d? | 2014-09-09 A | 2015-12-16 | 10% | 300.6d? |  |  |  | 391d |  | S4 | 7496h | 749.58h | IMS_TELEP_S4 | PCG-33 | Intel | Rel-13 | SP-65 | IMS_TELEP_S4 |  |  |
| 111 | 38.1 | TR on Media Handling Aspects of IMS-based Telepresence | 269d? | 2014-09-09 A | 2015-09-16 | 10% | 242.1d? |  |  |  | 456d | finish no earlier than 2015-09-16 | S4 | 2152h | 215.2h | IMS_TELEP_S4-SA4TR | PCG-33 | Intel | Rel-13 | SP-65 |  |  |  |
| 112 | 38.2 | Specification on Media Handling Aspects of IMS-based Telepresence | 334d? | 2014-09-09 A | 2015-12-16 | 10% | 300.6d? |  |  |  | 391d | finish no earlier than 2015-12-16 | S4 | 2672h | 267.2h | IMS_TELEP_S4-SA4 | PCG-33 | Intel | Rel-13 | SP-65 |  |  |  |
| 113 | 39 | HTML5 Presentation Layer | 334d? | 2014-09-09 A | 2015-12-16 | 5% | 317.3d? |  |  |  | 391d | finish no earlier than 2015-12-16 | S4 | 2672h | 133.6h | HTML5 | PCG-33 | Samsung | Rel-13 | SP-65 | HTML5 |  |  |
| 114 | 40 | Support of EVS in 3G Circuit-Switched networks | 334d? | 2014-09-09 A | 2015-12-16 | 5% | 317.3d? |  |  |  | 391d | finish no earlier than 2015-12-16 | S4 | 2672h | 133.6h | EVSoCS | PCG-33 | Qualcomm | Rel-13 | SP-65 | EVSoCS |  |  |
| 115 | 41 | Enhanced DASH (Dynamic Adaptive Streaming over HTTP in 3GPP) | 334d? | 2014-09-09 A | 2015-12-16 | 10% | 300.6d? |  |  |  | 391d | finish no earlier than 2015-12-16 | S4 | 2672h | 267.2h | eDASH | PCG-33 | Qualcomm, Huawei | Rel-13 | SP-65 | eDASH |  |  |
| 116 | 42 | **QoS End-to-end Multimedia Telephony Service for IMS (MTSI) extensions (Stage 3)** | 671d? | 2013-03-06 A | 2015-09-18 | 17% | 553.74d? | 2013-03-06 | 2015-03-13 | 533d? | 454d |  | S4; C3; C1; C4 | 64760h | 15218.7h | QOSE2EMTSI | PCG-30 | Ericsson | Rel-13 | SP-59 | QOSE2EMTSI | Paolo |  |
| 117 | 42.1 | TR on improved end-to-end QoS handling for MTSI | 399d? | 2013-12-11 A | 2015-06-19 | 70% | 119.7d? | 2013-12-11 | 2015-03-13 | 329d? | 519d | finish no earlier than 2015-06-19 | S4 | 3184h | 2226.4h | QOSE2EMTSI-SA4TR | PCG-32 | Ericsson | Rel-13 | SP-62 |  | Paolo |  |
| 118 | 42.2 | SA4 part of QoS End-to-end Multimedia Telephony Service for IMS (MTSI) extensions (Stage 3) | 667d? | 2013-03-06 A | 2015-09-18 | 36% | 426.2d? | 2013-03-06 | 2015-03-13 | 532d? | 454d | finish no earlier than 2015-09-18 | S4 | 5336h | 1926.4h | QOSE2EMTSI-SA4 | PCG-30 | Ericsson | Rel-13 | SP-59 |  | Paolo |  |
| 119 | 42.3 | **CT aspects of End-to-End Multimedia Telephony Service for IMS (MTSI) extensions** | 589d? | 2013-06-21 | 2015-09-14 |  |  | 2013-06-20 | 2014-09-12 | 326d? | 458d |  | C3; C1; C4 | 24064h |  | E2EMTSI-CT | PCG-31 | Ericsson | Rel-13 | CP-60 |  | Adrian |  |
| 120 | 42.3.1 | CT3 part of CT aspects of End-to-End Multimedia Telephony Service for IMS (MTSI) extensions | 589d? | 2013-06-21 | 2015-09-14 |  |  | 2013-06-20 | 2014-09-12 | 326d? | 458d | finish no earlier than 2015-09-14 | C3 | 4712h |  | E2EMTSI-CT3 | PCG-31 | Ericsson | Rel-13 | CP-60 |  | Adrian |  |
| 121 | 42.3.2 | CT1 part of CT aspects of End-to-End Multimedia Telephony Service for IMS (MTSI) extensions | 326d? | 2013-06-21 | 2014-09-12 |  |  | 2013-06-20 | 2014-09-12 | 326d? | 721d | finish no earlier than 2014-09-12 | C1 | 2608h |  | E2EMTSI-CT1 | PCG-31 | Ericsson | Rel-13 | CP-60 |  | Frederic |  |
| 122 | 42.3.3 | CT4 part of CT aspects of End-to-End Multimedia Telephony Service for IMS (MTSI) extensions | 326d? | 2013-06-21 | 2014-09-12 |  |  | 2013-06-20 | 2014-09-12 | 326d? | 721d | finish no earlier than 2014-09-12 | C4 | 2608h |  | E2EMTSI-CT4 | PCG-31 | Ericsson | Rel-13 | CP-60 |  | Kimmo |  |
| 123 | 42.4 | **CT Aspects of QoS End-to-End MTSI Extensions** | 223d? | 2014-11-05 | 2015-09-11 |  |  |  |  |  | 459d |  | C3; C1; C4 | 10704h |  | QOSE2EMTSI-CT |  | Ericsson | Rel-13 | CP-66 |  |  |  |
| 124 | 42.4.1 | CT3 Aspects of QoS End-to-End MTSI Extensions | 223d? | 2014-11-05 | 2015-09-11 |  |  |  |  |  | 459d | finish no earlier than 2015-09-11 | C3 | 1784h |  | QOSE2EMTSI-CT3 |  | Ericsson | Rel-13 | CP-66 |  |  |  |
| 125 | 42.4.2 | CT1 Aspects of QoS End-to-End MTSI Extensions | 223d? | 2014-11-05 | 2015-09-11 |  |  |  |  |  | 459d | start no earlier than 2014-11-05 | C1 | 1784h |  | QOSE2EMTSI-CT1 |  | Ericsson | Rel-13 | CP-66 |  |  |  |
| 126 | 42.4.3 | CT4 Aspects of QoS End-to-End MTSI Extensions | 223d? | 2014-11-05 | 2015-09-11 |  |  |  |  |  | 459d | start no earlier than 2014-11-05 | C4 | 1784h |  | QOSE2EMTSI-CT4 |  | Ericsson | Rel-13 | CP-66 |  |  |  |
| 127 | 43 | **Rel-13 Operations, Administration, Maintenance and Provisioning (OAM&P)** | 920d? | 2012-06-20 A | 2015-12-11 | 33% | 613.34d? | 2014-09-17 | 2015-12-11 | 323d? | 394d |  | S5 | 55440h | 17849.7h | OAM13 | PCG-32 |  | Rel-13 | SP-63 | OAM13 | Mirko | SON |
| 128 | 43.1 | Enhanced Network Management (NM) centralized Coverage and Capacity Optimization | 319d? | 2014-09-19 A | 2015-12-11 | 20% | 255.2d? | 2014-09-17 | 2015-12-11 | 319d? | 394d | finish no earlier than 2015-12-11 | S5 | 2552h | 510.4h | SON-NM-CCO | PCG-29 | Ericsson | Rel-13 | SP-56 | SON-NM-CCO | Mirko | SON |
| 129 | 43.2 | **Compliance of 3GPP SA5 specifications to the NGMN Top Operational Efficiency (OPE) Recommendations** | 728d? | 2012-06-20 A | 2015-03-18 | 64% | 261.86d? | 2012-06-20 | 2014-09-17 | 595d? | 586d |  | S5 | 17368h | 10253.5h | OAM-NGMN_OPE | PCG-29 | Huawei | Rel-13 | SP-56 | OAM-NGMN_OPE | Mirko |  |
| 130 | 43.2.1 | TR on Compliance of 3GPP SA5 specifications to the NGMN Top Operational Efficiency (OPE) Recommendations | 723d? | 2012-06-20 A | 2015-03-18 | 78% | 159.06d? | 2012-06-20 | 2014-09-17 | 593d? | 586d | finish no earlier than 2015-03-18 | S5 | 5784h | 4511.52h | OAM-NGMN_OPE-SA5TR | PCG-29 | Huawei | Rel-13 | SP-56 |  | Mirko |  |
| 131 | 43.2.2 | TS work on Compliance of 3GPP SA5 specifications to the NGMN Top Operational Efficiency (OPE) Recommendations | 720d? | 2012-06-25 A | 2015-03-18 | 50% | 360d? | 2012-06-25 | 2014-09-17 | 590d? | 586d | finish no earlier than 2015-03-18 | S5 | 5760h | 2880h | OAM-NGMN_OPE-SA5 | PCG-29 | Huawei | Rel-13 | SP-56 |  | Mirko |  |
| 132 | 43.3 | Converged management Performance Management Interface Definitions | 910d? | 2012-06-20 A | 2015-12-11 | 30% | 637d? | 2012-06-20 | 2014-09-17 | 588d? | 394d | finish no earlier than 2015-12-11 | S5 | 7280h | 2184h | OAM-PMID | PCG-29 | Huawei | Rel-13 | SP-56 | OAM-PMID | Mirko |  |

Notes:
- 106: Define a limited set of operation points for TV services enabling a consistent service offering within 3GPP, but also across different Ans including traditional distribution systems. TV video profiles in selected 3GPP MM services: MBMS, PSS, 3GP-DASH. / WI rapporteur e-mail: gilles.teniou@orange.com
- 107: LM: 0->5% / Impacted TSs and TRs: New TR 26.9xy / WI rapporteur e-mail: gilles.teniou@orange.com
- 108: LM: 0->5% / Impacted TSs and TRs: 26.234, 26.244, 26.346, 26.247, New TS 26.xyz / WI rapporteur e-mail: gilles.teniou@orange.com
- 109: Enhance LTE UE delay test cases & reqs to support DTX & LTE radio optimizations (SPS, DRX), clock accuracy/behaviour of UEs in presence of clock drift, introduce jitter/loss profile condition, testing under H/O condition, MTSI serv over LTE with EVS codec / Impacted TSs and TRs: 26.131, 26.132 / WI rapporteur e-mail: stephane.ragot@orange.com
- 110: Triggered by Rel-12 IMS-based Telepresence (IMS_TELEP) UID_530042 / WI rapporteur e-mail: ozgur.oyman@intel.com
- 111: LM: 0->10% / Impacted TSs and TRs: New TR 26.9xy / WI rapporteur e-mail: ozgur.oyman@intel.com
- 112: LM: 0->10% / Impacted TSs and TRs: New TS 26.1xy / WI rapporteur e-mail: ozgur.oyman@intel.com
- 113: Triggered by Rel-12 TR 26.907 (Study of HTML5 and 3GPP User Services). LM: 0->5% / Impacted TSs and TRs: 26.140, 26.234, 26.247, 26.346, New TS 26.xyz / WI rapporteur e-mail: Imed Bouazizi (i.bouazizi@samsung.com)
- 114: Provide CS support of EVS to enhance voice quality in CS services over UTRAN (3G WCDMA). LM: 0->5% / Impacted TSs and TRs: 26.103, 28.062, New TS 26.xyz (EVS; Speech Codec Frame Structure), New TS 26.xyw (EVS; Interface to Iu, Uu and Nb) / WI rapporteur e-mail: Imre Varga (ivarga@qti.qualcomm.com)
- 115: Triggered by Rel-12 LM: 0->10% / Impacted TSs and TRs: 26.233, 26.234, 26.244, 26.247, 26.938 / WI rapporteur e-mail: Thomas Stockhammer (tsto@qti.qualcomm.com), Li Zhiming (lizhiming@huawei.com)
- 116: SP#65 updated WID SP-130670=>SP-140601 (moved work from Rel-12 incl. new TR to Rel-13). Co-ordinate with SA2, CT1/3/4, IETF MMUSIC. Linked to SA4 Rel-7 Media handling and interaction in MTSI (MTSI-MHI) UID_7040 / WI rapporteur e-mail: tomas.frankkila@ericsson.com
- 117: SP#65 updated WID SP-130670=>SP-140601 (moved work from Rel12 incl. new TR to Rel-13). Completion 03/15=>06/15 / Impacted TSs and TRs: new TR 26.924 / WI rapporteur e-mail: tomas.frankkila@ericsson.com
- 118: SP#65 updated WID SP-130670=>SP-140601 (moved work from Rel12 incl. new TR to Rel-13). Completion 03/15=>06/15. Stage 1 in TS 22.173. LM: 70->40%, CD: 06/15->09/15 / Impacted TSs and TRs: 26.114 / WI rapporteur e-mail: tomas.frankkila@ericsson.com
- 119: Stage 2/3 / Impacted TSs and TRs: Stage 2/3 / WI rapporteur e-mail: susana.fernandez@ericsson.com
- 120: LM: CD: 09/14->09/15 / Impacted TSs and TRs: 29.162, 29.163, 29.213, 29.214 / WI rapporteur e-mail: susana.fernandez@ericsson.com
- 121: CP#64 completion 06/14=>09/14 / Impacted TSs and TRs: 24.229 / WI rapporteur e-mail: susana.fernandez@ericsson.com
- 122: CP#64 completion 06/14=>09/14 / Impacted TSs and TRs: 23.333, 23.334, 29.238, 29.332, 29.333, 29.334 / WI rapporteur e-mail: susana.fernandez@ericsson.com
- 124: Impacted TSs and TRs: 29.162, 29.163, 29.213, 29.214
- 125: Impacted TSs and TRs: 24.229
- 126: Impacted TSs and TRs: 23.333, 23.334, 29.238, 29.332, 29.333, 29.334
- 127: OAM13 is an umbrella Feature for changes that are not part of any other dedicated feature/WI
- 128: SP#64 work not started. LM: 0->20, cd: 06/15->12/15 / Impacted TSs and TRs: 28.627, 28.628, 32.103, 32.422, 32.425, 32.442 / WI rapporteur e-mail: robert.petersen@ericsson.com
- 129: SP#65 updated WID SP-120349=>SP-140538. Completion 12/14=>03/15. Moved to Rel-13. Source of external requirements: NGMN Top OPE Recommendations 1.0 / WI rapporteur e-mail: christian.toche@huawei.com
- 130: SP#65 updated WID SP-120349=>SP-140538. Completion 12/14=>03/15. Moved to Rel-13.. LM: 72->78 / Impacted TSs and TRs: New TR 32.838 / WI rapporteur e-mail: christian.toche@huawei.com
- 131: SP#65 updated WID SP-120349=>SP-140538. Completion 12/14=>03/15. Moved to Rel-13 / Impacted TSs and TRs: 32.101/2/3,32.111-1,32.111-2,32.111-6,32.15x,32.401,32.411,32.412,32.421,32.422,32.423,32.431,32.432,32.436,32.441,32.442,32.446,32.500,32.501,32.502,32.506,32.521,32.522,32.526,32.531,32.532,32.536,32.551,32.691,32.692,32.696,32.762 / WI rapporteur e-mail: christian.toche@huawei.com
- 132: SP#65 updated WID SP-130641=>SP-140613. Completion 09/14=>12/15. Moved to Rel-13. Completion 09/14=>12/15. LM: 20->30 / Impacted TSs and TRs: new TSs (32.PM1, 32.PM6, 32.PM7) / WI rapporteur e-mail: christian.toche@huawei.com

| ID | WBS | Task | Duration | Start | Finish | Complete | Remaining | Baseline start | Baseline finish | Baseline duration | Total slack | Constraint | Resources | Work | Actual work | Acronym | PCG approved | WI rapporteur name | WI rapporteur e-mail | Release | TSG approved | MCC resp | Special Focus Doc | Acronym_3GU_Export | Status Report |
| --- | --- | --- | --- | --- | --- | --- | --- | --- | --- | --- | --- | --- | --- | --- | --- | --- | --- | --- | --- | --- | --- | --- | --- | --- | --- |
| 133 | 43.4 | **WLAN Management** | 788d? | 2012-06-27 A | 2015-06-17 | 12% | 689.51d? | 2012-06-20 | 2014-09-17 | 595d? | 521d |  | S5 | 18848h | 3053.48h | WLAN-OAM | PCG-29 | Intel | joey.chou@intel.com | Rel-13 | SP-56 | Mirko | WLAN | WLAN-OAM |  |
| 134 | 43.4.1 | WLAN Network Resource Model for Type-2 interface | 784d? | 2012-06-27 A | 2015-06-17 | 20% | 627.2d? | 2012-06-27 | 2014-09-17 | 589d? | 521d | finish no earlier than 2015-06-17 | S5 | 6272h | 1254.4h | WLAN-OAM-SA5 | PCG-29 | Intel | joey.chou@intel.com | Rel-13 | SP-56 | Mirko | WLAN |  |  |
| 135 | 43.4.2 | WLAN measurements defined in IEEE and IETF WLAN performance measurements for use on Type-2 interface | 784d? | 2012-06-27 A | 2015-06-17 | 5% | 744.8d? | 2012-06-27 | 2014-09-17 | 589d? | 521d | finish no earlier than 2015-06-17 | S5 | 6272h | 313.6h | WLAN-OAM-SA5 | PCG-29 | Intel | joey.chou@intel.com | Rel-13 | SP-56 | Mirko | WLAN |  |  |
| 136 | 43.5 | Energy Efficiency related Performance Measurements | 521d? | 2013-06-21 A | 2015-06-17 | 25% | 390.75d? | 2013-06-21 | 2014-09-17 | 326d? | 521d | finish no earlier than 2015-06-17 | S5 | 4168h | 1042h | OAM-PM_EE | PCG-31 | Nokia Networks | Yizhi.yao@nsn.com | Rel-13 | SP-60 | Mirko |  | OAM-PM_EE |  |
| 137 | 44 | **Rel-13 Charging** | 393d? | 2014-06-19 A | 2015-12-16 | 10% | 353.67d? | 2014-06-18 | 2015-12-09 | 386d? | 391d |  | S5 | 11504h | 1151.28h | CH13 | PCG-33 |  |  | Rel-13 | SP-64 |  |  | CH13 |  |
| 138 | 44.1 | **Inter-PLMN PS domain online charging** | 393d? | 2014-06-19 A | 2015-12-16 | 10% | 353.67d? | 2014-06-18 | 2015-12-09 | 386d? | 391d |  | S5 | 8360h | 836.64h | iPLMN-PS-OCH | PCG-33 | Alcatel-Lucent | maryse.gardella@alcatel-lucent.com | Rel-13 | SP-64 |  |  | iPLMN-PS-OCH |  |
| 139 | 44.1.1 | TR on Inter-PLMN PS domain online charging | 261d? | 2014-06-19 A | 2015-06-17 | 25% | 195.75d? | 2014-06-18 | 2015-06-17 | 261d? | 521d | finish no earlier than 2015-06-17 | S5 | 2088h | 522h | iPLMN-PS-OCH-SA5TR | PCG-33 | Alcatel-Lucent | maryse.gardella@alcatel-lucent.com | Rel-13 | SP-64 |  |  |  |  |
| 140 | 44.1.2 | Specification of Inter-PLMN PS domain online charging | 391d? | 2014-06-23 | 2015-12-16 |  |  | 2014-06-18 | 2015-12-09 | 386d? | 391d | finish no earlier than 2015-12-16 | S5 | 3128h |  | iPLMN-PS-OCH-SA5 | PCG-33 | Alcatel-Lucent | maryse.gardella@alcatel-lucent.com | Rel-13 | SP-64 |  |  |  |  |
| 141 | 45 | **Support of Real-time Transport Protocol (RTP) / Real-time Transport Control Protocol (RTCP) multiplexing (signalling) in IMS** | 595d? | 2013-09-09 A | 2015-12-11 | 33% | 396.67d? | 2013-09-09 | 2014-09-12 | 267d? | 394d |  | C4; C1; C3 | 28464h | 9488h | RTCP_MUX | PCG-31 | Alcatel-Lucent | Albrecht.Schwarz@alcatel-lucent.com | Rel-13 | CP-61 | Kimmo |  | RTCP_MUX |  |
| 142 | 45.1 | CT4 part of Support of RTP / RTCP multiplexing (signalling) in IMS | 591d? | 2013-09-09 A | 2015-12-11 A | 100% |  | 2013-09-09 | 2014-09-12 | 266d? |  | finish no earlier than 2015-12-11 | C4 | 4728h | 4728h | RTCP_MUX-C4 | PCG-31 | Alcatel-Lucent | Albrecht.Schwarz@alcatel-lucent.com | Rel-13 | CP-61 | Kimmo |  |  |  |
| 143 | 45.2 | CT1 part of Support of RTP / RTCP multiplexing (signalling) in IMS | 591d? | 2013-09-13 | 2015-12-11 |  |  | 2013-09-10 | 2014-09-12 | 266d? | 394d | finish no earlier than 2015-12-11 | C1 | 4728h |  | RTCP_MUX-C1 | PCG-31 | Alcatel-Lucent | Albrecht.Schwarz@alcatel-lucent.com | Rel-13 | CP-61 | Frederic |  |  |  |
| 144 | 45.3 | CT3 part of Support of RTP / RTCP multiplexing (signalling) in IMS | 591d? | 2013-09-13 | 2015-12-11 |  |  | 2013-09-10 | 2014-06-13 | 201d? | 394d | finish no earlier than 2015-12-11 | C3 | 4728h |  | RTCP_MUX-C3 | PCG-31 | Alcatel-Lucent | Albrecht.Schwarz@alcatel-lucent.com | Rel-13 | CP-61 | Adrian |  |  |  |
| 145 | 46 | **LTE in the 1670-1675 MHz Band for US (on hold till 12/2014)** | 868d? | 2012-03-05 A | 2015-06-12 | 8% | 801.54d? | 2012-03-05 | 2015-06-12 | 865d? | 524d |  | R4; R2; R3 | 35264h | 2347.6h | LTE_FDD_1670_US | PCG-28 | LightSquared | masoud.olfat@lightsquared.com | Rel-13 | RP-55 | Issam |  | LTE_FDD_1670_US |  |
| 146 | 46.1 | Core part: LTE in the 1670-1675 MHz Band for US (on hold till 12/2014) | 313d? | 2013-08-06 A | 2015-03-13 | 15% | 266.05d? | 2013-08-06 | 2015-03-13 | 313d? | 589d | finish no earlier than 2015-03-13 | R4; R2; R3 | 7512h | 1126.8h | LTE_FDD_1670_US-Core | PCG-28 | LightSquared | masoud.olfat@lightsquared.com | Rel-13 | RP-55 | Issam |  | LTE_FDD_1670_US-Core | RP-141452 |
| 147 | 46.2 | Perf. Part: LTE in the 1670-1675 MHz Band for US (on hold till 12/2014) | 865d? | 2012-03-05 A | 2015-06-12 | 5% | 821.75d? | 2012-03-05 | 2015-06-12 | 865d? | 524d | finish no earlier than 2015-06-12 | R4 | 6920h | 346h | LTE_FDD_1670_US-Perf | PCG-28 | LightSquared | masoud.olfat@lightsquared.com | Rel-13 | RP-55 | Issam |  | LTE_FDD_1670_US-Perf | RP-141452 |
| 148 | 47 | **Enhanced Signalling for Inter-eNB Coordinated Multi-Point (CoMP) for LTE** | 262d? | 2014-06-18 A | 2015-06-15 | 15% | 222.71d? | 2014-06-13 | 2014-12-05 | 126d? | 523d |  | R3 | 4192h | 628.76h | COMP_LTE_IeNB_sig | PCG-33 | Samsung | sunghwan.won@samsung.com | Rel-13 | RP-64 |  |  | COMP_LTE_IeNB_sig |  |
| 149 | 47.1 | Core part: Enhanced Signalling for Inter-eNB Coordinated Multi-Point (CoMP) for LTE | 262d? | 2014-06-18 A | 2015-06-15 | 15% | 222.7d? | 2014-06-13 | 2014-12-05 | 126d? | 523d | finish no earlier than 2015-06-15 | R3 | 2096h | 314.4h | COMP_LTE_IeNB_sig-Core | PCG-33 | Samsung | sunghwan.won@samsung.com | Rel-13 | RP-64 |  |  | COMP_LTE_IeNB_sig-Core |  |
| 150 | 48 | **2GHz FDD LTE in Region 1 (1980-2010MHz and 2170-2200MHz Bands)** | 263d? | 2014-06-17 A | 2015-06-15 | 7% | 243.28d? | 2014-06-13 | 2015-06-12 | 261d? | 523d |  | R4 | 6296h | 472.17h | LTE_1980_2170_REG1 | PCG-33 | DISH Network | johny.kim@dish.com, mariam.sorond@dish.com | Rel-13 | RP-64 |  |  | LTE_1980_2170_REG1 |  |
| 151 | 48.1 | Core part: 2GHz FDD LTE in Region 1 (1980-2010MHz and 2170-2200MHz Bands) | 262d? | 2014-06-17 A | 2015-06-15 | 15% | 222.7d? | 2014-06-13 | 2015-06-12 | 261d? | 523d | finish no earlier than 2015-06-15 | R4 | 2096h | 314.4h | LTE_1980_2170_REG1-Core | PCG-33 | DISH Network | johny.kim@dish.com, mariam.sorond@dish.com | Rel-13 | RP-64 |  |  | LTE_1980_2170_REG1-Core | RP-141627 |
| 152 | 48.2 | Perf. Part: 2GHz FDD LTE in Region 1 (1980-2010MHz and 2170-2200MHz Bands) | 262d? | 2014-06-18 | 2015-06-15 |  |  | 2014-06-13 | 2015-06-12 | 261d? | 523d | finish no earlier than 2015-06-15 | R4 | 2096h |  | LTE_1980_2170_REG1-Perf | PCG-33 | DISH Network | johny.kim@dish.com, mariam.sorond@dish.com | Rel-13 | RP-64 |  |  | LTE_1980_2170_REG1-Perf | RP-141627 |
| 153 | 49 | **Further LTE Physical Layer Enhancements for MTC** | 461d? | 2014-09-12 A | 2016-06-15 | 4% | 441.77d? | 2014-06-13 | 2015-06-12 | 261d? | 261d |  | R1; R4; R2 | 22672h | 1253.59h | LTE_MTCe2_L1 | PCG-33 | Ericsson | johan.bergman@ericsson.com | Rel-13 | RP-65 |  |  | LTE_MTCe2_L1 |  |
| 154 | 49.1 | Core part: Further LTE Physical Layer Enhancements for MTC | 330d? | 2014-09-12 A | 2015-12-15 | 10% | 297d? | 2014-06-13 | 2015-06-12 | 261d? | 392d | finish no earlier than 2015-12-15 | R1; R2; R4 | 7920h | 792h | LTE_MTCe2_L1-Core | PCG-33 | Ericsson | johan.bergman@ericsson.com | Rel-13 | RP-65 |  |  | LTE_MTCe2_L1-Core |  |
| 155 | 49.2 | Perf. Part: Further LTE Physical Layer Enhancements for MTC | 461d? | 2014-09-12 | 2016-06-15 |  |  | 2014-06-13 | 2015-06-12 | 261d? | 261d | finish no earlier than 2016-06-15 | R4 | 3688h |  | LTE_MTCe2_L1-Perf | PCG-33 | Ericsson | johan.bergman@ericsson.com | Rel-13 | RP-65 |  |  | LTE_MTCe2_L1-Perf |  |
| 156 | 50 | **Self Organizing Networks (SON) for Active Antenna System (AAS) based deployments** | 199d? | 2014-09-12 A | 2015-06-15 | 15% | 169.16d? | 2014-06-13 | 2015-06-12 | 261d? | 523d |  | R3; G2 | 4776h | 716.18h | UTRA_LTE_SON_AAS | PCG-33 | Nokia Networks | krzysztof.kordybach@nsn.com | Rel-13 | RP-65 |  |  | UTRA_LTE_SON_AAS |  |
| 157 | 50.1 | Core part: Self Organizing Networks (SON) for Active Antenna System (AAS) based deployments | 199d? | 2014-09-12 A | 2015-06-15 | 15% | 169.15d? | 2014-06-13 | 2015-06-12 | 261d? | 523d | finish no earlier than 2015-06-15 | R3 | 1592h | 238.8h | UTRA_LTE_SON_AAS-Core | PCG-33 | Nokia Networks | krzysztof.kordybach@nsn.com | Rel-13 | RP-65 |  |  | UTRA_LTE_SON_AAS-Core |  |

Notes:
- 133: SP#65 moved to Rel-13. Updated WID SP-130042=>SP-140535 (split into Rel-12 Study & Rel-13 normative WI). TR 32.841 was completed as a Rel-12 Study and has triggered this normative work
- 134: SP#65 updated WID SP-130042=>SP-140535. Completion 09/14=>06/15. Moved to Rel-13. LM: 10->20 / Impacted TSs and TRs: new TS (28.680, 28.682)
- 135: SP#65 updated WID SP-130042=>SP-140535. Completion 09/14=>06/15. Moved to Rel-13 / Impacted TSs and TRs: new TS 28.403
- 136: SP#65 updated WID SP-130263=>SP-140612. Completion 09/14=>06/15. Moved to Rel-13 / Impacted TSs and TRs: 32.425
- 137: CH13 is an umbrella Feature for changes that are not part of any other dedicated feature/WI
- 138: Study and specify Gy Reference Point service data flows based online charging for inter-PLMN situations / Impacted TSs and TRs: Stage 2/3
- 139: LM: 10->25% / Impacted TSs and TRs: New TR 32.843
- 140: - / Impacted TSs and TRs: 32.251, 32.299
- 141: CP#65 moved to Rel-13. Stage 2/3 / Impacted TSs and TRs: Stage 2/3
- 142: CP#65 moved to Rel-13. Completion 09/14=>12/15. LM: 10->100 / Impacted TSs and TRs: 23.334, 29.334
- 143: CP#65 moved to Rel-13. Completion 09/14=>12/15 / Impacted TSs and TRs: 24.229
- 144: CP#65 moved to Rel-13. Completion 09/14=>12/15 / Impacted TSs and TRs: 29.213, 29.214
- 145: RP#65 FS_LTE_FDD_1670_US is extended to 12/14 and this WI (LTE_FDD_1670_US) is on hold till 12/14 / Impacted TSs and TRs: LTE
- 146: RP#65 completion 03/15=>06/15. On hold till 12/2014 / Impacted TSs and TRs: 25.101, 25.104, 25.113, 25.133, 25.306, 25.307, 25.331, 25.461, 25.466, 34.124, 36.101, 36.104, 36.113, 36.124, 36.133, 36.307, new TR 36.832
- 147: RP#65 completion 06/15=>09/15. . On hold till 12/2014 / Impacted TSs and TRs: 25.133, 25.306, 25.307, 25.331, 25.461, 25.466, 34.124, 36.113, 36.124, 36.133, 36.141, 36.307
- 148: Triggered by TR 36.874 Study on Coordinated Multi-Point (CoMP) operation for LTE with Non-Ideal Backhaul (UID_600015) / Impacted TSs and TRs: LTE
- 149: CD:Thu 11/12/14->Mon 15/06/15; Compl:0%->15% / Impacted TSs and TRs: 36.300, 36.423
- 150: Triggered by TR 37.846 Study on 2GHz FDD for UTRA and LTE in Region 1 (1980-2010MHz and 2170-2200MHz Bands) FS_UTRA_LTE_1980_2170_REG1 / Impacted TSs and TRs: LTE
- 151: CD:Fri 12/06/15->Mon 15/06/15; Compl:5%->15% / Impacted TSs and TRs: 36.101, 36.104, 36.133, 36.141, 36.307, generic TR 36.853 (3 Band CA with 1UL), New TR 36.862 (Technical Report for 2 GHz Band in Region 1)
- 152: CD:Fri 12/06/15->Mon 15/06/15; Compl:0%->0% / Impacted TSs and TRs: 36.101, 36.104, 36.133, 36.141, 36.307, 36.862
- 153: Triggered by Rel-12 TR 36.888 Study on Provision of low-cost MTC UEs based on LTE (FS_LC_MTC_LTE) and Low cost & enhanced coverage MTC UE for LTE (LC_MTC_UE) / Impacted TSs and TRs: LTE
- 154: CD:Mon 09/02/15->Tue 15/12/15; Compl:0%->10%; WID:RP-140955->RP-142043 / Impacted TSs and TRs: 36.101, 36.104, 36.133, 36.201, 36.211, 36.212, 36.213, 36.214, 36.300, 36.302, 36.306, 36.321, 36.331
- 155: CD:Thu 16/06/16->Wed 15/06/16; Compl:0%->0%; WID:RP-140955->RP-142043 / Impacted TSs and TRs: 36.101, 36.104, 36.133
- 156: Triggered by TR 37.822 Study on Next-Generation SON for UTRA and LTE (FS_UTRA_LTE_NG_SON) / Impacted TSs and TRs: LTE
- 157: CD:Tue 16/06/15->Mon 15/06/15; Compl:0%->15% / Impacted TSs and TRs: 36.300, 36.423, 36.413, 25.413

| ID | WBS | Task | Duration | Start | Finish | Complete | Remaining | Total slack | Constraint | Resources | Work | Actual work | Acronym | WI rapporteur name | Release | TSG approved | Impacted TSs and TRs |
| --- | --- | --- | --- | --- | --- | --- | --- | --- | --- | --- | --- | --- | --- | --- | --- | --- | --- |
| 158 | 51 | **Usage Monitoring Control PCC Extension** | 140d? | 2014-12-03 A | 2015-06-16 | 7% | 129.95d? | 522d |  | S2 | 2824h | 186.4h | eUMONC | CTBRI | Rel-13 | SP-66 |  |
| 159 | 51.1 | Stage 2 of Usage Monitoring Control PCC Extension | 140d? | 2014-12-03 A | 2015-06-16 | 6% | 132d? | 522d | finish no earlier than 2015-06-16 | S2 | 1120h | 64h | eUMONC-SA2 | CTBRI | Rel-13 | SP-66 |  |
| 160 | 51.2 | CT3 Aspect of Usage Monitoring Control extension | 73d? | 2014-12-03 A | 2015-03-13 | 10% | 65.7d? | 589d | finish no earlier than 2015-03-13 | C3 | 584h | 58.4h | eUMONC-CT3 | ZTE | Rel-13 | CT-66 | 29.212, 29.215 |
| 161 | 52 | **Service Domain Centralization** | 140d? | 2014-12-03 | 2015-06-16 |  |  | 522d |  | S2 | 3360h |  | SeDoC | T-Mobile | Rel-13 | SP-66 |  |
| 162 | 52.1 | Service Domain Centralization TR Phase | 140d? | 2014-12-03 | 2015-06-16 |  |  | 522d | finish no earlier than 2015-06-16 | S2 | 1120h |  | SeDoC-SA2TR | T-Mobile | Rel-13 | SP-66 |  |
| 163 | 52.2 | Service Domain Centralization - Stage 2 | 140d? | 2014-12-03 | 2015-06-16 |  |  | 522d | finish no earlier than 2015-06-16 | S2 | 1120h |  | SeDoC-SA2 | T-Mobile | Rel-13 | SP-66 |  |
| 164 | 53 | **MBMS Enhancements** | 204d? | 2014-12-03 | 2015-09-14 |  |  | 458d |  | S2 | 4896h |  | MBMS_enh | Rainer Liebhart | Rel-13 | SP-66 |  |
| 165 | 53.1 | MBMS Enhancements TR Phase | 204d? | 2014-12-03 | 2015-09-14 |  |  | 458d | finish no earlier than 2015-09-14 | S2 | 1632h |  | MBMS_enh-SA2TR | Rainer Liebhart | Rel-13 | SP-66 |  |
| 166 | 53.2 | MBMS Enhancements - Stage 2 | 204d? | 2014-12-03 | 2015-09-14 |  |  | 458d | finish no earlier than 2015-09-14 | S2 | 1632h |  | MBMS_enh-SA2 | Rainer Liebhart | Rel-13 | SP-66 |  |
| 167 | 54 | **Enhanced P-CSCF discovery using signalling for access to EPC via WLAN** | 115d? | 2014-10-06 A | 2015-03-13 | 39% | 70.35d? | 589d |  | C1 | 2424h | 892.46h | ePCSCF_WLAN | Ericsson | Rel-13 | CT-66 |  |
| 168 | 54.1 | CT1 aspects of Enhanced P-CSCF discovery using signalling for access to EPC via WLAN | 73d? | 2014-12-03 A | 2015-03-13 A | 100% |  |  | finish no earlier than 2015-03-13 | C1 | 584h | 584h | ePCSCF_WLAN-CT1 | Ericsson | Rel-13 | CT-66 | 24.229, 24.302 |
| 169 | 54.2 | CT4 aspects of Enhanced P-CSCF discovery using signalling for access to EPC via WLAN | 115d? | 2014-10-06 | 2015-03-13 |  |  | 589d | finish no earlier than 2015-03-13 | C4 | 920h |  | ePCSCF_WLAN-CT4 | Ericsson | Rel-13 | CT-66 | 29.274, 29.275 |
| 170 | 55 | Stage-3 SAE Protocol Development | 268d? | 2014-12-03 | 2015-12-11 |  |  | 394d | finish no earlier than 2015-12-11 | C1 | 2144h |  | SAES4, SAES4-CSFB, SAES4-non3GPP | interdigital | Rel-13 | CT-66 |  |
| 171 | 56 | IMS Stage-3 IETF Protocol Alignment | 268d? | 2014-12-03 | 2015-12-11 |  |  | 394d | finish no earlier than 2015-12-11 | C1 | 2144h |  | IMSProtoc7 | Alcatel-Lucent | Rel-13 | CT-66 |  |
| 172 | 57 | **Interworking solution for Called IN number and original called IN number ISUP parameters** | 73d? | 2014-12-03 A | 2015-03-13 | 53% | 34.67d? | 589d |  | C1 | 1606h | 613.2h | INNB_IW | Orange | Rel-13 | CT-66 |  |
| 173 | 57.1 | (IETF) CT1 part of Interworking solution for Called IN number and original called IN number ISUP parameters | 73d? | 2014-12-03 A | 2015-03-13 | 25% | 54.75d? | 589d | start no earlier than 2014-12-03 | C1 | 584h | 146h | INNB_IW-CT1 | Orange | Rel-13 | CT-66 | draft-mohali-dispatch-cause-for-service-number |
| 174 | 57.2 | CT3 aspects of Interworking solution for Called IN number and original called IN number ISUP parameters | 73d? | 2014-12-03 A | 2015-03-13 | 80% | 14.6d? | 589d | finish no earlier than 2015-03-13 | C3 | 584h | 467.2h | INNB_IW-CT3 | Orange | Rel-13 | CT-66 |  |
| 175 | 58 | **Warning Status Report in EPS** | 204d? | 2014-12-03 | 2015-09-14 |  |  | 458d |  | C4 | 4896h |  | WSR_EP | one2many | Rel-13 | CT-66 |  |
| 176 | 58.1 | CT1 aspects of Warning Status Report in EPS | 204d? | 2014-12-03 | 2015-09-14 |  |  | 458d | start no earlier than 2014-12-03 | C1 | 1632h |  | WSR_EP-CT1 | one2many | Rel-13 | CT-66 | New TR 23.712 |
| 177 | 58.2 | CT4 aspects of Warning Status Report in EPS | 204d? | 2014-12-03 | 2015-09-14 |  |  | 458d | finish no earlier than 2015-09-14 | C4 | 1632h |  | WSR_EP-CT4 | one2many | Rel-13 | CT-66 |  |
| 178 | 59 | Study on Diameter Load Control Mechanisms | 203d? | 2014-12-03 A | 2015-09-11 | 5% | 192.85d? | 459d | finish no earlier than 2015-09-11 | C4 | 1624h | 81.2h | FS_DLoCME | Alcatel-Lucent | Rel-13 | CT-66 | New 29.810 |
| 179 | 60 | Shared Data Update for Multiple Subscriber | 1d? | 2014-12-03 | 2014-12-03 |  |  | 661d | start no earlier than 2014-12-03 | C4 | 8h |  | SHARED_SubData_UPD | Huawei | Rel-13 | CT-66 | 29.328, 29.364 |
| 180 | 61 | Study on EPC Signalling Improvement for Race Scenarios | 203d? | 2014-12-03 | 2015-09-11 |  |  | 459d | finish no earlier than 2015-09-11 | C4 | 1624h |  | FS_EPC_SIG_RACE | Huawei | Rel-13 | CT-66 | New TR 29.811 |
| 181 | 62 | **P-CSCF Restoration Enhancements with WLAN** | 268.05d? | 2014-12-03 A | 2015-12-14 | 2% | 261.35d? | 393.95d |  | C4 | 6432.4h | 160.79h | PCSCF_RES_WLAN | Alcatel-Lucent | Rel-13 | CT-66 |  |
| 182 | 62.1 | CT4 aspects of P-CSCF Restoration Enhancements with WLAN | 268d? | 2014-12-03 A | 2015-12-11 | 5% | 254.6d? | 394d | finish no earlier than 2015-12-11 | C4 | 2144h | 107.2h | PCSCF_RES_WLAN-CT4 | Alcatel-Lucent | Rel-13 | CT-66 | New 29.8xy, 23.380, 29.273, 29.274, 29.275 |
| 183 | 62.2 | CT1 aspects of P-CSCF Restoration Enhancements with WLAN | 268d? | 2014-12-03 A | 2015-12-14 |  | 268d? | 393.95d | finish no earlier than 2015-12-11 | C1 | 2144h |  | PCSCF_RES_WLAN-CT1 | Alcatel-Lucent | Rel-13 | CT-66 | 24.302, 24.229, 24.244, 24.008 |
| 184 | 63 | ULI and release causes for charging enhancement for VoLTE | 203d? | 2014-12-03 | 2015-09-11 |  |  | 459d | finish no earlier than 2015-09-11 | S5 | 1624h |  | new4 |  | Rel-13 | SP-66 |  |
| 185 | 64 | Multi-Broadcast Single Frequency Network (MBSFN) Minimization of Drive Tests (MDT) enhancement | 138d? | 2014-12-03 | 2015-06-12 |  |  | 524d | finish no earlier than 2015-06-12 | S5 | 1104h |  | new5 |  | Rel-13 | SP-66 |  |

Notes:
- 158: Proposed at TSG#66
- 159: Proposed at TSG#66
- 160: Proposed at TSG#66
- 161: Proposed at TSG#66
- 162: Proposed at TSG#66
- 163: Proposed at TSG#66
- 164: Proposed at TSG#66
- 165: Proposed at TSG#66
- 166: Proposed at TSG#66
- 167: Proposed at TSG#66
- 168: Proposed at TSG#66. 12/12:0->100%
- 169: Proposed at TSG#66
- 170: Proposed at TSG#66
- 171: Proposed at TSG#66
- 172: Proposed at TSG#66
- 173: Proposed at TSG#66
- 174: Proposed at TSG#66
- 175: Proposed at TSG#66
- 176: Proposed at TSG#66
- 177: Proposed at TSG#66
- 178: 0->5%
- 179: Proposed at TSG#66
- 180: Proposed at TSG#66
- 181: WID added, acronym
- 182: 0->5%
- 183: CT4->CT1
- 184: Proposed at TSG#66
- 185: Proposed at TSG#66

| ID | WBS | Task | Duration | Start | Finish | Complete | Remaining | Baseline start | Baseline finish | Baseline duration | Total slack | Constraint | Resources | Work | Actual work | Acronym | PCG approved | WI rapporteur name | WI rapporteur e-mail | Release | TSG approved | MCC resp | Acronym_3GU_Export | Status Report | Special Focus Doc |
| --- | --- | --- | --- | --- | --- | --- | --- | --- | --- | --- | --- | --- | --- | --- | --- | --- | --- | --- | --- | --- | --- | --- | --- | --- | --- |
| 186 | 65 | **IMS Signalling Activated Trace** | 466d? | 2014-03-05 A | 2015-12-11 | 28% | 335.83d? | 2014-03-05 | 2014-09-12 | 138d? | 394d |  | C1; C3; C4; IETF | 33848h | 6700.85h | ISAT | PCG-32 | Vodafone | peter.dawes @vodafone.com | Rel-13 | CP-63 | Frederic | ISAT |  |  |
| 187 | 65.1 | CT1 part of IMS Signalling Activated Trace | 463d? | 2014-03-10 | 2015-12-11 |  |  | 2014-03-05 | 2014-09-12 | 138d? | 394d | finish no earlier than 2015-12-11 | C1 | 3704h |  | ISAT | PCG-32 | Vodafone | peter.dawes @vodafone.com | Rel-13 | CP-63 | Frederic |  | CP-140606 |  |
| 188 | 65.2 | (IETF) IMS Signalling Activated Trace (draft-dawes-sipping-debug) | 326d? | 2014-09-12 A | 2015-12-11 | 25% | 244.5d? |  |  |  | 394d | finish no earlier than 2015-12-11 | C1-IETF | 2608h | 652h | ISAT | PCG-33 | Vodafone | peter.dawes @vodafone.com | Rel-13 | CP-65 |  |  |  |  |
| 189 | 65.3 | (IETF) IMS Signalling Activated Trace (draft-dawes-sipping-debug) | 326d? | 2014-09-12 A | 2015-12-11 | 25% | 244.5d? |  |  |  | 394d | finish no earlier than 2015-12-11 | C3-IETF | 2608h | 652h | ISAT | PCG-33 | Vodafone | peter.dawes @vodafone.com | Rel-13 | CP-65 |  |  |  |  |
| 190 | 65.4 | (IETF) IMS Signalling Activated Trace (draft-dawes-sipping-debug) | 326d? | 2014-09-12 A | 2015-12-11 | 25% | 244.5d? |  |  |  | 394d | finish no earlier than 2015-12-11 | C4-IETF | 2608h | 652h | ISAT | PCG-33 | Vodafone | peter.dawes @vodafone.com | Rel-13 | CP-65 |  |  |  |  |
| 191 | 65.5 | CT3 part of IMS Signalling Activated Trace | 463d? | 2014-03-10 | 2015-12-11 |  |  | 2014-03-05 | 2014-06-13 | 73d? | 394d | finish no earlier than 2015-12-11 | C3 | 3704h |  | ISAT | PCG-32 | Vodafone | peter.dawes @vodafone.com | Rel-13 | CP-63 | Adrian |  | CP-140564 |  |
| 192 | 65.6 | CT4 part of IMS Signalling Activated Trace | 463d? | 2014-03-05 A | 2015-12-11 | 90% | 46.3d? | 2014-03-05 | 2014-09-12 | 138d? | 394d | finish no earlier than 2015-12-11 | C4 | 3704h | 3333.6h | ISAT | PCG-32 | Vodafone | peter.dawes @vodafone.com | Rel-13 | CP-63 | Kimmo |  | CP-140480 |  |
| 193 | 66 | **Rel-13 LTE Carrier Aggregation** | 400d? | 2013-12-09 A | 2015-06-15 | 54% | 182.47d? | 2014-03-06 | 2015-06-12 | 332d? | 523d |  | R4 | 154016h | 81206.8h | LTE_CA_Rel-13 | PCG-30 |  |  | Rel-13 | RP-58 | Issam | LTE_CA_Rel-13 |  | CA |
| 194 | 66.1 | **LTE Advanced inter-band Carrier Aggregation of Band 8 and Band 27** | 400d? | 2013-12-09 A | 2015-06-15 | 10% | 360.01d? | 2013-12-09 | 2014-12-11 | 265d? | 523d |  | R4 | 9552h | 743.88h | LTE_CA_B8_B27 | PCG-32 | KT | ilwhan.kim@kt.com | Rel-13 | RP-62 | Issam | LTE_CA_B8_B27 |  | CA |
| 195 | 66.1.1 | Core part: LTE Advanced inter-band Carrier Aggregation of Band 8 and Band 27 | 397d? | 2013-12-09 A | 2015-06-15 | 10% | 357.3d? | 2013-12-09 | 2014-12-11 | 265d? | 523d | finish no earlier than 2015-06-15 | R4 | 3176h | 317.6h | LTE_CA_B8_B27-Core | PCG-32 | KT | ilwhan.kim@kt.com | Rel-13 | RP-62 | Issam | LTE_CA_B8_B27-Core | RP-141084 | CA |
| 196 | 66.1.2 | Perf. part: LTE Advanced inter-band Carrier Aggregation of Band 8 and Band 27 | 397d? | 2013-12-09 A | 2015-06-15 | 10% | 357.3d? | 2013-12-09 | 2014-12-11 | 265d? | 523d | finish no earlier than 2015-06-15 | R4 | 3176h | 317.6h | LTE_CA_B8_B27-Perf | PCG-32 | KT | ilwhan.kim@kt.com | Rel-13 | RP-62 | Issam | LTE_CA_B8_B27-Perf | RP-141084 | CA |
| 197 | 66.2 | **LTE Advanced 3 band Carrier Aggregation (3DL/1UL) for Band 3, Band 8 and Band 27** | 400d? | 2013-12-09 A | 2015-06-15 | 25% | 300d? | 2013-12-09 | 2014-12-05 | 261d? | 523d |  | R4 | 9552h | 1860h | LTE_CA_B3_B8_B27 | PCG-32 | KT | Chungwoo HWANG (cwhwang@kt.com) | Rel-13 | RP-62 | Issam | LTE_CA_B3_B8_B27 |  | CA |
| 198 | 66.2.1 | Core part: LTE Advanced 3 band Carrier Aggregation (3DL/1UL) for Band 3, Band 8 and Band 27 | 397d? | 2013-12-09 A | 2015-06-15 | 25% | 297.75d? | 2013-12-09 | 2014-12-05 | 261d? | 523d | finish no earlier than 2015-06-15 | R4 | 3176h | 794h | LTE_CA_B3_B8_B27-Core | PCG-32 | KT | Chungwoo HWANG (cwhwang@kt.com) | Rel-13 | RP-62 | Issam | LTE_CA_B3_B8_B27-Core | RP-141084 | CA |
| 199 | 66.2.2 | Perf. part: LTE Advanced 3 band Carrier Aggregation (3DL/1UL) for Band 3, Band 8 and Band 27 | 397d? | 2013-12-09 A | 2015-06-15 | 25% | 297.75d? | 2013-12-09 | 2014-12-05 | 261d? | 523d | finish no earlier than 2015-06-15 | R4 | 3176h | 794h | LTE_CA_B3_B8_B27-Perf | PCG-32 | KT | Chungwoo HWANG (cwhwang@kt.com) | Rel-13 | RP-62 | Issam | LTE_CA_B3_B8_B27-Perf | RP-141084 | CA |
| 200 | 66.3 | **LTE Advanced inter-band Carrier Aggregation of Band 7 and Band 22** | 336d? | 2014-03-06 A | 2015-06-15 | 5% | 319.2d? | 2014-03-06 | 2014-12-05 | 197d? | 523d |  | R4 | 8016h | 346.33h | LTE_CA_B7_B22 | PCG-32 | Orange, Ericsson | erika.tejedor@ericsson.com | Rel-13 | RP-63 | Issam | LTE_CA_B7_B22 |  | CA |
| 201 | 66.3.1 | Core part: LTE Advanced inter-band Carrier Aggregation of Band 7 and Band 22 | 333d? | 2014-03-06 A | 2015-06-15 | 10% | 299.7d? | 2014-03-06 | 2014-12-05 | 197d? | 523d | finish no earlier than 2015-06-15 | R4 | 2664h | 266.4h | LTE_CA_B7_B22-Core | PCG-32 | Orange, Ericsson | erika.tejedor@ericsson.com | Rel-13 | RP-63 | Issam | LTE_CA_B7_B22-Core | RP-141084 | CA |
| 202 | 66.3.2 | Perf. part: LTE Advanced inter-band Carrier Aggregation of Band 7 and Band 22 | 333d? | 2014-03-11 | 2015-06-15 |  |  | 2014-03-06 | 2014-12-05 | 197d? | 523d | finish no earlier than 2015-06-15 | R4 | 2664h |  | LTE_CA_B7_B22-Perf | PCG-32 | Orange, Ericsson | erika.tejedor@ericsson.com | Rel-13 | RP-63 | Issam | LTE_CA_B7_B22-Perf | RP-141084 | CA |
| 203 | 66.4 | **LTE Advanced inter-band Carrier Aggregation of Band 5 and Band 13** | 206d? | 2014-03-06 A | 2014-12-15 A | 100% |  | 2014-03-06 | 2014-12-05 | 197d? |  |  | R4 | 4896h | 4896h | LTE_CA_B5_B13 | PCG-32 | Intel | xinrong.wang@intel.com | Rel-13 | RP-63 | Issam | LTE_CA_B5_B13 |  | CA |
| 204 | 66.4.1 | Core part: LTE Advanced inter-band Carrier Aggregation of Band 5 and Band 13 | 203d? | 2014-03-06 A | 2014-12-15 A | 100% |  | 2014-03-06 | 2014-12-05 | 197d? |  | finish no earlier than 2014-12-15 | R4 | 1624h | 1624h | LTE_CA_B5_B13-Core | PCG-32 | Intel | xinrong.wang@intel.com | Rel-13 | RP-63 | Issam | LTE_CA_B5_B13-Core | RP-141084 | CA |
| 205 | 66.4.2 | Perf. part: LTE Advanced inter-band Carrier Aggregation of Band 5 and Band 13 | 203d? | 2014-03-06 A | 2014-12-15 A | 100% |  | 2014-03-06 | 2014-12-05 | 197d? |  | finish no earlier than 2014-12-15 | R4 | 1624h | 1624h | LTE_CA_B5_B13-Perf | PCG-32 | Intel | xinrong.wang@intel.com | Rel-13 | RP-63 | Issam | LTE_CA_B5_B13-Perf | RP-141084 | CA |
| 206 | 66.5 | **LTE Advanced 3 Band Carrier Aggregation (3DL/1UL) of Band 2, Band 2 and Band 5** | 206d? | 2014-03-06 A | 2014-12-15 A | 100% |  | 2014-03-06 | 2014-12-05 | 197d? |  |  | R4 | 4912h | 4912h | LTE_CA_B2_B2_B5 | PCG-32 | Intel | peiling.zhang@intel.com | Rel-13 | RP-63 | Issam | LTE_CA_B2_B2_B5 |  | CA |
| 207 | 66.5.1 | Core part: LTE Advanced 3 Band Carrier Aggregation (3DL/1UL) of Band 2, Band 2 and Band 5 | 205d? | 2014-03-06 A | 2014-12-15 A | 100% |  | 2014-03-06 | 2014-12-05 | 197d? |  | finish no earlier than 2014-12-15 | R4 | 1640h | 1640h | LTE_CA_B2_B2_B5-Core | PCG-32 | Intel | peiling.zhang@intel.com | Rel-13 | RP-63 | Issam | LTE_CA_B2_B2_B5-Core | RP-141084 | CA |
| 208 | 66.5.2 | Perf. part: LTE Advanced 3 Band Carrier Aggregation (3DL/1UL) of Band 2, Band 2 and Band 5 | 203d? | 2014-03-06 A | 2014-12-15 A | 100% |  | 2014-03-06 | 2014-12-05 | 197d? |  | finish no earlier than 2014-12-15 | R4 | 1624h | 1624h | LTE_CA_B2_B2_B5-Perf | PCG-32 | Intel | peiling.zhang@intel.com | Rel-13 | RP-63 | Issam | LTE_CA_B2_B2_B5-Perf | RP-141084 | CA |
| 209 | 66.6 | **LTE Advanced 3 Band Carrier Aggregation (3DL/1UL) of Band 4, Band 4 and Band 5** | 206d? | 2014-03-06 A | 2014-12-15 A | 100% |  | 2014-03-06 | 2014-12-05 | 197d? |  |  | R4 | 4912h | 4912h | LTE_CA_B4_B4_B5 | PCG-32 | Intel | peiling.zhang@intel.com | Rel-13 | RP-63 | Issam | LTE_CA_B4_B4_B5 |  | CA |
| 210 | 66.6.1 | Core part: LTE Advanced 3 Band Carrier Aggregation (3DL/1UL) of Band 4, Band 4 and Band 5 | 205d? | 2014-03-06 A | 2014-12-15 A | 100% |  | 2014-03-06 | 2014-12-05 | 197d? |  | finish no earlier than 2014-12-15 | R4 | 1640h | 1640h | LTE_CA_B4_B4_B5-Core | PCG-32 | Intel | peiling.zhang@intel.com | Rel-13 | RP-63 | Issam | LTE_CA_B4_B4_B5-Core | RP-141084 | CA |
| 211 | 66.6.2 | Perf. part: LTE Advanced 3 Band Carrier Aggregation (3DL/1UL) of Band 4, Band 4 and Band 5 | 203d? | 2014-03-06 A | 2014-12-15 A | 100% |  | 2014-03-06 | 2014-12-05 | 197d? |  | finish no earlier than 2014-12-15 | R4 | 1624h | 1624h | LTE_CA_B4_B4_B5-Perf | PCG-32 | Intel | peiling.zhang@intel.com | Rel-13 | RP-63 | Issam | LTE_CA_B4_B4_B5-Perf | RP-141084 | CA |

Notes:
- 186: Linked to Rel-8 OAM8-Trace. Update interface protocols to include the procedures defined in SA5 TS 32.422 for trace activation, and for conveying a signalling activated tracing indicator.
- 187: CP66: moved to Rel-13` / Impacted TSs and TRs: 24.229, 24.323
- 188: CP66: moved to Rel-13` / Impacted TSs and TRs: draft-dawes-sipping-debug
- 189: CP66: moved to Rel-13` / Impacted TSs and TRs: draft-dawes-sipping-debug
- 190: CP66: moved to Rel-13` / Impacted TSs and TRs: draft-dawes-sipping-debug
- 191: CP66: moved to Rel-13` / Impacted TSs and TRs: 29.165
- 192: CP66: moved to Rel-13` / Impacted TSs and TRs: 23.008, 29.228, 29.229, 29.328, 29.329
- 193: LTE_CA_Rel-13
- 194: Inter-band CA 2DL/1UL / Impacted TSs and TRs: LTE
- 195: CD:Thu 18/06/15->Mon 15/06/15; Compl:10%->10% / Impacted TSs and TRs: 36.101, 36.104, 36.133, generic TR 36.851
- 196: CD:Thu 18/06/15->Mon 15/06/15; Compl:10%->10% / Impacted TSs and TRs: 36.141, 36.307
- 197: Inter-band CA 3DL / Impacted TSs and TRs: LTE
- 198: CD:Thu 18/06/15->Mon 15/06/15; Compl:25%->25% / Impacted TSs and TRs: 36.101, 36.104, 36.133, 36.141, 36.307, new generic TR 36.853 (3 Band CA with 1UL)
- 199: CD:Thu 18/06/15->Mon 15/06/15; Compl:25%->25% / Impacted TSs and TRs: 36.101, 36.104, 36.133, 36.141, 36.307
- 200: Inter-band CA 2DL / Impacted TSs and TRs: LTE
- 201: CD:Thu 11/12/14->Mon 15/06/15; Compl:10%->10% / Impacted TSs and TRs: 36.101, 36.104, 36.133, generic TR 36.851 (2 Band CA with 1UL),
- 202: CD:Thu 11/12/14->Mon 15/06/15; Compl:0%->0% / Impacted TSs and TRs: 36.141, 36.307
- 203: Inter-band CA 2DL / Impacted TSs and TRs: LTE
- 204: CD:Thu 12/03/15->Mon 15/12/14; Compl:50%->100% / Impacted TSs and TRs: 36.101, 36.104, 36.133, generic TR 36.851 (2 Band CA with 1UL)
- 205: CD:Thu 12/03/15->Mon 15/12/14; Compl:10%->100% / Impacted TSs and TRs: 36.101, 36.133, 36.141, 36.307
- 206: Inter-band CA 3DL / Impacted TSs and TRs: LTE
- 207: CD:Thu 12/03/15->Mon 15/12/14; Compl:90%->100% / Impacted TSs and TRs: 36.101, 36.104, 36.133, generic TR 36.853 (3 Band CA with 1UL)
- 208: CD:Thu 12/03/15->Mon 15/12/14; Compl:10%->100% / Impacted TSs and TRs: 36.101, 36.133, 36.141, 36.307
- 209: Inter-band CA 3DL / Impacted TSs and TRs: LTE
- 210: CD:Thu 12/03/15->Mon 15/12/14; Compl:90%->100% / Impacted TSs and TRs: 36.101, 36.104, 36.133, generic TR 36.853 (3 Band CA with 1UL)
- 211: CD:Thu 12/03/15->Mon 15/12/14; Compl:10%->100% / Impacted TSs and TRs: 36.101, 36.133, 36.141, 36.307

| ID | WBS | Task | Duration | Start | Finish | Complete | Remaining | Baseline start | Baseline finish | Baseline duration | Total slack | Constraint | Resources | Work | Actual work | Acronym | PCG approved | WI rapporteur name | WI rapporteur e-mail | Release | TSG approved | MCC resp | Special Focus Doc | Acronym_3GU_Export | Status Report |
| --- | --- | --- | --- | --- | --- | --- | --- | --- | --- | --- | --- | --- | --- | --- | --- | --- | --- | --- | --- | --- | --- | --- | --- | --- | --- |
| 212 | 66.7 | **LTE Advanced 3 Band Carrier Aggregation (3DL/1UL) of Band 2, Band 5 and Band 13** | 206d? | 2014-03-06 A | 2014-12-15 A | 100% |  | 2014-03-06 | 2014-12-05 | 197d? |  |  | R4 | 4896h | 4896h | LTE_CA_B2_B5_B13 | PCG-32 | Intel | xinrong.wang@intel.com | Rel-13 | RP-63 | Issam | CA | LTE_CA_B2_B5_B13 |  |
| 213 | 66.7.1 | Core part: LTE Advanced 3 Band Carrier Aggregation (3DL/1UL) of Band 2, Band 5 and Band 13 | 203d? | 2014-03-06 A | 2014-12-15 A | 100% |  | 2014-03-06 | 2014-12-05 | 197d? |  | finish no earlier than 2014-12-15 | R4 | 1624h | 1624h | LTE_CA_B2_B5_B13-Core | PCG-32 | Intel | xinrong.wang@intel.com | Rel-13 | RP-63 | Issam | CA | LTE_CA_B2_B5_B13-Core | RP-141084 |
| 214 | 66.7.2 | Perf. part: LTE Advanced 3 Band Carrier Aggregation (3DL/1UL) of Band 2, Band 5 and Band 13 | 203d? | 2014-03-06 A | 2014-12-15 A | 100% |  | 2014-03-06 | 2014-12-05 | 197d? |  | finish no earlier than 2014-12-15 | R4 | 1624h | 1624h | LTE_CA_B2_B5_B13-Perf | PCG-32 | Intel | xinrong.wang@intel.com | Rel-13 | RP-63 | Issam | CA | LTE_CA_B2_B5_B13-Perf | RP-141084 |
| 215 | 66.8 | **LTE Advanced 3 Band Carrier Aggregation (3DL/1UL) of Band 4, Band 5 and Band 13** | 206d? | 2014-03-06 A | 2014-12-15 A | 100% |  | 2014-03-06 | 2014-12-05 | 197d? |  |  | R4 | 4896h | 4896h | LTE_CA_B4_B5_B13 | PCG-32 | Intel | xinrong.wang@intel.com | Rel-13 | RP-63 | Issam | CA | LTE_CA_B4_B5_B13 |  |
| 216 | 66.8.1 | Core part: LTE Advanced 3 Band Carrier Aggregation (3DL/1UL) of Band 4, Band 5 and Band 13 | 203d? | 2014-03-06 A | 2014-12-15 A | 100% |  | 2014-03-06 | 2014-12-05 | 197d? |  | finish no earlier than 2014-12-15 | R4 | 1624h | 1624h | LTE_CA_B4_B5_B13-Core | PCG-32 | Intel | xinrong.wang@intel.com | Rel-13 | RP-63 | Issam | CA | LTE_CA_B4_B5_B13-Core | RP-141084 |
| 217 | 66.8.2 | Perf. part: LTE Advanced 3 Band Carrier Aggregation (3DL/1UL) of Band 4, Band 5 and Band 13 | 203d? | 2014-03-06 A | 2014-12-15 A | 100% |  | 2014-03-06 | 2014-12-05 | 197d? |  | finish no earlier than 2014-12-15 | R4 | 1624h | 1624h | LTE_CA_B4_B5_B13-Perf | PCG-32 | Intel | xinrong.wang@intel.com | Rel-13 | RP-63 | Issam | CA | LTE_CA_B4_B5_B13-Perf | RP-141084 |
| 218 | 66.9 | **LTE Advanced 3 Band Carrier Aggregation (3DL/1UL) of Band 1, Band 3 and Band 26** | 206d? | 2014-03-06 A | 2014-12-15 A | 100% |  | 2014-03-06 | 2014-12-05 | 197d? |  |  | R4 | 4896h | 4896h | LTE_CA_B1_B3_B26 | PCG-32 | China Telecom | Zhao Dong (zhaodong@ctbri.com.cn) | Rel-13 | RP-63 | Issam | CA | LTE_CA_B1_B3_B26 |  |
| 219 | 66.9.1 | Core part: LTE Advanced 3 Band Carrier Aggregation (3DL/1UL) of Band 1, Band 3 and Band 26 | 203d? | 2014-03-06 A | 2014-12-15 A | 100% |  | 2014-03-06 | 2014-12-05 | 197d? |  | finish no earlier than 2014-12-15 | R4 | 1624h | 1624h | LTE_CA_B1_B3_B26-Core | PCG-32 | China Telecom | Zhao Dong (zhaodong@ctbri.com.cn) | Rel-13 | RP-63 | Issam | CA | LTE_CA_B1_B3_B26-Core | RP-141084 |
| 220 | 66.9.2 | Perf. part: LTE Advanced 3 Band Carrier Aggregation (3DL/1UL) of Band 1, Band 3 and Band 26 | 203d? | 2014-03-06 A | 2014-12-15 A | 100% |  | 2014-03-06 | 2014-12-05 | 197d? |  | finish no earlier than 2014-12-15 | R4 | 1624h | 1624h | LTE_CA_B1_B3_B26-Perf | PCG-32 | China Telecom | Zhao Dong (zhaodong@ctbri.com.cn) | Rel-13 | RP-63 | Issam | CA | LTE_CA_B1_B3_B26-Perf | RP-141084 |
| 221 | 66.10 | **LTE Advanced 3 Band Carrier Aggregation (3DL/1UL) of Band 1, Band 18 and Band 28** | 206d? | 2014-03-06 A | 2014-12-15 A | 100% |  | 2014-03-06 | 2015-03-13 | 267d? |  |  | R4 | 4896h | 4896h | LTE_CA_B1_B18_B28 | PCG-32 | KDDI | Masaaki Obara (ms-obara@kddi.com) | Rel-13 | RP-63 | Issam | CA | LTE_CA_B1_B18_B28 |  |
| 222 | 66.10.1 | Core part: LTE Advanced 3 Band Carrier Aggregation (3DL/1UL) of Band 1, Band 18 and Band 28 | 203d? | 2014-03-06 A | 2014-12-15 A | 100% |  | 2014-03-06 | 2015-03-13 | 267d? |  | finish no earlier than 2014-12-15 | R4 | 1624h | 1624h | LTE_CA_B1_B18_B28-Core | PCG-32 | KDDI | Masaaki Obara (ms-obara@kddi.com) | Rel-13 | RP-63 | Issam | CA | LTE_CA_B1_B18_B28-Core | RP-141084 |
| 223 | 66.10.2 | Perf. part: LTE Advanced 3 Band Carrier Aggregation (3DL/1UL) of Band 1, Band 18 and Band 28 | 203d? | 2014-03-11 A | 2014-12-15 A | 100% |  | 2014-03-06 | 2015-03-13 | 267d? |  | finish no earlier than 2014-12-15 | R4 | 1624h | 1624h | LTE_CA_B1_B18_B28-Perf | PCG-32 | KDDI | Masaaki Obara (ms-obara@kddi.com) | Rel-13 | RP-63 | Issam | CA | LTE_CA_B1_B18_B28-Perf | RP-141084 |
| 224 | 66.11 | **LTE Advanced 3 Band Carrier Aggregation (3DL/1UL) for Band 2, Band 2 and Band 12** | 262d? | 2014-06-18 A | 2015-06-15 | 23% | 202.17d? | 2014-06-13 | 2015-03-13 | 196d? | 523d |  | R4 | 5760h | 1315.46h | LTE_CA_B2_B2_B12 | PCG-33 | U.S. Cellular | sebastian.thalanany@uscellular.com | Rel-13 | RP-64 |  | CA | LTE_CA_B2_B2_B12 |  |
| 225 | 66.11.1 | Core part: LTE Advanced 3 Band Carrier Aggregation (3DL/1UL) for Band 2, Band 2 and Band 12 | 196d? | 2014-06-18 A | 2015-03-15 | 40% | 117.6d? | 2014-06-13 | 2014-12-05 | 126d? | 589d | finish no earlier than 2015-03-15 | R4 | 1568h | 627.2h | LTE_CA_B2_B2_B12-Core | PCG-33 | U.S. Cellular | sebastian.thalanany@uscellular.com | Rel-13 | RP-64 |  | CA | LTE_CA_B2_B2_B12-Core | RP-141084 |
| 226 | 66.11.2 | Perf. Part: LTE Advanced 3 Band Carrier Aggregation (3DL/1UL) for Band 2, Band 2 and Band 12 | 262d? | 2014-06-18 A | 2015-06-15 | 10% | 235.8d? | 2014-06-13 | 2015-03-13 | 196d? | 523d | finish no earlier than 2015-06-15 | R4 | 2096h | 209.6h | LTE_CA_B2_B2_B12-Perf | PCG-33 | U.S. Cellular | sebastian.thalanany@uscellular.com | Rel-13 | RP-64 |  | CA | LTE_CA_B2_B2_B12-Perf | RP-141084 |
| 227 | 66.12 | **LTE Advanced 3 Band Carrier Aggregation (3DL/1UL) of Band 4, Band 7 and Band 12** | 132d? | 2014-06-18 A | 2014-12-15 A | 100% |  | 2014-06-13 | 2015-03-13 | 196d? |  |  | R4 | 3168h | 3168h | LTE_CA_B4_B7_B12 | PCG-33 | Rogers Wireless | pavlo.nebesny@rci.rogers.com | Rel-13 | RP-64 |  | CA | LTE_CA_B4_B7_B12 |  |
| 228 | 66.12.1 | Core part: LTE Advanced 3 Band Carrier Aggregation (3DL/1UL) of Band 4, Band 7 and Band 12 | 132d? | 2014-06-18 A | 2014-12-15 A | 100% |  | 2014-06-13 | 2015-03-13 | 196d? |  | finish no earlier than 2014-12-15 | R4 | 1056h | 1056h | LTE_CA_B4_B7_B12-Core | PCG-33 | Rogers Wireless | pavlo.nebesny@rci.rogers.com | Rel-13 | RP-64 |  | CA | LTE_CA_B4_B7_B12-Core | RP-141084 |
| 229 | 66.12.2 | Perf. Part: LTE Advanced 3 Band Carrier Aggregation (3DL/1UL) of Band 4, Band 7 and Band 12 | 132d? | 2014-06-18 A | 2014-12-15 A | 100% |  | 2014-06-13 | 2015-03-13 | 196d? |  | finish no earlier than 2014-12-15 | R4 | 1056h | 1056h | LTE_CA_B4_B7_B12-Perf | PCG-33 | Rogers Wireless | pavlo.nebesny@rci.rogers.com | Rel-13 | RP-64 |  | CA | LTE_CA_B4_B7_B12-Perf | RP-141084 |
| 230 | 66.13 | **LTE Advanced 3 Band Carrier Aggregation (3DL/1UL) of Band 4, Band 4 and Band 7** | 132d? | 2014-06-18 A | 2014-12-15 A | 100% |  | 2014-06-13 | 2015-03-13 | 196d? |  |  | R4 | 3168h | 3168h | LTE_CA_B4_B4_B7 | PCG-33 | Rogers Wireless | pavlo.nebesny@rci.rogers.com | Rel-13 | RP-64 |  | CA | LTE_CA_B4_B4_B7 |  |
| 231 | 66.13.1 | Core part: LTE Advanced 3 Band Carrier Aggregation (3DL/1UL) of Band 4, Band 4 and Band 7 | 132d? | 2014-06-18 A | 2014-12-15 A | 100% |  | 2014-06-13 | 2015-03-13 | 196d? |  | finish no earlier than 2014-12-15 | R4 | 1056h | 1056h | LTE_CA_B4_B4_B7-Core | PCG-33 | Rogers Wireless | pavlo.nebesny@rci.rogers.com | Rel-13 | RP-64 |  | CA | LTE_CA_B4_B4_B7-Core | RP-141084 |
| 232 | 66.13.2 | Perf. Part: LTE Advanced 3 Band Carrier Aggregation (3DL/1UL) of Band 4, Band 4 and Band 7 | 132d? | 2014-06-18 A | 2014-12-15 A | 100% |  | 2014-06-13 | 2015-03-13 | 196d? |  | finish no earlier than 2014-12-15 | R4 | 1056h | 1056h | LTE_CA_B4_B4_B7-Perf | PCG-33 | Rogers Wireless | pavlo.nebesny@rci.rogers.com | Rel-13 | RP-64 |  | CA | LTE_CA_B4_B4_B7-Perf | RP-141084 |
| 233 | 66.14 | **LTE Advanced 3 Band Carrier Aggregation (3DL/1UL) of Band 3, Band 3 and Band 8** | 264d? | 2014-06-16 A | 2015-06-15 | 30% | 184.8d? | 2014-06-13 | 2015-06-12 | 261d? | 523d |  | R4 | 6304h | 1891.17h | LTE_CA_B3_B3_B8 | PCG-33 | CHTTL | Po-Han Hsieh (pohanhsieh@cht.com.tw) | Rel-13 | RP-64 |  | CA | LTE_CA_B3_B3_B8 |  |
| 234 | 66.14.1 | Core part: LTE Advanced 3 Band Carrier Aggregation (3DL/1UL) of Band 3, Band 3 and Band 8 | 262d? | 2014-06-16 A | 2015-06-15 | 60% | 104.8d? | 2014-06-13 | 2015-06-12 | 261d? | 523d | finish no earlier than 2015-06-15 | R4 | 2096h | 1257.6h | LTE_CA_B3_B3_B8-Core | PCG-33 | CHTTL | Po-Han Hsieh (pohanhsieh@cht.com.tw) | Rel-13 | RP-64 |  | CA | LTE_CA_B3_B3_B8-Core | RP-141084 |
| 235 | 66.14.2 | Perf. Part: LTE Advanced 3 Band Carrier Aggregation (3DL/1UL) of Band 3, Band 3 and Band 8 | 262d? | 2014-06-18 | 2015-06-15 |  |  | 2014-06-13 | 2015-06-12 | 261d? | 523d | finish no earlier than 2015-06-15 | R4 | 2096h |  | LTE_CA_B3_B3_B8-Perf | PCG-33 | CHTTL | Po-Han Hsieh (pohanhsieh@cht.com.tw) | Rel-13 | RP-64 |  | CA | LTE_CA_B3_B3_B8-Perf | RP-141084 |

Notes:
- 212: Inter-band CA 3DL / Impacted TSs and TRs: LTE
- 213: CD:Thu 12/03/15->Mon 15/12/14; Compl:50%->100% / Impacted TSs and TRs: 36.101, 36.104, 36.133, generic TR 36.853 (3 Band CA with 1UL)
- 214: CD:Thu 12/03/15->Mon 15/12/14; Compl:10%->100% / Impacted TSs and TRs: 36.101, 36.133, 36.141, 36.307
- 215: Inter-band CA 3DL / Impacted TSs and TRs: LTE
- 216: CD:Thu 12/03/15->Mon 15/12/14; Compl:50%->100% / Impacted TSs and TRs: 36.101, 36.104, 36.133, generic TR 36.853 (3 Band CA with 1UL)
- 217: CD:Thu 12/03/15->Mon 15/12/14; Compl:10%->100% / Impacted TSs and TRs: 36.101, 36.133, 36.141, 36.307
- 218: Inter-band CA 3DL / Impacted TSs and TRs: LTE
- 219: CD:Thu 11/12/14->Mon 15/12/14; Compl:90%->100% / Impacted TSs and TRs: 36.101, 36.104, 36.133, generic TR 36.853 (3 Band CA with 1UL)
- 220: CD:Thu 11/12/14->Mon 15/12/14; Compl:90%->100% / Impacted TSs and TRs: 36.141, 36.307
- 221: Inter-band CA 3DL / Impacted TSs and TRs: LTE
- 222: CD:Fri 13/03/15->Mon 15/12/14; Compl:50%->100%; WID:RP-140955->RP-142043 / Impacted TSs and TRs: 36.101, 36.104, 36.133, generic TR 36.853 (3 Band CA with 1UL)
- 223: CD:Fri 13/03/15->Mon 15/12/14; Compl:0%->100%; WID:RP-140955->RP-142043 / Impacted TSs and TRs: 36.141, 36.307
- 224: Inter-band CA 3DL/1UL / Impacted TSs and TRs: LTE
- 225: CD:Thu 12/03/15->Sun 15/03/15; Compl:0%->40% / Impacted TSs and TRs: 36.101, 36.104, 36.133, 36.141, 36.307, generic new Rel-13 TR36.8xy [similar to Rel-12 TR 36.853 (3 Band CA with 1UL)]
- 226: CD:Thu 18/06/15->Mon 15/06/15; Compl:0%->10% / Impacted TSs and TRs: 36.101, 36.104, 36.133, 36.141, 36.307
- 227: Inter-band CA 3DL/1UL / Impacted TSs and TRs: LTE
- 228: CD:Thu 12/03/15->Mon 15/12/14; Compl:0%->100% / Impacted TSs and TRs: 36.101, 36.104, 36.133, 36.307, generic TR 36.851 (2 Band CA with 1UL), generic TR 36.853 (3 Band CA with 1UL)
- 229: CD:Thu 12/03/15->Mon 15/12/14; Compl:0%->100% / Impacted TSs and TRs: 36.133, 36.141
- 230: Inter-band CA 3DL/1UL / Impacted TSs and TRs: LTE
- 231: CD:Thu 12/03/15->Mon 15/12/14; Compl:0%->100% / Impacted TSs and TRs: 36.101, 36.104, 36.133, 36.307, generic TR 36.853 (3 Band CA with 1UL)
- 232: CD:Thu 12/03/15->Mon 15/12/14; Compl:0%->100% / Impacted TSs and TRs: 36.133, 36.141
- 233: Inter-band CA 3DL/1UL / Impacted TSs and TRs: LTE
- 234: CD:Thu 18/06/15->Mon 15/06/15; Compl:30%->60%; WID:RP-140955->RP-142043 / Impacted TSs and TRs: 36.101, 36.133, generic TR 36.853 (3 Band CA with 1UL)
- 235: CD:Thu 18/06/15->Mon 15/06/15; Compl:0%->0%; WID:RP-140955->RP-142043 / Impacted TSs and TRs: 36.307

| ID | WBS | Task | Duration | Start | Finish | Complete | Remaining | Baseline start | Baseline finish | Baseline duration | Total slack | Constraint | Resources | Work | Actual work | Acronym | PCG approved | WI rapporteur name | WI rapporteur e-mail | Release | TSG approved | Special Focus Doc | Acronym_3GU_Export | Status Report |
| --- | --- | --- | --- | --- | --- | --- | --- | --- | --- | --- | --- | --- | --- | --- | --- | --- | --- | --- | --- | --- | --- | --- | --- | --- |
| 236 | 66.15 | **LTE Advanced 3 Band Carrier Aggregation (3DL/1UL) of Band 39, Band 41 and Band 41** | 134d? | 2014-06-16 A | 2014-12-15 A | 100% |  | 2014-06-13 | 2014-12-05 | 126d? |  |  | R4 | 3184h | 3184h | LTE_CA_B39_B41_B41 | PCG-33 | China Mobile | PAN Qun (panqun@chinamobile.com) | Rel-13 | RP-64 | CA | LTE_CA_B39_B41_B41 |  |
| 237 | 66.15.1 | Core part: LTE Advanced 3 Band Carrier Aggregation (3DL/1UL) of Band 39, Band 41 and Band 41 | 132d? | 2014-06-16 A | 2014-12-15 A | 100% |  | 2014-06-13 | 2014-12-05 | 126d? |  | finish no earlier than 2014-12-15 | R4 | 1056h | 1056h | LTE_CA_B39_B41_B41-Core | PCG-33 | China Mobile | PAN Qun (panqun@chinamobile.com) | Rel-13 | RP-64 | CA | LTE_CA_B39_B41_B41-Core | RP-141084 |
| 238 | 66.15.2 | Perf. Part: LTE Advanced 3 Band Carrier Aggregation (3DL/1UL) of Band 39, Band 41 and Band 41 | 132d? | 2014-06-18 A | 2014-12-15 A | 100% |  | 2014-06-13 | 2014-12-05 | 126d? |  | finish no earlier than 2014-12-15 | R4 | 1056h | 1056h | LTE_CA_B39_B41_B41-Perf | PCG-33 | China Mobile | PAN Qun (panqun@chinamobile.com) | Rel-13 | RP-64 | CA | LTE_CA_B39_B41_B41-Perf | RP-141084 |
| 239 | 66.16 | **LTE Advanced 3 Band Carrier Aggregation (3DL/1UL) of Band 41, Band 42 and Band 42** | 198d? | 2014-06-16 A | 2015-03-15 | 25% | 148.5d? | 2014-06-13 | 2014-12-05 | 126d? | 589d |  | R4 | 4720h | 942.4h | LTE_CA_B41_B42_B42 | PCG-33 | Huawei | leo.liuye@huawei.com | Rel-13 | RP-64 | CA | LTE_CA_B41_B42_B42 |  |
| 240 | 66.16.1 | Core part: LTE Advanced 3 Band Carrier Aggregation (3DL/1UL) of Band 41, Band 42 and Band 42 | 196d? | 2014-06-16 A | 2015-03-15 | 50% | 98d? | 2014-06-13 | 2014-12-05 | 126d? | 589d | finish no earlier than 2015-03-15 | R4 | 1568h | 784h | LTE_CA_B41_B42_B42-Core | PCG-33 | Huawei | leo.liuye@huawei.com | Rel-13 | RP-64 | CA | LTE_CA_B41_B42_B42-Core | RP-141084 |
| 241 | 66.16.2 | Perf. Part: LTE Advanced 3 Band Carrier Aggregation (3DL/1UL) of Band 41, Band 42 and Band 42 | 196d? | 2014-06-18 | 2015-03-15 |  |  | 2014-06-13 | 2014-12-05 | 126d? | 589d | finish no earlier than 2015-03-15 | R4 | 1568h |  | LTE_CA_B41_B42_B42-Perf | PCG-33 | Huawei | leo.liuye@huawei.com | Rel-13 | RP-64 | CA | LTE_CA_B41_B42_B42-Perf | RP-141084 |
| 242 | 66.17 | **LTE Advanced 3 Band Carrier Aggregation (3DL/1UL) of Band 1, Band 41 and Band 41** | 132d? | 2014-06-18 A | 2014-12-15 A | 100% |  | 2014-06-13 | 2015-03-13 | 196d? |  |  | R4 | 3168h | 3168h | LTE_CA_B1_B41_B41 | PCG-33 | KDDI | Masaaki Obara (ms-obara@kddi.com) | Rel-13 | RP-64 | CA | LTE_CA_B1_B41_B41 |  |
| 243 | 66.17.1 | Core part: LTE Advanced 3 Band Carrier Aggregation (3DL/1UL) of Band 1, Band 41 and Band 41 | 132d? | 2014-06-18 A | 2014-12-15 A | 100% |  | 2014-06-13 | 2015-03-13 | 196d? |  | finish no earlier than 2014-12-15 | R4 | 1056h | 1056h | LTE_CA_B1_B41_B41-Core | PCG-33 | KDDI | Masaaki Obara (ms-obara@kddi.com) | Rel-13 | RP-64 | CA | LTE_CA_B1_B41_B41-Core | RP-141084 |
| 244 | 66.17.2 | Perf. Part: LTE Advanced 3 Band Carrier Aggregation (3DL/1UL) of Band 1, Band 41 and Band 41 | 132d? | 2014-06-18 A | 2014-12-15 A | 100% |  | 2014-06-13 | 2015-03-13 | 196d? |  | finish no earlier than 2014-12-15 | R4 | 1056h | 1056h | LTE_CA_B1_B41_B41-Perf | PCG-33 | KDDI | Masaaki Obara (ms-obara@kddi.com) | Rel-13 | RP-64 | CA | LTE_CA_B1_B41_B41-Perf | RP-141084 |
| 245 | 66.18 | **LTE Advanced 3 Band Carrier Aggregation (3DL/1UL) of Band 26, Band 41 and Band 41** | 132d? | 2014-06-18 A | 2014-12-15 A | 100% |  | 2014-06-13 | 2015-03-13 | 196d? |  |  | R4 | 3168h | 3168h | LTE_CA_B26_B41_B41 | PCG-33 | KDDI | Masaaki Obara (ms-obara@kddi.com) | Rel-13 | RP-64 | CA | LTE_CA_B26_B41_B41 |  |
| 246 | 66.18.1 | Core part: LTE Advanced 3 Band Carrier Aggregation (3DL/1UL) of Band 26, Band 41 and Band 41 | 132d? | 2014-06-18 A | 2014-12-15 A | 100% |  | 2014-06-13 | 2015-03-13 | 196d? |  | finish no earlier than 2014-12-15 | R4 | 1056h | 1056h | LTE_CA_B26_B41_B41-Core | PCG-33 | KDDI | Masaaki Obara (ms-obara@kddi.com) | Rel-13 | RP-64 | CA | LTE_CA_B26_B41_B41-Core | RP-141084 |
| 247 | 66.18.2 | Perf. Part: LTE Advanced 3 Band Carrier Aggregation (3DL/1UL) of Band 26, Band 41 and Band 41 | 132d? | 2014-06-18 A | 2014-12-15 A | 100% |  | 2014-06-13 | 2015-03-13 | 196d? |  | finish no earlier than 2014-12-15 | R4 | 1056h | 1056h | LTE_CA_B26_B41_B41-Perf | PCG-33 | KDDI | Masaaki Obara (ms-obara@kddi.com) | Rel-13 | RP-64 | CA | LTE_CA_B26_B41_B41-Perf | RP-141084 |
| 248 | 66.19 | **LTE Advanced inter-band Carrier Aggregation of Band 3 and Band 38** | 132d? | 2014-09-15 A | 2015-03-15 | 90% | 13.19d? | 2014-06-13 | 2015-03-13 | 196d? | 589d |  | R4 | 3168h | 2851.28h | LTE_CA_B3_B38 | PCG-33 | Nokia Networks | iwajlo.angelow@nsn.com | Rel-13 | RP-65 | CA | LTE_CA_B3_B38 |  |
| 249 | 66.19.1 | Core part: LTE Advanced inter-band Carrier Aggregation of Band 3 and Band 38 | 132d? | 2014-09-15 A | 2015-03-15 | 90% | 13.2d? | 2014-06-13 | 2015-03-13 | 196d? | 589d | finish no earlier than 2015-03-15 | R4 | 1056h | 950.4h | LTE_CA_B3_B38-Core | PCG-33 | Nokia Networks | iwajlo.angelow@nsn.com | Rel-13 | RP-65 | CA | LTE_CA_B3_B38-Core |  |
| 250 | 66.19.2 | Perf. Part: LTE Advanced inter-band Carrier Aggregation of Band 3 and Band 38 | 132d? | 2014-09-15 A | 2015-03-15 | 90% | 13.2d? | 2014-06-13 | 2015-03-13 | 196d? | 589d | finish no earlier than 2015-03-15 | R4 | 1056h | 950.4h | LTE_CA_B3_B38-Perf | PCG-33 | Nokia Networks | iwajlo.angelow@nsn.com | Rel-13 | RP-65 | CA | LTE_CA_B3_B38-Perf |  |
| 251 | 66.20 | **LTE Advanced inter-band Carrier Aggregation of Band 2 and Band 28** | 132d? | 2014-09-15 A | 2015-03-15 | 25% | 99d? | 2014-06-13 | 2015-03-13 | 196d? | 589d |  | R4 | 3168h | 792h | LTE_CA_B2_B28 | PCG-33 | Huawei | alf.ahlstrom@huawei.com | Rel-13 | RP-65 | CA | LTE_CA_B2_B28 |  |
| 252 | 66.20.1 | Core part: LTE Advanced inter-band Carrier Aggregation of Band 2 and Band 28 | 132d? | 2014-09-15 A | 2015-03-15 | 50% | 66d? | 2014-06-13 | 2015-03-13 | 196d? | 589d | finish no earlier than 2015-03-15 | R4 | 1056h | 528h | LTE_CA_B2_B28-Core | PCG-33 | Huawei | alf.ahlstrom@huawei.com | Rel-13 | RP-65 | CA | LTE_CA_B2_B28-Core |  |
| 253 | 66.20.2 | Perf. Part: LTE Advanced inter-band Carrier Aggregation of Band 2 and Band 28 | 132d? | 2014-09-15 | 2015-03-15 |  |  | 2014-06-13 | 2015-03-13 | 196d? | 589d | finish no earlier than 2015-03-15 | R4 | 1056h |  | LTE_CA_B2_B28-Perf | PCG-33 | Huawei | alf.ahlstrom@huawei.com | Rel-13 | RP-65 | CA | LTE_CA_B2_B28-Perf |  |
| 254 | 66.21 | **LTE Advanced inter-band Carrier Aggregation of Band 4 and Band 28** | 132d? | 2014-09-15 A | 2015-03-15 | 17% | 108.9d? | 2014-06-13 | 2015-03-13 | 196d? | 589d |  | R4 | 3168h | 554.37h | LTE_CA_B4_B28 | PCG-33 | Huawei | alf.ahlstrom@huawei.com | Rel-13 | RP-65 | CA | LTE_CA_B4_B28 |  |
| 255 | 66.21.1 | Core part: LTE Advanced inter-band Carrier Aggregation of Band 4 and Band 28 | 132d? | 2014-09-15 A | 2015-03-15 | 35% | 85.8d? | 2014-06-13 | 2015-03-13 | 196d? | 589d | finish no earlier than 2015-03-15 | R4 | 1056h | 369.6h | LTE_CA_B4_B28-Core | PCG-33 | Huawei | alf.ahlstrom@huawei.com | Rel-13 | RP-65 | CA | LTE_CA_B4_B28-Core |  |
| 256 | 66.21.2 | Perf. Part: LTE Advanced inter-band Carrier Aggregation of Band 4 and Band 28 | 132d? | 2014-09-15 | 2015-03-15 |  |  | 2014-06-13 | 2015-03-13 | 196d? | 589d | finish no earlier than 2015-03-15 | R4 | 1056h |  | LTE_CA_B4_B28-Perf | PCG-33 | Huawei | alf.ahlstrom@huawei.com | Rel-13 | RP-65 | CA | LTE_CA_B4_B28-Perf |  |
| 257 | 66.22 | **LTE Advanced inter-band Carrier Aggregation of Band 20 and Band 40** | 133d? | 2014-09-12 A | 2015-03-15 | 15% | 112.98d? | 2014-06-13 | 2015-03-13 | 196d? | 589d |  | R4 | 3184h | 479.4h | LTE_CA_B20_B40 | PCG-33 | Ericsson | imadur.rahman@ericsson.com | Rel-13 | RP-65 | CA | LTE_CA_B20_B40 |  |
| 258 | 66.22.1 | Core part: LTE Advanced inter-band Carrier Aggregation of Band 20 and Band 40 | 133d? | 2014-09-12 A | 2015-03-15 | 30% | 93.1d? | 2014-06-13 | 2015-03-13 | 196d? | 589d | finish no earlier than 2015-03-15 | R4 | 1064h | 319.2h | LTE_CA_B20_B40-Core | PCG-33 | Ericsson | imadur.rahman@ericsson.com | Rel-13 | RP-65 | CA | LTE_CA_B20_B40-Core |  |
| 259 | 66.22.2 | Perf. Part: LTE Advanced inter-band Carrier Aggregation of Band 20 and Band 40 | 132d? | 2014-09-15 | 2015-03-15 |  |  | 2014-06-13 | 2015-03-13 | 196d? | 589d | finish no earlier than 2015-03-15 | R4 | 1056h |  | LTE_CA_B20_B40-Perf | PCG-33 | Ericsson | imadur.rahman@ericsson.com | Rel-13 | RP-65 | CA | LTE_CA_B20_B40-Perf |  |

Notes:
- 236: Inter-band CA 3DL/1UL / Impacted TSs and TRs: LTE
- 237: CD:Thu 11/12/14->Mon 15/12/14; Compl:90%->100% / Impacted TSs and TRs: 36.101, 36.104, 36.133, generic TR 36.853 (3 Band CA with 1UL)
- 238: CD:Thu 11/12/14->Mon 15/12/14; Compl:0%->100% / Impacted TSs and TRs: 36.141, 36.307
- 239: Inter-band CA 3DL/1UL / Impacted TSs and TRs: LTE
- 240: CD:Thu 11/12/14->Sun 15/03/15; Compl:30%->50% / Impacted TSs and TRs: 36.101, 36.104, 36.133, generic TR 36.853 (3 Band CA with 1UL)
- 241: CD:Thu 11/12/14->Sun 15/03/15; Compl:0%->0% / Impacted TSs and TRs: 36.141, 36.307
- 242: Inter-band CA 3DL/1UL / Impacted TSs and TRs: LTE
- 243: CD:Fri 13/03/15->Mon 15/12/14; Compl:0%->100%; WID:RP-140955->RP-142043 / Impacted TSs and TRs: 36.101, 36.104, 36.133, generic TR 36.853 (3 Band CA with 1UL)
- 244: CD:Fri 13/03/15->Mon 15/12/14; Compl:0%->100%; WID:RP-140955->RP-142043 / Impacted TSs and TRs: 36.141, 36.307
- 245: Inter-band CA 3DL/1UL / Impacted TSs and TRs: LTE
- 246: CD:Thu 12/03/15->Mon 15/12/14; Compl:0%->100%; WID:RP-140955->RP-142043 / Impacted TSs and TRs: 36.101, 36.104, 36.133, generic TR 36.853 (3 Band CA with 1UL)
- 247: CD:Thu 12/03/15->Mon 15/12/14; Compl:0%->100%; WID:RP-140955->RP-142043 / Impacted TSs and TRs: 36.141, 36.307
- 248: Inter-band CA 2DL/1UL / Impacted TSs and TRs: LTE
- 249: CD:Thu 11/12/14->Sun 15/03/15; Compl:0%->90% / Impacted TSs and TRs: 36.101, 36.104, New TR 36.8xx
- 250: CD:Thu 11/12/14->Sun 15/03/15; Compl:0%->90% / Impacted TSs and TRs: 36.141, 36.307
- 251: Inter-band CA 2DL/1UL / Impacted TSs and TRs: LTE
- 252: CD:Fri 11/12/15->Sun 15/03/15; Compl:0%->50% / Impacted TSs and TRs: 36.101, 36.104, New TR 36.8xx
- 253: CD:Thu 12/03/15->Sun 15/03/15; Compl:0%->0% / Impacted TSs and TRs: 36.141, 36.307
- 254: Inter-band CA 2DL/1UL / Impacted TSs and TRs: LTE
- 255: CD:Fri 11/12/15->Sun 15/03/15; Compl:0%->35% / Impacted TSs and TRs: 36.101, 36.104, New TR 36.8xx
- 256: CD:Thu 12/03/15->Sun 15/03/15; Compl:0%->0% / Impacted TSs and TRs: 36.141, 36.307
- 257: Inter-band CA 2DL/1UL / Impacted TSs and TRs: LTE
- 258: CD:Wed 11/03/15->Sun 15/03/15; Compl:0%->30% / Impacted TSs and TRs: 36.101, 36.104, 36.133, New TR 36.8xx
- 259: CD:Thu 12/03/15->Sun 15/03/15; Compl:0%->0% / Impacted TSs and TRs: 36.141, 36.307

| ID | WBS | Task | Duration | Start | Finish | Complete | Remaining | Baseline start | Baseline finish | Baseline duration | Total slack | Constraint | Resources | Work | Actual work | Acronym | PCG approved | Impacted TSs and TRs | WI rapporteur name | WI rapporteur e-mail | Release | TSG approved | Special Focus Doc | Acronym_3GU_Export |
| --- | --- | --- | --- | --- | --- | --- | --- | --- | --- | --- | --- | --- | --- | --- | --- | --- | --- | --- | --- | --- | --- | --- | --- | --- |
| 260 | 66.23 | **LTE Advanced inter-band Carrier Aggregation of Band 1 and Band 40** | 198d? | 2014-09-15 A | 2015-06-15 | 70% | 59.4d? | 2014-06-13 | 2015-03-13 | 196d? | 523d |  | R4 | 4752h | 2908.17h | LTE_CA_B1_B40 | PCG-33 | LTE | KT | ilwhan.kim@kt.com | Rel-13 | RP-65 | CA | LTE_CA_B1_B40 |
| 261 | 66.23.1 | Core part: LTE Advanced inter-band Carrier Aggregation of Band 1 and Band 40 | 198d? | 2014-09-15 A | 2015-06-15 | 70% | 59.4d? | 2014-06-13 | 2015-03-13 | 196d? | 523d | finish no earlier than 2015-06-15 | R4 | 1584h | 1108.8h | LTE_CA_B1_B40-Core | PCG-33 | 36.101, 36.104, 36.133, New TR 36.8xx | KT | ilwhan.kim@kt.com | Rel-13 | RP-65 | CA | LTE_CA_B1_B40-Core |
| 262 | 66.23.2 | Perf. Part: LTE Advanced inter-band Carrier Aggregation of Band 1 and Band 40 | 198d? | 2014-09-15 A | 2015-06-15 | 70% | 59.4d? | 2014-06-13 | 2015-03-13 | 196d? | 523d | finish no earlier than 2015-06-15 | R4 | 1584h | 1108.8h | LTE_CA_B1_B40-Perf | PCG-33 | 36.141, 36.307 | KT | ilwhan.kim@kt.com | Rel-13 | RP-65 | CA | LTE_CA_B1_B40-Perf |
| 263 | 66.24 | **LTE Advanced inter-band Carrier Aggregation of Band 3 and Band 40** | 198d? | 2014-09-15 A | 2015-06-15 | 70% | 59.4d? | 2014-06-13 | 2015-03-13 | 196d? | 523d |  | R4 | 4752h | 3326.38h | LTE_CA_B3_B40 | PCG-33 | LTE | KT | Chungwoo HWANG (cwhwang@kt.com) | Rel-13 | RP-65 | CA | LTE_CA_B3_B40 |
| 264 | 66.24.1 | Core part: LTE Advanced inter-band Carrier Aggregation of Band 3 and Band 40 | 198d? | 2014-09-15 A | 2015-06-15 | 70% | 59.4d? | 2014-06-13 | 2015-03-13 | 196d? | 523d | finish no earlier than 2015-06-15 | R4 | 1584h | 1108.8h | LTE_CA_B3_B40-Core | PCG-33 | 36.101, 36.104, 36.133, New TR 36.8xx | KT | Chungwoo HWANG (cwhwang@kt.com) | Rel-13 | RP-65 | CA | LTE_CA_B3_B40-Core |
| 265 | 66.24.2 | Perf. Part: LTE Advanced inter-band Carrier Aggregation of Band 3 and Band 40 | 198d? | 2014-09-15 A | 2015-06-15 | 70% | 59.4d? | 2014-06-13 | 2015-03-13 | 196d? | 523d | finish no earlier than 2015-06-15 | R4 | 1584h | 1108.8h | LTE_CA_B3_B40-Perf | PCG-33 | 36.141, 36.307 | KT | Chungwoo HWANG (cwhwang@kt.com) | Rel-13 | RP-65 | CA | LTE_CA_B3_B40-Perf |
| 266 | 66.25 | **LTE Advanced inter-band Carrier Aggregation of Band 20 and Band 31** | 132d? | 2014-09-15 A | 2015-03-15 | 38% | 82.5d? | 2014-06-13 | 2015-03-13 | 196d? | 589d |  | R4 | 3168h | 1188h | LTE_CA_B20_B31 | PCG-33 | LTE | Huawei | Liu Liehai (liuliehai@huawei.com) | Rel-13 | RP-65 | CA | LTE_CA_B20_B31 |
| 267 | 66.25.1 | Core part: LTE Advanced inter-band Carrier Aggregation of Band 20 and Band 31 | 132d? | 2014-09-15 A | 2015-03-15 | 75% | 33d? | 2014-06-13 | 2015-03-13 | 196d? | 589d | finish no earlier than 2015-03-15 | R4 | 1056h | 792h | LTE_CA_B20_B31-Core | PCG-33 | 36.101, 36.104, New TR 36.8xx | Huawei | Liu Liehai (liuliehai@huawei.com) | Rel-13 | RP-65 | CA | LTE_CA_B20_B31-Core |
| 268 | 66.25.2 | Perf. Part: LTE Advanced inter-band Carrier Aggregation of Band 20 and Band 31 | 132d? | 2014-09-15 | 2015-03-15 |  |  | 2014-06-13 | 2015-03-13 | 196d? | 589d | finish no earlier than 2015-03-15 | R4 | 1056h |  | LTE_CA_B20_B31-Perf | PCG-33 | 36.141, 36.307 | Huawei | Liu Liehai (liuliehai@huawei.com) | Rel-13 | RP-65 | CA | LTE_CA_B20_B31-Perf |
| 269 | 66.26 | **LTE Advanced inter-band Carrier Aggregation of Band 3 and Band 31** | 132d? | 2014-09-15 A | 2015-03-15 | 25% | 99d? | 2014-06-13 | 2015-03-13 | 196d? | 589d |  | R4 | 3168h | 792h | LTE_CA_B3_B31 | PCG-33 | LTE | Huawei | Liu Liehai (liuliehai@huawei.com) | Rel-13 | RP-65 | CA | LTE_CA_B3_B31 |
| 270 | 66.26.1 | Core part: LTE Advanced inter-band Carrier Aggregation of Band 3 and Band 31 | 132d? | 2014-09-15 A | 2015-03-15 | 50% | 66d? | 2014-06-13 | 2015-03-13 | 196d? | 589d | finish no earlier than 2015-03-15 | R4 | 1056h | 528h | LTE_CA_B3_B31-Core | PCG-33 | 36.101, 36.104, New TR 36.8xx | Huawei | Liu Liehai (liuliehai@huawei.com) | Rel-13 | RP-65 | CA | LTE_CA_B3_B31-Core |
| 271 | 66.26.2 | Perf. Part: LTE Advanced inter-band Carrier Aggregation of Band 3 and Band 31 | 132d? | 2014-09-15 | 2015-03-15 |  |  | 2014-06-13 | 2015-03-13 | 196d? | 589d | finish no earlier than 2015-03-15 | R4 | 1056h |  | LTE_CA_B3_B31-Perf | PCG-33 | 36.141, 36.307 | Huawei | Liu Liehai (liuliehai@huawei.com) | Rel-13 | RP-65 | CA | LTE_CA_B3_B31-Perf |
| 272 | 66.27 | **LTE Advanced inter-band Carrier Aggregation of Band 5 and Band 40** | 199d? | 2014-09-12 | 2015-06-15 |  |  | 2014-06-13 | 2015-03-13 | 196d? | 523d |  | R4 | 4768h |  | LTE_CA_B5_B40 | PCG-33 | LTE | SK Telecom | haesung.park@sk.com | Rel-13 | RP-65 | CA | LTE_CA_B5_B40 |
| 273 | 66.27.1 | Core part: LTE Advanced inter-band Carrier Aggregation of Band 5 and Band 40 | 199d? | 2014-09-12 | 2015-06-15 |  |  | 2014-06-13 | 2015-03-13 | 196d? | 523d | finish no earlier than 2015-06-15 | R4 | 1592h |  | LTE_CA_B5_B40-Core | PCG-33 | 36.101, 36.104, New TR 36.8xx | SK Telecom | haesung.park@sk.com | Rel-13 | RP-65 | CA | LTE_CA_B5_B40-Core |
| 274 | 66.27.2 | Perf. Part: LTE Advanced inter-band Carrier Aggregation of Band 5 and Band 40 | 198d? | 2014-09-15 | 2015-06-15 |  |  | 2014-06-13 | 2015-03-13 | 196d? | 523d | finish no earlier than 2015-06-15 | R4 | 1584h |  | LTE_CA_B5_B40-Perf | PCG-33 | 36.141, 36.307 | SK Telecom | haesung.park@sk.com | Rel-13 | RP-65 | CA | LTE_CA_B5_B40-Perf |
| 275 | 66.28 | **LTE Advanced 3 Band Carrier Aggregation (3DL/1UL) of Band 25, Band 41 and Band 41** | 68d? | 2014-09-15 A | 2014-12-15 A | 100% |  | 2014-06-13 | 2015-03-13 | 196d? |  |  | R4 | 1632h | 1632h | LTE_CA_B25_B41_B41 | PCG-33 | LTE | Alcatel-Lucent | Ng, Man Hung (man-hung.ng@alcatel-lucent.com) | Rel-13 | RP-65 | CA | LTE_CA_B25_B41_B41 |
| 276 | 66.28.1 | Core part: LTE Advanced 3 Band Carrier Aggregation (3DL/1UL) of Band 25, Band 41 and Band 41 | 68d? | 2014-09-15 A | 2014-12-15 A | 100% |  | 2014-06-13 | 2015-03-13 | 196d? |  | finish no earlier than 2014-12-15 | R4 | 544h | 544h | LTE_CA_B25_B41_B41-Core | PCG-33 | 36.101, 36.104, 36.307, New TR 36.833-x-yz | Alcatel-Lucent | Ng, Man Hung (man-hung.ng@alcatel-lucent.com) | Rel-13 | RP-65 | CA | LTE_CA_B25_B41_B41-Core |
| 277 | 66.28.2 | Perf. Part: LTE Advanced 3 Band Carrier Aggregation (3DL/1UL) of Band 25, Band 41 and Band 41 | 68d? | 2014-09-15 A | 2014-12-15 A | 100% |  | 2014-06-13 | 2015-03-13 | 196d? |  | finish no earlier than 2014-12-15 | R4 | 544h | 544h | LTE_CA_B25_B41_B41-Perf | PCG-33 | 36.141 | Alcatel-Lucent | Ng, Man Hung (man-hung.ng@alcatel-lucent.com) | Rel-13 | RP-65 | CA | LTE_CA_B25_B41_B41-Perf |
| 278 | 66.29 | **LTE Advanced intra-band contiguous Carrier Aggregation in Band 42 for 3DL** | 198d? | 2014-09-15 A | 2015-06-15 | 35% | 128.7d? | 2014-06-13 | 2015-03-13 | 196d? | 523d |  | R4 | 4752h | 1663.16h | LTE_CA_C_B42_3DL | PCG-33 | LTE | CATT | Yuexia Song (songyuexia@catt.cn) | Rel-13 | RP-65 | CA | LTE_CA_C_B42_3DL |
| 279 | 66.29.1 | Core part: LTE Advanced intra-band contiguous Carrier Aggregation in Band 42 for 3DL | 198d? | 2014-09-15 A | 2015-06-15 | 70% | 59.4d? | 2014-06-13 | 2015-03-13 | 196d? | 523d | finish no earlier than 2015-06-15 | R4 | 1584h | 1108.8h | LTE_CA_C_B42_3DL-Core | PCG-33 | 36.101, 36.104, 36.133, New TR 36.833-5-42 | CATT | Yuexia Song (songyuexia@catt.cn) | Rel-13 | RP-65 | CA | LTE_CA_C_B42_3DL-Core |
| 280 | 66.29.2 | Perf. Part: LTE Advanced intra-band contiguous Carrier Aggregation in Band 42 for 3DL | 198d? | 2014-09-15 | 2015-06-15 |  |  | 2014-06-13 | 2015-03-13 | 196d? | 523d | finish no earlier than 2015-06-15 | R4 | 1584h |  | LTE_CA_C_B42_3DL-Perf | PCG-33 | 36.141, 36.307 | CATT | Yuexia Song (songyuexia@catt.cn) | Rel-13 | RP-65 | CA | LTE_CA_C_B42_3DL-Perf |
| 281 | 66.30 | **LTE Advanced 3 Band Carrier Aggregation (3DL/1UL) of Band 39, Band 39 and Band 41** | 68d? | 2014-09-15 A | 2014-12-15 A | 100% |  | 2014-06-13 | 2015-03-13 | 196d? |  |  | R4 | 1632h | 1632h | LTE_CA_B39_B39_B41 | PCG-33 | LTE | China Mobile | PAN, Qun (panqun@chinamobile.com) | Rel-13 | RP-65 | CA | LTE_CA_B39_B39_B41 |
| 282 | 66.30.1 | Core part: LTE Advanced 3 Band Carrier Aggregation (3DL/1UL) of Band 39, Band 39 and Band 41 | 68d? | 2014-09-15 A | 2014-12-15 A | 100% |  | 2014-06-13 | 2015-03-13 | 196d? |  | finish no earlier than 2014-12-15 | R4 | 544h | 544h | LTE_CA_B39_B39_B41-Core | PCG-33 | 36.101, 36.104, 36.133, New TR 36.8xx | China Mobile | PAN, Qun (panqun@chinamobile.com) | Rel-13 | RP-65 | CA | LTE_CA_B39_B39_B41-Core |
| 283 | 66.30.2 | Perf. Part: LTE Advanced 3 Band Carrier Aggregation (3DL/1UL) of Band 39, Band 39 and Band 41 | 68d? | 2014-09-15 A | 2014-12-15 A | 100% |  | 2014-06-13 | 2015-03-13 | 196d? |  | finish no earlier than 2014-12-15 | R4 | 544h | 544h | LTE_CA_B39_B39_B41-Perf | PCG-33 | 36.141, 36.307 | China Mobile | PAN, Qun (panqun@chinamobile.com) | Rel-13 | RP-65 | CA | LTE_CA_B39_B39_B41-Perf |

Notes:
- 260: Inter-band CA 2DL/1UL
- 261: CD:Fri 12/06/15->Mon 15/06/15; Compl:0%->70%
- 262: CD:Fri 11/12/15->Mon 15/06/15; Compl:0%->70%
- 263: Inter-band CA 2DL/1UL
- 264: CD:Fri 11/12/15->Mon 15/06/15; Compl:0%->70%
- 265: CD:Fri 12/06/15->Mon 15/06/15; Compl:0%->70%
- 266: Inter-band CA 2DL/1UL
- 267: CD:Fri 11/12/15->Sun 15/03/15; Compl:0%->75%; WID:RP-140955->RP-142043
- 268: CD:Thu 12/03/15->Sun 15/03/15; Compl:0%->0%; WID:RP-140955->RP-142043
- 269: Inter-band CA 2DL/1UL
- 270: CD:Fri 11/12/15->Sun 15/03/15; Compl:0%->50%
- 271: CD:Thu 12/03/15->Sun 15/03/15; Compl:0%->0%
- 272: Inter-band CA 2DL/1UL
- 273: CD:Wed 11/03/15->Mon 15/06/15; Compl:0%->0%; WID:RP-140955->RP-142043
- 274: CD:Thu 12/03/15->Mon 15/06/15; Compl:0%->0%; WID:RP-140955->RP-142043
- 275: Inter-band CA 3DL/1UL
- 276: CD:Fri 11/09/15->Mon 15/12/14; Compl:0%->100%; WID:RP-140955->RP-142043
- 277: CD:Fri 11/12/15->Mon 15/12/14; Compl:0%->100%; WID:RP-140955->RP-142043
- 278: Intra-band contig. CA 3DL
- 279: CD:Fri 12/06/15->Mon 15/06/15; Compl:0%->70%
- 280: CD:Fri 12/06/15->Mon 15/06/15; Compl:0%->0%
- 281: Inter-band CA 3DL/1UL
- 282: CD:Fri 11/12/15->Mon 15/12/14; Compl:0%->100%
- 283: CD:Fri 11/12/15->Mon 15/12/14; Compl:0%->100%

| ID | WBS | Task | Duration | Start | Finish | Complete | Remaining | Baseline start | Baseline finish | Baseline duration | Total slack | Constraint | Resources | Work | Actual work | Acronym | PCG approved | WI rapporteur name | WI rapporteur e-mail | Release | TSG approved | Special Focus Doc | Acronym_3GU_Export | MCC resp | Status Report |
| --- | --- | --- | --- | --- | --- | --- | --- | --- | --- | --- | --- | --- | --- | --- | --- | --- | --- | --- | --- | --- | --- | --- | --- | --- | --- |
| 284 | 66.31 | **LTE Advanced 3 Band Carrier Aggregation (3DL/1UL) of Band 8, Band 41 and Band 41** | 133d? | 2014-09-12 A | 2015-03-15 | 40% | 80d? | 2014-06-13 | 2015-03-13 | 196d? | 589d |  | R4 | 3184h | 1268.76h | LTE_CA_B8_B41_B41 | PCG-33 | China Mobile | PAN, Qun (panqun@chinamobile.com) | Rel-13 | RP-65 | CA | LTE_CA_B8_B41_B41 |  |  |
| 285 | 66.31.1 | Core part: LTE Advanced 3 Band Carrier Aggregation (3DL/1UL) of Band 8, Band 41 and Band 41 | 132d? | 2014-09-15 A | 2015-03-15 | 80% | 26.4d? | 2014-06-13 | 2015-03-13 | 196d? | 589d | finish no earlier than 2015-03-15 | R4 | 1056h | 844.8h | LTE_CA_B8_B41_B41-Core | PCG-33 | China Mobile | PAN, Qun (panqun@chinamobile.com) | Rel-13 | RP-65 | CA | LTE_CA_B8_B41_B41-Core |  |  |
| 286 | 66.31.2 | Perf. Part: LTE Advanced 3 Band Carrier Aggregation (3DL/1UL) of Band 8, Band 41 and Band 41 | 133d? | 2014-09-12 | 2015-03-15 |  |  | 2014-06-13 | 2015-03-13 | 196d? | 589d | finish no earlier than 2015-03-15 | R4 | 1064h |  | LTE_CA_B8_B41_B41-Perf | PCG-33 | China Mobile | PAN, Qun (panqun@chinamobile.com) | Rel-13 | RP-65 | CA | LTE_CA_B8_B41_B41-Perf |  |  |
| 287 | 66.32 | **LTE Advanced 3 Band Carrier Aggregation (3DL/1UL) of Band 2, Band 2 and Band 29** | 68d? | 2014-09-15 A | 2014-12-15 A | 100% |  | 2014-06-13 | 2015-03-13 | 196d? |  |  | R4 | 1632h | 1632h | LTE_CA_B2_B2_B29 | PCG-33 | AT&T | marc.grant@att.com | Rel-13 | RP-65 | CA | LTE_CA_B2_B2_B29 |  |  |
| 288 | 66.32.1 | Core part: LTE Advanced 3 Band Carrier Aggregation (3DL/1UL) of Band 2, Band 2 and Band 29 | 68d? | 2014-09-15 A | 2014-12-15 A | 100% |  | 2014-06-13 | 2015-03-13 | 196d? |  | finish no earlier than 2014-12-15 | R4 | 544h | 544h | LTE_CA_B2_B2_B29-Core | PCG-33 | AT&T | marc.grant@att.com | Rel-13 | RP-65 | CA | LTE_CA_B2_B2_B29-Core |  |  |
| 289 | 66.32.2 | Perf. Part: LTE Advanced 3 Band Carrier Aggregation (3DL/1UL) of Band 2, Band 2 and Band 29 | 68d? | 2014-09-15 A | 2014-12-15 A | 100% |  | 2014-06-13 | 2015-03-13 | 196d? |  | finish no earlier than 2014-12-15 | R4 | 544h | 544h | LTE_CA_B2_B2_B29-Perf | PCG-33 | AT&T | marc.grant@att.com | Rel-13 | RP-65 | CA | LTE_CA_B2_B2_B29-Perf |  |  |
| 290 | 66.33 | **LTE Advanced 3 Band Carrier Aggregation (3DL/1UL) of Band 38, Band 40 and Band 40** | 198d? | 2014-09-15 | 2015-06-15 |  |  | 2014-06-13 | 2015-03-13 | 196d? | 523d |  | R4 | 4752h |  | LTE_CA_B38_B40_B40 | PCG-33 | Samsung | xutao.zhou@samsung.com | Rel-13 | RP-65 | CA | LTE_CA_B38_B40_B40 |  |  |
| 291 | 66.33.1 | Core part: LTE Advanced 3 Band Carrier Aggregation (3DL/1UL) of Band 38, Band 40 and Band 40 | 198d? | 2014-09-15 | 2015-06-15 |  |  | 2014-06-13 | 2015-03-13 | 196d? | 523d | finish no earlier than 2015-06-15 | R4 | 1584h |  | LTE_CA_B38_B40_B40-Core | PCG-33 | Samsung | xutao.zhou@samsung.com | Rel-13 | RP-65 | CA | LTE_CA_B38_B40_B40-Core |  |  |
| 292 | 66.33.2 | Perf. Part: LTE Advanced 3 Band Carrier Aggregation (3DL/1UL) of Band 38, Band 40 and Band 40 | 198d? | 2014-09-15 | 2015-06-15 |  |  | 2014-06-13 | 2015-03-13 | 196d? | 523d | finish no earlier than 2015-06-15 | R4 | 1584h |  | LTE_CA_B38_B40_B40-Perf | PCG-33 | Samsung | xutao.zhou@samsung.com | Rel-13 | RP-65 | CA | LTE_CA_B38_B40_B40-Perf |  |  |
| 293 | 66.34 | **LTE Advanced 3 Band Carrier Aggregation (3DL/1UL) of Band 2, Band 4 and Band 29** | 68d? | 2014-09-15 A | 2014-12-15 A | 100% |  | 2014-06-13 | 2015-03-13 | 196d? |  |  | R4 | 1632h | 1632h | LTE_CA_B2_B4_B29 | PCG-33 | Huawei | SHAN Huiping (shanhuiping@huawei.com) | Rel-13 | RP-65 | CA | LTE_CA_B2_B4_B29 |  |  |
| 294 | 66.34.1 | Core part: LTE Advanced 3 Band Carrier Aggregation (3DL/1UL) of Band 2, Band 4 and Band 29 | 68d? | 2014-09-15 A | 2014-12-15 A | 100% |  | 2014-06-13 | 2015-03-13 | 196d? |  | finish no earlier than 2014-12-15 | R4 | 544h | 544h | LTE_CA_B2_B4_B29-Core | PCG-33 | Huawei | SHAN Huiping (shanhuiping@huawei.com) | Rel-13 | RP-65 | CA | LTE_CA_B2_B4_B29-Core |  |  |
| 295 | 66.34.2 | Perf. Part: LTE Advanced 3 Band Carrier Aggregation (3DL/1UL) of Band 2, Band 4 and Band 29 | 68d? | 2014-09-15 A | 2014-12-15 A | 100% |  | 2014-06-13 | 2015-03-13 | 196d? |  | finish no earlier than 2014-12-15 | R4 | 544h | 544h | LTE_CA_B2_B4_B29-Perf | PCG-33 | Huawei | SHAN Huiping (shanhuiping@huawei.com) | Rel-13 | RP-65 | CA | LTE_CA_B2_B4_B29-Perf |  |  |
| 296 | 66.35 | **LTE Advanced 3 Band Carrier Aggregation (3DL/1UL) of Band 2, Band 5 and Band 29** | 198d? | 2014-09-15 A | 2015-06-15 | 25% | 148.5d? | 2014-06-13 | 2015-03-13 | 196d? | 523d |  | R4 | 4752h | 1188h | LTE_CA_B2_B5_B29 | PCG-33 | Huawei | SHAN Huiping (shanhuiping@huawei.com) | Rel-13 | RP-65 | CA | LTE_CA_B2_B5_B29 |  |  |
| 297 | 66.35.1 | Core part: LTE Advanced 3 Band Carrier Aggregation (3DL/1UL) of Band 2, Band 5 and Band 29 | 198d? | 2014-09-15 A | 2015-06-15 | 50% | 99d? | 2014-06-13 | 2015-03-13 | 196d? | 523d | finish no earlier than 2015-06-15 | R4 | 1584h | 792h | LTE_CA_B2_B5_B29-Core | PCG-33 | Huawei | SHAN Huiping (shanhuiping@huawei.com) | Rel-13 | RP-65 | CA | LTE_CA_B2_B5_B29-Core |  |  |
| 298 | 66.35.2 | Perf. Part: LTE Advanced 3 Band Carrier Aggregation (3DL/1UL) of Band 2, Band 5 and Band 29 | 198d? | 2014-09-15 | 2015-06-15 |  |  | 2014-06-13 | 2015-03-13 | 196d? | 523d | finish no earlier than 2015-06-15 | R4 | 1584h |  | LTE_CA_B2_B5_B29-Perf | PCG-33 | Huawei | SHAN Huiping (shanhuiping@huawei.com) | Rel-13 | RP-65 | CA | LTE_CA_B2_B5_B29-Perf |  |  |
| 299 | 67 | (Small) Technical Enhancements and Improvements for Rel-13 | 593d? | 2013-09-18 | 2015-12-21 |  |  | 2013-09-18 | 2015-12-24 | 593d? | 388d | start no earlier than 2013-09-18 | SP; CP; RP; GP | 18976h |  | TEI13 | PCG-31 |  |  | Rel-13 | SP-61 |  | TEI13 |  |  |
| 300 | 68 | Release 13 Studies | 602d? | 2013-09-12 | 2015-12-25 |  |  | 2014-07-31 | 2015-12-25 | 366.5d? | 384d | start no earlier than 2013-09-12 | SP; RP | 9632h |  |  |  |  |  | Rel-13 |  |  |  |  |  |
| 301 | 69 | Study on Application specific Congestion control for Data Communication | 532d? | 2012-09-13 A | 2014-09-17 A | 100% |  | 2012-09-13 | 2014-09-17 | 532d? |  | finish no earlier than 2014-09-17 | S1 | 4250.29h | 4250.29h | FS_ACDC | PCG-29 | NTT DOCOMO | Atsushi Minokuchi (minokuchi@nttdocomo.co.jp) | Rel-13 | SP-57 |  | FS_ACDC | Alain | S1-143305 |
| 302 | 70 | Study on Isolated E-UTRAN Operation for Public Safety | 262d? | 2013-06-21 A | 2014-06-18 A | 100% |  | 2013-06-21 | 2014-06-18 | 262d? |  | finish no earlier than 2014-06-18 | S1 | 2088h | 2088h | FS_IOPS | PCG-31 | General Dynamics | paul.piggin@gd-broadband.com | Rel-13 | SP-60 | Public Safety (A-A) | FS_IOPS | Alain |  |
| 303 | 71 | Study on enhancements for Infrastructure based data Communication Between Devices | 266d? | 2013-09-12 A | 2014-09-17 A | 100% |  | 2013-09-12 | 2014-09-17 | 266d? |  | finish no earlier than 2014-09-17 | S1 | 2128h | 2128h | FS_eICBD | PCG-31 | KPN | toon.norp@tno.nl | Rel-13 | SP-61 | MTC, M2M | FS_eICBD | Alain | S1-143309 |
| 304 | 72 | Study on Co-ordinated packet data network gateway (P-GW) change for SIPTO | 202d? | 2013-09-12 A | 2014-06-18 A | 100% |  | 2013-09-12 | 2014-06-18 | 202d? |  | finish no earlier than 2014-06-18 | S1 | 1608h | 1608h | FS_CSIPTO | PCG-31 | Intel | Eric.siow@intel.com | Rel-13 | SP-61 |  | FS_CSIPTO | Alain |  |
| 305 | 73 | Study on Flexible Mobile Service Steering | 202d? | 2013-12-11 A | 2014-09-17 A | 100% |  | 2013-12-11 | 2014-09-17 | 202d? |  | finish no earlier than 2014-09-17 | S1 | 1608h | 1608h | FS_FMSS | PCG-32 | China Mobile | Lu Lu (lulu@chinamobile.com) | Rel-13 | SP-62 |  | FS_FMSS | Alain | S1-143310 |
| 306 | 74 | Study on Enhanced Calling Information Presentation | 201d? | 2013-12-11 A | 2014-09-17 A | 100% |  | 2013-12-11 | 2014-09-17 | 201d? |  | finish no earlier than 2014-09-17 | S1 | 1608h | 1608h | FS_ECIP | PCG-32 | China Mobile | LI Xiaofan (lixiaofan@chinamobile.com | Rel-13 | SP-62 |  | FS_ECIP | Alain | S1-143311 |
| 307 | 75 | Study on RAN Sharing Enhancements on GERAN and UTRAN | 140d? | 2014-03-07 A | 2014-09-17 A | 100% |  | 2014-03-07 | 2014-09-17 | 139d? |  | finish no earlier than 2014-09-17 | S1 | 1120h | 1120h | FS_GUSH | PCG-32 | Telefónica | chris.friel@telefonica.com | Rel-13 | SP-63 |  | FS_GUSH | Alain |  |

Notes:
- 284: Inter-band CA 3DL/1UL / Impacted TSs and TRs: LTE
- 285: CD:Fri 11/12/15->Sun 15/03/15; Compl:0%->80%; WID:RP-140955->RP-142043 / Impacted TSs and TRs: 36.101, 36.104, 36.133, New TR 36.8xx
- 286: CD:Wed 11/03/15->Sun 15/03/15; Compl:0%->0%; WID:RP-140955->RP-142043 / Impacted TSs and TRs: 36.141, 36.307
- 287: Inter-band CA 3DL/1UL / Impacted TSs and TRs: LTE
- 288: CD:Thu 11/12/14->Mon 15/12/14; Compl:0%->100% / Impacted TSs and TRs: 36.101, 36.104, 36.133, New TR 36.8xx
- 289: CD:Thu 11/12/14->Mon 15/12/14; Compl:0%->100% / Impacted TSs and TRs: 36.141, 36.307
- 290: Inter-band CA 3DL/1UL / Impacted TSs and TRs: LTE
- 291: CD:Fri 12/06/15->Mon 15/06/15; Compl:0%->0% / Impacted TSs and TRs: 36.101, 36.104, 36.133, New TR 36.8xx
- 292: CD:Fri 12/06/15->Mon 15/06/15; Compl:0%->0% / Impacted TSs and TRs: 36.141, 36.307
- 293: Inter-band CA 3DL/1UL / Impacted TSs and TRs: LTE
- 294: CD:Fri 11/12/15->Mon 15/12/14; Compl:0%->100% / Impacted TSs and TRs: 36.101, 36.104, 36.133, New TR 36.8xx
- 295: CD:Thu 11/12/14->Mon 15/12/14; Compl:0%->100% / Impacted TSs and TRs: 36.141, 36.307
- 296: Inter-band CA 3DL/1UL / Impacted TSs and TRs: LTE
- 297: CD:Fri 11/12/15->Mon 15/06/15; Compl:0%->50% / Impacted TSs and TRs: 36.101, 36.104, 36.133, New TR 36.8xy (inter-band CA 2DL/1UL (introduce CA_B5-B29), New TR 36.8xz (inter-band CA 3DL/1UL)
- 298: CD:Fri 12/06/15->Mon 15/06/15; Compl:0%->0% / Impacted TSs and TRs: 36.141, 36.307
- 299: -
- 300: -
- 301: SP#65 completed. SP#64 TR 22.806v200 for Approval. ACDC is applicable to UTRAN and E-UTRAN. Possible overlap with RAN2 TR 36.848 Study on smart congestion mitigation in E-UTRAN (prioritising MMTEL voice over other traffic during congestion) / Impacted TSs and TRs: 22.806
- 302: SP#64 completed. TR 22.897v200 for Approval. Linked to Rel-12 TR 22.803 (FS_ProSe) and Features: ProSe, GCSE_LTE / Impacted TSs and TRs: 22.897
- 303: SP#65 completed. TR 22.807v200 for Approval / Impacted TSs and TRs: 22.807
- 304: SP#64 completed. TR 22.828v200 for Approval. Linked to Features: Rel-10 LIPA_SIPTO & Rel-12 LIMONET / Impacted TSs and TRs: 22.828
- 305: SP#65 completed. TR 22.808v200 for Approval. Study supporting traffic classification and service chain selection capabilities per operators policy in order to realize efficient and flexible mobile service steering in the Gi-LAN network / Impacted TSs and TRs: 22.808
- 306: SP#65 completed. TR 22.810v200 for Approval. Linked to Multimedia Telephony Service for IMS (UID_7038), Customized Alerting Tone (CAT) UID_370028, Customized Ringing Signal (CRS) UID_380067 / Impacted TSs and TRs: 22.810
- 307: SP#65 completed. Update on GERAN and UTRAN of Rel-12 TR 22.852 Study on RAN Sharing Enhancements (FS_RSE) / Impacted TSs and TRs: 22.852 updates

| ID | WBS | Task | Duration | Start | Finish | Complete | Remaining | Baseline start | Baseline finish | Baseline duration | Total slack | Constraint | Resources | Work | Actual work | Acronym | PCG approved | Impacted TSs and TRs | WI rapporteur name | Release | TSG approved | MCC resp | Acronym_3GU_Export | PCG stopped | TSG stopped | Special Focus Doc | Status Report |
| --- | --- | --- | --- | --- | --- | --- | --- | --- | --- | --- | --- | --- | --- | --- | --- | --- | --- | --- | --- | --- | --- | --- | --- | --- | --- | --- | --- |
| 308 | 76 | **Study on Usage Monitoring Enhancements for Service, Application and Subscriber Group** | 934d? | 2011-06-08 A | 2014-12-12 A | 100% |  | 2011-06-08 | 2014-12-10 | 929d? |  |  | S2 | 13923.4h | 13923.4h | FS_UMONC_sas | PCG-27 | 23.858 | China Telecom | Rel-13 | SP-52 | Maurice | FS_UMONC_sas |  |  |  |  |
| 309 | 76.1 | Deleted - SA1 part of Study on Usage Monitoring Control PCC Enhancement | 275d? | 2011-06-08 A | 2012-06-20 A | 100% |  | 2011-06-08 | 2012-06-20 | 275d? |  | finish no earlier than 2012-06-20 | S1 | 2200h | 2200h | FS_UMONC | PCG-27 | 23.858 | ZTE |  | SP-52 | Maurice | FS_UMONC | PCG-31 | SP-58 |  |  |
| 310 | 76.2 | SA2 part of Study on Usage Monitoring Control PCC Enhancement | 397.26d? | 2013-06-02 A | 2014-12-12 A | 100% |  | 2013-06-02 | 2014-12-10 | 403d? |  | finish no earlier than 2014-12-12 | S2 | 3163.41h | 3163.41h | FS_UMONC_sas | PCG-27 | 23.858 | China Telecom | Rel-13 | SP-52 | Maurice |  |  |  |  |  |
| 311 | 76.3 | Deleted - SA5 part of Study on Usage Monitoring Control enhancement | 141d? | 2012-03-02 A | 2012-09-12 A | 100% |  | 2012-03-02 | 2012-09-12 | 141d? |  | finish no earlier than 2012-09-12 | S5 | 1088h | 1088h | FS_UMONC | PCG-27 | 32.858 | Huawei |  | SP-52 | Mirko |  | PCG-29 | SP-57 |  |  |
| 312 | 77 | Study on Optimizations to support High Latency communications | 196d? | 2014-09-19 A | 2015-06-17 | 30% | 137.2d? |  |  |  | 521d | finish no earlier than 2015-06-17 | S2 | 1568h | 470.4h | FS_HLcom | PCG-33 | New TR 23.7xy | Ericsson | Rel-13 | SP-65 |  | FS_HLcom |  |  |  |  |
| 313 | 78 | Study on Security aspects of Integration of Single Sign-On (SSO) frameworks with 3GPP networks | 1180d? | 2010-12-16 A | 2015-06-12 | 65% | 413d? | 2010-12-16 | 2014-09-17 | 988d? | 524d | finish no earlier than 2015-06-12 | S3 | 9440h | 6136h | FS_SSO_Int_Sec | PCG-26 | 33.895 | Ericsson | Rel-13 | SP-50 | Mirko | FS_SSO_Int_Sec |  |  |  |  |
| 314 | 79 | Study on Security for Proximity-based Services | 596d? | 2013-03-07 A | 2015-06-17 | 95% | 29.8d? | 2013-03-07 | 2014-09-17 | 401d? | 521d | finish no earlier than 2015-06-17 | S3 | 4768h | 4529.6h | FS_ProSe_Sec | PCG-30 | 33.833 | Qualcomm | Rel-13 | SP-59 | Mirko | FS_ProSe_Sec |  |  | Public Safety (A-A) |  |
| 315 | 80 | Study on Subscriber Privacy Impact in 3GPP | 591d? | 2013-09-12 A | 2015-12-16 | 85% | 88.65d? | 2013-09-12 | 2014-09-17 | 266d? | 391d | finish no earlier than 2015-12-16 | S3 | 4728h | 4018.8h | FS_SPI | PCG-31 | 33.849 | China Unicom | Rel-13 | SP-61 | Mirko | FS_SPI |  |  |  |  |
| 316 | 81 | Study on Lawful Interception Service Evolution | 386d? | 2014-06-23 | 2015-12-09 |  |  | 2014-06-18 | 2015-12-09 | 386d? | 396d | finish no earlier than 2015-12-09 | S3 | 3088h |  | FS_LISE | PCG-33 | 33.826 | Alcatel-Lucent | Rel-13 | SP-64 |  | FS_LISE |  |  |  |  |
| 317 | 82 | Study on IMS Enhanced Spoofed Call Prevention and Detection | 261d? | 2014-09-19 | 2015-09-16 |  |  |  |  |  | 456d | finish no earlier than 2015-09-16 | S3 | 2088h |  | FS_ESCAPADES | PCG-33 | 33.832 | Sprint | Rel-13 | SP-64 |  | FS_ESCAPADES |  |  |  |  |
| 318 | 83 | Study on Enhanced Acoustic Test Specifications | 528d? | 2013-03-06 A | 2015-03-13 | 31% | 365.95d? | 2013-03-06 | 2014-09-17 | 401d? | 589d | finish no earlier than 2015-03-13 | S4 | 4224h | 1296.4h | FS_SEATS | PCG-30 | 26.931 | Audience, Intel | Rel-13 | SP-59 | Paolo | FS_SEATS |  |  |  |  |
| 319 | 84 | Study on Compliance of 3GPP SA5 specifications to the NGMN NGCOR | 854d? | 2012-06-20 A | 2015-09-16 | 45% | 469.7d? | 2012-06-20 | 2015-09-16 | 854d? | 456d | finish no earlier than 2015-09-16 | S5 | 6832h | 3074.4h | FS_OAM_NGMN_NGCOR | PCG-29 | 32.837 | Huawei | Rel-13 | SP-56 | Mirko | FS_OAM_NGMN_NGCOR |  |  |  |  |
| 320 | 85 | Study on Enhancements of OAM aspects of Distributed Mobility Load Balancing (MLB) SON function | 458d? | 2013-09-12 A | 2015-06-12 | 25% | 343.5d? | 2013-09-12 | 2014-12-10 | 326d? | 524d | finish no earlier than 2015-06-12 | S5 | 3664h | 916h | FS_D_MLB_SON_OAM | PCG-31 | 32.860 | Cisco | Rel-13 | SP-61 | Mirko | FS_D_MLB_SON_OAM |  |  | SON |  |
| 321 | 86 | Study on Application and Partitioning of Itf-N | 458d? | 2013-12-11 A | 2015-09-11 | 30% | 320.6d? | 2013-12-11 | 2014-12-10 | 261d? | 459d | finish no earlier than 2015-09-11 | S5 | 3664h | 1099.2h | FS_OAM_AP_Itf-N | PCG-32 | 32.861 | China Mobile | Rel-13 | SP-62 | Mirko | FS_OAM_AP_Itf-N |  |  |  |  |
| 322 | 87 | Study on Charging aspects on Roaming End-to-end scenarios with VoLTE IMS and interconnecting networks | 393d? | 2013-12-11 A | 2015-06-12 | 55% | 176.85d? | 2013-12-11 | 2014-12-10 | 261d? | 524d | finish no earlier than 2015-06-12 | S5 | 3144h | 1729.2h | FS_REVOLTE_IMS_CH | PCG-32 | 32.849 | Deutsche Telekom | Rel-13 | SP-62 | Mirko | FS_REVOLTE_IMS_CH |  |  |  |  |
| 323 | 88 | Study on Network Management of Virtualized Networks | 269d? | 2014-06-09 A | 2015-06-17 | 25% | 201.75d? | 2014-06-06 | 2015-06-17 | 269d? | 521d | finish no earlier than 2015-06-17 | S5 | 2152h | 538h | FS_OAM_VIRNET | PCG-33 | 32.842 | China Mobile, Huawei | Rel-13 | SP-64 |  | FS_OAM_VIRNET |  |  |  |  |
| 324 | 89 | Study on Review of dedicated 3GPP UICC features | 729d? | 2013-03-04 A | 2015-12-16 A | 100% |  | 2013-03-04 | 2014-09-12 | 401d? |  | finish no earlier than 2015-12-16 | C6 | 5832h | 5832h | FS_Red_UCe | PCG-30 | 31.901 | BlackBerry | Rel-13 | CP-59 | Xavier | FS_Red_UCe |  |  |  |  |
| 325 | 90 | Study on Solutions for GSM/EDGE BTS Energy Saving | 617d? | 2009-03-10 A | 2014-11-21 | 95% | 30.85d? | 2009-03-10 | 2014-08-29 | 557d? | 669d | finish no earlier than 2014-11-21 | G1; G2 | 9872h | 9378.4h | FS_Energy_BTS | PCG-25 | 45.926 | Nokia Networks, Vodafone | Rel-13 | GP-47 | Paolo | FS_Energy_BTS |  |  |  |  |
| 326 | 91 | Study on Downlink MIMO | 398d? | 2013-08-21 A | 2015-02-20 | 65% | 139.3d? | 2013-08-20 | 2015-02-20 | 396d? | 604d | finish no earlier than 2015-02-20 | G1; G2 | 3484.8h | 1288h | FS_DOMIMO | PCG-30 | 45.8xy | Nokia Networks | Rel-13 | GP-57 | Paolo | FS_DOMIMO |  |  |  |  |
| 327 | 92 | Study on Power saving for Machine-Type Communications (MTC) devices | 230.5d? | 2014-06-18 A | 2015-05-29 | 40% | 138.3d? | 2014-06-18 | 2015-02-20 | 160.5d? | 534d | finish no earlier than 2015-05-29 | G2; G1 | 3688h | 1475.2h | FS_uPoD | PCG-32 | 43.869 | China Mobile | Rel-13 | GP-60 |  | FS_uPoD |  |  |  |  |
| 328 | 93 | Study on UpLink MultiUser Multiple-Input Multiple-Output (UL MU-MIMO) | 255.5d? | 2014-04-17 A | 2015-05-15 | 20% | 204.4d? | 2014-04-17 | 2015-02-20 | 195.5d? | 544d | finish no earlier than 2015-05-15 | G1; G2 | 4088h | 817.6h | FS_UL_MU_MIMO | PCG-32 | 45.876 | Huawei | Rel-13 | GP-60 |  | FS_UL_MU_MIMO |  |  |  |  |
| 329 | 94 | Study on Cellular system support for ultra Low Complexity and low throughput Internet of Things | 163d? | 2014-05-30 A | 2015-08-28 | 40% | 97.8d? | 2015-01-14 | 2015-08-28 | 163d? | 469d | finish no earlier than 2015-08-28 | G1; G2 | 2608h | 1043.2h | FS_IoT_LC | PCG-33 | 45.8xy | Vodafone | Rel-13 | GP-62 |  | FS_IoT_LC |  |  | MTC, M2M |  |
| 330 | 95 | Study on LTE FDD in the bands 1980-2010 MHz and 2170-2200 MHz | 657d? | 2012-09-11 A | 2015-03-15 | 90% | 65.7d? | 2012-09-11 | 2014-09-12 | 527d? | 589d | finish no earlier than 2015-03-15 | R4 | 5256h | 4730.4h | FS_LTE_1980_2170_Korea | PCG-29 | LTE 36.861 | KT | Rel-13 | RP-57 | Issam | FS_LTE_1980_2170_Korea |  |  |  | RP-141153 |
| 331 | 96 | Study on Positioning enhancements for E-UTRA | 262d? | 2013-04-25 A | 2014-12-15 A | 100% |  | 2013-04-25 | 2014-12-05 | 256d? |  | finish no earlier than 2014-12-15 | R4; R1 | 4192h | 4192h | FS_LCSenh_LTE | PCG-31 | LTE 36.855 | Huawei | Rel-13 | RP-60 | Issam | FS_LCSenh_LTE |  |  |  | RP-140639 |
| 332 | 97 | Study on Multi-RAT joint coordination | 397d? | 2013-12-06 A | 2015-06-15 | 55% | 178.65d? | 2013-12-06 | 2014-12-05 | 261d? | 523d | finish no earlier than 2015-06-15 | R3 | 3176h | 1746.8h | FS_MultiRAT_JC | PCG-32 | UTRA, LTE 37.870 | China Mobile | Rel-13 | RP-62 | Juha | FS_MultiRAT_JC |  |  | WLAN | RP-141301 |
| 333 | 98 | Study on Advanced Wireless Services (AWS) - Extension band for LTE | 265d? | 2013-12-16 A | 2014-12-15 A | 100% |  | 2013-12-09 | 2014-12-05 | 261d? |  | finish no earlier than 2014-12-15 | R4 | 2120h | 2120h | FS_LTE_AWS_EXT | PCG-33 | LTE 36.849 | Qualcomm | Rel-13 | RP-64 |  | FS_LTE_AWS_EXT |  |  |  | RP-141429 |
| 334 | 99 | Study on MIMO OTA antenna test function for LTE | 462d? | 2013-03-18 A | 2014-12-15 A | 100% |  | 2013-03-15 | 2014-12-05 | 456d? |  | finish no earlier than 2014-12-15 | R5 | 3696h | 3696h | FS_LTE_MIMO_OTA_ATF | PCG-33 | 36.509, new TR 37.978 | Keysight | Rel-13 | RP-64 |  | FS_LTE_MIMO_OTA_ATF |  |  |  | RP-141124 |
| 335 | 100 | Study on Indoor Positioning Enhancements for UTRA and LTE | 328d? | 2014-06-18 A | 2015-09-15 | 8% | 301.76d? | 2014-06-13 | 2015-09-17 | 330d? | 457d | finish no earlier than 2015-09-15 | R1; R4 | 5248h | 419.84h | FS_UTRA_LTE_iPos_enh | PCG-33 | UTRA, LTE 37.857 | NextNav | Rel-13 | RP-64 |  | FS_UTRA_LTE_iPos_enh |  |  |  | RP-141101 |
| 336 | 101 | Study on Small data transmission enhancements for UMTS | 197d? | 2014-09-16 A | 2015-06-15 | 30% | 137.9d? |  |  |  | 523d | finish no earlier than 2015-06-15 | R1; R2 | 3152h | 945.6h | FS_UTRA_SDATA | PCG-33 | UTRA TR 25.8xy | Ericsson | Rel-13 | RP-65 |  | FS_UTRA_SDATA |  |  |  |  |
| 337 | 102 | Study on Downlink enhancements for UMTS | 133d? | 2014-09-12 A | 2015-03-15 | 40% | 79.8d? |  |  |  | 589d | finish no earlier than 2015-03-15 | R2; R1 | 2128h | 851.2h | FS_UTRA_EDL | PCG-33 | UTRA TR 25.706 | Huawei | Rel-13 | RP-65 |  | FS_UTRA_EDL |  |  |  |  |
| 338 | 103 | Study on Elevation Beamforming/Full-Dimension (FD) MIMO for LTE | 199d? | 2014-09-12 A | 2015-06-15 | 30% | 139.3d? |  |  |  | 523d | finish no earlier than 2015-06-15 | R1 | 1592h | 477.6h | FS_LTE_EBF_FDMIMO | PCG-33 | LTE 36.8xy | Nokia Networks (DL), Samsung (UL) | Rel-13 | RP-65 |  | FS_LTE_EBF_FDMIMO |  |  |  |  |
| 339 | 104 | Study on Licensed-Assisted Access using LTE | 197d? | 2014-09-16 A | 2015-06-15 | 30% | 137.9d? |  |  |  | 523d | finish no earlier than 2015-06-15 | R1; R2; R4 | 4728h | 1418.4h | FS_LTE_LAA | PCG-33 | LTE 36.8xy | Ericsson, Huawei | Rel-13 | RP-65 |  | FS_LTE_LAA |  |  |  |  |
| 340 | 105 | Feasibility study on Extended DRX cycle for Power Consumption Optimization | 140d? | 2014-12-03 | 2015-06-16 |  |  |  |  |  | 522d | finish no earlier than 2015-06-16 | S2 | 1120h |  | FS_eDRX |  |  | Qualcomm | Rel-13 | SP-66 |  |  |  |  |  |  |
| 341 | 106 | Study on KQIs for Service Experience | 203d? | 2014-12-03 | 2015-09-11 |  |  |  |  |  | 459d | finish no earlier than 2015-09-11 | S5 | 1624h |  |  |  |  |  | Rel-13 | SP-66 |  |  |  |  |  |  |
| 342 | 107 | Release 12 Features | 306d? | 2013-10-14 A | 2014-12-12 | 65% | 108.4d? | 2013-10-14 | 2014-12-10 | 304d? | 654d | finish no earlier than 2014-12-12 | SP; CP; RP; GP | 9792h | 6323.2h |  |  |  |  | Rel-12 |  |  |  |  |  |  |  |
| 343 | 108 | Stage 1 - ONLY Features | 647d? | 2011-09-27 | 2014-03-05 |  |  | 2011-09-27 | 2014-03-05 | 647d? | 859d | start no earlier than 2011-09-27 | SP; CP | 10352h |  |  | PCG-30 |  |  | Rel-12 | SP-58 |  |  |  |  |  |  |

Notes:
- 308: SP#64 revived. Added to the Title "for Service, Application and Subscriber Group", Changed Acronym: FS_UMONC=>FS_UMONC_sas / WI rapporteur e-mail: Jinyan Li (lijy@ctbri.com.cn)
- 309: SP#56 completed / WI rapporteur e-mail: Li.Mian@zte.com.cn
- 310: SP#64 revived. Updated WID SP-120554=>SP-140403. Changed Justification/objectives/Rapporteut ZTE=>China Unciom. SP#58 SA2 stopped (at 70% completion). LM: 80->100% / WI rapporteur e-mail: Jinyan Li (lijy@ctbri.com.cn)
- 311: SP#57 stopped / WI rapporteur e-mail: Hui Cai (Sarah.Cai@huawei.com)
- 312: LM: 0->30% / WI rapporteur e-mail: hans.ronneke@ericsson.com
- 313: SP#65 moved to Rel-13. Updated WID SP-100734=>SP-140576. Completion 09/14=>06/15. LM: 60->65% / WI rapporteur e-mail: vesa.lehtovirta@ericsson.com
- 314: SP#65 updated WID SP-140300=>SP-140629 (Moved the TR phase to Rel-13 as a stand-alone Study). Completion 09/14=>06/15. SP#64 TR 33.833 v100 for Information / WI rapporteur e-mail: Adrian Escott (aescott@qti.qualcomm.com)
- 315: SP#65 moved to Rel-13. Completion 09/14=>12/15. Related to SA1 TR 22.949 Rel-6 Study on Privacy Capability (PrivCap) UID_31030 studied generalized privacy capability (protection of personal data and non-disclosure of identity). LM: 80->85 / WI rapporteur e-mail: Feng Gao (gaofeng149@chinaunicom.cn)
- 316: Linked to LI13 which defines existing LI service requirements in TS 33.106 as well as existing HI1, HI2 & HI3 reference points / WI rapporteur e-mail: terry.jacobson@alcatel-lucent.com
- 317: LM: TR number added / WI rapporteur e-mail: Gregory.schumacher@sprint.com
- 318: SP#65 completion 09/14=>12/14. Moved to Rel-13. LM: 30->35%, CD 12/14->03/15 / WI rapporteur e-mail: Chris Steck (Audience), David Isherwood (Intel)
- 319: SP#65 updated WID SP-140349=>SP-140539. LM: 35->45 / WI rapporteur e-mail: zoulan@huawei.com
- 320: SP#64 completion 06/14=>12/14. LM: 20->25%, CD: 12/14->06/15 / WI rapporteur e-mail: Vladimir Yanover (vyanover@cisco.com)
- 321: -LM: 15->30%, CD: 12/14->09/15 / WI rapporteur e-mail: Li Jian (lijian@chinamobile.com), Hu Yaxi (huyaxi@cmdi.chinamobile.com)
- 322: SP#64 moved to Rel-13. Completion 06/14=>12/14. LM: 35->55, CD: 12/14->06/15 / WI rapporteur e-mail: Roland Jesske (r.jesske@telekom.de)
- 323: LM: 10->25% / WI rapporteur e-mail: Liu Jinglei (liujinglei@chinamobile.com), zoulan@huawei.com
- 324: CP#65 TR 31.901v100 for Information. Moved to Rel-13. Completion 09/14=>12/15. Waiting for feedback from external organizations (PTCRB/PVG). LM: 65->100% / WI rapporteur e-mail: Adrian Buckley (abuckley@blackberry.com)
- 325: GP#63 moved to Rel-13. Completion 08/14=>11/14. GP#55 TR 45.926v100 for Information. GP#47 approved WID. LM: 90->95% / WI rapporteur e-mail: juergen.hofmann@nsn.com, leo.patanapongpibul@vodafone.com
- 326: GP#62 completion 08/14=>02/15. Moved to Rel-13. GP#57 approved WID. LM: 50->65%, CD: 02/15->05/15 / WI rapporteur e-mail: Khairul Hasan
- 327: GP#65 completion 02/15=>05/15. GP#60 approved WID. Linked to Rel-12 Feature MTCe, Stage 2 BB3: UE Power Consumptions Optimizations (UEPCOP). LM: 30->40% / WI rapporteur e-mail: Jing Han (hanjing@chinamobile.com)
- 328: GP#62 completion 11/14=>02/15. GP#60 approved WID. LM: 02/15->05/15 / WI rapporteur e-mail: Chao Luo (chluo@huawei.com)
- 329: GP#62 approved WID. LM: 15->40% / WI rapporteur e-mail: chris.pudney@vodafone.com
- 330: CD:Thu 11/12/14->Sun 15/03/15; Compl:85%->90% / WI rapporteur e-mail: Chungwoo HWANG (cwhwang@kt.com)
- 331: CD:Thu 11/12/14->Mon 15/12/14; Compl:85%->100% / WI rapporteur e-mail: Jie Cui (cuijie@huawei.com)
- 332: CD:Thu 11/12/14->Mon 15/06/15; Compl:50%->55%; WID:RP-140955->RP-142043 / WI rapporteur e-mail: Kimba Dit Adamou, Boubacar (jinba@chinamobile.com)
- 333: CD:Thu 11/12/14->Mon 15/12/14; Compl:10%->100% / WI rapporteur e-mail: Gene Fong (gfong@qti.qualcomm.com)
- 334: CD:Thu 11/12/14->Mon 15/12/14; Compl:60%->100% / WI rapporteur e-mail: Moray_Rumney@keysight.com
- 335: CD:Thu 17/09/15->Tue 15/09/15; Compl:0%->8% / WI rapporteur e-mail: Vogedes Jerome (jvogedes@NextNav.com)
- 336: CD:Thu 18/06/15->Mon 15/06/15; Compl:0%->30%; WID:RP-140955->RP-142043 / WI rapporteur e-mail: gerardo.agni.medina.acosta@ericsson.com
- 337: CD:Wed 11/03/15->Sun 15/03/15; Compl:0%->40%; WID:RP-140955->RP-142043 / WI rapporteur e-mail: jun.chen@huawei.com
- 338: CD:Tue 16/06/15->Mon 15/06/15; Compl:0%->30%; WID:RP-140955->RP-142043 / WI rapporteur e-mail: bishwarup.mondal@nsn.com, hyoungju.ji@samsung.com
- 339: CD:Thu 18/06/15->Mon 15/06/15; Compl:0%->30%; WID:RP-140955->RP-142043 / WI rapporteur e-mail: havish.koorapaty@ericsson.com, david.mazzarese@huawei.com
- 340: Proposed TSG#66
- 341: Proposed TSG#66
- 342: -
- 343: -

| ID | WBS | Task | Duration | Start | Finish | Complete | Baseline start | Baseline finish | Baseline duration | Constraint | Resources | Work | Actual work | Acronym | PCG approved | Impacted TSs and TRs | WI rapporteur name | WI rapporteur e-mail | Release | TSG approved | MCC resp | Special Focus Doc | Acronym_3GU_Export | PCG stopped | TSG stopped |
| --- | --- | --- | --- | --- | --- | --- | --- | --- | --- | --- | --- | --- | --- | --- | --- | --- | --- | --- | --- | --- | --- | --- | --- | --- | --- |
| 344 | 109 | **SIPTO Service Continuity of IP Data Session** | 262d? | 2010-09-23 A | 2011-09-21 A | 100% | 2010-09-23 | 2011-09-21 | 262d? |  | S1 | 4176h | 4176h | SIPTO_SC | PCG-25 | Stage 1 | Vodafone | mona.mustapha@vodafone.com | Rel-12 | SP-49 | Alain | HNB | SIPTO_SC |  |  |
| 345 | 109.1 | Stage 1 for SIPTO Service Continuity of IP Data Session | 262d? | 2010-09-23 A | 2011-09-21 A | 100% | 2010-09-23 | 2011-09-21 | 262d? | finish no earlier than 2011-09-21 | S1 | 2080h | 2080h | SIPTO_SC-SA1 | PCG-25 | 22.101, 22.220 | Vodafone | mona.mustapha@vodafone.com | Rel-12 | SP-49 | Alain | HNB |  |  |  |
| 346 | 110 | **Interworking between Mobile Operators using the Evolved Packet System and Data Application Providers** | 792d? | 2010-12-16 A | 2013-12-11 A | 100% | 2010-12-16 | 2013-12-11 | 792d? |  | S1; S2 | 22794.7h | 22794.7h | MOSAP | PCG-26 | Stage 1 | Cisco | Vojislav Vucetic (vvucetic@cisco.com) | Rel-12 | SP-50 | Alain |  | MOSAP |  |  |
| 347 | 110.1 | Stage 1 for MOSAP | 202d? | 2010-12-16 A | 2011-09-21 A | 100% | 2010-12-16 | 2011-09-21 | 202d? | finish no earlier than 2011-09-21 | S1 | 1600h | 1600h | MOSAP-SA1 | PCG-26 | 22.278 | Cisco | Vojislav Vucetic (vvucetic@cisco.com) | Rel-12 | SP-50 | Alain |  |  |  |  |
| 348 | 110.2 | TR on Stage 2 for MOSAP | 669d? | 2011-06-06 A | 2013-12-11 A | 100% | 2011-06-06 | 2013-12-11 | 669d? | finish no earlier than 2012-12-12 | S2 | 5338.74h | 5338.74h | MOSAP-SA2TR | PCG-27 | new TR 23.862 | Intel | chang.hong.shan@intel.com | Rel-12 | SP-52 | Maurice |  |  |  |  |
| 349 | 110.3 | Deleted - Stage 2 for MOSAP | 399d? | 2011-06-14 A | 2012-12-12 A | 100% | 2011-06-14 | 2012-12-12 | 399d? | finish no earlier than 2012-12-12 | S2 | 3184h | 3184h | MOSAP-SA2Del | PCG-27 | TBD | Intel | chang.hong.shan@intel.com | Rel-12 | SP-52 | Maurice |  |  | PCG-30 | SP-58 |
| 350 | 111 | **IMS Network-Independent Public User Identities** | 275d? | 2011-06-08 A | 2012-06-20 A | 100% | 2011-06-08 | 2012-06-20 | 275d? |  | S1 | 4390.4h | 4390.4h | INIPUI | PCG-27 | Stage 1 | Vodafone | mona.mustapha@vodafone.com | Rel-12 | SP-52 | Alain |  | INIPUI |  |  |
| 351 | 111.1 | Stage 1 for IMS Network-Independent Public User Identities | 275d? | 2011-06-08 A | 2012-06-20 A | 100% | 2011-06-08 | 2012-06-20 | 275d? | finish no earlier than 2012-06-20 | S1 | 2190.4h | 2190.4h | INIPUI-SA1 | PCG-27 | 22.115, 22.228 | Vodafone | mona.mustapha@vodafone.com | Rel-12 | SP-52 | Alain |  |  |  |  |
| 352 | 112 | **Service and Media Reachability for Users over Restrictive Firewalls** | 198d? | 2011-09-21 A | 2012-06-20 A | 100% | 2011-09-21 | 2012-06-20 | 198d? |  | S1 | 3161.67h | 3161.67h | SMURFs | PCG-27 | Stage 1 | Vodafone | mona.mustapha@vodafone.com | Rel-12 | SP-53 | Alain |  | SMURFs |  |  |
| 353 | 112.1 | Stage 1 for Service and Media Reachability for Users over Restrictive Firewalls | 198d? | 2011-09-21 A | 2012-06-20 A | 100% | 2011-09-21 | 2012-06-20 | 198d? | finish no earlier than 2012-06-08 | S1 | 1577.67h | 1577.67h | SMURFs-SA1 | PCG-27 | 22.278 | Vodafone | mona.mustapha@vodafone.com | Rel-12 | SP-53 | Alain |  |  |  |  |
| 354 | 113 | **Advanced IP Interconnection of Services (IPXS) for national interconnect** | 139d? | 2012-03-06 A | 2012-09-12 A | 100% | 2012-03-06 | 2012-09-12 | 139d? |  | S1 | 2208h | 2208h | IPXSNAT | PCG-28 | Stage 1 | KPN | toon.norp@tno.nl | Rel-12 | SP-55 | Alain |  | IPXSNAT |  |  |
| 355 | 113.1 | Stage 1 for Advanced IP Interconnection of Services (IPXS) for national interconnect | 139d? | 2012-03-06 A | 2012-09-12 A | 100% | 2012-03-06 | 2012-09-12 | 139d? | finish no earlier than 2012-09-12 | S1 | 1096h | 1096h | IPXSNAT-SA1 | PCG-28 | 22.228 CR#0161 | KPN | toon.norp@tno.nl | Rel-12 | SP-55 | Alain |  |  |  |  |
| 356 | 114 | **Integration of Single Sign-On (SSO) frameworks with 3GPP networks** | 137d? | 2012-03-08 A | 2012-09-12 A | 100% | 2012-03-08 | 2012-09-12 | 137d? |  | S1 | 2184h | 2184h | SSO_Int | PCG-28 | Stage 1 | InterDigital | christopher.wallace@interdigital.com | Rel-12 | SP-55 | Alain |  | SSO_Int |  |  |
| 357 | 114.1 | Stage 1 for Integration of Single Sign-On (SSO) frameworks with 3GPP networks | 137d? | 2012-03-08 A | 2012-09-12 A | 100% | 2012-03-08 | 2012-09-12 | 137d? | finish no earlier than 2012-09-12 | S1 | 1088h | 1088h | SSO_Int-SA1 | PCG-28 | 22.101 | InterDigital | christopher.wallace@interdigital.com | Rel-12 | SP-55 | Alain |  |  |  |  |
| 358 | 115 | **Explicit Communication Transfer Blind (ECT Blind) service interactions** | 3d? | 2012-06-18 A | 2012-06-20 A | 100% | 2012-06-18 | 2012-06-20 | 3d? |  | S1 | 48h | 48h | ECTB | PCG-29 | Stage 1 | Orange | philippe.lottin@orange.com | Rel-12 | SP-56 | Alain |  | ECTB |  |  |
| 359 | 115.1 | Stage 1 for Explicit Communication Transfer Blind (ECT Blind) service interactions | 3d? | 2012-06-18 A | 2012-06-20 A | 100% | 2012-06-18 | 2012-06-20 | 3d? | finish no earlier than 2012-06-20 | S1 | 24h | 24h | ECTB-SA1 | PCG-29 | 22.173 | Orange | philippe.lottin@orange.com | Rel-12 | SP-56 | Alain |  |  |  |  |
| 360 | 116 | **IMS access via Digital Video Broadcast - Return Channel via Satellite (DVB-RCS2)** | 162d? | 2012-02-02 A | 2012-09-12 A | 100% | 2012-02-02 | 2012-09-12 | 162d? |  | S1 | 2584h | 2584h | IMSSat | PCG-29 | Stage 1 | KPN | toon.norp@tno.nl | Rel-12 | SP-57 | Alain |  | IMSSat |  |  |
| 361 | 116.1 | Stage 1 for IMS access via DVB-RCS2 | 162d? | 2012-02-02 A | 2012-09-12 A | 100% | 2012-02-02 | 2012-09-12 | 162d? | finish no earlier than 2012-09-12 | S1 | 1288h | 1288h | IMSSat-SA1 | PCG-29 | 22.228 | KPN | toon.norp@tno.nl | Rel-12 | SP-57 | Alain |  |  |  |  |
| 362 | 117 | **Sequential Flexible Alerting** | 3d? | 2012-12-10 A | 2012-12-12 A | 100% | 2012-12-10 | 2012-12-12 | 3d? |  | S1 | 48h | 48h | IMSSat | PCG-30 | Stage 1 | Orange | bruno.tossou@orange-ftgroup.com | Rel-12 | SP-58 | Alain |  | IMSSat |  |  |
| 363 | 117.1 | Stage 1 for Sequential Flexible Alerting | 3d? | 2012-12-10 A | 2012-12-12 A | 100% | 2012-12-10 | 2012-12-12 | 3d? | finish no earlier than 2012-12-12 | S1 | 24h | 24h | SEQ_FA | PCG-30 | 22.173 | Orange | bruno.tossou@orange-ftgroup.com | Rel-12 | SP-58 | Alain |  |  |  |  |
| 364 | 118 | **Language and Modality Information for communications** | 63d? | 2012-12-11 A | 2013-03-06 A | 100% | 2012-12-11 | 2013-03-06 | 63d? |  | S1 | 1008h | 1008h | LangInfo | PCG-30 | Stage 1 | Orange | philippe.lottin@orange.com | Rel-12 | SP-58 | Alain |  | LangInfo |  |  |
| 365 | 118.1 | Stage 1 for Language and Modality Information for communications | 63d? | 2012-12-11 A | 2013-03-06 A | 100% | 2012-12-11 | 2013-03-06 | 63d? | finish no earlier than 2013-03-06 | S1 | 504h | 504h | LangInfo-SA1 | PCG-30 | 22.228 | Orange | philippe.lottin@orange.com | Rel-12 | SP-58 | Alain |  |  |  |  |
| 366 | 119 | **Emergency Session Identification** | 3d? | 2013-03-04 A | 2013-03-06 A | 100% | 2013-03-04 | 2013-03-06 | 3d? |  | S1 | 48h | 48h | ESID | PCG-30 | Stage 1 | Telecom Italia | carmen.catalano@telecomitalia.it | Rel-12 | SP-59 | Alain |  | ESID |  |  |
| 367 | 119.1 | Stage 1 for Emergency Session Identification | 3d? | 2013-03-04 A | 2013-03-06 A | 100% | 2013-03-04 | 2013-03-06 | 3d? | finish no earlier than 2013-03-06 | S1 | 24h | 24h | ESID-SA1 | PCG-30 | 22.101 | Telecom Italia | carmen.catalano@telecomitalia.it | Rel-12 | SP-59 | Alain |  |  |  |  |

Notes:
- 344: SP#57 moved to Rel-12 (Reason: Stage 2 for requirements in TS 22.101 clause 4.3.5 have not been implemented in Rel-11). Linked to Rel-10 Local IP Access and Selected Internet IP Traffic Offload (LIPA_SIPTO)
- 345: SP#57 moved to Rel-12. SP#53 completed
- 346: SP#58 Stage 2 stopped (TR only, no normative work done)
- 347: SP#53 completed
- 348: SP#62 completed. TR 23.862v200 for Approval. SP#58 frozen as v100.
- 349: SP#58 stopped (no normative work done)
- 350: Triggered by Rel-11 TR 22.894 (FS_INIPUI)
- 351: SP#56 re-completed. Updated WID SP-110381=>SP-120425 (Re-opened & moved to Rel-12 by adding new reqs & removing reqs from Rel-11). SP#53 Rel-11 Stage 1 completed
- 352: SP#56 Stage 1 completed
- 353: SP#56 completed
- 354: SP#57 Stage 1 completed. Linked to Rel-11 Feature Advanced IP Interconnection of Services (IPXS) UID_470051.
- 355: SP#57 completed
- 356: SP#57 Stage 1 completed. Triggered by Rel-12 TR 22.895. Linked to SA3 33.8xy (Study on Security aspects of SSO_Int), 33.914 (SSO application security for common IMS based on SIP Digest), 33.924 (i/w GBA and OpenID), 33.980 (i/w GBA and Liberty Alliance)
- 357: SP#57 completed
- 358: SP#56 WID approved & Stage 1 completed
- 359: SP#56 new WID approved & work completed. Clarify the service interactions between ECT Blind and other MMTEL Supplementary Services
- 360: SP#57 Stage 1 completed. Integrate Satcom access with IMS. Specify DVB-RCS2 as an IP Connectivity Access Network for IMS
- 361: SP#57 completed. Definition of DVB-RCS2 as a non-3GPP IP Connectivity Access Network for IMS
- 362: SP#58 approved WID & Stage 1 completed. Currently Flexible Alerting (FA) group members are simultaneously alerted by the incoming call. Add the possibility to alert FA group members sequentially.
- 363: SP#58 approved WID & Stage 1 completed
- 364: SP#59 Stage 1 completed. Triggered by Rel-11 Study on Non Voice Emergency Services (FS_NOVES) TR 22.871 use case 10
- 365: SP#59 completed. Updated WID SP-120937=>SP-130108
- 366: SP#59 Stage 1 completed.
- 367: SP#59 completed (22.101 CR#0445)

| ID | WBS | Task | Duration | Start | Finish | Complete | Baseline start | Baseline finish | Baseline duration | Total slack | Constraint | Resources | Work | Actual work | Acronym | PCG approved | WI rapporteur name | WI rapporteur e-mail | Release | TSG approved | MCC resp | PCG stopped | TSG stopped | Acronym_3GU_Export | Special Focus Doc | Status Report |
| --- | --- | --- | --- | --- | --- | --- | --- | --- | --- | --- | --- | --- | --- | --- | --- | --- | --- | --- | --- | --- | --- | --- | --- | --- | --- | --- |
| 368 | 120 | **Deleted - Application and Service Access Control** | 77d? | 2013-03-06 A | 2013-06-19 A | 100% | 2013-03-06 | 2013-06-19 | 77d? |  |  | S1 | 1224h | 1224h | ASAC | PCG-30 | NTT DOCOMO | Atsushi Minokuchi (minokuchi@nttdocomo.co.jp) | Rel-12 | SP-59 | Alain | PCG-31 | SP-60 | ASAC |  |  |
| 369 | 120.1 | Deleted - Stage 1 for Application and Service Access Control | 77d? | 2013-03-06 A | 2013-06-19 A | 100% | 2013-03-06 | 2013-06-19 | 77d? |  | finish no earlier than 2013-06-19 | S1 | 608h | 608h | ASAC-SA1del | PCG-30 | NTT DOCOMO | Atsushi Minokuchi (minokuchi@nttdocomo.co.jp) | Rel-12 | SP-59 | Alain | PCG-31 | SP-60 |  |  |  |
| 370 | 121 | **Prevention of Mobile-Originating signalling and/or data traffic of UE in Connected mode** | 3d? | 2013-03-04 A | 2013-03-06 A | 100% | 2013-03-04 | 2013-03-06 | 3d? |  |  | S1 | 48h | 48h | PMOC | PCG-30 | NTT DOCOMO | Atsushi Minokuchi (minokuchi@nttdocomo.co.jp) | Rel-12 | SP-59 | Alain |  |  | PMOC |  |  |
| 371 | 121.1 | Stage 1 for Prevention of Mobile-Originating signalling and/or data traffic of UE in Connected mode | 3d? | 2013-03-04 A | 2013-03-06 A | 100% | 2013-03-04 | 2013-03-06 | 3d? |  | finish no earlier than 2013-03-06 | S1 | 24h | 24h | PMOC-SA1 | PCG-30 | NTT DOCOMO | Atsushi Minokuchi (minokuchi@nttdocomo.co.jp) | Rel-12 | SP-59 | Alain |  |  |  |  |  |
| 372 | 122 | SA1/SA2 Features | 216d? | 2013-05-17 | 2014-03-07 |  | 2013-05-17 | 2014-03-07 | 216d? | 857d | finish no earlier than 2014-03-07 | SP; CP; RP | 5184h |  |  | PCG-30 |  |  | Rel-12 | SP-58 |  |  |  |  |  |  |
| 373 | 123 | **LIPA Mobility and SIPTO at the Local Network** | 898d? | 2010-10-15 A | 2014-03-06 A | 100% | 2010-10-15 | 2014-03-06 | 898d? |  |  | S2; C4; C1; R3 | 87994h | 87994h | LIMONET | PCG-26 | Huawei | zhufenqin@huawei.com | Rel-12 | SP-50 | Maurice |  |  | LIMONET | HNB |  |
| 374 | 123.1 | TR on Stage 2 for LIPA Mobility and SIPTO at the Local Network | 580.85d? | 2010-10-15 A | 2013-03-06 A | 100% | 2010-10-15 | 2013-03-06 | 580.85d? |  | finish no earlier than 2013-03-06 | S2 | 4646.8h | 4646.8h | LIMONET-SA3 | PCG-26 | Huawei | zhufenqin@huawei.com | Rel-12 | SP-50 | Maurice |  |  |  | HNB |  |
| 375 | 123.2 | **BB1: SIPTO at the Local Network** | 892d? | 2010-10-22 A | 2014-03-05 A | 100% | 2010-10-22 | 2014-03-05 | 892d? |  |  | S2 | 31685.6h | 31685.6h | LIMONET-SIPTO | PCG-26 | Huawei | zhufenqin@huawei.com | Rel-12 | SP-50 | Maurice |  |  | LIMONET-SIPTO | HNB |  |
| 376 | 123.2.1 | Stage 2 for SIPTO at the Local Network | 655.85d? | 2010-10-22 A | 2013-06-19 A | 100% | 2010-10-22 | 2013-06-19 | 655.85d? |  | finish no earlier than 2013-06-19 | S2 | 5246.8h | 5246.8h | LIMONET-SIPTO-SA2 | PCG-26 | Huawei | zhufenqin@huawei.com | Rel-12 | SP-50 | Maurice |  |  |  | HNB |  |
| 377 | 123.2.2 | **Stage 3 CN aspects of SIPTO at the Local Network** | 649d? | 2011-09-24 A | 2014-03-05 A | 100% | 2011-09-24 | 2014-03-05 | 649d? |  |  | C4; C1 | 19680h | 19680h | LIMONET-SIPTO | PCG-27 | Huawei | peter.schmitt@huawei.com | Rel-12 | CP-53 | Kimmo |  |  |  | HNB |  |
| 378 | 123.2.2.1 | CT4 part of Stage 3 CN aspects of SIPTO at the Local Network | 518d? | 2011-09-24 A | 2013-09-06 A | 100% | 2011-09-24 | 2013-09-06 | 518d? |  | finish no earlier than 2013-09-06 | C4 | 4136h | 4136h | LIMONET-SIPTO-CT4 | PCG-27 | Huawei | peter.schmitt@huawei.com | Rel-12 | CP-53 | Kimmo |  |  |  | HNB |  |
| 379 | 123.2.2.2 | CT1 part of Stage 3 CN aspects of SIPTO at the Local Network | 646d? | 2011-09-24 A | 2014-03-05 A | 100% | 2011-09-24 | 2014-03-05 | 646d? |  | finish no earlier than 2014-01-29 | C1 | 5160h | 5160h | LIMONET-SIPTO-CT1 | PCG-27 | Huawei | peter.schmitt@huawei.com | Rel-12 | CP-53 | Frederic |  |  |  | HNB |  |
| 380 | 123.3 | **RAN aspects for SIPTO at the Local Network** | 269d? | 2013-03-04 A | 2014-03-06 A | 100% | 2013-03-04 | 2014-03-06 | 269d? |  |  | R3 | 4272h | 4272h | LIMONET-RAN | PCG-30 | Huawei | zheng.zhou@huawei.com | Rel-12 | RP-59 | Juha |  |  | LIMONET-RAN | HNB |  |
| 381 | 123.3.1 | Core part: RAN aspects for SIPTO at the Local Network | 266d? | 2013-03-04 A | 2014-03-06 A | 100% | 2013-03-04 | 2014-03-06 | 266d? |  | finish no earlier than 2014-03-06 | R3 | 2120h | 2120h | LIMONET-RAN-Core | PCG-30 | Huawei | zheng.zhou@huawei.com | Rel-12 | RP-59 | Juha |  |  | LIMONET-RAN-Core | HNB | RP-131512 |
| 382 | 123.4 | **Deleted - BB2: Stand-alone L-GW and associated Mobility for LIPA and SIPTO at the Local Network** | 566d? | 2010-10-22 A | 2012-12-12 A | 100% | 2010-10-22 | 2012-12-12 | 566d? |  |  | S2 | 18653.6h | 18653.6h | LIMONET-LIPA | PCG-26 | Huawei | zhufenqin@huawei.com | Rel-12 | SP-50 | Maurice | PCG-30 | SP-58 | LIMONET-LIPA | HNB |  |
| 383 | 123.4.1 | Deleted - Stage 2 for stand-alone L-GW and associated Mobility for LIPA and SIPTO at the Local Network | 519.85d? | 2010-10-22 A | 2012-12-12 A | 100% | 2010-10-22 | 2012-12-12 | 519.85d? |  | finish no earlier than 2012-12-12 | S2 | 4158.8h | 4158.8h | LIMONET-LIPA-del1 | PCG-26 | Huawei | zhufenqin@huawei.com | Rel-12 | SP-50 | Maurice | PCG-30 | SP-58 |  | HNB |  |
| 384 | 123.4.2 | **Deleted - Stage 3 CN aspects of LIPA Mobility** | 323d? | 2011-09-24 A | 2012-12-12 A | 100% | 2011-09-24 | 2012-12-12 | 323d? |  |  | C1; C4 | 10336h | 10336h | LIMONET-LIPA-del2 | PCG-27 | Huawei | christian.herrero@huawei.com | Rel-12 | CP-53 | Frederic | PCG-30 | SP-58 |  | HNB |  |
| 385 | 123.4.2.1 | Deleted - CT1 part of CN aspects of LIPA Mobility | 323d? | 2011-09-24 A | 2012-12-12 A | 100% | 2011-09-24 | 2012-12-12 | 323d? |  | finish no earlier than 2012-12-12 | C1 | 2584h | 2584h | LIMONET-LIPA-del3 | PCG-27 | Huawei | christian.herrero@huawei.com | Rel-12 | CP-53 | Frederic | PCG-30 | SP-58 |  | HNB |  |
| 386 | 123.4.2.2 | Deleted - CT4 part of CN aspects of LIPA Mobility | 323d? | 2011-09-24 A | 2012-12-12 A | 100% | 2011-09-24 | 2012-12-12 | 323d? |  | finish no earlier than 2012-12-12 | C4 | 2584h | 2584h | LIMONET-LIPA-del4 | PCG-27 | Huawei | christian.herrero@huawei.com | Rel-12 | CP-53 | Kimmo | PCG-30 | SP-58 |  | HNB |  |
| 387 | 124 | **Operator Policies for IP Interface Selection** | 720d? | 2011-03-23 A | 2013-12-06 A | 100% | 2011-03-23 | 2013-12-06 | 720d? |  |  | S2; C1 | 20256h | 20256h | OPIIS | PCG-26 | LG Electronics | taehyeon.kim@lge.com | Rel-12 | SP-51 | Maurice |  |  | OPIIS |  |  |
| 388 | 124.1 | TR on Stage 2 for Operator Policies for IP Interface Selection | 457d? | 2011-03-23 A | 2012-12-12 A | 100% | 2011-03-23 | 2012-12-12 | 457d? |  | finish no earlier than 2012-12-12 | S2 | 3640h | 3640h | OPIIS-SA2TR | PCG-26 | LG Electronics | taehyeon.kim@lge.com | Rel-12 | SP-51 | Maurice |  |  |  |  |  |
| 389 | 124.2 | Stage 2 for Operator Policies for IP Interface Selection | 511d? | 2011-04-04 A | 2013-03-06 A | 100% | 2011-04-04 | 2013-03-06 | 511d? |  | finish no earlier than 2013-03-06 | S2 | 4088h | 4088h | OPIIS-SA2 | PCG-26 | LG Electronics | taehyeon.kim@lge.com | Rel-12 | SP-51 | Maurice |  |  |  |  |  |
| 390 | 124.3 | Stage 3 for Operator Policies for IP Interface Selection | 126d? | 2013-06-14 A | 2013-12-06 A | 100% | 2013-06-14 | 2013-12-06 | 126d? |  | finish no earlier than 2013-12-06 | C1 | 1008h | 1008h | OPIIS-CT | PCG-31 | LG Electronics | Jaehyun Kim (jaehyun7.kim@lge.com) | Rel-12 | CP-60 | Frederic |  |  | OPIIS-CT |  |  |
| 391 | 125 | **Short Message Service (SMS) submit and delivery without MSISDN in IMS** | 665d? | 2011-06-08 A | 2013-12-06 A | 100% | 2011-06-08 | 2013-12-06 | 665d? |  |  | S2; C1; C4 | 28336.3h | 28336.3h | SMSMI | PCG-27 | Nokia Siemens Networks | curt.wong@nsn.com | Rel-12 | SP-52 | Maurice |  |  | SMSMI |  |  |
| 392 | 125.1 | TR on Stage 2 for SMS submit and delivery without MSISDN in IMS | 402d? | 2011-06-08 A | 2012-12-12 A | 100% | 2011-06-08 | 2012-12-12 | 402d? |  | finish no earlier than 2012-12-12 | S2 | 3192.32h | 3192.32h | SMSMI-SA2TR | PCG-27 | Nokia Siemens Networks | curt.wong@nsn.com | Rel-12 | SP-52 | Maurice |  |  |  |  |  |
| 393 | 125.2 | Stage 2 for SMS submit and delivery without MSISDN in IMS | 400d? | 2011-06-13 A | 2012-12-12 A | 100% | 2011-06-13 | 2012-12-12 | 400d? |  | finish no earlier than 2012-12-12 | S2 | 3192h | 3192h | SMSMI-SA2 | PCG-27 | Nokia Siemens Networks | curt.wong@nsn.com | Rel-12 | SP-52 | Maurice |  |  |  |  |  |

Notes:
- 368: SP#60 stopped and Rel-13 FS_ACDC continues. Triggered by TR 22.806 Study on Application specific Congestion control for Data Communication (FS_ACDC) UID_570034 / Impacted TSs and TRs: Stage 1
- 369: SP#60 stopped and Rel-13 FS_ACDC contd. Allow/prohibit for E-UTRAN idle mode UE initiation of particular applications defined by operator and subject to regional regulations. Prevent/mitigate overload of AN/CN defined by operator (congestion or disaster) / Impacted TSs and TRs: 22.011
- 370: SP#59 Stage 1 completed / Impacted TSs and TRs: Stage 1
- 371: SP#59 completed / Impacted TSs and TRs: 22.011
- 372: -
- 373: CP#63 completed. SP#58 updated WID SP-120256=>SP-120926 (stopped BB2 LIMONET-LIPA on Mobility). Linked to UID_450035 Local IP Access and Selected IP Traffic Offload (LIPA_SIPTO) / Impacted TSs and TRs: Stage 2/3
- 374: SP#59 completed. TR 23.859 v100 for Information and Approval / Impacted TSs and TRs: new TR 23.859
- 375: SP#60 completed / Impacted TSs and TRs: 23.060, 23.401
- 376: SP#60 completed / Impacted TSs and TRs: 23.060, 23.401
- 377: CP#63 completed / Impacted TSs and TRs: Stage 3
- 378: CP#61 completed / Impacted TSs and TRs: 23.003, 23.008, 29.002, 29.060, 29.230, 29.272, 29.274, 29.303
- 379: CP#63 completed / Impacted TSs and TRs: 24.008, 24.301
- 380: - / Impacted TSs and TRs: UTRA, LTE
- 381: RP#62 completed / Impacted TSs and TRs: 25.401, 25.413, 25.423, 25.467, 25.469, 36.300, 36.413, 36.423
- 382: SP#58 updated WID SP-120256=>SP-120926 (stopped BB2 LIMONET-LIPA on Mobility) / Impacted TSs and TRs: 23.060, 23.401
- 383: SP#58 updated WID SP-120256=>SP-120926 (stopped BB2 LIMONET-LIPA on Mobility) / Impacted TSs and TRs: 23.060, 23.401
- 384: SP#58 CT Stage 3 part stopped because of SA stopping Stage 2 for BB2 LIMONET-LIPA on Mobility) / Impacted TSs and TRs: Stage 3
- 385: SP#58 CT Stage 3 part stopped because of SA stopping Stage 2 for BB2 LIMONET-LIPA on Mobility) / Impacted TSs and TRs: 24.008, 24.301
- 386: SP#58 CT Stage 3 part stopped because of SA stopping Stage 2 for BB2 LIMONET-LIPA on Mobility) / Impacted TSs and TRs: 29.060, 29.274, 29.281, 29.303, 29.002, 29.272, 29.275, 29.282, 29.305
- 387: Linked to Rel-10 IFOM IP Flow Mobility and seamless WLAN offload (non-seamless WLAN offload aspects) & Rel-11 LIMONET (support traffic offload at local network) / Impacted TSs and TRs: Stage 2/3
- 388: SP#58 completed / Impacted TSs and TRs: new TR 23.853
- 389: SP#59 completed (23.402 CR#152: Introduction of Inter-APN Routing Policies) / Impacted TSs and TRs: 23.402
- 390: CP#62 completed. Specify Inter-APN Routing Policies for selecting an IP interface to route IP flows among a choice of available interfaces in both 3GPP and non-3GPP accesses / Impacted TSs and TRs: 24.302, 24.312
- 391: Linked to Rel-7 SMSIP (Support of SMS over generic 3GPP IP access), Rel-11 SIMTC, Rel-12 TR 22.988 SA1 Study on alternatives to E.164 for MTC / Impacted TSs and TRs: Stage 2/3
- 392: SP#58 completed / Impacted TSs and TRs: new TR 23.863
- 393: SP#58 completed / Impacted TSs and TRs: 23.204, 23.682

| ID | WBS | Task | Duration | Start | Finish | Complete | Remaining | Baseline start | Baseline finish | Baseline duration | Total slack | Constraint | Resources | Work | Actual work | Acronym | PCG approved | Impacted TSs and TRs | WI rapporteur name | WI rapporteur e-mail | Release | TSG approved | MCC resp | Acronym_3GU_Export | Status Report | Special Focus Doc |
| --- | --- | --- | --- | --- | --- | --- | --- | --- | --- | --- | --- | --- | --- | --- | --- | --- | --- | --- | --- | --- | --- | --- | --- | --- | --- | --- |
| 394 | 125.3 | **Stage 3 for SMS submit and delivery without MSISDN in IMS** | 205d? | 2013-03-01 A | 2013-12-06 A | 100% |  | 2013-03-01 | 2013-12-06 | 205d? |  |  | C1; C4 | 5992h | 5992h | SMSMI-CT | PCG-30 | Stage 3 | NSN | peter.leis@nsn.com | Rel-12 | CP-59 | Frederic | SMSMI-CT |  |  |
| 395 | 125.3.1 | CT1 part of Stage 3 for SMS submit and delivery without MSISDN in IMS | 205d? | 2013-03-01 A | 2013-12-06 A | 100% |  | 2013-03-01 | 2013-12-06 | 205d? |  | finish no earlier than 2013-12-06 | C1 | 1608h | 1608h | SMSMI-CT1 | PCG-30 | 23.040, 24.341 | NSN | peter.leis@nsn.com | Rel-12 | CP-59 | Frederic |  |  |  |
| 396 | 125.3.2 | CT4 part of Stage 3 for SMS submit and delivery without MSISDN in IMS | 139d? | 2013-03-01 A | 2013-09-06 A | 100% |  | 2013-03-01 | 2013-09-06 | 139d? |  | finish no earlier than 2013-09-06 | C4 | 1104h | 1104h | SMSMI-CT4 | PCG-30 | 23.008, 29.002, 29.305, 29.328, 29.338 | NSN | peter.leis@nsn.com | Rel-12 | CP-59 | Kimmo |  |  |  |
| 397 | 126 | **IMS-based Telepresence** | 1247.5d? | 2010-03-22 A | 2014-12-09 | 60% | 496.31d? | 2010-03-19 | 2014-12-05 | 1243.5d? | 657d |  | S1; C1; C3; C4; IETF | 122882h | 36021.9h | IMS_TELEP | PCG-27 | Stage 1/2/3 | Orange | bruno.tossou@orange-ftgroup.com | Rel-12 | SP-53 | Alain | IMS_TELEP |  |  |
| 398 | 126.1 | Stage 1 for IMS-based Telepresence | 197d? | 2011-09-22 A | 2012-06-20 A | 100% |  | 2011-09-22 | 2012-06-20 | 197d? |  | finish no earlier than 2012-06-08 | S1 | 1569.86h | 1569.86h | IMS_TELEP-SA1 | PCG-27 | 22.228 | Orange | bruno.tossou@orange-ftgroup.com | Rel-12 | SP-53 | Alain |  |  |  |
| 399 | 126.2 | **CT part for IMS Telepresence (Stage 2/3)** | 1247.5d? | 2010-03-22 A | 2014-12-09 | 59% | 512.68d? | 2010-03-19 | 2014-12-05 | 1243.5d? | 657d |  | C1; C3; C4; IETF | 87712h | 28148h | IMS_TELEP-CT | PCG-30 | Stage 2/3 | Huawei | Weiwei(Tommy) Yang (tommy@huawei.com) | Rel-12 | CP-58 | Frederic |  |  |  |
| 400 | 126.2.1 | TR on CT part of IMS Telepresence (Stage 2/3) | 399d? | 2012-12-07 A | 2014-06-13 A | 100% |  | 2012-12-07 | 2014-06-13 | 399d? |  | finish no earlier than 2014-06-13 | C1 | 3184h | 3184h | IMS_TELEP-CT1TR | PCG-30 | New TR 24.803 | Huawei | Weiwei(Tommy) Yang (tommy@huawei.com) | Rel-12 | CP-58 | Frederic |  |  |  |
| 401 | 126.2.2 | CT1 part of IMS Telepresence (Stage 3) | 526d? | 2012-12-07 A | 2014-12-09 A | 100% |  | 2012-12-07 | 2014-09-12 | 464d? |  | finish no earlier than 2014-12-09 | C1 | 4208h | 4208h | IMS_TELEP-CT1 | PCG-30 | 24.147, 24.166, 24.229, New TS 24.103 | Huawei | Weiwei(Tommy) Yang (tommy@huawei.com) | Rel-12 | CP-58 | Frederic |  | CP-140616 |  |
| 402 | 126.2.3 | (IETF) CT1 part of IMS Telepresence (mmusic-sctp-sdp) | 851d? | 2010-03-22 A | 2014-12-09 | 50% | 425.5d? | 2010-03-19 | 2014-12-05 | 849d? | 657d | finish no earlier than 2014-12-09 | C1-IETF | 6808h | 3404h | IMS_TELEP-mmusic | PCG-33 | draft-ietf-mmusic-sctp-sdp | christer.holmberg@ericsson.com | christer.holmberg@ericsson.com | Rel-12 | CP-64 |  |  |  |  |
| 403 | 126.2.4 | (IETF) CT1 part of IMS Telepresence (clue-framework ) | 851d? | 2010-03-22 A | 2014-12-09 | 50% | 425.5d? | 2010-03-19 | 2014-12-05 | 849d? | 657d | finish no earlier than 2014-12-09 | C1-IETF | 6808h | 3404h | IMS_TELEP-cluef | PCG-33 | draft-ietf-clue-framework | christer.holmberg@ericsson.com | christer.holmberg@ericsson.com | Rel-12 | CP-64 |  |  |  |  |
| 404 | 126.2.5 | (IETF) CT1 part of IMS Telepresence (clue-datachannel) | 851d? | 2010-03-22 A | 2014-12-09 | 50% | 425.5d? | 2010-03-19 | 2014-12-05 | 849d? | 657d | finish no earlier than 2014-12-09 | C1-IETF | 6808h | 3404h | IMS_TELEP-clued | PCG-33 | draft-ietf-clue-datachannel | christer.holmberg@ericsson.com | christer.holmberg@ericsson.com | Rel-12 | CP-64 |  |  |  |  |
| 405 | 126.2.6 | (IETF) CT1 part of IMS Telepresence (clue-signaling) | 851d? | 2010-03-22 A | 2014-12-09 | 50% | 425.5d? | 2010-03-19 | 2014-12-05 | 849d? | 657d | finish no earlier than 2014-12-09 | C1-IETF | 6808h | 3404h | IMS_TELEP-clues | PCG-33 | draft-ietf-clue-signaling | christer.holmberg@ericsson.com | christer.holmberg@ericsson.com | Rel-12 | CP-64 |  |  |  |  |
| 406 | 126.2.7 | (IETF) CT1 part of IMS Telepresence (clue-data-model-schema) | 851d? | 2010-03-22 A | 2014-12-09 | 50% | 425.5d? | 2010-03-19 | 2014-12-05 | 849d? | 657d | finish no earlier than 2014-12-09 | C1-IETF | 6808h | 3404h | IMS_TELEP-cluedms | PCG-33 | draft-ietf-clue-data-model-schema | christer.holmberg@ericsson.com | christer.holmberg@ericsson.com | Rel-12 | CP-64 |  |  |  |  |
| 407 | 126.2.8 | CT3 part of IMS Telepresence (Stage 3) | 467d? | 2012-12-07 A | 2014-09-11 A | 100% |  | 2012-12-07 | 2014-09-12 | 467d? |  | finish no earlier than 2014-09-12 | C3 | 3736h | 3736h | IMS_TELEP-CT3 | PCG-30 | 29.165 | Huawei | Weiwei(Tommy) Yang (tommy@huawei.com) | Rel-12 | CP-58 | Adrian |  |  |  |
| 408 | 126.2.9 | CT4 part of IMS Telepresence (Stage 2/3) | 328d? | 2013-09-13 | 2014-12-09 |  |  | 2013-09-10 | 2014-09-12 | 266d? | 657d | finish no earlier than 2014-12-09 | C4 | 2624h |  | IMS_TELEP-CT4 | PCG-31 | 23.333, 29.333 | Huawei | Weiwei(Tommy) Yang (tommy@huawei.com) | Rel-12 | CP-61 | Kimmo |  | CP-140477 |  |
| 409 | 127 | **Group Communication System Enablers for LTE** | 727d? | 2012-06-18 A | 2015-03-15 | 98% | 15.91d? | 2012-06-18 | 2014-09-17 | 597d? | 589d |  | S1; S2; S3; C3; C4; R3; C1 | 59744h | 36553.7h | GCSE_LTE | PCG-29 | Stage 1/2/3 | Nokia Networks | Juergen.Merkel@nsn.com | Rel-12 | SP-56 | Alain | GCSE_LTE |  | Public Safety (A-A) |
| 410 | 127.1 | Stage 1 for Group Communication System Enablers for LTE | 267d? | 2012-06-18 A | 2013-06-19 A | 100% |  | 2012-06-18 | 2013-06-19 | 267d? |  | finish no earlier than 2013-06-19 | S1 | 2128h | 2128h | GCSE_LTE-SA1 | PCG-29 | New TS 22.468 | Nokia Networks | Juergen.Merkel@nsn.com | Rel-12 | SP-56 | Alain |  |  | Public Safety (A-A) |
| 411 | 127.2 | TR on Architecture enhancements to support Group Communication System Enablers for LTE | 267d? | 2013-03-07 A | 2014-03-07 A | 100% |  | 2013-03-07 | 2014-03-07 | 267d? |  | finish no earlier than 2014-03-07 | S2 | 2128h | 2128h | GCSE_LTE-SA1TR | PCG-30 | New TR 23.768 | Nokia Networks | rainer.liebhart@nsn.com | Rel-12 | SP-59 | Maurice |  |  | Public Safety (A-A) |
| 412 | 127.3 | Stage 2 for Group Communication System Enablers for LTE | 402d? | 2013-03-12 A | 2014-09-16 A | 100% |  | 2013-03-12 | 2014-09-17 | 402d? |  | finish no earlier than 2014-09-17 | S2 | 3208h | 3208h | GCSE_LTE-SA2 | PCG-30 | New TS 23.468 | Nokia Networks | rainer.liebhart@nsn.com | Rel-12 | SP-59 | Maurice |  |  | Public Safety (A-A) |
| 413 | 127.4 | TR on Security for Group Communication System Enablers for LTE (Stage 2) | 201d? | 2013-09-12 A | 2014-06-18 A | 100% |  | 2013-09-12 | 2014-06-18 | 201d? |  | finish no earlier than 2014-06-18 | S3 | 1608h | 1608h | GCSE_LTE-SA2TR | PCG-31 | New TR 33.888 | Nokia Networks | anja.jerichow@nsn.com | Rel-12 | SP-61 | Mirko |  |  | Public Safety (A-A) |
| 414 | 127.5 | Security for Group Communication System Enablers for LTE (Stage 2) | 201d? | 2013-09-13 A | 2014-06-18 A | 100% |  | 2013-09-13 | 2014-06-18 | 201d? |  | finish no earlier than 2014-06-18 | S3 | 1608h | 1608h | GCSE_LTE-SA3 | PCG-31 | 33.246 | Nokia Networks | anja.jerichow@nsn.com | Rel-12 | SP-61 | Mirko |  |  | Public Safety (A-A) |
| 415 | 127.6 | **CT aspects of Group Communication System Enablers for LTE** | 131d? | 2014-06-13 A | 2014-12-09 | 100% | 0d? | 2014-06-13 | 2014-09-12 | 66d? | 0d |  | C3; C4; C1 | 5200h | 4152h | GCSE_LTE-CT | PCG-33 | Stage 3 | Nokia Networks | thomas.belling@nsn.com | Rel-12 | CP-64 |  | GCSE_LTE-CT |  | Public Safety (A-A) |
| 416 | 127.6.1 | CT3 part of Group Communication System Enablers for LTE | 66d? | 2014-06-13 A | 2014-09-11 A | 100% |  | 2014-06-13 | 2014-09-12 | 66d? |  | finish no earlier than 2014-09-12 | C3 | 528h | 528h | GCSE_LTE-CT3 | PCG-33 | 29.212, 29.213, 29.214, 29.274, New TS 29.468 | Nokia Networks | thomas.belling@nsn.com | Rel-12 | CP-64 |  |  |  | Public Safety (A-A) |
| 417 | 127.6.2 | CT4 part of Group Communication System Enablers for LTE | 128d? | 2014-06-13 A | 2014-12-09 A | 100% |  | 2014-06-13 | 2014-09-12 | 66d? |  | finish no earlier than 2014-12-09 | C4 | 1024h | 1024h | GCSE_LTE-CT4 | PCG-33 | 23.007, 23.008 | Nokia Networks | thomas.belling@nsn.com | Rel-12 | CP-64 |  |  | CP-140725 | Public Safety (A-A) |
| 418 | 127.6.3 | CT1 part of Group Communication System Enablers for LTE | 63d? | 2014-09-12 A | 2014-12-09 A | 100% |  |  |  |  |  | finish no earlier than 2014-12-09 | C1 | 504h | 504h | GCSE_LTE-CT1 | PCG-33 | 24.301 | Nokia Networks | thomas.belling@nsn.com | Rel-12 | CP-65 |  |  | CP-140614 | Public Safety (A-A) |

Notes:
- 394: CP#62 completed. Address scenario IMS client to IMS client SMS (comprises SMS receive and send SMS without requiring an MSISDN associated as part of their subscription record in HSS
- 395: CP#62 completed
- 396: CP#61 completed
- 397: This feature does not introduce any changes to the IMS architecture, and no stage 2 impacts are identified
- 398: SP#56 completed
- 399: CP#65 updated WID CP-140196=>CP-140624
- 400: CP#64 completed
- 401: CP#65 TS 24.103v100 for Information. Updated WID CP-140196=>CP-140624. Completion 09/14=>12/14. Exception in CP-140616. LM: 90->100%
- 402: work in progress
- 403: work in progress
- 404: work in progress
- 405: work in progress
- 406: work in progress
- 407: CP#65 completed
- 408: CP#65 updated WID CP-140196=>CP-140624. Completion 09/14=>12/14. Exception in CP-140477
- 409: Linked to Rel-12 FS_ProSe TR 22.803 Study on Proximity-based Services. External requirements: NIST, MESA, APCO Global Alliance, TCCA. Specify 3GPP system enablers to support group communication over LTE for Public Safety
- 410: SP#60 completed. TS 22.468 v100 for 1-step Approval
- 411: SP#63 completed. TR 23.768v200 for Approval
- 412: SP#65 completed. Updated WID SP-140113=>SP-140433. SP#63 TS 23.468v100 for 1-step Approval
- 413: SP#64 completed. TR 33.888v100 for 1-step Approval
- 414: SP#64 completed
- 415: CP#65 updated WID CP-140452=>C3-143199 (added CT1 part)
- 416: CP#65 completed. TS 29.468v200 for Approval
- 417: CP#65 completion 09/14=>12/14. Exception in CP-140725. LM: 35->100
- 418: CP#65 updated WID CP-140452=>CP-140559 (added CT1 part). Exception in CP-140614. LM: 90->100%

| ID | WBS | Task | Duration | Start | Finish | Complete | Remaining | Baseline start | Baseline finish | Baseline duration | Total slack | Constraint | Resources | Work | Actual work | Acronym | PCG approved | Impacted TSs and TRs | WI rapporteur name | WI rapporteur e-mail | Release | TSG approved | Special Focus Doc | Acronym_3GU_Export | Status Report | MCC resp | PCG stopped | TSG stopped |
| --- | --- | --- | --- | --- | --- | --- | --- | --- | --- | --- | --- | --- | --- | --- | --- | --- | --- | --- | --- | --- | --- | --- | --- | --- | --- | --- | --- | --- |
| 419 | 127.7 | **Group Call eMBMS congestion management for LTE** | 198d? | 2014-06-16 A | 2015-03-15 | 80% | 39.59d? | 2014-06-13 | 2014-09-12 | 66d? | 589d |  | R3 | 3152h | 2521.67h | GCSE_LTE-MBMS_CM | PCG-33 | LTE | Alcatel-Lucent | hakon.helmers@alcatel-lucent.com | Rel-12 | RP-64 | Public Safety (A-A) | GCSE_LTE-MBMS_CM |  |  |  |  |
| 420 | 127.7.1 | Core part: Group Call eMBMS congestion management for LTE | 196d? | 2014-06-16 A | 2015-03-15 | 80% | 39.2d? | 2014-06-13 | 2014-09-12 | 66d? | 589d | finish no earlier than 2015-03-15 | R3 | 1568h | 1254.4h | GCSE_LTE-MBMS_CM-Core | PCG-33 | 36.413 | Alcatel-Lucent | hakon.helmers@alcatel-lucent.com | Rel-12 | RP-64 | Public Safety (A-A) | GCSE_LTE-MBMS_CM-Core | RP-141327 |  |  |  |
| 421 | 128 | **Machine-Type and other mobile data applications Communications enhancements** | 1320d? | 2009-12-10 A | 2014-12-09 | 99% | 7.35d? | 2009-12-10 | 2014-09-12 | 1255d? | 657d |  | S2; S1; S3; C1; C3; C4; C6; R2; R3; G1 | 180632h | 179281h | MTCe | PCG-29 | Stage 1/2/3 | Intel | puneet.jain@intel.com | Rel-12 | SP-56 | MTC, M2M | MTCe |  | Maurice |  |  |
| 422 | 128.1 | Stage 1 for Support for Interworking with M2M Service Enablement | 189d? | 2012-06-18 A | 2013-03-06 A | 100% |  | 2012-06-18 | 2013-03-06 | 189d? |  | finish no earlier than 2013-03-06 | S1 | 1504h | 1504h | MTCe-SIMSE | PCG-29 | 22.368 | KPN | toon.norp@tno.nl | Rel-12 | SP-56 | MTC, M2M | MTCe-SIMSE |  | Alain |  |  |
| 423 | 128.2 | Stage 1 for Machine-Type and other mobile data applications Communications – Service Requirement Maintenance | 127d? | 2012-09-13 A | 2013-03-06 A | 100% |  | 2012-09-13 | 2013-03-06 | 127d? |  | finish no earlier than 2013-03-06 | S1 | 1008h | 1008h | MTCe-SRM | PCG-29 | 22.101, 22.368 | KPN | toon.norp@tno.nl | Rel-12 | SP-57 | MTC, M2M | MTCe-SRM |  | Alain |  |  |
| 424 | 128.3 | TR on Security aspects of Machine-Type Communications | 1113d? | 2009-12-10 A | 2014-03-07 A | 100% |  | 2009-12-10 | 2014-03-07 | 1113d? |  | finish no earlier than 2014-03-07 | S3 | 8896h | 8896h | MTCe-SA3TR | PCG-29 | New TR 33.868 | Samsung | Rajavelsamy R (rajvel@samsung.com) | Rel-12 | SP-56 | MTC, M2M |  |  | Mirko |  |  |
| 425 | 128.4 | Security and Privacy aspects for Machine-Type and other mobile data applications Communications enhancements (Stage 2) | 452d? | 2012-06-22 A | 2014-03-07 A | 100% |  | 2012-06-22 | 2014-03-07 | 452d? |  | finish no earlier than 2014-03-07 | S3 | 3608h | 3608h | MTCe-SA3 | PCG-29 | New TS 33.187 | Samsung | Rajavelsamy R (rajvel@samsung.com) | Rel-12 | SP-56 | MTC, M2M |  |  | Mirko |  |  |
| 426 | 128.5 | **BB1: Small Data and Device Triggering Enhancements (SDDTE)** | 594d? | 2012-06-18 A | 2014-09-11 A | 100% |  | 2012-06-18 | 2014-09-12 | 594d? |  |  | S2; C4; C3 | 24400h | 24400h | MTCe-SDDTE | PCG-29 |  | Intel | puneet.jain@intel.com | Rel-12 | SP-56 | MTC, M2M | MTCe-SDDTE |  | Maurice |  |  |
| 427 | 128.5.1 | TR on Stage 2 BB1: Small Data and Device Triggering Enhancements | 394d? | 2012-06-18 A | 2013-12-11 A | 100% |  | 2012-06-18 | 2013-12-11 | 394d? |  | finish no earlier than 2013-12-11 | S2 | 3128h | 3128h | MTCe-SDDTE-SA2TR | PCG-29 | New TR 23.887 | Intel | puneet.jain@intel.com | Rel-12 | SP-56 | MTC, M2M |  |  | Maurice |  |  |
| 428 | 128.5.2 | Stage 2 for BB1: Small Data and Device Triggering Enhancements | 390d? | 2012-06-26 A | 2013-12-11 A | 100% |  | 2012-06-26 | 2013-12-11 | 390d? |  | finish no earlier than 2013-12-11 | S2 | 3120h | 3120h | MTCe-SDDTE-SA2 | PCG-29 | 23.682 | Intel | puneet.jain@intel.com | Rel-12 | SP-56 | MTC, M2M |  |  | Maurice |  |  |
| 429 | 128.5.3 | **Stage 3 for BB1: Small Data and Device Triggering Enhancements** | 138d? | 2014-03-05 A | 2014-09-11 A | 100% |  | 2014-03-05 | 2014-09-12 | 138d? |  |  | C4; C3 | 3896h | 3896h | MTCe-SDDTE-CT | PCG-32 | Stage 3 | Huawei | peter.schmitt@huawei.com | Rel-12 | CP-63 | MTC, M2M | MTCe-SDDTE-CT |  | Kimmo |  |  |
| 430 | 128.5.3.1 | CT4 part of Stage 3 for BB1: Small Data and Device Triggering Enhancement | 138d? | 2014-03-05 A | 2014-09-11 A | 100% |  | 2014-03-05 | 2014-09-12 | 138d? |  | finish no earlier than 2014-09-12 | C4 | 1104h | 1104h | MTCe-SDDTE-CT4 | PCG-32 | 29.002, 29.336, 23.008, 29.337, 29.338, 29.230 | Huawei | peter.schmitt@huawei.com | Rel-12 | CP-63 | MTC, M2M |  |  | Kimmo |  |  |
| 431 | 128.5.3.2 | CT3 part of Stage 3 for BB1: Small Data and Device Triggering Enhancement | 73d? | 2014-03-05 A | 2014-06-13 A | 100% |  | 2014-03-05 | 2014-06-13 | 73d? |  | finish no earlier than 2014-06-13 | C3 | 584h | 584h | MTCe-SDDTE-CT3 | PCG-32 | 29.368 | Huawei | peter.schmitt@huawei.com | Rel-12 | CP-63 | MTC, M2M |  |  | Adrian |  |  |
| 432 | 128.6 | Deleted - BB2: Monitoring Enhancements (MONTE) | 131d? | 2012-06-18 A | 2012-12-12 A | 100% |  | 2012-06-18 | 2012-12-12 | 131d? |  | finish no earlier than 2012-12-12 | S2 | 1048h | 1048h | MTCe-MONTE | PCG-29 | 23.682 | Intel | puneet.jain@intel.com | Rel-12 | SP-56 | MTC, M2M | MTCe-MONTE |  | Maurice | PCG-30 | SP-58 |
| 433 | 128.7 | **BB3: UE Power Consumptions Optimizations (UEPCOP)** | 659d? | 2012-06-18 A | 2014-12-09 | 98% | 11.91d? | 2012-06-18 | 2014-09-12 | 594d? | 657d |  | S2; C1; C4; C6; G1 | 36221.3h | 35422.5h | MTCe-UEPCOP | PCG-29 |  | Ericsson | peter.hedman@ericsson.com | Rel-12 | SP-56 | MTC, M2M | MTCe-UEPCOP |  | Maurice |  |  |
| 434 | 128.7.1 | TR on Stage 2 BB3: UE Power Consumptions Optimizations (UEPCOP) | 394d? | 2012-06-18 A | 2013-12-11 A | 100% |  | 2012-06-18 | 2013-12-11 | 394d? |  | finish no earlier than 2013-12-11 | S2 | 3128h | 3128h | MTCe-UEPCOP-SA2TR | PCG-29 | New TR 23.887 | Ericsson | peter.hedman@ericsson.com | Rel-12 | SP-56 | MTC, M2M |  |  | Maurice |  |  |
| 435 | 128.7.2 | Stage 2 for BB3: UE Power Consumptions Optimizations (UEPCOP) | 390d? | 2012-06-26 A | 2013-12-11 A | 100% |  | 2012-06-26 | 2013-12-11 | 390d? |  | finish no earlier than 2013-12-11 | S2 | 3120h | 3120h | MTCe-UEPCOP-SA2 | PCG-29 | 23.060, 23.401, 23.682 | Ericsson | peter.hedman@ericsson.com | Rel-12 | SP-56 | MTC, M2M |  |  | Maurice |  |  |
| 436 | 128.7.3 | **Stage 3 for BB3: UE Power Consumptions Optimizations (UEPCOP)** | 267d? | 2013-12-06 A | 2014-12-09 | 96% | 10.54d? | 2013-12-06 | 2014-09-12 | 202d? | 657d |  | C1; C4; C6 | 11728h | 11264.6h | MTCe-UEPCOP-CT | PCG-32 | Stage 3 | Ericsson | mikael.wass@ericsson.com | Rel-12 | CP-62 | MTC, M2M | MTCe-UEPCOP-CT |  | Frederic |  |  |
| 437 | 128.7.3.1 | CT1 part of Stage 3 for BB3: UE Power Consumptions Optimizations (UEPCOP) | 202d? | 2013-12-06 A | 2014-09-11 A | 100% |  | 2013-12-06 | 2014-09-12 | 202d? |  | finish no earlier than 2014-09-12 | C1 | 1608h | 1608h | MTCe-UEPCOP-CT1 | PCG-32 | 24.008, 24.301 | Ericsson | mikael.wass@ericsson.com | Rel-12 | CP-62 | MTC, M2M |  |  | Frederic |  |  |
| 438 | 128.7.3.2 | Deleted - CT4 part of Stage 3 for BB3: UE Power Consumptions Optimizations (UEPCOP) | 201d? | 2013-12-09 A | 2014-09-11 A | 100% |  | 2013-12-09 | 2014-09-12 | 201d? |  | finish no earlier than 2014-09-12 | C4 | 1608h | 1608h | MTCe-UEPCOP-CT4 | PCG-32 | 29.274, 29.060, 23.008 | Ericsson | mikael.wass@ericsson.com | Rel-12 | CP-62 | MTC, M2M |  |  | Kimmo | PCG-33 | CP-65 |
| 439 | 128.7.3.3 | CT6 part of Stage 3 for BB3: UE Power Consumptions Optimizations (UEPCOP) | 263d? | 2013-12-09 A | 2014-12-09 | 90% | 26.3d? | 2013-12-09 | 2014-09-12 | 201d? | 657d | finish no earlier than 2014-12-09 | C6 | 2104h | 1893.6h | MTCe-UEPCOP-CT6 | PCG-32 | 31.101, 31.102, 31.111 | Ericsson | mikael.wass@ericsson.com | Rel-12 | CP-62 | MTC, M2M |  | CP-140697 | Xavier |  |  |
| 440 | 128.7.4 | Support of Power Saving Mode in GERAN | 5d? | 2014-08-25 A | 2014-08-29 A | 100% |  |  |  |  |  | finish no earlier than 2014-08-29 | G1 | 40h | 40h | MTCe-UEPCOP-GERAN | PCG-33 | 43.022 | Ericsson | sajal.kumar.das@ericsson.com | Rel-12 | GP-63 |  | MTCe-UEPCOP-GERAN |  |  |  |  |
| 441 | 128.8 | Deleted - BB4: Group based MTC feature (GROUP) | 129d? | 2012-06-20 A | 2012-12-12 A | 100% |  | 2012-06-20 | 2012-12-12 | 129d? |  | finish no earlier than 2012-12-12 | S2 | 1032h | 1032h | MTCe-GROUP | PCG-29 | 23.682 | KPN | Annemieke Kips | Rel-12 | SP-56 | MTC, M2M | MTCe-GROUP |  | Maurice | PCG-30 | SP-58 |
| 442 | 128.9 | **RAN enhancements for Machine-Type and other mobile data applications Communications** | 161.2d? | 2014-02-03 A | 2014-09-12 A | 100% |  | 2014-02-03 | 2014-09-12 | 160.2d? |  |  | R2; R3 | 3651h | 3651h | MTCe-RAN | PCG-32 | UTRA, LTE | ZTE | sergio.parolari@zte.com.cn | Rel-12 | RP-62 | MTC, M2M | MTCe-RAN |  | Yong-Jun |  |  |
| 443 | 128.9.1 | Core part: RAN enhancements for Machine-Type and other mobile data applications Communications | 133d? | 2014-02-03 A | 2014-09-12 A | 100% |  | 2014-02-03 | 2014-09-12 | 133d? |  | finish no earlier than 2014-09-12 | R2; R3 | 2128h | 2128h | MTCe-RAN-Core | PCG-32 | 25.300, 25.304, 25.413, 36.300, 36.304, 36.413, 36.423 | ZTE | sergio.parolari@zte.com.cn | Rel-12 | RP-62 | MTC, M2M | MTCe-RAN-Core | RP-141096 | Yong-Jun |  |  |

Notes:
- 419: -
- 420: CD:Thu 11/12/14->Sun 15/03/15; Compl:25%->80%
- 421: -
- 422: SP#59 completed. Define requirements for interworking with M2M service enablement layer specified by ETSI TC M2M in TS 102 689 ( specification for Service Enablement layer)
- 423: SP#59 completed. Updated WID SP-120541=>SP-130105
- 424: SP#63 completed. TR 33.868v100 for 1-step Approval. Was Rel-10 UID_460023 (Security for NIMTC). Was Rel-11 UID_490028 (TR on Security aspects of MTC). SP#56 activity transferred to Rel-12 Feature MTCe
- 425: SP#63 completed. TS 33.187v100 for 1-step Approval
- 426: -
- 427: SP#62 completed. TR 23.887v200 for Approval
- 428: SP#62 completed
- 429: CP#65 updated WID CP-140272=>CP-140489
- 430: CP#65 completed. Updated WID CP-140272=>CP-140489
- 431: CP#64 completed
- 432: SP#58 stopped (at 20% completion)
- 433: -
- 434: SP#62 completed. TR 23.887v200 for Approval
- 435: SP#62 completed
- 436: -
- 437: CP#65 completed
- 438: CP#65 stopped (no inpact on CT4)
- 439: CP#65 completion 09/14=>12/14. Exception in CP-140697
- 440: GP#63 approved WID and completed
- 441: SP#58 stopped (at 25% completion)
- 442: Triggered by TR 23.887 Machine Type and other mobile data applications Communications Enhancements (MTCe), TR 37.869 Study on Enhancements MTC and other Mobile Data Applications; RAN aspects (FS_MTCe_RAN), Rel-11 TR 23.888 SIMTC
- 443: RP#65 completed

| ID | WBS | Task | Duration | Start | Finish | Complete | Baseline start | Baseline finish | Baseline duration | Constraint | Resources | Work | Actual work | Acronym | PCG approved | Impacted TSs and TRs | WI rapporteur name | WI rapporteur e-mail | Release | TSG approved | MCC resp | Acronym_3GU_Export | Special Focus Doc | PCG stopped | TSG stopped | Status Report |
| --- | --- | --- | --- | --- | --- | --- | --- | --- | --- | --- | --- | --- | --- | --- | --- | --- | --- | --- | --- | --- | --- | --- | --- | --- | --- | --- |
| 444 | 129 | **Policy and Charging Control for supporting fixed broadband access networks** | 660d? | 2012-06-20 A | 2014-12-12 A | 100% | 2012-06-20 | 2014-09-17 | 595d? |  | S2; S1; S5; C3; C1; C4 | 84075.4h | 84075.4h | P4C | PCG-29 | Stage 1/2/3 | Huawei | marco.spini@huawei.com | Rel-12 | SP-56 | Maurice | P4C |  |  |  |  |
| 445 | 129.1 | Stage 1 for Policy and Charging Support for Fixed Mobile Convergence | 3d? | 2012-09-10 A | 2012-09-12 A | 100% | 2012-09-10 | 2012-09-12 | 3d? | finish no earlier than 2012-09-12 | S1 | 24h | 24h | P4C-FMC | PCG-29 | 22.278 | Huawei | amar.deol@huawei.com | Rel-12 | SP-57 | Alain | P4C-FMC |  |  |  |  |
| 446 | 129.2 | **BB1: Policy and Charging Control for supporting traffic from fixed terminals and NSWO (Non Seamless WLAN Offload) traffic from 3GPP UEs in fixed broadband access networks (P4C-F)** | 660d? | 2012-06-20 A | 2014-12-12 A | 100% | 2012-06-20 | 2014-09-17 | 595d? |  | S2; S5; C3; C1; C4 | 45657.3h | 45657.3h | P4C-F | PCG-29 |  | Huawei | marco.spini@huawei.com | Rel-12 | SP-56 | Maurice | P4C-F | WLAN |  |  |  |
| 447 | 129.2.1 | TR on Stage 2 for BB1: Policy and Charging Control for supporting traffic from fixed terminals and NSWO traffic from 3GPP UEs in fixed broadband access networks (P4C-F) | 539.9d? | 2012-06-20 A | 2014-12-12 A | 100% | 2012-06-20 | 2014-09-17 | 476.9d? | finish no earlier than 2014-12-12 | S2 | 4290.1h | 4290.1h | P4C-F-SA2TR | PCG-29 | new TR 23.896 | Huawei | marco.spini@huawei.com | Rel-12 | SP-56 | Maurice |  | WLAN |  |  |  |
| 448 | 129.2.2 | Stage 2 for BB1: Policy and Charging Control for supporting traffic from fixed terminals and NSWO traffic from 3GPP UEs in fixed broadband access networks (P4C-F) | 272.9d? | 2012-06-20 A | 2013-12-11 A | 100% | 2012-06-20 | 2013-12-11 | 272.9d? | finish no earlier than 2013-12-11 | S2 | 2183.2h | 2183.2h | P4C-F-SA2 | PCG-29 | 23.139, 23.203 | Huawei | marco.spini@huawei.com | Rel-12 | SP-56 | Maurice |  | WLAN |  |  |  |
| 449 | 129.2.3 | **Stage 3 for BB1: Policy and Charging Control for supporting traffic from fixed terminals and NSWO traffic from 3GPP UEs in fixed broadband access networks** | 203d? | 2013-09-06 A | 2014-06-13 A | 100% | 2013-09-06 | 2014-06-13 | 203d? |  | C3; C1; C4 | 8088h | 8088h | P4C-F-CT3 | PCG-31 | Stage 3 | Huawei | Xia Haitao (xiahaitao@huawei.com) | Rel-12 | CP-61 | Adrian | P4C-F-CT3 | WLAN |  |  |  |
| 450 | 129.2.3.1 | CT3 part of Stage 3 for BB1: Policy and Charging Control for supporting traffic from fixed terminals and NSWO traffic from 3GPP UEs in fixed broadband access networks | 203d? | 2013-09-06 A | 2014-06-13 A | 100% | 2013-09-06 | 2014-06-13 | 203d? | finish no earlier than 2014-06-13 | C3 | 1608h | 1608h | P4C-F-CT3 | PCG-31 | 29.212, 29.213, 29.215, 29.219 | Huawei | Xia Haitao (xiahaitao@huawei.com) | Rel-12 | CP-61 | Adrian |  | WLAN |  |  |  |
| 451 | 129.2.3.2 | CT1 part of Stage 3 for BB1: Policy and Charging Control for supporting traffic from fixed terminals and NSWO traffic from 3GPP UEs in fixed broadband access networks | 65d? | 2013-12-06 A | 2014-03-05 A | 100% | 2013-12-06 | 2014-03-05 | 65d? | finish no earlier than 2014-03-05 | C1 | 512h | 512h | P4C-F-CT1 | PCG-32 | 24.302 | Huawei | Xia Haitao (xiahaitao@huawei.com) | Rel-12 | CP-62 | Frederic |  | WLAN |  |  |  |
| 452 | 129.2.3.3 | CT4 part of Stage 3 for BB1: Policy and Charging Control for supporting traffic from fixed terminals and NSWO traffic from 3GPP UEs in fixed broadband access networks | 137d? | 2013-12-06 A | 2014-06-13 A | 100% | 2013-12-06 | 2014-06-13 | 137d? | finish no earlier than 2014-06-13 | C4 | 1096h | 1096h | P4C-F-CT4 | PCG-32 | 29.273 | Huawei | Xia Haitao (xiahaitao@huawei.com) | Rel-12 | CP-62 | Kimmo |  | WLAN |  |  |  |
| 453 | 129.2.4 | Policy and Charging Enforcement Function (PCEF) based Charging for traffic from fixed terminals and NSWO traffic from 3GPP UEs in fixed broadband access networks (Stage 2/3) | 326d? | 2013-06-21 A | 2014-09-17 A | 100% | 2013-06-21 | 2014-09-17 | 326d? | finish no earlier than 2014-09-17 | S5 | 2608h | 2608h | P4C-F-CH_P | PCG-31 | Stage 2 (32.240, 32.251), Stage 3 (32.298, 32.299) | Alcatel-Lucent | maryse.gardella@alcatel-lucent.com | Rel-12 | SP-60 | Mirko | P4C-F-CH_P | WLAN |  |  |  |
| 454 | 129.2.5 | Traffic Detection Function (TDF) based Charging for traffic from fixed terminals and NSWO traffic from 3GPP UEs in fixed broadband access networks (Stage 2/3) | 261d? | 2013-06-24 A | 2014-06-18 A | 100% | 2013-06-24 | 2014-06-18 | 261d? | finish no earlier than 2014-06-18 | S5 | 2088h | 2088h | P4C-F-CH_T | PCG-31 | Stage 2 (32.240, 32.251), Stage 3 (32.298, 32.299) | Openet Telecom | alan.mcnamee@openet.com | Rel-12 | SP-60 | Mirko | P4C-F-CH_T | WLAN |  |  |  |
| 455 | 129.3 | **BB2: Policy and Charging Control for 3GPP UEs connected to BroadBand Forum access network as Trusted network in Interworking scenario (P4C-TI)** | 266d? | 2012-06-20 A | 2013-06-19 A | 100% | 2012-06-20 | 2013-06-19 | 266d? |  | S2 | 2610.07h | 2610.07h | P4C-TI | PCG-29 |  | Alcatel-Lucent | konstantin.livanos@alcatel-lucent.com | Rel-12 | SP-56 | Maurice | P4C-TI |  |  |  |  |
| 456 | 129.3.1 | TR on Stage 2 for BB2: Policy and Charging Control for 3GPP UEs connected to BroadBand Forum access network as Trusted network in Interworking scenario (P4C-TI) | 109.2d? | 2012-06-20 A | 2013-06-19 A | 100% | 2012-06-20 | 2013-06-19 | 109.2d? | finish no earlier than 2013-06-06 | S2 | 862.87h | 862.87h | P4C-TI-SA2TR | PCG-29 | new TR 23.839 | Alcatel-Lucent | konstantin.livanos@alcatel-lucent.com | Rel-12 | SP-56 | Maurice |  |  |  |  |  |
| 457 | 129.3.2 | Stage 2 for BB2: Policy and Charging Control for 3GPP UEs connected to BroadBand Forum access network as Trusted network in Interworking scenario (P4C-TI) | 109.2d? | 2012-06-20 A | 2013-06-19 A | 100% | 2012-06-20 | 2013-06-19 | 109.2d? | finish no earlier than 2013-06-19 | S2 | 873.6h | 873.6h | P4C-TI-SA2 | PCG-29 | 23.139, 23.203 | Alcatel-Lucent | konstantin.livanos@alcatel-lucent.com | Rel-12 | SP-56 | Maurice |  |  |  |  |  |
| 458 | 129.4 | Deleted - BB3: Policy and Charging Control for 3GPP UEs connected to fixed broadband access network via S2b and S2c reference points for EPC routed traffic (P4C-S2bc) | 128d? | 2012-06-21 A | 2012-12-12 A | 100% | 2012-06-21 | 2012-12-12 | 128d? | finish no earlier than 2012-12-12 | S2 | 1024h | 1024h | P4C-S2bc | PCG-29 | 23.139, 23.203, new TR 23.896 | ZTE | Tricci So (tso@zteusa.com) | Rel-12 | SP-56 | Maurice | P4C-S2bc |  | PCG-30 | SP-58 |  |
| 459 | 129.5 | Deleted - BB4: Policy and Charging Control for EPC routed traffic over fixed broadband access networks of 3GPP UEs connected via H(e)NB in convergent scenarios (P4C-HeNB) | 128d? | 2012-06-21 A | 2012-12-12 A | 100% | 2012-06-21 | 2012-12-12 | 128d? | finish no earlier than 2012-12-12 | S2 | 1024h | 1024h | P4C-HeNB | PCG-29 | 23.139, 23.203, new TR 23.896 | NEC | Stefan.Schmid@neclab.eu | Rel-12 | SP-56 | Maurice | P4C-HeNB |  | PCG-30 | SP-58 |  |
| 460 | 129.6 | Deleted - BB5: Policy and Charging Control for supporting Layer 2 traffic in fixed broadband access network (P4C-FL2) | 128d? | 2012-06-21 A | 2012-12-12 A | 100% | 2012-06-21 | 2012-12-12 | 128d? | finish no earlier than 2012-12-12 | S2 | 1024h | 1024h | P4C-FL2 | PCG-29 | 23.139, 23.203, new TR 23.896 | Huawei | marco.spini@huawei.com | Rel-12 | SP-56 | Maurice | P4C-FL2 |  | PCG-30 | SP-58 |  |
| 461 | 129.7 | Deleted - BB6: Policy and Charging Control for 3GPP UEs connected to fixed broadband access networks via S2a reference point for EPC routed traffic in convergence (P4C-TC) | 129d? | 2012-06-20 A | 2012-12-12 A | 100% | 2012-06-20 | 2012-12-12 | 129d? | finish no earlier than 2012-12-12 | S2 | 1032h | 1032h | P4C-TC | PCG-29 | 23.139, 23.203, new TR 23.896 | ZTE | Tricci So (tso@zteusa.com) | Rel-12 | SP-56 | Maurice | P4C-TC |  | PCG-30 | SP-58 |  |
| 462 | 130 | **IMS Business Trunking for IP-PBX in Static Mode of Operation** | 847.1d? | 2011-09-28 A | 2014-12-09 A | 100% | 2011-09-28 | 2014-09-12 | 782.1d? |  | S2; S1; C1; C3 | 43555.2h | 43555.2h | BusTI | PCG-29 | Stage 1/2/3 | Deutsche Telekom | michele.zarri@telekom.com | Rel-12 | SP-56 | Maurice | BusTI |  |  |  |  |
| 463 | 130.1 | Stage 1 for IMS Business Trunking for IP-PBX in Static Mode of Operation | 64d? | 2011-09-28 A | 2012-09-12 A | 100% | 2011-09-28 | 2012-09-12 | 64d? | finish no earlier than 2012-08-30 | S1 | 504h | 504h | BusTI-SA1 | PCG-29 | 22.228 | Deutsche Telekom | kurt.bischinger@t-mobile.at | Rel-12 | SP-56 | Alain |  |  |  |  |  |
| 464 | 130.2 | TR on IMS Business Trunking for IP-PBX in Static Mode of Operation | 268d? | 2012-06-18 A | 2013-06-19 A | 100% | 2012-06-18 | 2013-06-19 | 268d? | finish no earlier than 2013-06-19 | S2; S1 | 4288h | 4288h | BusTI-SATR | PCG-29 | new TR 23.897 | Deutsche Telekom | michele.zarri@telekom.com | Rel-12 | SP-56 | Maurice |  |  |  |  |  |
| 465 | 130.3 | Stage 2 for IMS Business Trunking for IP-PBX in Static Mode of Operation | 263d? | 2012-06-25 A | 2013-06-19 A | 100% | 2012-06-25 | 2013-06-19 | 263d? | finish no earlier than 2013-06-19 | S2 | 2104h | 2104h | BusTI-SA2 | PCG-29 | 23.228 | Deutsche Telekom | michele.zarri@telekom.com | Rel-12 | SP-56 | Maurice |  |  |  |  |  |
| 466 | 130.4 | **CT aspects of IMS Business Trunking for IP-PBX in Static Mode of Operation (Stage 3)** | 333d? | 2013-09-06 A | 2014-12-09 A | 100% | 2013-09-06 | 2014-09-12 | 268d? |  | C1; C3 | 9552h | 9552h | BusTI-CT | PCG-31 | Stage 3 | Deutsche Telekom | michael.kreipl@telekom.de | Rel-12 | CP-61 | Frederic | BusTI-CT |  |  |  |  |
| 467 | 130.4.1 | CT1 part of CT aspects of IMS Business Trunking for IP-PBX in Static Mode of Operation (Stage 3) | 329d? | 2013-09-06 A | 2014-12-09 A | 100% | 2013-09-06 | 2014-09-12 | 267d? | finish no earlier than 2014-12-09 | C1 | 2632h | 2632h | BusTI-CT1 | PCG-31 | 23.218, 24.229, 24.525 (transfer of ETSI TS 182 025) | Deutsche Telekom | michael.kreipl@telekom.de | Rel-12 | CP-61 | Frederic |  |  |  |  | CP-140607 |
| 468 | 130.4.2 | CT3 part of CT aspects of IMS Business Trunking for IP-PBX in Static Mode of Operation (Stage 3) | 201d? | 2013-09-06 A | 2014-06-11 A | 100% | 2013-09-06 | 2014-06-13 | 201d? | finish no earlier than 2014-06-13 | C3 | 1608h | 1608h | BusTI-CT3 | PCG-31 | 29.165 | Deutsche Telekom | michael.kreipl@telekom.de | Rel-12 | CP-61 | Adrian |  |  |  |  |  |

Notes:
- 444: Linked to BBF, IETF work. SP#58 stopped BB3 to BB6. Split BB1 and BB2 into TR and Stage 2 work
- 445: SP#57 completed
- 446: -
- 447: SP#64 TR 23.896 was never sent for approval due to incomplete P4C BBs. SP#61 TR 23.896v100 for Information. LM: 90->100%
- 448: SP#62 completed
- 449: -
- 450: CP#64 completed
- 451: CP#63 completed
- 452: CP#64 completed
- 453: SP#65 completed. Introduce Charging Characteristics in Convergent scenario, Include missing fixed user location information for NSWO
- 454: SP#64 completed
- 455: -
- 456: SP#60 completed
- 457: SP#60 completed
- 458: SP#58 stopped (at 0% completion)
- 459: SP#58 stopped (at 0% completion)
- 460: SP#58 stopped (at 0% completion)
- 461: SP#58 stopped (at 30% completion)
- 462: Linked to Rel-11 IPXS Feature UID_470051 Advanced IP Interconnection of Services. This WI defines a generic framework for interconnecting with any type of IMS based network including IP-PBXs.
- 463: SP#57 completed. 22.228CR#0171
- 464: SP#60 completed
- 465: SP#60 completed
- 466: -
- 467: CP#65 completion 09/14=>12/14. Exception in CP-140607. LM: 85->100%
- 468: CP#64 completed

| ID | WBS | Task | Duration | Start | Finish | Complete | Remaining | Baseline start | Baseline finish | Baseline duration | Total slack | Constraint | Resources | Work | Actual work | Acronym | PCG approved | Impacted TSs and TRs | WI rapporteur name | WI rapporteur e-mail | Release | TSG approved | MCC resp | Special Focus Doc | Acronym_3GU_Export | PCG stopped | TSG stopped | Status Report |
| --- | --- | --- | --- | --- | --- | --- | --- | --- | --- | --- | --- | --- | --- | --- | --- | --- | --- | --- | --- | --- | --- | --- | --- | --- | --- | --- | --- | --- |
| 469 | 131 | **WLAN Network Selection for 3GPP Terminals** | 659d? | 2012-06-18 A | 2014-12-09 A | 100% |  | 2012-06-18 | 2014-09-12 | 594d? |  |  | S2; S1; S3; C1 | 35272h | 35272h | WLAN_NS | PCG-29 | Stage 1/2/3 | Intel | vivek.g.gupta@intel.com | Rel-12 | SP-56 | Maurice | WLAN | WLAN_NS |  |  |  |
| 470 | 131.1 | TR on Stage 2 for WLAN Network Selection for 3GPP Terminals | 396d? | 2012-06-18 A | 2013-12-11 A | 100% |  | 2012-06-18 | 2013-12-11 | 396d? |  | finish no earlier than 2013-12-11 | S2; S1 | 6336h | 6336h | WLAN_NS-SATR | PCG-29 | New TR 23.865 | Intel | vivek.g.gupta@intel.com | Rel-12 | SP-56 | Maurice | WLAN |  |  |  |  |
| 471 | 131.2 | Stage 2 for WLAN Network Selection for 3GPP Terminals | 392d? | 2012-06-22 A | 2013-12-11 A | 100% |  | 2012-06-22 | 2013-12-11 | 392d? |  | finish no earlier than 2013-12-11 | S2 | 3136h | 3136h | WLAN_NS-SA2 | PCG-29 | 23.402, 23.865 | Intel | vivek.g.gupta@intel.com | Rel-12 | SP-56 | Maurice | WLAN |  |  |  |  |
| 472 | 131.3 | Deleted - TR on Security Aspects of WLAN Network Selection for 3GPP Terminals | 326d? | 2012-12-13 A | 2014-03-07 A | 100% |  | 2012-12-13 | 2014-03-07 | 326d? |  | finish no earlier than 2014-03-07 | S3 | 2608h | 2608h | WLAN_Nsdel | PCG-30 | New TR 33.865 | Huawei | Lydia Xu (xuyixian@huawei.com) | Rel-12 | SP-58 | Mirko | WLAN |  | PCG-32 | CP-63 |  |
| 473 | 131.4 | CT aspects of WLAN Network Selection for 3GPP Terminals (Stage 3) | 263d? | 2013-12-06 A | 2014-12-09 A | 100% |  | 2013-12-06 | 2014-09-12 | 201d? |  | finish no earlier than 2014-12-09 | C1 | 2104h | 2104h | WLAN_NS-CT | PCG-32 | 24.302, 24.312 | Qualcomm | Amer Catovic, amerc@qualcomm.com | Rel-12 | CP-62 | Frederic | WLAN | WLAN_NS-CT |  |  | CP-140622 |
| 474 | 132 | **Deleted - IMS Registration Control** | 496d? | 2012-01-31 A | 2013-12-11 A | 100% |  | 2012-01-31 | 2013-12-11 | 496d? |  |  | S1; S2; C1; C4 | 23400h | 23400h | IMS_RegCon | PCG-29 | Stage 1/2/3 | China Mobile | lulu@chinamobile.com | Rel-12 | SP-57 | Alain |  | IMS_RegCon | PCG-32 | SP-62 |  |
| 475 | 132.1 | Deleted - Stage 1 for IMS Registration Control | 164d? | 2012-01-31 A | 2012-09-12 A | 100% |  | 2012-01-31 | 2012-09-12 | 164d? |  | finish no earlier than 2012-09-12 | S1 | 1304h | 1304h | IMS_RegCon-del1 | PCG-29 | 22.228 | China Mobile | lulu@chinamobile.com | Rel-12 | SP-57 | Alain |  |  | PCG-32 | SP-62 |  |
| 476 | 132.2 | Deleted - Stage 2 for IMS Registration Control | 262d? | 2012-12-13 A | 2013-12-11 A | 100% |  | 2012-12-13 | 2013-12-11 | 262d? |  | finish no earlier than 2013-12-11 | S2 | 2096h | 2096h | IMS_RegCon-del2 | PCG-30 | 23.228 | China Mobile | Jiang Yi (jiangyi@chinamobile.com) | Rel-12 | SP-58 | Maurice |  |  | PCG-32 | SP-62 |  |
| 477 | 132.3 | **Deleted - CT aspects of IMS registration control** | 129d? | 2013-06-19 A | 2013-12-11 A | 100% |  | 2013-06-19 | 2013-12-11 | 129d? |  |  | C1; C4 | 4128h | 4128h | IMS_RegCon-CT | PCG-31 | Stage 2/3 | China Mobile | Jiang Yi (jiangyi@chinamobile.com) | Rel-12 | CP-60 | Frederic |  | IMS_RegCon-CT | PCG-32 | SP-62 |  |
| 478 | 132.3.1 | Deleted - CT1 aspects of CT aspects of IMS registration control (Stage 2/3) | 129d? | 2013-06-19 A | 2013-12-11 A | 100% |  | 2013-06-19 | 2013-12-11 | 129d? |  | finish no earlier than 2013-12-11 | C1 | 1032h | 1032h | IMS_RegCon-CT1 | PCG-31 | 23.218, 24.229 | China Mobile | Jiang Yi (jiangyi@chinamobile.com) | Rel-12 | CP-60 | Frederic |  |  | PCG-32 | SP-62 |  |
| 479 | 132.3.2 | Deleted - CT4 aspects of CT aspects of IMS registration control (Stage 3) | 129d? | 2013-06-19 A | 2013-12-11 A | 100% |  | 2013-06-19 | 2013-12-11 | 129d? |  | finish no earlier than 2013-12-11 | C4 | 1032h | 1032h | IMS_RegCon-CT4 | PCG-31 | 29.228, 29.229, 23.008 | China Mobile | Jiang Yi (jiangyi@chinamobile.com) | Rel-12 | CP-60 | Kimmo |  |  | PCG-32 | SP-62 |  |
| 480 | 133 | **Proximity-based Services** | 728d? | 2012-12-13 A | 2015-09-15 | 84% | 117.54d? | 2012-12-13 | 2015-03-13 | 593d? | 457d |  | S1; S2; S3; C1; C3; C4; C6; R1; R2; R4; S5; IETF | 108593h | 33677.8h | ProSe | PCG-30 | Stage 1/2 | Qualcomm | Rich Hovey (rhovey@qualcomm.com) | Rel-12 | SP-58 | Alain | Public Safety (A-A) | ProSe |  |  |  |
| 481 | 133.1 | Stage 1 for Proximity-based Services | 137d? | 2012-12-13 A | 2013-06-19 A | 100% |  | 2012-12-13 | 2013-06-19 | 137d? |  | finish no earlier than 2013-06-19 | S1 | 1088h | 1088h | ProSe-SA1 | PCG-30 | 22.115, 22.278 | Qualcomm | Rich Hovey (rhovey@qualcomm.com) | Rel-12 | SP-58 | Alain | Public Safety (A-A) |  |  |  |  |
| 482 | 133.2 | TR on Stage 2 for Proximity-based Services | 327d? | 2012-12-13 A | 2014-03-07 A | 100% |  | 2012-12-13 | 2014-03-07 | 327d? |  | finish no earlier than 2014-03-07 | S2 | 2608h | 2608h | ProSe-SA2TR | PCG-30 | New TR 23.703 | Qualcomm | Haris Zisimopoulos (harisz@qti.qualcomm.com) | Rel-12 | SP-58 | Maurice | Public Safety (A-A) |  |  |  |  |
| 483 | 133.3 | Stage 2 for Proximity-based Services | 397d? | 2012-12-19 A | 2014-06-18 A | 100% |  | 2012-12-19 | 2014-06-18 | 397d? |  | finish no earlier than 2014-06-18 | S2 | 3168.8h | 3168.8h | ProSe-SA2 | PCG-30 | New TS 23.303 | Qualcomm | Haris Zisimopoulos (harisz@qti.qualcomm.com) | Rel-12 | SP-58 | Maurice | Public Safety (A-A) |  |  |  |  |
| 484 | 133.4 | Security for Proximity-based Services | 464d? | 2013-03-13 A | 2014-12-12 | 90% | 46.4d? | 2013-03-13 | 2014-06-18 | 336d? | 654d | finish no earlier than 2014-12-12 | S3 | 3712h | 3340.8h | ProSe-SA3 | PCG-30 | 33.220, New TS 33.303 | Qualcomm | Adrian Escott (aescott@qti.qualcomm.com) | Rel-12 | SP-59 | Mirko | Public Safety (A-A) |  |  |  | SP-140584 |
| 485 | 133.5 | (IETF) Security for Proximity-based Services (ietf-avtcore-srtp-aes-gcm) | 63d? | 2014-09-12 A | 2014-12-09 | 75% | 15.75d? |  |  |  | 657d | finish no earlier than 2014-12-09 | S3-IETF | 504h | 378h | ProSe | PCG-33 | ietf-avtcore-srtp-aes-gcm | Atle Monrad | atle.monrad@ericsson.com | Rel-12 | SP-65 |  | Public Safety (A-A) |  |  |  |  |
| 486 | 133.6 | **Charging Aspects of Proximity-based Services** | 195d? | 2014-06-19 A | 2015-03-13 | 85% | 29.25d? | 2014-06-18 | 2014-09-17 | 66d? | 589d |  | S5 | 4160h | 3120h | ProSe-CH | PCG-33 | Stage 2/3 | Qualcomm | Cheng Hong (hongc@qti.qualcomm.com) | Rel-12 | SP-64 |  | Public Safety (A-A) | ProSe-CH |  |  | SP-140543 |
| 487 | 133.6.1 | Study on Charging support for ProSe one-to-many Direct Communication for Public Safety use | 130d? | 2014-06-19 A | 2014-12-12 A | 100% |  | 2014-06-18 | 2014-09-17 | 66d? |  | finish no earlier than 2014-12-12 | S5 | 1040h | 1040h | ProSe-CH-SA5TR | PCG-33 | New TR 32.844 | Qualcomm | Cheng Hong (hongc@qti.qualcomm.com) | Rel-12 | SP-64 |  | Public Safety (A-A) |  |  |  | SP-140543 |
| 488 | 133.6.2 | Specification of Charging Aspects of Proximity-based Services | 195d? | 2014-06-19 A | 2015-03-13 | 75% | 48.75d? | 2014-06-18 | 2014-09-17 | 66d? | 589d | finish no earlier than 2015-03-13 | S5 | 1560h | 1170h | ProSe-CH-SA5 | PCG-33 | 32.240, 32.297, 32.298, 32.299, New TS 32.277 | Qualcomm | Cheng Hong (hongc@qti.qualcomm.com) | Rel-12 | SP-64 |  | Public Safety (A-A) |  |  |  | SP-140543 |
| 489 | 133.7 | **CT aspects of Proximity-based Services (Stage 3)** | 203d? | 2014-03-05 A | 2014-12-09 A | 100% |  | 2014-03-05 | 2014-09-12 | 138d? |  |  | C1; C3; C4; C6 | 12888h | 12888h | ProSe-CT | PCG-32 | Stage 3 | Qualcomm | Lena Chaponniere (lguellec@qti.qualcomm.com) | Rel-12 | CP-63 | Frederic | Public Safety (A-A) | ProSe-CT |  |  |  |
| 490 | 133.7.1 | CT1 part of CT aspects of Proximity-based Services | 200d? | 2014-03-05 A | 2014-12-09 A | 100% |  | 2014-03-05 | 2014-09-12 | 138d? |  | finish no earlier than 2014-12-09 | C1 | 1600h | 1600h | ProSe-CT1 | PCG-32 | 24.301, 23.122, New TSs (24.333, 24.334) | Qualcomm | Lena Chaponniere (lguellec@qti.qualcomm.com) | Rel-12 | CP-63 | Frederic | Public Safety (A-A) |  |  |  | CP-140615 |
| 491 | 133.7.2 | CT3 part of CT aspects of Proximity-based Services | 200d? | 2014-03-05 A | 2014-12-09 A | 100% |  | 2014-03-05 | 2014-09-12 | 138d? |  | finish no earlier than 2014-12-09 | C3 | 1600h | 1600h | ProSe-CT3 | PCG-32 | New TS 29.343 | Qualcomm | Lena Chaponniere (lguellec@qti.qualcomm.com) | Rel-12 | CP-63 | Adrian | Public Safety (A-A) |  |  |  | CP-140568 |
| 492 | 133.7.3 | CT4 part of CT aspects of Proximity-based Services | 200d? | 2014-03-05 A | 2014-12-09 A | 100% |  | 2014-03-05 | 2014-09-12 | 138d? |  | finish no earlier than 2014-12-09 | C4 | 1600h | 1600h | ProSe-CT4 | PCG-32 | 29.272, 23.008, 23.003, New TSs (29.344, 29.345) | Qualcomm | Lena Chaponniere (lguellec@qti.qualcomm.com) | Rel-12 | CP-63 | Kimmo | Public Safety (A-A) |  |  |  | CP-140484 |
| 493 | 133.7.4 | CT6 part of CT aspects of Proximity-based Services | 199d? | 2014-03-06 A | 2014-12-09 A | 100% |  | 2014-03-06 | 2014-09-12 | 137d? |  | finish no earlier than 2014-12-09 | C6 | 1592h | 1592h | ProSe-CT6 | PCG-32 | 31.102 | Qualcomm | Lena Chaponniere (lguellec@qti.qualcomm.com) | Rel-12 | CP-63 | Xavier | Public Safety (A-A) |  |  |  | CP-140695 |

Notes:
- 469: Evaluate and if needed enhance existing 3GPP solutions for WLAN network selection taking into account WFA Hotspot 2.0 solutions
- 470: SP#62 completed
- 471: SP#62 completed
- 472: SP#63 stopped (84% complete)
- 473: CP#65 completion 09/14=>12/14. CP#65 exception CP-140622. LM: 95->100%
- 474: SP#62 stopped. Specify for fixed line the requirement of controlling user registration to IMS based on network information related to user location (e.g. IP address, DSLAM information)
- 475: SP#57 completed
- 476: SP#62 stopped at 50% completion
- 477: SP#62 no CT/Stage 3 work is needed (stopped at 0% completion)
- 478: SP#62 no CT/Stage 3 work is needed (stopped at 0% completion)
- 479: SP#62 no CT/Stage 3 work is needed (stopped at 0% completion)
- 480: SP#65 SA3 updated the SA-wide WID SP-140300=>SP-140574 (Moved the TR phase to Rel-13 as a stand-alone Study). Triggered by Rel-12 TR 22.803 Study on Proximity-based Services (FS_ProSe) UID_530044
- 481: SP#60 completed
- 482: SP#63 completed. TR 23.703v200 for Approval
- 483: SP#64 completed open issue/alignment to RAN/SA3 decisions. SP#63 TS 23.303v100 for 1-step Approval
- 484: SP#65 re-opened. Completion 06/14=>12/14. Exception in SP-140584. Updated WID SP-140300=>SP-140574 (Moved the TR phase to Rel-13 as a stand-alone Study). SP#64 completed. TS 33.303 v100 for 1-step Approval
- 485: Submitted to IESG for publication
- 486: SP#65 exception in SP-140543
- 487: SP#65 completion 09/14=>12/14. Exception in SP-140543. TR 32.844v100 for Information. LM: CD: 09/14->12/14, 60->100%
- 488: SP#65 completion 09/14=>12/14. Exception in SP-140543. SP#65 TR 32.277v100 for Information. LM: CD: 09/14->03/15, 40->75%
- 489: CP#64 updated WID CP-140194=>CP-140290
- 490: CP#65 completion 09/14=>12/14. Exception in CP-140615. TS 24.333/4v200 for Approval. LM: 90->100%
- 491: CP#65 completion 09/14=>12/14. TS 29.343v100 for 1-step Approval. Exception in CP-140568. LM: 90->100
- 492: CP#65 completion 09/14=>12/14. TS 29.344/5v100 for 1-step Approval. Exception in CP-140484. LM: 90->100
- 493: CP#65 completion 09/14=>12/14. Exception in CP-140695. LM: 60->100%

| ID | WBS | Task | Type | Duration | Start | Finish | Complete | Remaining | Baseline start | Baseline finish | Baseline duration | Total slack | Constraint | Resources | Work | Actual work | Acronym | PCG approved | WI rapporteur name | WI rapporteur e-mail | Release | TSG approved | MCC resp | Special Focus Doc | Acronym_3GU_Export | Status Report |
| --- | --- | --- | --- | --- | --- | --- | --- | --- | --- | --- | --- | --- | --- | --- | --- | --- | --- | --- | --- | --- | --- | --- | --- | --- | --- | --- |
| 494 | 133.8 | **LTE Device to Device Proximity Services** |  | 399d? | 2014-03-11 A | 2015-09-15 | 10% | 359.1d? | 2014-03-06 | 2015-03-13 | 267d? | 457d |  | R1; R2; R4 | 12768h | 1886.2h | LTE_D2D_Prox | PCG-32 | Qualcomm | Shailesh Patil (patil@qti.qualcomm.com) | Rel-12 | RP-63 | Patrick | Public Safety (A-A) | LTE_D2D_Prox |  |
| 495 | 133.8.1 | Core part: LTE Device to Device Proximity Services | milestone | 0d? | 2014-03-15 A | 2014-03-15 | 95% | 0d? | 2014-07-11 | 2014-09-12 | 45.67d? | 0d | finish no earlier than 2014-03-15 | R1; R2; R4 |  |  | LTE_D2D_Prox-Core | PCG-32 | Qualcomm | Shailesh Patil (patil@qti.qualcomm.com) | Rel-12 | RP-63 | Patrick | Public Safety (A-A) | LTE_D2D_Prox-Core | RP-141244 |
| 496 | 133.8.2 | Perf. part: LTE Device to Device Proximity Services |  | 399d? | 2014-03-11 A | 2015-09-15 | 10% | 359.1d? | 2014-03-06 | 2015-03-13 | 267d? | 457d | finish no earlier than 2015-09-15 | R4 | 3192h | 319.2h | LTE_D2D_Prox-Perf | PCG-32 | Qualcomm | Shailesh Patil (patil@qti.qualcomm.com) | Rel-12 | RP-63 | Issam | Public Safety (A-A) | LTE_D2D_Prox-Perf | RP-141244 |
| 497 | 134 | **Web Real Time Communication access to IMS** |  | 530d? | 2012-12-14 A | 2014-12-12 | 78% | 115.03d? | 2012-12-14 | 2014-12-10 | 525d? | 654d |  | S1; S2; S3 | 34985.8h | 20389h | IMS_WebRTC | PCG-30 | China Mobile | lulu@chinamobile.com | Rel-12 | SP-58 | Alain |  | IMS_WebRTC |  |
| 498 | 134.1 | Stage 1 for Web Real Time Communication access to IMS |  | 136d? | 2012-12-14 A | 2013-06-19 A | 100% |  | 2012-12-14 | 2013-06-19 | 136d? |  | finish no earlier than 2013-06-19 | S1 | 1088h | 1088h | IMS_WebRTC-SA1 | PCG-30 | China Mobile | lulu@chinamobile.com | Rel-12 | SP-58 | Alain |  |  |  |
| 499 | 134.2 | TR on Stage 2 for Web Real Time Communication access to IMS |  | 126d? | 2013-06-19 A | 2013-12-11 A | 100% |  | 2013-06-19 | 2013-12-11 | 126d? |  | finish no earlier than 2013-12-11 | S2 | 1008h | 1008h | IMS_WebRTC-SA2TR | PCG-31 | China Mobile | Yu Qing (yuqing@chinamobile.com) | Rel-12 | SP-60 | Maurice |  |  |  |
| 500 | 134.3 | Stage 2 for Web Real Time Communication access to IMS |  | 192d? | 2013-06-19 A | 2014-03-07 A | 100% |  | 2013-06-19 | 2014-03-07 | 192d? |  | finish no earlier than 2014-03-07 | S2 | 1528h | 1528h | IMS_WebRTC-SA2 | PCG-31 | China Mobile | Yu Qing (yuqing@chinamobile.com) | Rel-12 | SP-60 | Maurice |  |  |  |
| 501 | 134.4 | (IETF) Web Real Time Communication access to IMS (rtcweb-overview) |  | 391d? | 2013-06-19 A | 2014-12-12 | 50% | 196.5d? | 2013-06-19 | 2014-12-10 | 389d? | 654d | finish no earlier than 2014-12-12 | S2-IETF | 3128h | 1556h | IMS_WebRTC-SA2IETF | PCG-32 | Uwe Rauschenbach | Uwe Rauschenbach | Rel-12 | SP-63 |  |  |  |  |
| 502 | 134.5 | TR on Security for Web Real Time Communication access to IMS |  | 202d? | 2013-12-11 A | 2014-09-17 A | 100% |  | 2013-12-11 | 2014-09-17 | 202d? |  | finish no earlier than 2014-09-17 | S3 | 1608h | 1608h | IMS_WebRTC-SA3TR | PCG-32 | Ericsson | oscar.ohlsson@ericsson.com | Rel-12 | SP-62 | Mirko |  |  |  |
| 503 | 134.6 | Security for Web Real Time Communication access to IMS |  | 202d? | 2013-09-12 A | 2014-06-18 A | 100% |  | 2013-09-12 | 2014-06-18 | 202d? |  | finish no earlier than 2014-06-18 | S3 | 1609.85h | 1609.85h | IMS_WebRTC-SA3 | PCG-31 | Ericsson | oscar.ohlsson@ericsson.com | Rel-12 | SP-61 | Mirko |  |  |  |
| 504 | 134.7 | **CT aspects of Web Real Time Communication (WebRTC) Access to IMS** |  | 203d? | 2014-03-05 A | 2014-12-09 | 70% | 60.38d? | 2014-03-05 | 2014-12-05 | 198d? | 657d |  | C1; C4; IETF | 12296h | 8727.2h | IMS_WebRTC-CT | PCG-32 | China Mobile | Jiang Yi (jiangyi@chinamobile.com) | Rel-12 | CP-63 | Frederic |  | IMS_WebRTC-CT |  |
| 505 | 134.7.1 | CT1 part of CT aspects of Web Real Time Communication (WebRTC) Access to IMS |  | 200d? | 2014-03-05 A | 2014-12-09 | 90% | 20d? | 2014-03-05 | 2014-09-12 | 138d? | 657d | finish no earlier than 2014-12-09 | C1 | 1600h | 1440h | IMS_WebRTC-CT1 | PCG-32 | China Mobile | Jiang Yi (jiangyi@chinamobile.com) | Rel-12 | CP-63 | Frederic |  |  | CP-140621 |
| 506 | 134.7.2 | (IETF) Web Real Time Communication access to IMS (rtcweb-data-channel) |  | 200d? | 2014-03-06 A | 2014-12-09 | 90% | 20d? | 2014-03-05 | 2014-12-05 | 198d? | 657d | finish no earlier than 2014-12-09 | C1-IETF | 1600h | 1440h | IMS_WebRTC-data | PCG-33 | christer.holmberg@ericsson.com | christer.holmberg@ericsson.com | Rel-12 | CP-64 |  |  |  |  |
| 507 | 134.7.3 | (IETF) Web Real Time Communication access to IMS (rtcweb-stun-consent-freshness) |  | 200d? | 2014-03-06 A | 2014-12-09 | 50% | 100d? | 2014-03-05 | 2014-12-05 | 198d? | 657d | finish no earlier than 2014-12-09 | C1-IETF | 1600h | 800h | IMS_WebRTC-stun | PCG-33 | christer.holmberg@ericsson.com | christer.holmberg@ericsson.com | Rel-12 | CP-64 |  |  |  |  |
| 508 | 134.7.4 | (IETF) Web Real Time Communication access to IMS (draft-yusef-sipcore-sip-oauth) |  | 63d? | 2014-09-12 A | 2014-12-09 | 25% | 47.25d? |  |  |  | 657d | finish no earlier than 2014-12-09 | C1-IETF | 504h | 126h | IMS_WebRTC-yusef | PCG-33 | christer.holmberg@ericsson.com | christer.holmberg@ericsson.com | Rel-12 | CP-65 |  |  |  |  |
| 509 | 134.7.5 | (IETF) Web Real Time Communication access to IMS (draft-holmberg-sipcore-auth-id) |  | 65d? | 2014-09-12 A | 2014-12-09 | 25% | 48.75d? |  |  |  | 657d | start no earlier than 2014-09-12 | C1-IETF | 520h | 130h | IMS_WebRTC-holmb |  | christer.holmberg@ericsson.com |  | Rel-12 | CP-66 |  |  |  |  |
| 510 | 134.7.6 | CT4 part of CT aspects of Web Real Time Communication (WebRTC) Access to IMS |  | 200d? | 2014-03-05 A | 2014-12-09 | 80% | 40d? | 2014-03-05 | 2014-09-19 | 143d? | 657d | finish no earlier than 2014-12-09 | C4 | 1600h | 1280h | IMS_WebRTC-CT4 | PCG-32 | China Mobile | Jiang Yi (jiangyi@chinamobile.com) | Rel-12 | CP-63 | Kimmo |  |  | CP-140732 |
| 511 | 135 | **Usage Monitoring Control PCC enhancement** |  | 196d? | 2012-12-13 A | 2013-09-06 A | 100% |  | 2012-12-13 | 2013-09-06 | 196d? |  |  | S2; C3 | 4112h | 4112h | UMONC | PCG-30 | ZTE | bi.yifeng@zte.com.cn | Rel-12 | SP-58 | Maurice |  | UMONC |  |
| 512 | 135.1 | Stage 2 for Usage Monitoring Control PCC enhancement |  | 61d? | 2012-12-13 A | 2013-03-06 A | 100% |  | 2012-12-13 | 2013-03-06 | 61d? |  | finish no earlier than 2013-03-06 | S2 | 488h | 488h | UMONC-SA2 | PCG-30 | ZTE | bi.yifeng@zte.com.cn | Rel-12 | SP-58 | Maurice |  |  |  |
| 513 | 135.2 | CT3 aspects of Usage Monitoring Control PCC enhancement (Stage 3) |  | 63d? | 2013-06-14 A | 2013-09-06 A | 100% |  | 2013-06-14 | 2013-09-06 | 63d? |  | finish no earlier than 2013-09-06 | C3 | 488h | 488h | UMONC-CT3 | PCG-31 | ZTE | zhou.xiaoyun@zte.com.cn | Rel-12 | CP-60 | Adrian |  | UMONC-CT3 |  |
| 514 | 136 | **Application Based Charging** |  | 340d? | 2013-03-07 A | 2014-06-18 A | 100% |  | 2013-03-07 | 2014-06-18 | 340d? |  |  | S2; S5; C3 | 11612h | 11612h | ABC | PCG-30 | Allot | Alla Goldner (agoldner@allot.com) | Rel-12 | SP-59 | Maurice |  | ABC |  |
| 515 | 136.1 | Stage 2 for Application Based Charging |  | 76d? | 2013-03-07 A | 2013-06-19 A | 100% |  | 2013-03-07 | 2013-06-19 | 76d? |  | finish no earlier than 2013-12-11 | S2 | 608h | 608h | ABC-SA2 | PCG-30 | Allot | Alla Goldner (agoldner@allot.com) | Rel-12 | SP-59 | Maurice |  |  |  |
| 516 | 136.2 | Charging for Application Based Charging |  | 232.5d? | 2013-06-19 A | 2014-06-18 A | 100% |  | 2013-06-19 | 2014-06-18 | 232.5d? |  | finish no earlier than 2014-06-18 | S5 | 1836h | 1836h | ABC-CT5 | PCG-31 | Openet Telecom | alan.mcnamee@openet.com | Rel-12 | SP-60 | Mirko |  |  |  |
| 517 | 136.3 | CT3 aspects of Application Based Charging (Stage 3) |  | 127d? | 2013-06-14 A | 2013-12-06 A | 100% |  | 2013-06-14 | 2013-12-06 | 127d? |  | finish no earlier than 2013-12-06 | C3 | 1008h | 1008h | ABC-CT3 | PCG-31 | Allot | Alla Goldner (agoldner@allot.com) | Rel-12 | CP-60 | Adrian |  | ABC-CT3 |  |

Notes:
- 494: follow-up of TR 36.843 FS_LTE_D2D_Prox / Impacted TSs and TRs: LTE
- 495: CD:Sat 15/03/14->Sat 15/03/14; Compl:95%->95%; WID: RP-140955 => RP-142043 / Impacted TSs and TRs: 36.101, 36.133, 36.211, 36.212, 36.213, 36.214, 36.300, 36.304, 36.306, 36.321, 36.322, 36.323, 36.331, 36.413, 36.423, New TR 36.877
- 496: CD:Fri 12/06/15->Tue 15/09/15; Compl:0%->10%; WID: RP-140955 => RP-142043 / Impacted TSs and TRs: 36.101, 36.133
- 497: IETF RTCWEB and W3C WEBRTC groups are specifying a browser-based client to support communication services. Interoperability for WebRTC clients to access 3GPP IMS is needed. / Impacted TSs and TRs: Stage 1/2
- 498: SP#60 completed / Impacted TSs and TRs: 22.101, 22.228
- 499: SP#62 completed. TR 23.701v100 for Information & Approval / Impacted TSs and TRs: New TR 23.701
- 500: SP#63 completed / Impacted TSs and TRs: 23.228
- 501: In WGLC / Impacted TSs and TRs: draft-ietf-rtcweb-overview
- 502: SP#65 completed. TR 33.871v200 for Approval / Impacted TSs and TRs: New TR 33.871
- 503: SP#64 completed / Impacted TSs and TRs: 33.203, 33.328
- 504: - / Impacted TSs and TRs: Stage 3
- 505: CP#65 TS 24.371v100 for Information. Completion 09/14=>12/14. Exception in CP-140621. LM: 70->90% / Impacted TSs and TRs: 24.229, New TS 24.371
- 506: Submitted to IESG for publication / Impacted TSs and TRs: draft-ietf-rtcweb-data-channel
- 507: work in progress / Impacted TSs and TRs: draft-ietf-rtcweb-stun-consent-freshness
- 508: work in progress / Impacted TSs and TRs: draft-yusef-sipcore-sip-oaut
- 509: Impacted TSs and TRs: draft-holmberg-sipcore-auth-id
- 510: CP#65 completion 09/14=>12/14. Exception in CP-140732. LM: 30->80% / Impacted TSs and TRs: 23.334, 29.334
- 511: SP#59 Stage 2 completed. Triggered by Rel-12 TR 23.858 Study on Usage Monitoring Control enhancement (UID_520035) / Impacted TSs and TRs: Stage 2/3
- 512: SP#59 completed. 23.203 CR#0782 (Time Based Usage Monitoring), CR#0784 (Usage Monitoring via Online Charging System) / Impacted TSs and TRs: 23.203
- 513: CP#61 completed / Impacted TSs and TRs: 29.212, 29.214, 29.215
- 514: Triggered by TR 23.800 Study on Application Based Charging (FS_ABC) UID_560038 / Impacted TSs and TRs: Stage 2/3
- 515: SP#60 completed / Impacted TSs and TRs: 23.203
- 516: SP#64 completed / Impacted TSs and TRs: 32.240, 32.251, 32.296, 32.298, 32.299
- 517: CP#62 completed / Impacted TSs and TRs: 29.212, 29.213, 29.214, 29.215, 29.219

| ID | WBS | Task | Duration | Start | Finish | Complete | Baseline start | Baseline finish | Baseline duration | Constraint | Resources | Work | Actual work | Acronym | PCG approved | WI rapporteur name | WI rapporteur e-mail | Release | TSG approved | MCC resp | Special Focus Doc | Acronym_3GU_Export | Status Report | PCG stopped | TSG stopped |
| --- | --- | --- | --- | --- | --- | --- | --- | --- | --- | --- | --- | --- | --- | --- | --- | --- | --- | --- | --- | --- | --- | --- | --- | --- | --- |
| 518 | 137 | **Enhanced S2a Mobility Over trusted WLAN access to EPC** | 332d? | 2013-09-09 A | 2014-12-09 A | 100% | 2013-09-09 | 2014-09-12 | 267d? |  | S2; C1; C4 | 19024h | 19024h | eSaMOG | PCG-31 | ZTE | Tricci So (tso@zteusa.com) | Rel-12 | SP-61 | Maurice | WLAN | eSaMOG |  |  |  |
| 519 | 137.1 | Stage 2 for Enhanced S2a Mobility Over trusted WLAN access to EPC | 130d? | 2013-09-11 A | 2014-03-07 A | 100% | 2013-09-11 | 2014-03-07 | 130d? | finish no earlier than 2014-03-07 | S2 | 1032h | 1032h | eSaMOG-SA2 | PCG-31 | ZTE | Tricci So (tso@zteusa.com) | Rel-12 | SP-61 | Maurice | WLAN |  |  |  |  |
| 520 | 137.2 | **Stage 3 for Enhanced S2a Mobility Over trusted WLAN access to EPC** | 332d? | 2013-09-09 A | 2014-12-09 A | 100% | 2013-09-09 | 2014-09-12 | 267d? |  | C1; C4 | 10048h | 10048h | eSaMOG-St3 | PCG-31 | ZTE | Joy Zhou (zhou.xingyue@zte.com.cn) | Rel-12 | CP-61 | Frederic | WLAN | eSaMOG-St3 |  |  |  |
| 521 | 137.2.1 | CT1 part of Stage 3 for Enhanced S2a Mobility Over trusted WLAN access to EPC | 329d? | 2013-09-09 A | 2014-12-09 A | 100% | 2013-09-09 | 2014-09-12 | 267d? | finish no earlier than 2014-12-09 | C1 | 2624h | 2624h | eSaMOG-CT1 | PCG-31 | ZTE | Joy Zhou (zhou.xingyue@zte.com.cn) | Rel-12 | CP-61 | Frederic | WLAN |  | CP-140608 |  |  |
| 522 | 137.2.2 | CT4 part of Stage 3 for Enhanced S2a Mobility Over trusted WLAN access to EPC | 266d? | 2013-09-09 A | 2014-09-11 A | 100% | 2013-09-09 | 2014-09-12 | 266d? | finish no earlier than 2014-09-12 | C4 | 2128h | 2128h | eSaMOG-CT4 | PCG-31 | ZTE | Joy Zhou (zhou.xingyue@zte.com.cn) | Rel-12 | CP-61 | Kimmo | WLAN |  |  |  |  |
| 523 | 138 | **Optimized Offloading to WLAN in 3GPP-RAT Mobility** | 199d? | 2013-09-12 A | 2014-06-13 A | 100% | 2013-09-12 | 2014-06-13 | 199d? |  | S2; C1 | 4800h | 4800h | WORM | PCG-31 | BlackBerry | Steve Barrett (sbarrett@blackberry.com) | Rel-12 | SP-61 | Maurice | WLAN | WORM |  |  |  |
| 524 | 138.1 | Stage 2 for Optimized Offloading to WLAN in 3GPP-RAT Mobility | 66d? | 2013-09-12 A | 2013-12-11 A | 100% | 2013-09-12 | 2013-12-11 | 66d? | finish no earlier than 2013-12-11 | S2 | 528h | 528h | WORM-SA2 | PCG-31 | BlackBerry | Steve Barrett (sbarrett@blackberry.com) | Rel-12 | SP-61 | Maurice | WLAN |  |  |  |  |
| 525 | 138.2 | CT aspects of Optimized Offloading to WLAN in 3GPP-RAT Mobility (Stage 3) | 136d? | 2013-12-06 A | 2014-06-13 A | 100% | 2013-12-06 | 2014-06-13 | 136d? | finish no earlier than 2014-06-13 | C1 | 1088h | 1088h | WORM-CT | PCG-32 | Intel | Chen-ho Chin (chen-hox.chin@intel.com) | Rel-12 | CP-62 | Frederic | WLAN | WORM-CT |  |  |  |
| 526 | 139 | **Network-provided Location information for IMS Trusted WLAN Access Network (TWAN) case** | 264d? | 2013-09-12 A | 2014-09-11 A | 100% | 2013-09-12 | 2014-09-12 | 264d? |  | S2; C3; C1; C4 | 18624h | 18624h | NETLOC_TWAN | PCG-31 | Alcatel-Lucent | Laurent.thiebaut@alcatel-lucent.com | Rel-12 | SP-61 | Maurice | WLAN | NETLOC_TWAN |  |  |  |
| 527 | 139.1 | Stage 2 for Network-provided Location information for IMS Trusted WLAN Access Network (TWAN) case | 129d? | 2013-09-12 A | 2014-03-07 A | 100% | 2013-09-12 | 2014-03-07 | 129d? | finish no earlier than 2014-03-07 | S2 | 1024h | 1024h | NETLOC_TWAN-SA2 | PCG-31 | Alcatel-Lucent | Laurent.thiebaut@alcatel-lucent.com | Rel-12 | SP-61 | Maurice |  |  |  |  |  |
| 528 | 139.2 | **CT aspects of Network-provided Location information for IMS Trusted WLAN Access Network (TWAN) case (Stage 3)** | 202d? | 2013-12-06 A | 2014-09-11 A | 100% | 2013-12-06 | 2014-09-12 | 202d? |  | C3; C1; C4 | 9152h | 9152h | NETLOC_TWAN-CT | PCG-32 | China Telecom | Xia Xu (xiaxu@ctbri.com.cn) | Rel-12 | CP-62 | Adrian |  | NETLOC_TWAN-CT |  |  |  |
| 529 | 139.2.1 | CT3 part of Network-provided Location information for IMS Trusted WLAN Access Network (TWAN) case | 137d? | 2013-12-06 A | 2014-06-13 A | 100% | 2013-12-06 | 2014-06-13 | 137d? | finish no earlier than 2014-06-13 | C3 | 1088h | 1088h | NETLOC_TWAN-CT3 | PCG-32 | China Telecom | Xia Xu (xiaxu@ctbri.com.cn) | Rel-12 | CP-62 | Adrian |  |  |  |  |  |
| 530 | 139.2.2 | CT1 part of Network-provided Location information for IMS Trusted WLAN Access Network (TWAN) case | 201d? | 2013-12-09 A | 2014-09-11 A | 100% | 2013-12-09 | 2014-09-12 | 201d? | finish no earlier than 2014-09-12 | C1 | 1608h | 1608h | NETLOC_TWAN-CT1 | PCG-32 | China Telecom | Xia Xu (xiaxu@ctbri.com.cn) | Rel-12 | CP-62 | Frederic |  |  |  |  |  |
| 531 | 139.2.3 | CT4 part of Network-provided Location information for IMS Trusted WLAN Access Network (TWAN) case | 201d? | 2013-12-06 A | 2014-09-11 A | 100% | 2013-12-06 | 2014-09-12 | 201d? | finish no earlier than 2014-09-12 | C4 | 1608h | 1608h | NETLOC_TWAN-CT4 | PCG-32 | China Telecom | Xia Xu (xiaxu@ctbri.com.cn) | Rel-12 | CP-62 | Kimmo |  |  |  |  |  |
| 532 | 140 | **Core Network Overload - User Location Information reporting improvement** | 203d? | 2013-12-11 A | 2014-09-17 A | 100% | 2013-12-11 | 2014-09-12 | 199d? |  | S2; C3; C4; S5 | 10920h | 10920h | CNO_ULI | PCG-32 | Alcatel-Lucent | nicolas.drevon@alcatel-lucent.com | Rel-12 | SP-62 | Maurice |  | CNO_ULI |  |  |  |
| 533 | 140.1 | Stage 2 for Core Network Overload - User Location Information reporting improvement | 64d? | 2013-12-11 A | 2014-03-07 A | 100% | 2013-12-11 | 2014-03-07 | 64d? | finish no earlier than 2014-03-07 | S2 | 504h | 504h | CNO_ULI-SA2 | PCG-32 | Alcatel-Lucent | nicolas.drevon@alcatel-lucent.com | Rel-12 | SP-62 | Maurice |  |  |  |  |  |
| 534 | 140.2 | Charging aspects of Core Network Overload – User Location Information reporting improvements | 3d? | 2014-09-15 A | 2014-09-17 A | 100% |  |  |  | finish no earlier than 2014-09-17 | S5 | 24h | 24h | CNO_ULI-CH | PCG-33 | Alcatel-Lucent | maryse.gardella@alcatel-lucent.com | Rel-12 | SP-65 |  |  | CNO_ULI-CH |  |  |  |
| 535 | 140.3 | **CT aspects of Core Network Overload – User Location Information reporting improvements** | 138d? | 2014-03-05 A | 2014-09-11 A | 100% | 2014-03-05 | 2014-09-12 | 138d? |  | C3; C4 | 3896h | 3896h | CNO_ULI-CT | PCG-32 | Alcatel-Lucent | horst.brinkmann@alcatel-lucent.com | Rel-12 | CP-63 | Adrian |  | CNO_ULI-CT |  |  |  |
| 536 | 140.3.1 | CT3 part of CT aspects of Core Network Overload – User Location Information reporting improvements | 73d? | 2014-03-05 A | 2014-06-13 A | 100% | 2014-03-05 | 2014-06-13 | 73d? | finish no earlier than 2014-06-13 | C3 | 584h | 584h | CNO_ULI-CT3 | PCG-32 | Alcatel-Lucent | horst.brinkmann@alcatel-lucent.com | Rel-12 | CP-63 | Adrian |  |  |  |  |  |
| 537 | 140.3.2 | CT4 part of CT aspects of Core Network Overload – User Location Information reporting improvements | 138d? | 2014-03-05 A | 2014-09-11 A | 100% | 2014-03-05 | 2014-09-12 | 138d? | finish no earlier than 2014-09-12 | C4 | 1104h | 1104h | CNO_ULI-CT4 | PCG-32 | Alcatel-Lucent | horst.brinkmann@alcatel-lucent.com | Rel-12 | CP-63 | Kimmo |  |  |  |  |  |
| 538 | 141 | Rel-12 Security small Enhancements | 923d? | 2011-03-23 A | 2014-09-17 A | 100% | 2011-03-23 | 2014-06-18 | 859d? | finish no earlier than 2014-09-17 | S3 | 7384h | 7384h | SEC12 | PCG-29 |  |  | Rel-12 | SP-56 | Mirko |  | SEC12 |  |  |  |
| 539 | 142 | **Security aspects of Public Warning System** | 925d? | 2011-03-23 A | 2014-09-17 A | 100% | 2011-03-23 | 2014-09-17 | 924d? |  | S3; S1 | 36832h | 36832h | PWS_Sec | PCG-26 | ST-Ericsson | john.mattsson@ericsson.com | Rel-12 | SP-51 | Mirko | Public Safety (I-A) | PWS_Sec |  |  |  |
| 540 | 142.1 | Stage 1 for Protection against false PWS Warning Notifications | 65d? | 2012-06-15 A | 2012-09-12 A | 100% | 2012-06-15 | 2012-09-12 | 65d? | finish no earlier than 2012-09-12 | S1 | 512h | 512h | PWS_Sec-SA1 | PCG-29 | Vodafone | adrian.neal@vodafone.com | Rel-12 | SP-56 | Alain | Public Safety (I-A) |  |  |  |  |
| 541 | 142.2 | TR on SA3 part for Security aspects of Public Warning System | 921d? | 2011-03-23 A | 2014-09-17 A | 100% | 2011-03-23 | 2014-09-17 | 921d? | finish no earlier than 2014-09-17 | S3 | 7360h | 7360h | PWS_Sec-SA3TR | PCG-26 | ST-Ericsson | john.mattsson@ericsson.com | Rel-12 | SP-51 | Mirko | Public Safety (I-A) |  |  |  |  |
| 542 | 142.3 | Deleted - SA3 part for Security aspects of Public Warning System | 852d? | 2011-03-30 A | 2014-06-18 A | 100% | 2011-03-30 | 2014-06-18 | 852d? | finish no earlier than 2014-06-18 | S3 | 6808h | 6808h | PWS_Sec-del1 | PCG-26 | ST-Ericsson | john.mattsson@ericsson.com | Rel-12 | SP-51 | Mirko | Public Safety (I-A) |  |  | PCG-33 | SP-64 |
| 543 | 142.4 | Deleted - Stage 1 for Security aspects of Public Warning System | 330d? | 2011-03-23 A | 2012-06-20 A | 100% | 2011-03-23 | 2012-06-20 | 330d? | start no earlier than 2011-03-23 | S1 | 2640h | 2640h | PWS_Sec-del2 | PCG-26 | ST-Ericsson | john.mattsson@ericsson.com | Rel-12 | SP-51 | Alain | Public Safety (I-A) |  |  | PCG-29 | SP-56 |
| 544 | 142.5 | Deleted - Stage 2 for Security aspects of Public Warning System | 133d? | 2011-03-23 A | 2011-09-21 A | 100% | 2011-03-23 | 2011-09-21 | 133d? | start no earlier than 2011-03-23 | S2 | 1064h | 1064h | PWS_Sec-del3 | PCG-26 | ST-Ericsson | john.mattsson@ericsson.com | Rel-12 | SP-51 | Maurice | Public Safety (I-A) |  |  | PCG-27 | SP-53 |
| 545 | 142.6 | Deleted - CT1 part for Security aspects of Public Warning System | 328d? | 2011-03-25 A | 2012-06-20 A | 100% | 2011-03-25 | 2012-06-20 | 328d? | finish no earlier than 2012-06-20 | C1 | 2624h | 2624h | PWS_Sec-del4 | PCG-26 | ST-Ericsson | mikael.wass@ericsson.com | Rel-12 | SP-51 | Frederic | Public Safety (I-A) |  |  | PCG-29 | SP-56 |
| 546 | 142.7 | Deleted - RAN2 part for Security aspects of Public Warning System | 128d? | 2011-03-25 A | 2011-09-16 A | 100% | 2011-03-25 | 2011-09-16 | 128d? | start no earlier than 2011-03-25 | R2 | 1024h | 1024h | PWS_Sec-del5 | PCG-26 | ST-Ericsson | john.mattsson@ericsson.com | Rel-12 | SP-51 | Yong-Jun | Public Safety (I-A) |  |  | PCG-27 | RP-53 |
| 547 | 143 | Security enhancements for usage of Generic Bootstrapping Architecture (GBA) from the browser (Stage 2) | 536d? | 2011-06-08 A | 2013-06-20 A | 100% | 2011-06-08 | 2013-06-19 | 536d? | finish no earlier than 2013-06-19 | S3 | 4256h | 4256h | Web_GBA | PCG-27 | Nokia | Silke.Holtmanns@nokia.com | Rel-12 | SP-52 | Mirko |  | Web_GBA |  |  |  |

Notes:
- 518: - / Impacted TSs and TRs: Stage 2/3
- 519: SP#63 completed / Impacted TSs and TRs: 23.402
- 520: CP#62 updated WID CP-130580=>CP-130715 / Impacted TSs and TRs: Stage 3
- 521: CP#65 completion 09/14=>12/14. Exception in CP-140608. TS 24.244 v200 for Approval. LM: 95->100% / Impacted TSs and TRs: 24.302, New TS 24.244 (WLAN control plane protocol for trusted WLAN access to EPC)
- 522: CP#65 completed / Impacted TSs and TRs: 29.273, 29.274, 29.275
- 523: Linked to TR 23.890 Study on Optimized Offloading to WLAN in 3GPP-RAT mobility (FS_WORM), SAE for support for non-3GPP accesses, Multi-Access PDN Connectivity (MAPCON), IP Flow Mobility and Seamless WLAN Offload (IFOM), CS Fallback in EPS (SAES-CSFB) / Impacted TSs and TRs: Stage 2/3
- 524: SP#62 completed / Impacted TSs and TRs: 23.272, 23.401, 23.402
- 525: CP#64 completed. Stage 3 enabling differentiation/prioritization of 3GPP RATs relative to WLAN for traffic flow routing based on Inter-System Routing Policies / Impacted TSs and TRs: 24.302, 24.312
- 526: Rel-11 Network Provided Location Information for IMS (NWK-PL2IMS) covers the case where UE is served by a 3GPP RAN. This WI covers the case where the UE is served by a TWAN / Impacted TSs and TRs: Stage 2/3
- 527: SP#63 completed / Impacted TSs and TRs: 23.203, 23.228, 23.402
- 528: - / Impacted TSs and TRs: Stage 3
- 529: CP#64 completed / Impacted TSs and TRs: 29.212, 29.214
- 530: CP#65 completed / Impacted TSs and TRs: 24.229
- 531: CP#65 completed / Impacted TSs and TRs: 29.273, 29.274, 29.275, 29.328, 29.329
- 532: - / Impacted TSs and TRs: Stage 2/3
- 533: SP#63 completed / Impacted TSs and TRs: 23.060, 23.203, 23.401
- 534: SP#65 New WID approved & completed. Introduction of Presence Reporting Areas for Charging / Impacted TSs and TRs: 32.251, 32.298, 32.299
- 535: Specify Stage 3 procedures to support the ULI signalling optimizations / Impacted TSs and TRs: Stage 3
- 536: CP#64 completed / Impacted TSs and TRs: 29.212, 29.213
- 537: CP#65 completed / Impacted TSs and TRs: 23.008, 29.060, 29.274
- 538: SEC12 is an umbrella Feature for Security related TEI12 type of changes that are not part of any other dedicated feature / Impacted TSs and TRs: Stage 2/3
- 539: -
- 540: SP#57 completed. Specify reqs to protect against false PWS Warning Notifications (Optional as not all regions/countries require this functionality). WID covers all objectives in SA3 PWS_Sec Feature-level WID replacing the original Stage 1 UID_510154 / Impacted TSs and TRs: 22.268
- 541: SP#65 completed. TR 33.969v100 for 1-step Approval. Former TR 33.869 changed to 33.969. / Impacted TSs and TRs: New TR 33.869 changed to 33.969
- 542: SP#64 stopped / Impacted TSs and TRs: New TS 33.269
- 543: Completed in Rel-9 under PWS. SP#55 stopped, Stage 1 requirements removed from Rel-9 onwards (SP-120172). AP 55/1: SA1 to align Stage 1 PWS security for Rel-12. SA1 new WID PWS Security UID_560029. / Impacted TSs and TRs: 22.268
- 544: SP#53 work stopped as already done in previous releases / Impacted TSs and TRs: 23.401
- 545: TSG#56 work stopped. SP#56 updated WID SP-110223=>SP-120334 (removed all but SA3 impacted specs) / Impacted TSs and TRs: 23.041
- 546: RP#53 work stopped as no WI in RAN / Impacted TSs and TRs: 36.331
- 547: SP#60 completed / Impacted TSs and TRs: 33.220, 33.222, New TR 33.823

| ID | WBS | Task | Duration | Start | Finish | Complete | Remaining | Baseline start | Baseline finish | Baseline duration | Total slack | Constraint | Resources | Work | Actual work | Acronym | PCG approved | WI rapporteur name | Release | TSG approved | MCC resp | Acronym_3GU_Export | Status Report |
| --- | --- | --- | --- | --- | --- | --- | --- | --- | --- | --- | --- | --- | --- | --- | --- | --- | --- | --- | --- | --- | --- | --- | --- |
| 548 | 144 | **Extended IMS media plane security features** | 657d? | 2012-06-20 A | 2014-12-09 A | 100% |  | 2012-06-20 | 2014-12-10 | 655d? |  |  | S3; C4; C1; C3; IETF | 73585.2h | 73585.2h | eMEDIASEC | PCG-29 | Vodafone | Rel-12 | SP-56 | Mirko | eMEDIASEC |  |
| 549 | 144.1 | SA3 part of Extended IMS media plane security features (Stage 2) | 530d? | 2012-06-20 A | 2014-06-18 A | 100% |  | 2012-06-20 | 2014-06-18 | 530d? |  | finish no earlier than 2014-06-18 | S3 | 4185.2h | 4185.2h | eMEDIASEC-SA3 | PCG-29 | Vodafone | Rel-12 | SP-56 | Mirko |  |  |
| 550 | 144.2 | (IETF) SA3 part of Extended IMS media plane security features (RFC 7345) | 591d? | 2012-06-20 A | 2014-09-12 A | 100% |  | 2012-06-20 | 2014-12-10 | 654d? |  | finish no earlier than 2014-09-12 | S3-IETF | 4728h | 4728h | eMEDIASECSA3IETF | PCG-31 | christer.holmberg@ericsson.com | Rel-12 | SP-61 |  |  |  |
| 551 | 144.3 | **CT aspects of Extended IMS media plane security features (Stage 2/3)** | 528d? | 2012-12-13 A | 2014-12-09 A | 100% |  | 2012-12-13 | 2014-12-05 | 523d? |  |  | C4; C1; C3; IETF | 38392h | 38392h | eMEDIASEC-CT | PCG-30 | Alcatel-Lucent | Rel-12 | CP-58 | Kimmo | eMEDIASEC-CT |  |
| 552 | 144.3.1 | TR on Extended IMS media plane security features and TCP related NAT traversal support; IMS H.248 profiles aspects | 461d? | 2012-12-13 A | 2014-09-11 A | 100% |  | 2012-12-13 | 2014-09-12 | 461d? |  | finish no earlier than 2014-09-12 | C4 | 3688h | 3688h | eMEDIASEC-CT4TR | PCG-30 | Alcatel-Lucent | Rel-12 | CP-58 | Kimmo |  |  |
| 553 | 144.3.2 | CT4 part of CT aspects of Extended IMS media plane security features | 520d? | 2012-12-19 A | 2014-12-09 A | 100% |  | 2012-12-19 | 2014-09-12 | 458d? |  | finish no earlier than 2014-12-09 | C4 | 4160h | 4160h | eMEDIASEC-CT4 | PCG-30 | Alcatel-Lucent | Rel-12 | CP-58 | Kimmo |  | CP-140479 |
| 554 | 144.3.3 | (IETF) CT4 part of Extended IMS media plane security features (RFC 7345) | 457d? | 2012-12-18 A | 2014-09-11 A | 100% |  | 2012-12-18 | 2014-12-05 | 519d? |  | finish no earlier than 2014-09-11 | C4-IETF | 3656h | 3656h | eMEDIASEC-CT4_7345 | PCG-32 | christer.holmberg@ericsson.com | Rel-12 | CP-62 |  |  |  |
| 555 | 144.3.4 | (IETF) CT4 part of Extended IMS media plane security features (draft-schwarz-mmusic-sdp-for-gw) | 129d? | 2014-06-12 A | 2014-12-09 A | 100% |  | 2014-06-12 | 2014-12-05 | 127d? |  | finish no earlier than 2014-12-09 | C4-IETF | 1032h | 1032h | eMEDIASEC-CT4_schw | PCG-33 | christer.holmberg@ericsson.com | Rel-12 | CP-64 |  |  |  |
| 556 | 144.3.5 | CT1 part of CT aspects of Extended IMS media plane security features | 463d? | 2012-12-13 A | 2014-09-11 A | 100% |  | 2012-12-13 | 2014-09-12 | 463d? |  | finish no earlier than 2014-09-12 | C1 | 3696h | 3696h | eMEDIASEC-CT1 | PCG-30 | Alcatel-Lucent | Rel-12 | CP-58 | Frederic |  |  |
| 557 | 144.3.6 | (IETF) CT1 part of Extended IMS media plane security features (RFC 7345) | 137d? | 2014-03-06 A | 2014-09-11 A | 100% |  | 2014-03-06 | 2014-12-05 | 197d? |  | finish no earlier than 2014-09-11 | C1-IETF | 1096h | 1096h | eMEDIASEC-CT1_7345 | PCG-32 | christer.holmberg@ericsson.com | Rel-12 | CP-62 |  |  |  |
| 558 | 144.3.7 | CT3 part of CT aspects of Extended IMS media plane security features | 521d? | 2012-12-19 A | 2014-12-09 A | 100% |  | 2012-12-19 | 2014-06-13 | 394d? |  | finish no earlier than 2014-12-09 | C3 | 4168h | 4168h | eMEDIASEC-CT3 | PCG-30 | Alcatel-Lucent | Rel-12 | CP-58 | Adrian |  | CP-140569 |
| 559 | 145 | Lawful Interception in the 3GPP Rel-12 | 592d? | 2012-09-17 A | 2014-12-12 | 75% | 148d? | 2012-09-17 | 2014-09-12 | 526d? | 654d | finish no earlier than 2014-12-12 | S3 | 4736h | 3552h | LI12 | PCG-29 | PIDS, Alcatel-Lucent | Rel-12 | SP-57 | Mirko | LI12 |  |
| 560 | 146 | **Tunneling of UE Services over Restrictive Access Networks (Stage 2/3)** | 401d? | 2012-12-13 A | 2014-06-18 A | 100% |  | 2012-12-13 | 2014-06-18 | 401d? |  |  | S3; C1 | 11662.5h | 11662.5h | TURAN | PCG-30 | Acme Packet | Rel-12 | SP-58 | Mirko | TURAN |  |
| 561 | 146.1 | SA3 part of Tunneling of UE Services over Restrictive Access Networks (Stage 2/3) | 400d? | 2012-12-13 A | 2014-06-18 A | 100% |  | 2012-12-13 | 2014-06-18 | 400d? |  | finish no earlier than 2014-06-18 | S3 | 3168h | 3168h | TURAN-SA3 | PCG-30 | Acme Packet | Rel-12 | SP-58 | Mirko |  |  |
| 562 | 146.2 | CT aspects of Tunneling of UE Services over Restrictive Access Networks (Stage 3) | 264d? | 2013-06-14 A | 2014-06-13 A | 100% |  | 2013-06-14 | 2014-06-13 | 264d? |  | finish no earlier than 2014-06-13 | C1 | 2094.45h | 2094.45h | TURAN-CT | PCG-31 | Huawei | Rel-12 | CP-60 | Frederic | TURAN-CT |  |
| 563 | 147 | Specification of the TUAK Algorithm Set | 139d? | 2013-12-09 A | 2014-06-18 A | 100% |  | 2013-12-09 | 2014-06-18 | 139d? |  | finish no earlier than 2014-06-18 | S3 | 1112h | 1112h | STAS | PCG-32 | Vodafone | Rel-12 | SP-62 | Mirko | STAS |  |
| 564 | 148 | **Codec for Enhanced Voice Services** | 1248d? | 2010-03-25 A | 2014-12-12 | 93% | 86.92d? | 2010-03-25 | 2014-12-12 | 1245d? | 654d |  | S4; S1; C4; C1; C3 | 72736h | 21368.8h | EVS_codec | PCG-24 | Huawei | Rel-12 | SP-47 | Paolo | EVS_codec |  |
| 565 | 148.1 | Stage 1 for Codec for Enhanced Voice Services | 1d? | 2010-03-25 A | 2010-03-25 A | 100% |  | 2010-03-25 | 2010-03-25 | 1d? |  | start no earlier than 2010-03-25 | S1 | 8h | 8h | EVS_codec-SA1 | PCG-24 | Huawei | Rel-12 | SP-47 | Paolo |  |  |
| 566 | 148.2 | Stage 2/3 for Codec for Enhanced Voice Services | 1240d? | 2010-03-25 A | 2014-12-12 | 95% | 62d? | 2010-03-25 | 2014-09-17 | 1178d? | 654d | finish no earlier than 2014-12-12 | S4 | 9896h | 9400h | EVS_codec-SA4 | PCG-24 | Huawei | Rel-12 | SP-47 | Paolo |  | SP-140467 |
| 567 | 148.3 | TR on Performance characterization of Codec for Enhanced Voice Services | 1239d? | 2010-03-25 A | 2014-12-12 | 90% | 123.9d? | 2010-03-25 | 2014-12-12 | 1239d? | 654d | finish no earlier than 2014-12-12 | S4 | 9888h | 8896.8h | EVS_codec-SA4TR | PCG-24 | Huawei | Rel-12 | SP-47 | Paolo |  | SP-140467 |
| 568 | 148.4 | **CT impacts of codec for Enhanced Voice Services** | 63d? | 2014-09-16 A | 2014-12-09 A | 100% |  |  |  |  |  |  | C4; C1; C3 | 3024h | 3024h | EVS_codec-CT | PCG-33 | Nokia Networks | Rel-12 | CP-65 |  | EVS_codec-CT |  |
| 569 | 148.4.1 | CT4 part of CT impacts of codec for Enhanced Voice Services | 63d? | 2014-09-16 A | 2014-12-09 A | 100% |  |  |  |  |  | finish no earlier than 2014-12-09 | C4 | 504h | 504h | EVS_codec-CT4 | PCG-33 | Nokia Networks | Rel-12 | CP-65 |  |  | CP-140478 |
| 570 | 148.4.2 | CT1 part of CT impacts of codec for Enhanced Voice Services | 63d? | 2014-09-16 A | 2014-12-09 A | 100% |  |  |  |  |  | finish no earlier than 2014-12-09 | C1 | 504h | 504h | EVS_codec-CT1 | PCG-33 | Nokia Networks | Rel-12 | CP-65 |  |  | CP-140618 |
| 571 | 148.4.3 | CT3 part of CT impacts of codec for Enhanced Voice Services | 63d? | 2014-09-16 A | 2014-12-09 A | 100% |  |  |  |  |  | finish no earlier than 2014-12-09 | C3 | 504h | 504h | EVS_codec-CT3 | PCG-33 | Nokia Networks | Rel-12 | CP-65 |  |  | CP-140560 |

Notes:
- 548: Triggered by Rel-11 TR 33.829 Study on Extended IMS media plane security features (FS_eMEDIASEC) / Impacted TSs and TRs: Stage 2/3 / WI rapporteur e-mail: Aguibou.Barry@vodafone.com
- 549: SP#64 completed / Impacted TSs and TRs: 33.328 / WI rapporteur e-mail: Aguibou.Barry@vodafone.com
- 550: SP#65 completed / Impacted TSs and TRs: RFC 7345 (was draft-ietf-mmusic-udptl-dtls) / WI rapporteur e-mail: christer.holmberg@ericsson.com
- 551: - / Impacted TSs and TRs: Stage 2/3 / WI rapporteur e-mail: bruno.landais@alcatel-lucent.com
- 552: CP#65 completed. TR 29.828v200 for Approval / Impacted TSs and TRs: New TR 29.828 / WI rapporteur e-mail: bruno.landais@alcatel-lucent.com
- 553: CP#65 completion 09/14=>12/14. Exception in CP-140479. LM: 90->100 / Impacted TSs and TRs: 23.334, 29.334, 29.238, 23.333, 29.333 / WI rapporteur e-mail: bruno.landais@alcatel-lucent.com
- 554: CP#65 completed / Impacted TSs and TRs: RFC 7345 (was draft-ietf-mmusic-udptl-dtls) / WI rapporteur e-mail: christer.holmberg@ericsson.com
- 555: Work in progress / Impacted TSs and TRs: draft-schwarz-mmusic-sdp-for-gw / WI rapporteur e-mail: christer.holmberg@ericsson.com
- 556: CP#65 completed / Impacted TSs and TRs: 23.218, 24.147, 24.229, 24.247 / WI rapporteur e-mail: bruno.landais@alcatel-lucent.com
- 557: CP#65 completed / Impacted TSs and TRs: RFC 7345 (was draft-ietf-mmusic-udptl-dtls) / WI rapporteur e-mail: christer.holmberg@ericsson.com
- 558: CP#65 completion 06/14=>12/14. Level 100%=>80%. Exception in CP-140569. CP#64 completed. LM: 80->100 / Impacted TSs and TRs: 29.162 / WI rapporteur e-mail: bruno.landais@alcatel-lucent.com
- 559: - / Impacted TSs and TRs: 33.106, 33.107, 33.108 / WI rapporteur e-mail: Koen Jaspers (k.b.jaspers@minjus.nl), terry.jacobson@alcatel-lucent.com
- 560: Linked to Rel-12 SMURFs. Related to TS 22.278 (EPS) cl.7.1.8 Service Reachability (Firewall traversal for IP based services for non-3GPP access), TS 22.228 (IMS) cl.5 (support Firewall traversal), TR 33.830 (Study on Firewall traversal) / Impacted TSs and TRs: Stage 2/3 / WI rapporteur e-mail: Prashant Kumar (PKumar@acmepacket.com)
- 561: SP#64 completed / Impacted TSs and TRs: 33.203, 33.402 / WI rapporteur e-mail: Prashant Kumar (PKumar@acmepacket.com)
- 562: CP#64 completed. Stage 3 for 2 new SA3 solutions for firewall traversal: 1) UE access to PLMN IP-based services via restrictive non-3GPP Ans, 2) UE access to IMS services via restrictive ANs / Impacted TSs and TRs: 24.229, 24.302, New TS 24.322 / WI rapporteur e-mail: Haitao Wei (weihaitao@huawei.com)
- 563: SP#64 completed. Triggered by SP-130602 LS from ETSI SAGE (TUAK as alternative to Milenage) / Impacted TSs and TRs: New TSs (35.231, 35.232, 35.233) / WI rapporteur e-mail: aguibou.barry@vodafone.com
- 564: Triggered by UID_370045 Study on enhanced voice service requirements for EPS (TR 22.813) / WI rapporteur e-mail: lei.miao@huawei.com
- 565: SP#47 completed / Impacted TSs and TRs: 22.173 / WI rapporteur e-mail: lei.miao@huawei.com
- 566: SP#65 completion 09/14=>12/14. Exception in SP-140467. TS 26.441v200 for Approval. TSs 26.442/44/45/46/47/48/49/50/51v100 for 1-step Approval. Ongoing TS 26.443 EVS Codec ANSI C code (floating point). LM: 90->95 / Impacted TSs and TRs: 26.114, New TS (26.441, 26.442, 26.443, 26.444, 26.445, 26.446, 26.447, 26.448, 26.449, 26.450, 26.451) / WI rapporteur e-mail: lei.miao@huawei.com
- 567: SP#65 completion 09/14=>12/14. Ongoing TR 26.952 EVS Codec Performance Characterization. Exception in SP-140467 / Impacted TSs and TRs: New TR 26.952 / WI rapporteur e-mail: lei.miao@huawei.com
- 568: Stage 3; WID: CP-140492-> CP-140800 / WI rapporteur e-mail: Jan.Kall@nsn.com
- 569: CP#65 exception in CP-140478. LM: 0->100; WID: CP-140492-> CP-140800 / Impacted TSs and TRs: 23.334, 29.232, 29.238, 29.332, 29.333, 29.334 / WI rapporteur e-mail: Jan.Kall@nsn.com
- 570: CP#65 exception in CP-140618. LM: 0->100%; WID: CP-140492-> CP-140800 / Impacted TSs and TRs: 24.229 / WI rapporteur e-mail: Jan.Kall@nsn.com
- 571: CP#65 exception in CP-140560. LM: 20->100; WID: CP-140492-> CP-140800 / Impacted TSs and TRs: 29.163, 29.292 / WI rapporteur e-mail: Jan.Kall@nsn.com

| ID | WBS | Task | Duration | Start | Finish | Complete | Remaining | Baseline start | Baseline finish | Baseline duration | Total slack | Constraint | Resources | Work | Actual work | Acronym | PCG approved | WI rapporteur name | WI rapporteur e-mail | Release | TSG approved | MCC resp | Acronym_3GU_Export | Impacted TSs and TRs | Status Report |
| --- | --- | --- | --- | --- | --- | --- | --- | --- | --- | --- | --- | --- | --- | --- | --- | --- | --- | --- | --- | --- | --- | --- | --- | --- | --- |
| 572 | 149 | **Coordination of Video Orientation** | 400d? | 2012-06-07 A | 2013-12-06 A | 100% |  | 2012-06-07 | 2013-12-06 | 400d? |  |  | S4; C4; C1; C3 | 20496.8h | 20496.8h | CVO | PCG-29 | Ericsson | frederic.gabin@ericsson.com | Rel-12 | SP-56 | Paolo | CVO |  |  |
| 573 | 149.1 | SA4 part of Coordination of Video Orientation | 196d? | 2012-06-07 A | 2013-03-06 A | 100% |  | 2012-06-07 | 2013-03-06 | 196d? |  | finish no earlier than 2013-03-06 | S4 | 1560h | 1560h | CVO-SA4 | PCG-29 | Ericsson | frederic.gabin@ericsson.com | Rel-12 | SP-56 | Paolo |  | 26.114, 26.141, 26.234, 26.346 |  |
| 574 | 149.2 | **CT aspects of Coordination of Video Orientation** | 129d? | 2013-06-14 A | 2013-12-06 A | 100% |  | 2013-06-14 | 2013-12-06 | 129d? |  |  | C4; C1; C3 | 6136.8h | 6136.8h | CVO-CT | PCG-31 | Ericsson | nevenka.biondic@ericsson.com | Rel-12 | CP-60 | Kimmo | CVO-CT | Stage 2/3 |  |
| 575 | 149.2.1 | CT4 part of CT aspects of Coordination of Video Orientation | 128.05d? | 2013-06-14 A | 2013-12-06 A | 100% |  | 2013-06-14 | 2013-12-06 | 128.05d? |  | finish no earlier than 2013-12-06 | C4 | 1008.4h | 1008.4h | CVO-CT4 | PCG-31 | Ericsson | nevenka.biondic@ericsson.com | Rel-12 | CP-60 | Kimmo |  | 23.333, 23.334, 29.238, 29.332, 29.333, 29.334 |  |
| 576 | 149.2.2 | CT1 part of CT aspects of Coordination of Video Orientation | 129d? | 2013-06-14 A | 2013-12-06 A | 100% |  | 2013-06-14 | 2013-12-06 | 129d? |  | finish no earlier than 2013-12-06 | C1 | 1016h | 1016h | CVO-CT1 | PCG-31 | Ericsson | nevenka.biondic@ericsson.com | Rel-12 | CP-60 | Frederic |  | 24.229 |  |
| 577 | 149.2.3 | CT3 part of CT aspects of Coordination of Video Orientation | 127.05d? | 2013-06-14 A | 2013-12-06 A | 100% |  | 2013-06-14 | 2013-12-06 | 127.05d? |  | finish no earlier than 2013-12-06 | C3 | 1016.4h | 1016.4h | CVO-CT3 | PCG-31 | Ericsson | nevenka.biondic@ericsson.com | Rel-12 | CP-60 | Adrian |  | 29.162, 29.163 |  |
| 578 | 150 | **High Efficiency Video Coding** | 594d? | 2012-09-12 A | 2014-12-05 | 81% | 115.23d? | 2012-09-12 | 2014-12-05 | 591d? | 659d |  | S4; IETF | 21576h | 13508h | HEVC | PCG-29 | Qualcomm | Ye-Kui Wang (yekuiw@qti.qualcomm.com) | Rel-12 | SP-57 | Paolo | HEVC |  |  |
| 579 | 150.1 | TR on Evaluation of High Efficiency Video Coding for 3GPP Services | 464d? | 2012-09-12 A | 2014-06-19 A | 100% |  | 2012-09-12 | 2014-06-19 | 464d? |  | finish no earlier than 2014-06-18 | S4 | 3704h | 3704h | HEVC-SA4TR | PCG-29 | Qualcomm | Ye-Kui Wang (yekuiw@qti.qualcomm.com) | Rel-12 | SP-57 | Paolo |  | New TR 26.906 |  |
| 580 | 150.2 | High Efficiency Video Coding in 3GPP services PSS, MBMS, DASH, MMS, MTSI, IMS Messaging and Presence | 462d? | 2012-09-17 A | 2014-06-18 A | 100% |  | 2012-09-17 | 2014-06-18 | 462d? |  | finish no earlier than 2014-06-18 | S4 | 3688h | 3688h | HEVC-SA4 | PCG-29 | Qualcomm | Ye-Kui Wang (yekuiw@qti.qualcomm.com) | Rel-12 | SP-57 | Paolo |  | 26.114, 26.140, 26.141, 26.234, 26.244, 26.247, 26.346 |  |
| 581 | 150.3 | (IETF) High Efficiency Video Coding | 587d? | 2012-09-17 A | 2014-12-05 | 50% | 293.5d? | 2012-09-17 | 2014-12-05 | 587d? | 659d | finish no earlier than 2014-12-05 | S4-IETF | 4696h | 2348h | HEVC-SA4IETF | PCG-32 | Thomas Stockhammer | Thomas Stockhammer | Rel-12 | CP-63 |  |  | draft-ietf-payload-rtp-h265 |  |
| 582 | 151 | Mobile stereoscopic 3D services extensions | 200d? | 2012-12-12 A | 2013-09-11 A | 100% |  | 2012-12-12 | 2013-09-11 | 200d? |  | finish no earlier than 2013-09-11 | S4 | 1568h | 1568h | M3DV_Ext | PCG-30 | Huawei | lukasz.kondrad@huawei.com | Rel-12 | SP-58 | Paolo | M3DV_Ext | 26.114, 26.245, 26.247, 26.430 |  |
| 583 | 152 | **IMS-based Streaming and Download Delivery Enhancements** | 329d? | 2012-12-12 A | 2014-03-07 A | 100% |  | 2012-12-12 | 2014-03-07 | 329d? |  |  | S4 | 7800h | 7800h | IMS_SDE | PCG-30 | Intel | ozgur.oyman@intel.com | Rel-12 | SP-58 | Paolo | IMS_SDE |  |  |
| 584 | 152.1 | TR on IMS-based Streaming and Download Delivery Enhancements | 326d? | 2012-12-12 A | 2014-03-07 A | 100% |  | 2012-12-12 | 2014-03-07 | 326d? |  | finish no earlier than 2014-03-07 | S4 | 2584h | 2584h | IMS_SDE-SA4TR | PCG-30 | Intel | ozgur.oyman@intel.com | Rel-12 | SP-58 | Paolo |  | new TR 26.827 |  |
| 585 | 152.2 | Specification on IMS-based Streaming and Download Delivery Enhancements | 327d? | 2012-12-13 A | 2014-03-07 A | 100% |  | 2012-12-13 | 2014-03-07 | 327d? |  | finish no earlier than 2014-03-07 | S4 | 2584h | 2584h | IMS_SDE-SA4 | PCG-30 | Intel | ozgur.oyman@intel.com | Rel-12 | SP-58 | Paolo |  | 26.237 |  |
| 586 | 153 | **Acoustic Requirements and Test methods for IMS-based conversational speech services over LTE** | 532d? | 2012-12-12 A | 2014-12-12 A | 100% |  | 2012-12-12 | 2014-09-17 | 467d? |  |  | S4 | 14224h | 14224h | ART_LTE | PCG-30 | Qualcomm | Andre Schevciw (aschevci@qualcomm.com) | Rel-12 | SP-58 | Paolo | ART_LTE | Stage 3 |  |
| 587 | 153.1 | Acoustic Requirements and Test methods for IMS-based conversational speech services over LTE - NarrowBand and WideBand aspects | 265d? | 2012-12-12 A | 2013-12-11 A | 100% |  | 2012-12-12 | 2013-12-11 | 265d? |  | finish no earlier than 2013-12-11 | S4 | 2088h | 2088h | ART_LTE-NBWB | PCG-30 | Sony Mobile Communications | peter.isberg@sonymobile.com | Rel-12 | SP-58 | Paolo | ART_LTE-NBWB | 26.131, 26.132 |  |
| 588 | 153.2 | Acoustic Requirements and Test methods for IMS-based conversational speech services over LTE - UE Delay aspects | 462d? | 2012-12-12 A | 2014-09-17 A | 100% |  | 2012-12-12 | 2014-09-17 | 461d? |  | finish no earlier than 2014-09-17 | S4 | 3696h | 3696h | ART_LTE-UED | PCG-30 | AT&T, Orange | luisa.marchetto@att.com, stephane.ragot@orange.com | Rel-12 | SP-58 | Paolo | ART_LTE-UED | 26.131, 26.132 |  |
| 589 | 153.3 | Acoustic Requirements and Test methods for IMS-based conversational speech services over LTE - Super wideband and fullband aspects | 523d? | 2012-12-12 A | 2014-12-12 A | 100% |  | 2012-12-12 | 2014-09-17 | 461d? |  | finish no earlier than 2014-12-12 | S4 | 4184h | 4184h | ART_LTE-SUPER | PCG-30 | Sony Mobile Communications | peter.isberg@sonymobile.com | Rel-12 | SP-58 | Paolo | ART_LTE-SUPER | 26.131, 26.132 | SP-140470 |
| 590 | 154 | **MBMS Improvements** | 471d? | 2013-03-06 A | 2014-12-12 A | 100% |  | 2013-03-06 | 2014-09-17 | 406d? |  |  | S4 | 18584h | 18584h | MI | PCG-30 | Ericsson | eric.turcotte@ericsson.com | Rel-12 | SP-59 | Paolo | MI |  | SP-140471 |
| 591 | 154.1 | TR on Enhanced MBMS Operation | 463d? | 2013-03-06 A | 2014-12-12 A | 100% |  | 2013-03-06 | 2014-09-17 | 401d? |  | finish no earlier than 2014-12-12 | S4 | 3704h | 3704h | MI-EMO-SA4TR | PCG-30 | Huawei | Zhiming Li (lizhiming@huawei.com) | Rel-12 | SP-59 | Paolo |  | New TR 26.848 | SP-140471 |
| 592 | 154.2 | Enhanced MBMS Operation | 463d? | 2013-03-06 A | 2014-12-12 A | 100% |  | 2013-03-06 | 2014-09-17 | 401d? |  | finish no earlier than 2014-12-12 | S4 | 3704h | 3704h | MI-EMO-SA4 | PCG-30 | Huawei | Zhiming Li (lizhiming@huawei.com) | Rel-12 | SP-59 | Paolo | MI-EMO | 26.247, 26.346 | SP-140471 |
| 593 | 154.3 | TR on MBMS operation on Demand | 463d? | 2013-03-06 A | 2014-12-12 A | 100% |  | 2013-03-06 | 2014-09-17 | 401d? |  | finish no earlier than 2014-12-12 | S4 | 3704h | 3704h | MI-MooD-SA4TR | PCG-30 | Qualcomm | Charles Lo (clo@qti.qualcomm.com) | Rel-12 | SP-59 | Paolo |  | New TR 26.849 | SP-140471 |
| 594 | 154.4 | MBMS operation on Demand | 463d? | 2013-03-06 A | 2014-12-12 A | 100% |  | 2013-03-06 | 2014-09-17 | 401d? |  | finish no earlier than 2014-12-12 | S4 | 3704h | 3704h | MI-MooD-SA4 | PCG-30 | Qualcomm | Charles Lo (clo@qti.qualcomm.com) | Rel-12 | SP-59 | Paolo | MI-MooD | 26.346 | SP-140471 |
| 595 | 155 | End-to-End Multimedia Telephony Service for IMS (MTSI) extensions | 406d? | 2013-03-06 A | 2014-09-16 A | 100% |  | 2013-03-06 | 2015-03-13 | 533d? |  | finish no earlier than 2014-09-17 | S4 | 3248h | 3248h | E2EMTSI | PCG-30 | Ericsson | tomas.frankkila@ericsson.com | Rel-12 | SP-59 | Paolo | E2EMTSI | 26.114 |  |
| 596 | 156 | Video Coding Enhancements in IMS Messaging and Presence | 64d? | 2013-12-11 A | 2014-03-07 A | 100% |  | 2013-12-11 | 2014-03-07 | 64d? |  | finish no earlier than 2014-03-07 | S4 | 504h | 504h | VCEIMP | PCG-32 | Ericsson | frederic.gabin@ericsson.com | Rel-12 | SP-62 | Paolo | VCEIMP | 26.141 |  |
| 597 | 157 | Video Telephony Robustness Improvements | 66d? | 2014-06-18 A | 2014-09-16 A | 100% |  | 2014-06-18 | 2014-09-17 | 66d? |  | finish no earlier than 2014-09-17 | S4 | 528h | 528h | VTRI | PCG-33 | Qualcomm | Muhammed Coban (mcoban@qti.qualcomm.com) | Rel-12 | SP-64 |  | VTRI | 26.114 |  |

Notes:
- 572: CP#62 completed. Resolve backward compatible video orientation mis-alignment in MTSI real-time video communication via interaction between MTSI video clients at call setup & during mid-call of the video orientation for correct local rendering
- 573: SP#59 completed. Resolve backward compatible video orientation mis-alignment in MTSI real-time video communication via interaction between MTSI video clients at call setup & during mid-call of the video orientation for correct local rendering
- 574: Complete CVO support (both, basic 2 bit orientation and additional option for extra 6 bit granularity) within CN protocols/procedures for IMS nodes, e.g. IMS ALG/AGW,IBCF/TrGW,MRFC/MRFP & add support of CVO-related SDP attributes to be negotiated by UE
- 575: CP#62 completed
- 576: CP#62 completed
- 577: CP#62 completed
- 578: Specify the support of HEVC in 3GPP services (PSS, DASH, MTSI, MMS, MBMS, IMS Messaging and Presence)
- 579: SP#64 completed. TR 26.906v200 for Approval
- 580: SP#64 completed
- 581: Submitted to IESG for publication
- 582: SP#61 completed. Related to Rel-11 Study On Mobile 3D Video Coding (FS_M3DVC) TR 26.905 and Rel-11 Mobile 3D Video Coding (M3DVC)
- 583: Provide an extension of IMS based PSS and MBMS user services
- 584: SP#63 completed. Identify use cases and requirements based on Rel-10/11 PSS and MBMS functionality to be addressed for IMS-based streaming and download enhancements
- 585: SP#63 completed. Develop procedures towards enabling the IMS-based extensions of the identified use cases in TS 26.237. Refine existing MBMS download procedures to enable IMS-based MBMS file repair with the use of conventional HTTP web servers.
- 586: Triggered by Rel-12 Feature Codec for Enhanced Voice Services (EVS_codec) UID_470030. Need for super wideband acoustic requirements and test methods
- 587: SP#62 completed
- 588: SP#65 completed
- 589: SP#65 completion 09/14=>12/14. Exception in SP-140470. LM: 65->100
- 590: Stage 3 based on existing Stage 2 in TS 23.246 MBMS Architecture and functional description
- 591: SP#65 completion 09/14=>12/14. Exception in SP-140471. SP#63 TR 26.848v100 for Information. LM: 85->100
- 592: SP#65 completion 09/14=>12/14. Exception in SP-140471. LM: 85->100
- 593: SP#65 completion 09/14=>12/14. Exception in SP-140471. SP#63 TR 26.849v100 for Information. LM: 75->100
- 594: SP#65 completion 09/14=>12/14. Exception in SP-140471. LM: 75->100
- 595: SP#65 completed. Updated WID SP-130670=>SP-140594. Reduced Scope & Objectives. Moved work on new TR 26.924, etc. to Rel-13. Co-ordinate with CT1/3/4. Linked to SA4 Rel-7 Media handling and interaction in MTSI (MTSI-MHI) UID_7040
- 596: SP#63 completed. Linked to Rel-6 Media Codecs and Formats for IMS Messaging and Presence (PRESNC-COFIMP) UID_34025. Work item which gave rise to TS 26.141
- 597: SP#65 completed. Linked to E2EMTSI (End-to-End Multimedia Telephony Service for IMS extensions). Add Reqs&guidelines for video telephony robustness to improve service perf. for PLI, Generic NACK, and FIR messages within overall bitrate limit

| ID | WBS | Task | Duration | Start | Finish | Complete | Baseline start | Baseline finish | Baseline duration | Constraint | Resources | Work | Actual work | Acronym | PCG approved | Release | TSG approved | MCC resp | Acronym_3GU_Export | Special Focus Doc | WI rapporteur name | WI rapporteur e-mail | Status Report |
| --- | --- | --- | --- | --- | --- | --- | --- | --- | --- | --- | --- | --- | --- | --- | --- | --- | --- | --- | --- | --- | --- | --- | --- |
| 598 | 158 | **Rel-12 Operations, Administration, Maintenance and Provisioning (OAM&P)** | 857d? | 2011-09-21 A | 2014-12-12 A | 100% | 2011-09-21 | 2014-09-17 | 792d? |  | S5 | 58352.5h | 58352.5h | OAM12 | PCG-29 | Rel-12 | SP-56 | Mirko | OAM12 |  |  |  |  |
| 599 | 158.1 | **Rel-12 Self-Organizing Networks (SON) - OAM aspects** | 591d? | 2011-09-21 A | 2013-12-11 A | 100% | 2011-09-21 | 2013-12-11 | 591d? |  | S5 | 9408h | 9408h | OAM12-SON | PCG-29 | Rel-12 | SP-56 | Mirko | OAM12-SON | HNB, SON |  |  |  |
| 600 | 158.1.1 | Multi-vendor Plug and Play eNB connection to the network | 586d? | 2011-09-21 A | 2013-12-11 A | 100% | 2011-09-21 | 2013-12-11 | 586d? | finish no earlier than 2013-12-11 | S5 | 4680h | 4680h | SON-NM-MUPPET | PCG-29 | Rel-12 | SP-56 | Mirko | SON-NM-MUPPET | HNB, SON | NSN | anatoly.andrianov@nsn.com |  |
| 601 | 158.2 | **Compliance of 3GPP SA5 specifications to the NGMN Next Generation Converged Operations Requirements (NGCOR)** | 596d? | 2012-06-20 A | 2014-09-17 A | 100% | 2012-06-20 | 2014-09-17 | 595d? |  | S5 | 11616.5h | 11616.5h | OAM-NGMN_NGCOR | PCG-29 | Rel-12 | SP-56 | Mirko | OAM-NGMN_NGCOR |  | Huawei | christian.toche@huawei.com |  |
| 602 | 158.2.1 | Converged Management Model Alignment (Phase 2) | 593d? | 2012-06-20 A | 2014-09-17 A | 100% | 2012-06-20 | 2014-09-17 | 593d? | finish no earlier than 2014-09-17 | S5 | 4744h | 4744h | OAM-MODAL | PCG-29 | Rel-12 | SP-56 | Mirko | OAM-MODAL |  | NSN | olaf.pollakowski@nsn.com |  |
| 603 | 158.2.2 | 3GPP Fault Management Solution Profile for NGMN NGCOR | 266d? | 2012-06-20 A | 2013-06-19 A | 100% | 2012-06-20 | 2013-06-19 | 266d? | finish no earlier than 2013-06-19 | S5 | 2104.53h | 2104.53h | OAM-FMSP | PCG-29 | Rel-12 | SP-56 | Mirko | OAM-FMSP |  | Ericsson | thomas.tovinger@ericsson.com |  |
| 604 | 158.3 | **Network Management for 3GPP Interworking WLAN** | 793d? | 2011-09-21 A | 2014-09-17 A | 100% | 2011-09-21 | 2014-06-18 | 727d? |  | S5 | 17232h | 17232h | OAM-IWLAN | PCG-27 | Rel-12 | SP-53 | Mirko | OAM-IWLAN | WLAN | China Mobile | Chengang@chinamobile.com, lijian@chinamobile.com |  |
| 605 | 158.3.1 | Performance measurements part Network Management for 3GPP Interworking WLAN | 785d? | 2011-09-22 A | 2014-09-17 A | 100% | 2011-09-22 | 2014-06-18 | 720d? | finish no earlier than 2014-09-17 | S5 | 6272h | 6272h | OAM-IWLAN-SA5P | PCG-27 | Rel-12 | SP-53 | Mirko |  | WLAN | China Mobile | Chengang@chinamobile.com, lijian@chinamobile.com |  |
| 606 | 158.3.2 | NIM part Network Management for 3GPP Interworking WLAN | 585d? | 2011-09-21 A | 2013-12-11 A | 100% | 2011-09-21 | 2013-12-11 | 585d? | finish no earlier than 2013-12-11 | S5 | 4672h | 4672h | OAM-IWLAN-SA5NM | PCG-27 | Rel-12 | SP-53 | Mirko |  | WLAN | China Mobile | Chengang@chinamobile.com, lijian@chinamobile.com |  |
| 607 | 158.4 | **Rel-12 Network Infrastructure Management** | 267d? | 2013-12-11 A | 2014-12-12 A | 100% | 2013-12-11 | 2014-09-17 | 202d? |  | S5 | 5848h | 5848h | OAM12-NIM | PCG-30 | Rel-12 | SP-58 | Mirko | OAM12-NIM |  |  |  |  |
| 608 | 158.4.1 | Alarm quality improvements | 263d? | 2013-12-11 A | 2014-12-12 A | 100% | 2013-12-11 | 2014-09-17 | 201d? | finish no earlier than 2014-12-12 | S5 | 2104h | 2104h | OAM-AMI-SA5 | PCG-32 | Rel-12 | SP-62 | Mirko | OAM-AMI |  | TeliaSonera | tommy.berggren@teliasonera.com | SP-140544 |
| 609 | 158.4.2 | Radio Planning Tool (RPT) interface | 201d? | 2014-03-07 A | 2014-12-12 A | 100% | 2014-03-07 | 2014-09-17 | 139d? | finish no earlier than 2014-12-12 | S5 | 1608h | 1608h | OAM-RPTi-SA5 | PCG-32 | Rel-12 | SP-63 | Mirko | OAM-RPTi |  | Nokia Networks | olaf.pollakowski@nsn.com | SP-140546 |
| 610 | 158.5 | Deleted - Rel-12 Performance Management | 328d? | 2013-06-21 A | 2014-09-16 A | 100% | 2013-06-21 | 2014-09-17 | 328d? |  | S5 | 2624h | 2624h | OAM12-PM | PCG-30 | Rel-12 | SP-58 | Mirko | OAM12-PM |  |  |  |  |
| 611 | 158.6 | **OAM aspects of Network Sharing** | 267d? | 2013-12-11 A | 2014-12-12 A | 100% | 2013-12-11 | 2014-09-17 | 202d? |  | S5 | 6344h | 6344h | OAM-SHARE | PCG-32 | Rel-12 | SP-62 | Mirko | OAM-SHARE |  | Orange | jeanmichel.cornily@orange.com | SP-140545 |
| 612 | 158.6.1 | OAM aspects of Network Sharing - Concepts and high-level requirements | 263d? | 2013-12-11 A | 2014-12-12 A | 100% | 2013-12-11 | 2014-09-17 | 201d? | finish no earlier than 2014-12-12 | S5 | 2104h | 2104h | OAM-SHARE-SA5c | PCG-32 | Rel-12 | SP-62 | Mirko |  |  | Orange | jeanmichel.cornily@orange.com | SP-140545 |
| 613 | 158.6.2 | OAM aspects of Network Sharing - Impacts on existing specifications | 263d? | 2013-12-12 A | 2014-12-12 A | 100% | 2013-12-12 | 2014-09-17 | 201d? | finish no earlier than 2014-12-12 | S5 | 2104h | 2104h | OAM-SHARE-SA5imp | PCG-32 | Rel-12 | SP-62 | Mirko |  |  | Orange | jeanmichel.cornily@orange.com | SP-140545 |
| 614 | 159 | **Rel-12 Charging** | 402d? | 2012-12-12 A | 2014-06-18 A | 100% | 2012-12-12 | 2014-06-18 | 402d? |  | S5 | 10112h | 10112h | CH12 | PCG-29 | Rel-12 | SP-57 | Mirko | CH12 |  |  |  |  |
| 615 | 159.1 | Short Message Service - Service Center (SMS-SC) Offline Charging | 325d? | 2012-12-12 A | 2014-03-10 A | 100% | 2012-12-12 | 2014-03-07 | 325d? | finish no earlier than 2014-03-07 | S5 | 2592h | 2592h | SMS-SC-CH | PCG-30 | Rel-12 | SP-58 | Mirko | SMS-SC-CH |  | Alcatel-Lucent | maryse.gardella@alcatel-lucent.com |  |
| 616 | 159.2 | Charging per IP - Connectivity Access Network (IP-CAN) Session (Stage 2/3) | 201d? | 2013-09-12 A | 2014-06-18 A | 100% | 2013-09-12 | 2014-06-18 | 201d? | finish no earlier than 2014-06-18 | S5 | 1608h | 1608h | CHIPCAN | PCG-31 | Rel-12 | SP-61 | Mirko | CHIPS |  | Ericsson | david.shrader@ericsson.com |  |
| 617 | 159.3 | Charging using an Alternative Roaming Provider (Stage 2/3) | 202d? | 2013-09-12 A | 2014-06-18 A | 100% | 2013-09-12 | 2014-06-18 | 202d? | finish no earlier than 2014-06-18 | S5 | 1608h | 1608h | CHARP | PCG-31 | Rel-12 | SP-61 | Mirko | CHARP |  | Ericsson | david.shrader@ericsson.com |  |
| 618 | 159.4 | Charging for IMS centralized service (ICS) control (Stage 2/3) | 137d? | 2013-12-11 A | 2014-06-18 A | 100% | 2013-12-11 | 2014-06-18 | 137d? | finish no earlier than 2014-06-18 | S5 | 1088h | 1088h | CHICS | PCG-32 | Rel-12 | SP-62 | Mirko | CHICS |  | NSN | Gerald.Goermer@nsn.com |  |
| 619 | 160 | **IMS Emergency PSAP Callback (Stage 3)** | 724d? | 2011-09-21 A | 2014-06-13 A | 100% | 2011-09-21 | 2014-06-13 | 724d? |  | C1; C3; IETF | 38848h | 38848h | EMC_PC | PCG-27 | Rel-12 | CP-53 | Frederic | EMC_PC | Public Safety (I-A) | Ericsson | christer.holmberg@ericsson.com |  |
| 620 | 160.1 | CT1 part of IMS Emergency PSAP Callback | 721d? | 2011-09-22 A | 2014-06-13 A | 100% | 2011-09-22 | 2014-06-13 | 721d? | finish no earlier than 2014-06-13 | C1 | 5760h | 5760h | EMC_PC-CT1 | PCG-27 | Rel-12 | CP-53 | Frederic |  | Public Safety (I-A) | Ericsson | christer.holmberg@ericsson.com |  |
| 621 | 160.2 | (IETF) CT1 part of IMS Emergency PSAP Callback (RFC 7090) | 723d? | 2011-09-21 A | 2014-06-13 A | 100% | 2011-09-21 | 2014-06-13 | 723d? | finish no earlier than 2014-06-13 | C1-IETF | 5776h | 5776h | EMC_PC-CT1ietf | PCG-27 | Rel-12 | CP-53 | Frederic |  | Public Safety (I-A) | christer.holmberg@ericsson.com | christer.holmberg@ericsson.com |  |
| 622 | 160.3 | CT3 part of IMS Emergency PSAP Callback | 519d? | 2011-09-24 A | 2013-09-06 A | 100% | 2011-09-24 | 2013-09-06 | 519d? | finish no earlier than 2013-09-06 | C3 | 4152h | 4152h | EMC_PC-CT3 | PCG-27 | Rel-12 | CP-53 | Adrian |  | Public Safety (I-A) | Ericsson | christer.holmberg@ericsson.com |  |
| 623 | 160.4 | (IETF) CT3 part of IMS Emergency PSAP Callback (RFC 7090) | 724d? | 2011-09-21 A | 2014-06-13 A | 100% | 2011-09-21 | 2014-06-13 | 724d? | finish no earlier than 2014-06-13 | C3-IETF | 5784h | 5784h | EMC_PC-CT3ietf | PCG-31 | Rel-12 | CP-60 | Adrian |  | Public Safety (I-A) | christer.holmberg@ericsson.com | christer.holmberg@ericsson.com |  |
| 624 | 161 | Interworking between a PLMN with WLAN to access the EPC and a PDN (Stage 3) | 265d? | 2012-09-10 A | 2013-09-06 A | 100% | 2012-09-10 | 2013-09-06 | 265d? | finish no earlier than 2013-08-12 | C3 | 2091.72h | 2091.72h | SAES_WLAN_EPC_intwk | PCG-29 | Rel-12 | CP-57 | Adrian | SAES_WLAN_EPC_intwk | WLAN | Huawei | Christian.Herrero@huawei.com |  |

Notes:
- 598: OAM12 is an umbrella Feature for changes that are not part of any other dedicated feature/WI
- 599: OAM12-SON is an umbrella BB also for SON related TEI12 type of changes that are not part of any other dedicated feature/WI
- 600: SP#62 completed. TS 32.508v200 for Approval, TS 32.509v100 for 1-step Approval / Impacted TSs and TRs: 32.501, New TSs (32.508, 32.509)
- 601: SP#65 moved to Rel-13 OAM-PMID (Converged management Performance Management Interface Definition) UID_560235
- 602: SP#65 completed. TR 28.280v100 for 1-step Approval / Impacted TSs and TRs: 32.156, new TR 28.820
- 603: SP#60 completed. TS 28.390v200 for Approval / Impacted TSs and TRs: new TS 28.390
- 604: SP#65 updated WID SP-120779=>SP-140542 (removed parts on CN and non-3GPP access). Discontinue I-WLAN spec.
- 605: SP#65 completed. TS 28.402v100 for 1-step Approval, withdraw New TS 28.401 (CN and non-3GPP access i/w PMs). Moved PMs for EPC and non-3GPP access i/w from 28.401=>28.402 / Impacted TSs and TRs: new TS 28.401, withdrawn new TS 28.402
- 606: SP#65 discontinue I-WLAN specs: Move parts (e.g. IOCs) applicable for EPC and non-3GPP access interworking NRMs from 28.601/2/6 to 28.611/2/6. Withdraw 28.601/2/6 (CN and non-3GPP access i/w NRMs). SP#62 completed. TSs 28.601/2/6/11/12/16 for Approval / Impacted TSs and TRs: 32.632, 32.636, 32.752, 32.756, new TS (28.611, 28.612, 28.616, withdrawn 28.601, 28.602, 28.606)
- 607: -
- 608: SP#65 completion 09/14=>12/14. Exception in SP-140544. Triggered by Rel-12 TR 32.859 Study on Alarm Management (FS_OAM_AM) . LM: 50->100 / Impacted TSs and TRs: 32.111-1, 32.111-2, 32.111-6
- 609: SP#65 completion 09/14=>12/14. Exception in SP-140546. SP#65 v100 TS 28.667/8 for Information. LM: 60->100 / Impacted TSs and TRs: 32.101, New TSs (28.667, 28.668, 28.669)
- 610: OAM12-PM is an umbrella BB also for PM related TEI12 type of changes that are not part of any other dedicated feature/WI
- 611: SP#65 completion 09/14=>12/14. Exception in SP-140545. Triggered by Rel-12 TR 32.851 Study on OAM aspects of Network Sharing (FS_OAM_SHARE), Rel-6 Network Sharing (NTShar) UID_31018 / Impacted TSs and TRs: Stage 1/2/3
- 612: SP#65 completion 09/14=>12/14. Exception in SP-140545. LM 80->100 / Impacted TSs and TRs: new TS 32.130
- 613: SP#65 completion 09/14=>12/14. Exception in SP-140545. LM: 60->100 / Impacted TSs and TRs: 28.401,28.621/2/3,28.651/2/3,28.654/5/6,28.657/8/9,28.701/2/3,28.731/2/3,28.734/5/6,32.101/2,32.111-1/2/3/6,32.121/2/6,32.155,32.171/2/6,32.300/1/2/6,32.311/2/6,32.321/2/6,32.331/2/6,32.341/2/6,32.351/352/6,32.361/2/6,32.381/2/6,32.405/6/7/8/9/10/11/12/41
- 614: CH12 is an umbrella Feature for changes that are not part of any other dedicated feature/WI
- 615: Stage 2/3. SP#63 completed. Updated WID SP-120775=>SP-140027 / Impacted TSs and TRs: 32.240, 32.274, 32.297, 32.298, 32.299
- 616: SP#64 completed / Impacted TSs and TRs: 32.251, 32.298, 32.299
- 617: SP#64 completed. TS 32.276v200 for Approval, 32.293v100 for 1-step Approval / Impacted TSs and TRs: 32.240, 32.299, New TSs [32.276 (Voice Call Service Charging), 32.293 (Proxy Function)]
- 618: SP#64 completed. Align SA5 Charging specifications with Rel-8 Feature IMS Centralized Service control (ICSRA) and subsequent enhancements under TEIx (SA2 23.292 ICSRA Stage 2, CT3 29.292, CT1 24.607, 24.611) / Impacted TSs and TRs: 32.250, 32.298
- 619: Dep. IETF ECRIT on PSAP call back. Fulfill SA1/2 Rel-7 EMC1 reqs UID_32045 PS domain and IMS impacts for supporting IMS Emergency calls (related to BB UID_1653 Emergency Call Enhancements for IP& PS Based Calls / Impacted TSs and TRs: Stage 3
- 620: CP#64 completed / Impacted TSs and TRs: 24.229, tied to completion of IETF dependencies: 24.604, 24.605, 24.610, 24.611, 24.629
- 621: CP#64 completed / Impacted TSs and TRs: RFC 7090 (was draft-ietf-ecrit-psap-callback
- 622: CP#61 completed / Impacted TSs and TRs: 29.163, 29.165
- 623: CP#64 completed / Impacted TSs and TRs: RFC 7090 (was draft-ietf-ecrit-psap-callback)
- 624: CP#61 completed. Linked to Rel-8 Feature SAES: System Architecture Evolution specification - Evolved Packet System (non RAN aspects) UID_320005 / Impacted TSs and TRs: 29.061

| ID | WBS | Task | Duration | Start | Finish | Complete | Remaining | Baseline start | Baseline finish | Baseline duration | Total slack | Constraint | Resources | Work | Actual work | Acronym | PCG approved | WI rapporteur name | Release | TSG approved | MCC resp | Special Focus Doc | Acronym_3GU_Export | Status Report |
| --- | --- | --- | --- | --- | --- | --- | --- | --- | --- | --- | --- | --- | --- | --- | --- | --- | --- | --- | --- | --- | --- | --- | --- | --- |
| 625 | 162 | **Reporting Enhancements in Warning Message Delivery (Stage 2/3)** | 402d? | 2012-12-07 A | 2014-06-13 A | 100% |  | 2012-12-07 | 2014-06-13 | 402d? |  |  | C1; C4; R3 | 20832.2h | 20832.2h | REP_WMD | PCG-30 | one2many | Rel-12 | CP-58 | Frederic | Public Safety (I-A) | REP_WMD |  |
| 626 | 162.1 | CT1 part of Reporting Enhancements in Warning Message Delivery (Stage 2) | 329d? | 2012-12-07 A | 2014-03-04 A | 100% |  | 2012-12-07 | 2014-03-04 | 329d? |  | finish no earlier than 2014-03-06 | C1 | 2592.18h | 2592.18h | REP_WMD-CT1 | PCG-30 | one2many | Rel-12 | CP-58 | Frederic | Public Safety (I-A) |  |  |
| 627 | 162.2 | CT4 part of Reporting Enhancements in Warning Message Delivery (Stage 2/3) | 400d? | 2012-12-10 A | 2014-06-13 A | 100% |  | 2012-12-10 | 2014-06-13 | 400d? |  | finish no earlier than 2014-06-13 | C4 | 3168h | 3168h | REP_WMD-CT4 | PCG-30 | one2many | Rel-12 | CP-58 | Kimmo | Public Safety (I-A) |  |  |
| 628 | 162.3 | **Public Warning System - Reset/Failure/Restart in Warning Message Delivery in LTE** | 340d? | 2013-03-04 A | 2014-06-13 A | 100% |  | 2013-03-04 | 2014-06-13 | 340d? |  |  | R3 | 5424h | 5424h | REP_WMD-RFR_PWS | PCG-30 | one2many, Huawei | Rel-12 | RP-59 | Juha | Public Safety (I-A) | REP_WMD-RFR_PWS |  |
| 629 | 162.3.1 | Core part: PWS - Reset/Failure/Restart in Warning Message Delivery in LTE | 338d? | 2013-03-04 A | 2014-06-13 A | 100% |  | 2013-03-04 | 2014-06-13 | 338d? |  | finish no earlier than 2014-06-13 | R3 | 2704h | 2704h | REP_WMD-RFR_PWS-Core | PCG-30 | one2many, Huawei | Rel-12 | RP-59 | Juha | Public Safety (I-A) | REP_WMD-RFR_PWS-Core | RP-140637 |
| 630 | 163 | **Single Radio Voice Call Continuity (SRVCC) before ringing (Stage 3)** | 331d? | 2012-12-07 A | 2014-03-06 A | 100% |  | 2012-12-07 | 2014-03-06 | 331d? |  |  | C1; C3; R5 | 9584h | 9584h | bSRVCC | PCG-30 | NTT DOCOMO | Rel-12 | CP-58 | Frederic |  | bSRVCC |  |
| 631 | 163.1 | CT1 part of Single Radio Voice Call Continuity (SRVCC) before ringing | 138d? | 2012-12-07 A | 2013-06-14 A | 100% |  | 2012-12-07 | 2013-06-14 | 138d? |  | finish no earlier than 2013-06-14 | C1 | 1096h | 1096h | bSRVCC-CT1 | PCG-30 | NTT DOCOMO | Rel-12 | CP-58 | Frederic |  |  |  |
| 632 | 163.2 | CT3 part of Single Radio Voice Call Continuity (SRVCC) before ringing | 3d? | 2013-06-12 A | 2013-06-14 A | 100% |  | 2013-06-12 | 2013-06-14 | 3d? |  | finish no earlier than 2013-06-14 | C3 | 24h | 24h | bSRVCC-CT3 | PCG-31 | NTT DOCOMO | Rel-12 | CP-60 | Adrian |  |  |  |
| 633 | 163.3 | Test part: Single Radio Voice Call Continuity (SRVCC) before ringing | 65d? | 2013-12-06 A | 2014-03-06 A | 100% |  | 2013-12-06 | 2014-03-06 | 65d? |  | finish no earlier than 2014-03-06 | R5 | 520h | 520h | bSRVCC-UEConTest | PCG-32 | NTT DOCOMO | Rel-12 | CP-62 | Ingbert |  | bSRVCC-UEConTest | RP-140422 |
| 634 | 164 | **IMS Stage 3 IETF Protocol Alignment - phase 6** | 532d? | 2012-12-07 A | 2014-12-09 | 67% | 176.89d? | 2012-12-07 | 2014-12-05 | 527d? | 657d |  | C1; C3; IETF | 20640.6h | 13665.2h | IMSProtoc6 | PCG-30 | Alcatel-Lucent | Rel-12 | CP-58 | Frederic |  | IMSProtoc6 |  |
| 635 | 164.1 | CT1 part of IMS Stage 3 IETF Protocol Alignment - phase 6 | 464d? | 2012-12-07 A | 2014-09-11 A | 100% |  | 2012-12-07 | 2014-09-12 | 464d? |  | finish no earlier than 2014-09-12 | C1 | 3712h | 3712h | IMSProtoc6-CT1 | PCG-30 | Alcatel-Lucent | Rel-12 | CP-58 | Frederic |  |  |  |
| 636 | 164.2 | (IETF) CT1 part of IMS Stage 3 IETF Protocol Alignment - phase 6 (holmberg-sipcore-received-realm) | 410d? | 2013-05-21 A | 2014-12-09 | 50% | 206d? | 2013-05-21 | 2014-12-05 | 408d? | 657d | finish no earlier than 2014-12-09 | C1-IETF | 3256.25h | 1608.25h | IMSProtoc6-CT1_holm | PCG-31 | christer.holmberg@ericsson.com | Rel-12 | CP-60 | Frederic |  |  |  |
| 637 | 164.3 | (IETF) CT1 part of IMS Stage 3 IETF Protocol Alignment - phase 6 (allen-sipcore-sip-tree-cap-indicators) | 63d? | 2014-09-12 A | 2014-12-09 | 25% | 47.25d? |  |  |  | 657d | finish no earlier than 2014-12-09 | C1-IETF | 504h | 126h | IMSProtoc6-CT1_allen | PCG-33 | christer.holmberg@ericsson.com | Rel-12 | CP-65 |  |  |  |  |
| 638 | 164.4 | (IETF) CT1 part of IMS Stage 3 IETF Protocol Alignment - phase 6 (draft-ietf-insipid-session-id) | 65d? | 2014-09-12 A | 2014-12-09 | 25% | 48.75d? |  |  |  | 657d | start no earlier than 2014-09-12 | C1-IETF | 520h | 130h | IMSProtoc6-CT1_insip |  | christer.holmberg@ericsson.com | Rel-12 | CP-65 |  |  |  |  |
| 639 | 164.5 | CT3 part of IMS Stage 3 IETF Protocol Alignment - phase 6 | 71d? | 2014-06-06 A | 2014-09-11 A | 100% |  | 2014-06-06 | 2014-09-12 | 71d? |  | finish no earlier than 2014-09-12 | C3 | 568h | 568h | IMSProtoc6-CT3 | PCG-30 | Alcatel-Lucent | Rel-12 | CP-58 | Adrian |  |  |  |
| 640 | 164.6 | (IETF) CT3 part of IMS Stage 3 IETF Protocol Alignment - phase 6 (holmberg-sipcore-received-realm) | 327d? | 2013-09-06 A | 2014-12-05 | 50% | 163.5d? | 2013-09-06 | 2014-12-05 | 327d? | 659d | finish no earlier than 2014-12-05 | C3-IETF | 2608h | 1300h | IMSProtoc6-CT3ietf | PCG-31 | christer.holmberg@ericsson.com | Rel-12 | CP-61 |  |  |  |  |
| 641 | 165 | **SAE Protocol Development - Phase 3** | 467d? | 2012-12-07 A | 2014-09-11 A | 100% |  | 2012-12-07 | 2014-09-12 | 467d? |  |  | C1 | 14920h | 14920h | SAES3 | PCG-30 | InterDigital | Rel-12 | CP-58 | Frederic |  | SAES3 |  |
| 642 | 165.1 | SAE Protocol Development (Stage 3) - Phase 3 | 466d? | 2012-12-07 A | 2014-09-11 A | 100% |  | 2012-12-07 | 2014-09-12 | 466d? |  | finish no earlier than 2014-09-12 | C1 | 3728h | 3728h | SAES3-CT1 | PCG-30 | InterDigital | Rel-12 | CP-58 | Frederic |  |  |  |
| 643 | 165.2 | CS Fallback in EPS - Phase 3 | 466d? | 2012-12-07 A | 2014-09-11 A | 100% |  | 2012-12-07 | 2014-09-12 | 466d? |  | finish no earlier than 2014-09-12 | C1 | 3728h | 3728h | SAES3-CSFB | PCG-30 | InterDigital | Rel-12 | CP-58 | Frederic |  | SAES3-CSFB |  |
| 644 | 165.3 | SAE for support for non-3GPP accesses - Phase 3 | 466d? | 2012-12-07 A | 2014-09-11 A | 100% |  | 2012-12-07 | 2014-09-12 | 466d? |  | finish no earlier than 2014-09-12 | C1 | 3728h | 3728h | SAES3-non3GPP | PCG-30 | InterDigital | Rel-12 | CP-58 | Frederic |  | SAES3-non3GPP |  |
| 645 | 166 | **IM-SSF Application Server Service Data Descriptions (Stage 2/3)** | 138d? | 2012-12-07 A | 2013-06-14 A | 100% |  | 2012-12-07 | 2013-06-14 | 138d? |  |  | C4; C1 | 3780h | 3780h | IMS_SSFDD | PCG-30 | Huawei | Rel-12 | CP-58 | Kimmo |  | IMS_SSFDD |  |
| 646 | 166.1 | Stage 2 for IM-SSF Application Server Service Data Descriptions | 62d? | 2012-12-07 A | 2013-03-01 A | 100% |  | 2012-12-07 | 2013-03-01 | 62d? |  | finish no earlier than 2013-06-14 | C1 | 488h | 488h | IMS_SSFDD-CT1 | PCG-30 | Huawei | Rel-12 | CP-58 | Frederic |  |  |  |
| 647 | 166.2 | Stage 3 for IM-SSF Application Server Service Data Descriptions | 136.5d? | 2012-12-10 A | 2013-06-14 A | 100% |  | 2012-12-10 | 2013-06-14 | 136.5d? |  | finish no earlier than 2013-06-14 | C4 | 1084h | 1084h | IMS_SSFDD-CT4 | PCG-30 | Huawei | Rel-12 | CP-58 | Kimmo |  |  |  |
| 648 | 167 | **Diameter based interface between SGSN and SMS central functions (Stage 2/3)** | 265d? | 2012-12-10 A | 2013-12-06 A | 100% |  | 2012-12-10 | 2013-12-06 | 265d? |  |  | C4; C1 | 7952h | 7952h | Dia_SGSN_SMS | PCG-30 | Alcatel-Lucent | Rel-12 | CP-58 | Kimmo |  | Dia_SGSN_SMS |  |
| 649 | 167.1 | Stage 2 for Diameter based interface between SGSN and SMS central functions | 201d? | 2013-03-07 A | 2013-12-06 A | 100% |  | 2013-03-07 | 2013-12-06 | 201d? |  | finish no earlier than 2013-12-06 | C1 | 1608h | 1608h | Dia_SGSN_SMS-CT1 | PCG-30 | Alcatel-Lucent | Rel-12 | CP-59 | Frederic |  |  |  |
| 650 | 167.2 | Stage 3 for Diameter based interface between SGSN and SMS central functions | 265d? | 2012-12-10 A | 2013-12-06 A | 100% |  | 2012-12-10 | 2013-12-06 | 265d? |  | finish no earlier than 2013-12-06 | C4 | 2104h | 2104h | Dia_SGSN_SMS-CT4 | PCG-30 | Alcatel-Lucent | Rel-12 | CP-58 | Kimmo |  |  |  |
| 651 | 168 | Diameter based interface between SGSN-GMLC (Stage 3) | 265d? | 2012-12-10 A | 2013-12-06 A | 100% |  | 2012-12-10 | 2013-12-06 | 265d? |  | finish no earlier than 2013-12-06 | C4 | 2096h | 2096h | Dia_SGSN_GMLC | PCG-30 | Cisco | Rel-12 | CP-58 | Kimmo |  | Dia_SGSN_GMLC |  |
| 652 | 169 | IMS impacts on UICC Application Aspects (Stage 3) | 465d? | 2013-03-04 A | 2014-12-09 A | 100% |  | 2013-03-04 | 2014-09-12 | 403d? |  | finish no earlier than 2014-12-09 | C6 | 3720h | 3720h | IMS_UApAs | PCG-30 | Giesecke & Devrient | Rel-12 | CP-59 | Xavier |  | IMS_UApAs | CP-140696 |

Notes:
- 625: Stage 1 for Cell Broadcast does not exist. This WID enhances the reporting capabilities of Warning Message Delivery. Introduce LTE functionality requested by regulators, equivalent to existing 2G/3G functionality. / Impacted TSs and TRs: Stage 2/3 / WI rapporteur e-mail: peter.sanders@one2many.eu
- 626: CP#63 completed / Impacted TSs and TRs: 23.041 / WI rapporteur e-mail: peter.sanders@one2many.eu
- 627: CP#64 completed / Impacted TSs and TRs: 23.007, 29.168 / WI rapporteur e-mail: peter.sanders@one2many.eu
- 628: - / Impacted TSs and TRs: LTE / WI rapporteur e-mail: peter.sanders@one2many.eu, Dai Mingzeng (daimingzeng@huawei.com)
- 629: RP#64 completed / Impacted TSs and TRs: 36.413 / WI rapporteur e-mail: peter.sanders@one2many.eu, Dai Mingzeng (daimingzeng@huawei.com)
- 630: Linked to Rel-8 Feature IMS Service Continuity (IMS-Cont) UID_390056. TS 23.237 Rel-12 CR#0444 under TEI12 / Impacted TSs and TRs: GERAN, UTRA, LTE / WI rapporteur e-mail: keisuke.sasada.kx@nttdocomo.com
- 631: CP#60 completed / Impacted TSs and TRs: 24.008, 24.237 / WI rapporteur e-mail: keisuke.sasada.kx@nttdocomo.com
- 632: CP#60 completed / Impacted TSs and TRs: 29.165 / WI rapporteur e-mail: keisuke.sasada.kx@nttdocomo.com
- 633: RP#63 completed. Testing for CT1 TS 24.237 (IMS service continuity Stage 3) / Impacted TSs and TRs: 34.229-1, 34.229-2, 36.523-1, 36.523-2 / WI rapporteur e-mail: Masahiro.Tamaoki.eu@nttdocomo.com
- 634: - / Impacted TSs and TRs: Stage 3 / WI rapporteur e-mail: keith.drage@alcatel-lucent.com
- 635: CP#65 completed / Impacted TSs and TRs: 23.218, 24.229, 24.930 / WI rapporteur e-mail: keith.drage@alcatel-lucent.com
- 636: Not completed internet-draft / Impacted TSs and TRs: draft-holmberg-sipcore-received-realm / WI rapporteur e-mail: christer.holmberg@ericsson.com
- 637: Not completed internet-draft / Impacted TSs and TRs: draft-allen-sipcore-sip-tree-cap-indicators / WI rapporteur e-mail: christer.holmberg@ericsson.com
- 638: work in progress / Impacted TSs and TRs: draft-ietf-insipid-session-id
- 639: CP#65 completed / Impacted TSs and TRs: 29.163, 29.165 / WI rapporteur e-mail: keith.drage@alcatel-lucent.com
- 640: Not completed internet-draft / Impacted TSs and TRs: draft-holmberg-sipcore-received-realm / WI rapporteur e-mail: christer.holmberg@ericsson.com
- 641: Stage 3 continuation of Rel-8 Feature SAES (3GPP System Architecture Evolution Specification - Evolved Packet System) UID_320005 / Impacted TSs and TRs: Stage 2/3 / WI rapporteur e-mail: behrouz.aghili@interdigital.com
- 642: CP#65 completed / Impacted TSs and TRs: 23.122, 24.008, 24.167, 24.229, 24.301, 24.302, 24.303, 24.304, 24.305, 24.312, 29.018, 29.118 / WI rapporteur e-mail: behrouz.aghili@interdigital.com
- 643: CP#65 completed / Impacted TSs and TRs: 23.122, 24.008, 24.167, 24.229, 24.301, 24.302, 24.303, 24.304, 24.305, 24.312, 29.018, 29.118 / WI rapporteur e-mail: behrouz.aghili@interdigital.com
- 644: CP#65 completed / Impacted TSs and TRs: 23.122, 24.008, 24.167, 24.229, 24.301, 24.302, 24.303, 24.304, 24.305, 24.312, 29.018, 29.118 / WI rapporteur e-mail: behrouz.aghili@interdigital.com
- 645: CP#60 completed / Impacted TSs and TRs: Stage 2/3 / WI rapporteur e-mail: susan.shishufeng@huawei.com
- 646: CP#59 completed / Impacted TSs and TRs: 23.218 / WI rapporteur e-mail: susan.shishufeng@huawei.com
- 647: CP#60 completed / Impacted TSs and TRs: 29.328, 29.329, 29.364 / WI rapporteur e-mail: susan.shishufeng@huawei.com
- 648: CP#62 completed / Impacted TSs and TRs: Stage 2/3 / WI rapporteur e-mail: jean-jacques.trottin@alcatel-lucent.com
- 649: CP#62 completed / Impacted TSs and TRs: 23.040 / WI rapporteur e-mail: jean-jacques.trottin@alcatel-lucent.com
- 650: CP#62 completed / Impacted TSs and TRs: 29.002, 29.230, 29.272, 29.305, 29.336, 29.337, 29.338 / WI rapporteur e-mail: jean-jacques.trottin@alcatel-lucent.com
- 651: CP#62 completed. Updated WID CP-130273=>CP-130598. No Stage 2 impact. Define a Diameter variant for the protocol used over existing reference points between SGSN and GMLC for LCS (replace the use of MAP by Diameter protocol) / Impacted TSs and TRs: 29.002, 29.172, 29.173, 29.230, 29.272 / WI rapporteur e-mail: Nirav Salot (nsalot@cisco.com)
- 652: CP#65 completion 09/14=>12/14. Exception in CP-140696. LM: 85->100% / Impacted TSs and TRs: 31.102, 31.103, 31.111, 31.130 / WI rapporteur e-mail: sergi.espi@gi-de.com

| ID | WBS | Task | Duration | Start | Finish | Complete | Baseline start | Baseline finish | Baseline duration | Constraint | Resources | Work | Actual work | Acronym | PCG approved | Impacted TSs and TRs | WI rapporteur name | WI rapporteur e-mail | Release | TSG approved | MCC resp | Acronym_3GU_Export | Status Report |
| --- | --- | --- | --- | --- | --- | --- | --- | --- | --- | --- | --- | --- | --- | --- | --- | --- | --- | --- | --- | --- | --- | --- | --- |
| 653 | 170 | **eMBMS restoration procedures** | 406d? | 2013-03-01 A | 2014-09-11 A | 100% | 2013-03-01 | 2014-06-13 | 341d? |  | C4; C3 | 10272h | 10272h | eMBMS_Rest | PCG-30 | Stage 3 | Alcatel-Lucent | bruno.landais@alcatel-lucent.com | Rel-12 | CP-59 | Kimmo | eMBMS_Rest |  |
| 654 | 170.1 | CT4 part of eMBMS restoration procedures | 205d? | 2013-03-01 A | 2013-12-06 A | 100% | 2013-03-01 | 2013-12-06 | 205d? | finish no earlier than 2013-12-06 | C4 | 1616h | 1616h | eMBMS_Rest-CT4 | PCG-30 | 23.007, 23.008, 29.274 | Alcatel-Lucent | bruno.landais@alcatel-lucent.com | Rel-12 | CP-59 | Kimmo |  |  |
| 655 | 170.2 | CT3 part of eMBMS restoration procedures | 270d? | 2013-09-04 A | 2014-09-11 A | 100% | 2013-09-04 | 2014-06-13 | 205d? | finish no earlier than 2014-09-12 | C3 | 2160h | 2160h | eMBMS_Rest-CT3 | PCG-31 | 29.061 | Alcatel-Lucent | bruno.landais@alcatel-lucent.com | Rel-12 | CP-61 | Kimmo |  |  |
| 656 | 171 | **Dual Radio VCC enhancements (Stage 2/3)** | 325d? | 2012-09-19 A | 2013-12-06 A | 100% | 2012-09-19 | 2013-12-06 | 325d? |  | C1; C3.S2 | 10866.2h | 10866.2h | eDRVCC | PCG-30 | Stage 2/3 | Ericsson | Jan.Holm@ericsson.com | Rel-12 | CP-59 | Maurice | eDRVCC |  |
| 657 | 171.1 | Stage 2 for Dual Radio VCC enhancements | 57.55d? | 2012-09-19 A | 2013-03-01 A | 100% | 2012-09-19 | 2013-03-01 | 57.55d? | finish no earlier than 2013-03-01 | S2 | 460.4h | 460.4h | eDRVCC-SA2 | PCG-30 | 23.237 | Ericsson | Jan.Holm@ericsson.com | Rel-12 | CP-59 | Maurice |  |  |
| 658 | 171.2 | **Stage 3 for Dual Radio VCC enhancements** | 205d? | 2013-03-01 A | 2013-12-06 A | 100% | 2013-03-01 | 2013-12-06 | 205d? |  | C1; C3 | 5205.8h | 5205.8h | eDRVCC | PCG-30 | Stage 3 | Ericsson | Jan.Holm@ericsson.com | Rel-12 | CP-59 | Frederic |  |  |
| 659 | 171.2.1 | CT1 part of Stage 3 for Dual Radio VCC enhancements | 205d? | 2013-03-01 A | 2013-12-06 A | 100% | 2013-03-01 | 2013-12-06 | 205d? | finish no earlier than 2013-12-06 | C1 | 1608h | 1608h | eDRVCC-CT1 | PCG-30 | 24.237, 24.292 | Ericsson | Jan.Holm@ericsson.com | Rel-12 | CP-59 | Frederic |  |  |
| 660 | 171.2.2 | CT3 part of Stage 3 for Dual Radio VCC enhancements | 41.7d? | 2013-03-01 A | 2013-09-06 A | 100% | 2013-03-01 | 2013-09-06 | 41.7d? | finish no earlier than 2013-09-06 | C3 | 317.8h | 317.8h | eDRVCC-CT3 | PCG-30 | 29.165 | Ericsson | Jan.Holm@ericsson.com | Rel-12 | CP-59 | Adrian |  |  |
| 661 | 172 | **CT aspects of Signalling of Image Size (Stage 2/3)** | 129d? | 2013-06-14 A | 2013-12-06 A | 100% | 2013-06-14 | 2013-12-06 | 129d? |  | C4; C1; C3 | 6136.8h | 6136.8h | SIS_CT | PCG-31 | Stage 2/3 | Ericsson | nevenka.biondic@ericsson.com | Rel-12 | CP-60 | Kimmo | SIS_CT |  |
| 662 | 172.1 | CT4 part of Signalling of Image Size | 128.05d? | 2013-06-14 A | 2013-12-06 A | 100% | 2013-06-14 | 2013-12-06 | 128.05d? | finish no earlier than 2013-12-06 | C4 | 1008.4h | 1008.4h | SIS_CT-CT4 | PCG-31 | 23.333, 23.334, 29.238, 29.332, 29.333, 29.334 | Ericsson | nevenka.biondic@ericsson.com | Rel-12 | CP-60 | Kimmo |  |  |
| 663 | 172.2 | CT1 part of CT Aspects of Signalling of Image Size | 129d? | 2013-06-14 A | 2013-12-06 A | 100% | 2013-06-14 | 2013-12-06 | 129d? | finish no earlier than 2013-12-06 | C1 | 1016h | 1016h | SIS_CT-CT1 | PCG-31 | 24.229 | Ericsson | nevenka.biondic@ericsson.com | Rel-12 | CP-60 | Frederic |  |  |
| 664 | 172.3 | CT3 part of CT Aspects of Signalling of Image Size | 128.05d? | 2013-06-14 A | 2013-12-06 A | 100% | 2013-06-14 | 2013-12-06 | 128.05d? | finish no earlier than 2013-12-06 | C3 | 1016.4h | 1016.4h | SIS_CT | PCG-31 | 29.162, 29.163 | Ericsson | nevenka.biondic@ericsson.com | Rel-12 | CP-60 | Adrian |  |  |
| 665 | 173 | IMS Centralized Services (ICS) InterWorking Enhancement in Mobile Switching Center Server (MSC-S) | 129d? | 2013-06-14 A | 2013-12-06 A | 100% | 2013-06-14 | 2013-12-06 | 129d? | finish no earlier than 2013-12-06 | C3 | 1008h | 1008h | ICS_IWE | PCG-31 | 29.292 | Orange | marianne.mohali@orange.com | Rel-12 | CP-60 | Adrian | ICS_IWE |  |
| 666 | 174 | GPRS Tunnelling Protocol for the Control plane (GTP-C) Overload Control Mechanisms | 267d? | 2013-09-06 A | 2014-09-11 A | 100% | 2013-09-06 | 2014-09-12 | 267d? | finish no earlier than 2014-09-12 | C4 | 2136h | 2136h | GOCMe | PCG-31 | 23.008, 29.230, 29.273, 29.274, 29.303, New TR 29.807 | Cisco | Nirav Salot (nsalot@cisco.com) | Rel-12 | CP-61 | Kimmo | GOCMe |  |
| 667 | 175 | **Proxy Call Session Control Function (P-CSCF) restoration enhancements (Stage 2/3)** | 447.1d? | 2013-04-03 A | 2014-12-09 A | 100% | 2013-04-03 | 2014-12-05 | 442.1d? |  | C4; C3; C1 | 54903.2h | 54903.2h | PCSCF_RES | PCG-31 | Stage 2/3 | Ericsson | maria.cruz.bartolome@ericsson.com | Rel-12 | CP-61 | Kimmo | PCSCF_RES |  |
| 668 | 175.1 | TR on Proxy Call Session Control Function (P-CSCF) restoration enhancements | 266d? | 2013-09-06 A | 2014-09-11 A | 100% | 2013-09-06 | 2014-09-12 | 266d? | finish no earlier than 2014-09-12 | C4 | 2128h | 2128h | PCSCF_RES | PCG-31 | New TR 29.806 | Ericsson | maria.cruz.bartolome@ericsson.com | Rel-12 | CP-61 | Kimmo |  |  |
| 669 | 175.2 | **Common for HSS & PCRF solutions** | 447.1d? | 2013-04-03 A | 2014-12-09 A | 100% |  |  |  |  | C4; C3; C1 | 18602.4h | 18602.4h | PCSCF_RES | PCG-33 |  | Ericsson | maria.cruz.bartolome@ericsson.com | Rel-12 | CP-64 |  |  |  |
| 670 | 175.2.1 | CT4 part of Common for HSS & PCRF solutions | 328d? | 2013-09-06 A | 2014-12-09 A | 100% | 2013-09-06 | 2014-12-05 | 326d? | finish no earlier than 2014-12-09 | C4 | 2624h | 2624h | PCSCF_RES | PCG-31 | 23.380, 29.060, 29.274 | Ericsson | maria.cruz.bartolome@ericsson.com | Rel-12 | CP-61 | Kimmo |  | CP-140481 |
| 671 | 175.2.2 | CT1 part of Common for HSS & PCRF solutions | 328d? | 2013-04-03 A | 2014-12-05 A | 100% | 2013-04-03 | 2014-12-05 | 326d? | finish no earlier than 2014-12-09 | C1 | 2624h | 2624h | PCSCF_RES | PCG-33 | 24.008 | Ericsson | maria.cruz.bartolome@ericsson.com | Rel-12 | CP-64 | Kimmo |  |  |
| 672 | 175.2.3 | CT3 part of Common for HSS & PCRF solutions | 328d? | 2013-05-03 A | 2014-12-09 A | 100% | 2013-05-03 | 2014-12-05 | 326d? | finish no earlier than 2014-12-09 | C3 | 2624h | 2624h | PCSCF_RES | PCG-33 | 29.061, 29.165 | Huawei | susan.shishufeng@huawei.com | Rel-12 | CP-65 | Kimmo |  | CP-140687 |
| 673 | 175.3 | **HSS based solution** | 447.1d? | 2013-04-03 A | 2014-12-09 A | 100% |  |  |  |  | C4; C1 | 12401.6h | 12401.6h | PCSCF_RES | PCG-33 |  | Ericsson | maria.cruz.bartolome@ericsson.com | Rel-12 | CP-64 |  |  |  |
| 674 | 175.3.1 | CT4 part of HSS based solution | 328d? | 2013-09-06 A | 2014-12-09 A | 100% | 2013-09-06 | 2014-12-05 | 326d? | finish no earlier than 2014-12-09 | C4 | 2624h | 2624h | PCSCF_RES | PCG-31 | 29.002, 29.228, 29.229, 29.272, 29.305 | Ericsson | maria.cruz.bartolome@ericsson.com | Rel-12 | CP-61 | Kimmo |  | CP-140481 |
| 675 | 175.3.2 | CT1 part of HSS based solution | 328d? | 2013-04-03 A | 2014-12-09 A | 100% | 2013-04-03 | 2014-12-05 | 326d? | finish no earlier than 2014-12-09 | C1 | 2624h | 2624h | PCSCF_RES | PCG-33 | 24.229 | Ericsson | maria.cruz.bartolome@ericsson.com | Rel-12 | CP-64 | Kimmo |  | CP-140605 |
| 676 | 175.4 | **PCRF based solution** | 447.1d? | 2013-04-03 A | 2014-12-09 A | 100% |  |  |  |  | C3; C1 | 12401.6h | 12401.6h | PCSCF_RES | PCG-33 |  | Huawei | susan.shishufeng@huawei.com | Rel-12 | CP-64 |  |  |  |
| 677 | 175.4.1 | CT3 part of PCRF based solution | 328d? | 2013-05-03 A | 2014-12-09 A | 100% | 2013-05-03 | 2014-12-05 | 326d? | finish no earlier than 2014-12-09 | C3 | 2624h | 2624h | PCSCF_RES | PCG-33 | 29.212, 29.213, 29.214, 29.215 | Huawei | susan.shishufeng@huawei.com | Rel-12 | CP-64 | Kimmo |  | CP-140687 |
| 678 | 175.4.2 | CT1 part of PCRF based solution | 328d? | 2013-04-03 A | 2014-12-09 A | 100% | 2013-04-03 | 2014-12-05 | 326d? | finish no earlier than 2014-12-09 | C1 | 2624h | 2624h | PCSCF_RES | PCG-33 | 24.229 | Huawei | susan.shishufeng@huawei.com | Rel-12 | CP-64 | Kimmo |  | CP-140605 |

Notes:
- 653: CP#62 completed. Linked to Rel-9 MBMS support in EPS (MBMS_EPS). Rel-10 CT Features EPC Node Restoration with/out Idle mode Signalling Reduction (ISR) activated (EPC_NR/EPC_NR_ISR)
- 654: CP#62 completed
- 655: CP#65 completed
- 656: CP#62 completed. Stage 2 in Rel-12 TEI12 TS 23.237 CR#0431, CR#0440, CR#0441, CR#0453 (pre-alerting). Stage 3 linked to Rel-8 Feature IMS Service Continuity (IMS-Cont) UID_390056 (Stage 2 in TS 23.237)
- 657: Stage 2 in Rel-12 TEI12 TS 23.237 CR#0431, CR#0440, CR#0441, CR#0453 (pre-alerting)
- 658: CP#62 completed
- 659: CP#62 completed
- 660: CP#61 completed
- 661: CP#62 completed. SA4 Rel-8 MTSI Video: Dynamic Rate Adaptation/Signalling of Image Size UID_34041 has included service aspects to support image attribute (a=imageattr) in TS 26.114 as in RFC 6236. But associated CN aspects were not included
- 662: CP#62 completed
- 663: CP#62 completed
- 664: CP#62 completed
- 665: CP#62 completed. Stage 3 enhancement interworking between IMS and MSC-S for IMS Centralized Services (ICS)
- 666: CP#65 completed. Updated WID CP-130433=>CP-140488
- 667: CP#65 updated WID CP-140443=>CP-140490. Based TR 29.806, solutions B and D are selected for standardization. LM: 95->100
- 668: CP#65 completed. TR 29.806v200 for Approval
- 669: -
- 670: CP#65 completion 09/14=>12/14. Exception in CP-140481. LM: 90->100
- 671: CP#65 completed
- 672: CP#65 updated WID CP-140443=>CP-140490 (added CT3 part). Exception in CP-140687
- 673: -
- 674: CP#65 completion 09/14=>12/14. Exception in CP-140481. LM: 90->100
- 675: CP#65 completion 09/14=>12/14. Exception in CP-140605. LM: 65->100%
- 676: -
- 677: CP#65 updated WID CP-140443=>CP-140490 (added CT3 part). Exception in CP-140687
- 678: CP#65 completion 09/14=>12/14. Exception in CP-140605. LM: 65->100

| ID | WBS | Task | Duration | Start | Finish | Complete | Remaining | Baseline start | Baseline finish | Baseline duration | Total slack | Constraint | Resources | Work | Actual work | Acronym | PCG approved | WI rapporteur name | WI rapporteur e-mail | Release | TSG approved | MCC resp | Acronym_3GU_Export | Status Report |
| --- | --- | --- | --- | --- | --- | --- | --- | --- | --- | --- | --- | --- | --- | --- | --- | --- | --- | --- | --- | --- | --- | --- | --- | --- |
| 679 | 176 | **Updating IMS to conform to RFC 6665 (Stage 3)** | 332d? | 2013-09-09 A | 2014-12-09 | 97% | 11.05d? | 2013-09-09 | 2014-09-12 | 267d? | 657d |  | C1; C3 | 8464h | 4102.72h | UP6665 | PCG-31 | BlackBerry | Andrew Allen (aallen@blackberry.com) | Rel-12 | CP-61 | Frederic | UP6665 |  |
| 680 | 176.1 | CT1 part of Updating IMS to conform to RFC 6665 | 329d? | 2013-09-09 A | 2014-12-09 | 96% | 13.16d? | 2013-09-09 | 2014-09-12 | 267d? | 657d | finish no earlier than 2014-12-09 | C1 | 2624h | 2518.72h | UP6665 | PCG-31 | BlackBerry | Andrew Allen (aallen@blackberry.com) | Rel-12 | CP-61 | Frederic |  | CP-140620 |
| 681 | 176.2 | CT3 part of Updating IMS to conform to RFC 6665 | 66d? | 2013-09-09 A | 2013-12-06 A | 100% |  | 2013-09-09 | 2013-12-06 | 66d? |  | finish no earlier than 2013-12-06 | C3 | 528h | 528h | UP6665 | PCG-31 | BlackBerry | Andrew Allen (aallen@blackberry.com) | Rel-12 | CP-61 | Maurice |  |  |
| 682 | 177 | **IMS Operator Determined Call Barring enhancements (Stage 3)** | 202d? | 2013-12-06 A | 2014-09-11 A | 100% |  | 2013-12-06 | 2014-06-13 | 137d? |  |  | C1; C3 | 5928h | 5928h | eIODB | PCG-32 | Ericsson | Jorgen.Axell@ericsson.com | Rel-12 | CP-62 | Frederic | eIODB |  |
| 683 | 177.1 | CT1 part of IMS Operator Determined Call Barring enhancements | 136d? | 2013-12-06 A | 2014-06-13 A | 100% |  | 2013-12-06 | 2014-06-13 | 136d? |  | finish no earlier than 2014-06-13 | C1 | 1088h | 1088h | eIODB | PCG-32 | Ericsson | Jorgen.Axell@ericsson.com | Rel-12 | CP-62 | Frederic |  |  |
| 684 | 177.2 | CT3 part of IMS Operator Determined Call Barring enhancements | 201d? | 2013-12-09 A | 2014-09-11 A | 100% |  | 2013-12-09 | 2014-06-13 | 136d? |  | finish no earlier than 2014-09-12 | C3 | 1608h | 1608h | eIODB | PCG-32 | Ericsson | Jorgen.Axell@ericsson.com | Rel-12 | CP-62 | Adrian |  |  |
| 685 | 178 | Signalling Improvements for Network Efficiency (Stage 3) | 264d? | 2013-12-06 A | 2014-12-09 | 85% | 39.6d? | 2013-12-06 | 2014-09-12 | 202d? | 657d | finish no earlier than 2014-12-09 | C1 | 2112h | 1795.2h | SINE | PCG-32 | Huawei | Lin Shu (shulin@huawei.com) | Rel-12 | CP-62 | Frederic | SINE | CP-140617 |
| 686 | 179 | **Interactive Connectivity Establishment (ICE, IETF RFC 5245) impacts on IMS H.248 profiles** | 138d? | 2014-03-05 A | 2014-09-11 A | 100% |  | 2014-03-05 | 2014-09-12 | 138d? |  |  | C4; C3 | 3896h | 3896h | ICEH248 | PCG-32 | NSN | Jan.Kall@nsn.com | Rel-12 | CP-63 | Kimmo | ICEH248 |  |
| 687 | 179.1 | CT4 part of ICE impacts on IMS H.248 profiles (Stage 2/3) | 138d? | 2014-03-05 A | 2014-09-11 A | 100% |  | 2014-03-05 | 2014-09-12 | 138d? |  | finish no earlier than 2014-09-12 | C4 | 1104h | 1104h | ICEH248 | PCG-32 | NSN | Jan.Kall@nsn.com | Rel-12 | CP-63 | Kimmo |  |  |
| 688 | 179.2 | CT3 part of ICE impacts on IMS H.248 profiles (Stage 2) | 73d? | 2014-03-05 A | 2014-06-13 A | 100% |  | 2014-03-05 | 2014-06-13 | 73d? |  | finish no earlier than 2014-06-13 | C3 | 584h | 584h | ICEH248 | PCG-32 | NSN | Jan.Kall@nsn.com | Rel-12 | CP-63 | Adrian |  |  |
| 689 | 180 | **Transfer of ETSI business trunking specifications** | 203d? | 2014-03-05 A | 2014-12-09 A | 100% |  | 2014-03-05 | 2014-09-17 | 141d? |  |  | C1; S1 | 5976h | 5976h | IMS_Corp2 | PCG-32 | Alcatel-Lucent | keith.drage@alcatel-lucent.com, Youssef Chadli | Rel-12 | CP-63 | Frederic | IMS_Corp2 |  |
| 690 | 180.1 | SA1 part of Transfer of ETSI business trunking specifications | 141d? | 2014-03-05 A | 2014-09-17 A | 100% |  | 2014-03-05 | 2014-09-17 | 141d? |  | finish no earlier than 2014-09-17 | S1 | 1128h | 1128h | IMS_Corp2 | PCG-32 | Alcatel-Lucent | betsy.covell@alcatel-lucent.com | Rel-12 | SP-63 | Alain |  | S1-143300 |
| 691 | 180.2 | CT1 part of Transfer of ETSI business trunking specifications | 200d? | 2014-03-05 A | 2014-12-09 A | 100% |  | 2014-03-05 | 2014-09-12 | 138d? |  | finish no earlier than 2014-12-09 | C1 | 1600h | 1600h | IMS_Corp2 | PCG-32 | Alcatel-Lucent | keith.drage@alcatel-lucent.com, Youssef Chadli | Rel-12 | CP-63 | Frederic |  | CP-140619 |
| 692 | 181 | **Support of ALT-C attribute** | 200d? | 2014-03-10 A | 2014-12-09 A | 100% |  | 2014-03-05 | 2014-09-12 | 138d? |  |  | C4; C1; C3 | 9600h | 9600h | ALTC | PCG-32 | Orange | lionel.morand@orange.com | Rel-12 | CP-63 | Kimmo | ALTC |  |
| 693 | 181.1 | CT4 part of Support of ALT-C attribute | 200d? | 2014-03-10 A | 2014-12-09 A | 100% |  | 2014-03-05 | 2014-09-12 | 138d? |  | finish no earlier than 2014-12-09 | C4 | 1600h | 1600h | ALTC | PCG-32 | Orange | lionel.morand@orange.com | Rel-12 | CP-63 | Kimmo |  | CP-140485 |
| 694 | 181.2 | CT1 part of Support of ALT-C attribute | 200d? | 2014-03-10 A | 2014-12-09 A | 100% |  | 2014-03-05 | 2014-09-12 | 138d? |  | finish no earlier than 2014-12-09 | C1 | 1600h | 1600h | ALTC | PCG-32 | Orange | lionel.morand@orange.com | Rel-12 | CP-63 | Frederic |  | CP-140611 |
| 695 | 181.3 | CT3 part of Support of ALT-C attribute | 200d? | 2014-03-10 A | 2014-12-09 A | 100% |  | 2014-03-05 | 2014-06-13 | 73d? |  | finish no earlier than 2014-12-09 | C3 | 1600h | 1600h | ALTC | PCG-32 | Orange | lionel.morand@orange.com | Rel-12 | CP-63 | Adrian |  | CP-140563 |
| 696 | 182 | **Diameter Overload Control Mechanisms** | 131d? | 2014-06-13 A | 2014-12-09 | 75% | 32.75d? | 2014-06-13 | 2014-12-05 | 126d? | 657d |  | C4; IETF | 4144h | 2197.5h | DOCME | PCG-33 | Orange | lionel.morand@orange.com | Rel-12 | CP-64 |  | DOCME |  |
| 697 | 182.1 | CT4 part of Diameter Overload Control Mechanisms | 128d? | 2014-06-13 A | 2014-12-09 A | 100% |  | 2014-06-13 | 2014-09-12 | 66d? |  | finish no earlier than 2014-12-09 | C4 | 1024h | 1024h | DOCME | PCG-33 | Orange | lionel.morand@orange.com | Rel-12 | CP-64 |  |  | CP-140486 |
| 698 | 182.2 | (IETF) Diameter Overload Control Mechanisms | 128d? | 2014-06-13 A | 2014-12-09 | 50% | 64d? | 2014-06-13 | 2014-12-05 | 126d? | 657d | finish no earlier than 2014-12-09 | C4-IETF | 1024h | 512h | DOCME | PCG-33 | christer.holmberg@ericsson.com | christer.holmberg@ericsson.com | Rel-12 | CP-64 |  |  |  |
| 699 | 183 | **Impacts of RFC7044 for introduction of the new History-Info header field** | 131d? | 2014-06-13 A | 2014-12-09 A | 100% |  | 2014-06-13 | 2014-09-12 | 66d? |  |  | C1; C3 | 3648h | 3648h | HISTORY_CT | PCG-33 | Deutsche Telekom | Roland Jesske (r.jesske@telekom.de) | Rel-12 | CP-64 |  | HISTORY_CT |  |
| 700 | 183.1 | CT1 part of Impacts of RFC7044 for introduction of the new History-Info header field | 128d? | 2014-06-13 A | 2014-12-09 A | 100% |  | 2014-06-13 | 2014-09-12 | 66d? |  | finish no earlier than 2014-12-09 | C1 | 1024h | 1024h | HISTORY_CT | PCG-33 | Deutsche Telekom | Roland Jesske (r.jesske@telekom.de) | Rel-12 | CP-64 |  |  | CP-140609 |
| 701 | 183.2 | CT3 part of Impacts of RFC7044 for introduction of the new History-Info header field | 66d? | 2014-06-13 A | 2014-09-11 A | 100% |  | 2014-06-13 | 2014-09-12 | 66d? |  | finish no earlier than 2014-09-12 | C3 | 528h | 528h | HISTORY_CT | PCG-33 | Deutsche Telekom | Roland Jesske (r.jesske@telekom.de) | Rel-12 | CP-64 |  |  |  |
| 702 | 184 | **Indication of NNI Routeing scenarios in SIP requests** | 131d? | 2014-06-13 A | 2014-12-09 | 84% | 21.53d? | 2014-06-13 | 2014-12-05 | 126d? | 657d |  | C1; C3; IETF | 5456h | 2284h | NNI_RS | PCG-33 | Ericsson | Jan.Holm@ericsson.com | Rel-12 | CP-64 |  | NNI_RS |  |
| 703 | 184.1 | CT1 part of Indication of NNI Routeing scenarios in SIP requests | 128d? | 2014-06-13 A | 2014-12-09 A | 100% |  | 2014-06-13 | 2014-09-12 | 66d? |  | finish no earlier than 2014-12-09 | C1 | 1024h | 1024h | NNI_RS | PCG-33 | Ericsson | Jan.Holm@ericsson.com | Rel-12 | CP-64 |  |  | CP-140613 |
| 704 | 184.2 | (IETF) CT1 part of Indication of NNI Routeing scenarios in SIP requests (holmberg-dispatch-iotl) | 95d? | 2014-06-13 A | 2014-12-09 | 50% | 47.5d? | 2014-06-13 | 2014-12-05 | 93d? | 657d | finish no earlier than 2014-12-09 | C1-IETF | 760h | 380h | NNI_RS | PCG-33 | christer.holmberg@ericsson.com | christer.holmberg@ericsson.com | Rel-12 | CP-64 |  |  |  |
| 705 | 184.3 | CT3 part of Indication of NNI Routeing scenarios in SIP requests | 66d? | 2014-06-13 A | 2014-09-11 A | 100% |  | 2014-06-13 | 2014-09-12 | 66d? |  | finish no earlier than 2014-09-12 | C3 | 528h | 528h | NNI_RS | PCG-33 | Ericsson | Jan.Holm@ericsson.com | Rel-12 | CP-64 |  |  |  |
| 706 | 185 | Unstructured Supplementary Service Data (USSD) method selection (Stage 3) | 3d? | 2014-06-11 A | 2014-06-13 A | 100% |  | 2014-06-11 | 2014-06-13 | 3d? |  | finish no earlier than 2014-06-13 | C1 | 24h | 24h | USSD_MS | PCG-33 | Ericsson | ivo.sedlacek@ericsson.com | Rel-12 | CP-64 |  | USSD_MS |  |
| 707 | 186 | Representational State Transfer (REST) reference point between Application Function (AF) and Protocol Converter (PC) | 128d? | 2014-06-13 A | 2014-12-09 A | 100% |  | 2014-06-13 | 2014-09-12 | 66d? |  | finish no earlier than 2014-12-09 | C3 | 1024h | 1024h | REST_AF_PC | PCG-33 | Alcatel-Lucent | horst.brinkmann@alcatel-lucent.com | Rel-12 | CP-64 |  | REST_AF_PC | CP-140561 |

Notes:
- 679: Stage 3. Review the references related to RFC 3265 in the 3GPP IMS specifications and determine the impact of the RFC 6665 changes / Impacted TSs and TRs: Stage 3
- 680: CP#65 completion 09/14=>12/14. Exception in CP-140620 / Impacted TSs and TRs: 23.218, 24.141, 24.147, 24.229, 24.237, 24.292, 24.337, 24.341, 24.604, 24.606, 24.623, 24.628, 24.629, 24.642
- 681: CP#62 completed / Impacted TSs and TRs: 29.163, 29.165
- 682: Handling of premium rate numbers remained OPEN in Rel-11 (shifted to Rel-12). CP-130384 LS_out sent to SA1 / GSMA informing this TSG CP#60 decision / Impacted TSs and TRs: Stage 3
- 683: CP#64 completed / Impacted TSs and TRs: 24.229, 24.315
- 684: CP#65 completed / Impacted TSs and TRs: 29.165
- 685: CP#65 completion 09/14=>12/14. Exception in CP-140617.LM: 80->85% / Impacted TSs and TRs: 24.008, 24.301
- 686: Add optional ICE support as defined in Rel-8 TS (23.228, 24.229) to Iq, Ix, Mn, Mp, Mc interfaces. SA2 Rel-12 TS 23.228 requires support for ICE in eP-CSCF, eIMS-AGW for WebRTC / Impacted TSs and TRs: Stage 2/3
- 687: CP#65 completed / Impacted TSs and TRs: 23.333, 23.334, 29.232, 29.238, 29.332, 29.333, 29.334
- 688: CP#64 completed / Impacted TSs and TRs: 29.162, 29.163, 29.292
- 689: Rel-12 enhancements to business trunking (BusTI). ETSI E2NA(14)000019 asked 3GPP to take responsibility of business communications over IMS: TS 181 019, TS 182 023, TS 182 024, TS 182 025, TR 183 060
- 690: SP#65 completed. TS 22.519v200 for Approval / Impacted TSs and TRs: New TS 22.519 (ETSI TS 181 019)
- 691: CP#65 TS 24.525v200 for Approval. TR 24.969v100 for Information. Completion 09/14=>12/14. Exception in CP-140619. LM: 90->100 / Impacted TSs and TRs: New TSs [24.523 (TS 182 023), 24.524 (TS 182 024), 24.525 (TS 182 025)], New TR 24.969 (TR 183 069)
- 692: SA2 TS 23.228 requires UEs supporting IPv4, IPv6 or both IPv4 and IPv6 IP address formats shall be supported by IMS. Specify procedures to support altc SDP attribute within IMS for terminating communications destined to an enterprise network.
- 693: CP#65 completion 09/14=>12/14. Exception in CP-140485. LM: 0->100 / Impacted TSs and TRs: 23.334, 29.238, 29.334
- 694: CP#65 completion 09/14=>12/14. Exception in CP-140611. LM: 0->100 / Impacted TSs and TRs: 24.229
- 695: CP#65 completion 09/14=>12/14. Exception in CP-140563. LM: 0->100 / Impacted TSs and TRs: 29.162
- 696: Triggered by TR 29.809 Study on Diameter overload control mechanism (FS_DOCME)
- 697: CP#65 completion 09/14=>12/14. Exception in CP-140486. LM: 70->100 / Impacted TSs and TRs: 29.228, 29.229, 29.272, 29.273, 29.328, 29.329, 29.336, 29.337, 29.344, 29.345
- 698: work in progress / Impacted TSs and TRs: draft-ietf-dime-ovli
- 699: IETF updated RFC4244 for History-Info header field to RFC7044. IETF introduced new features which could be useful for 3GPP use cases.
- 700: CP#65 completion 09/14=>12/14. Exception in CP-140609. LM: 85->100 / Impacted TSs and TRs: 24.229, 24.259, 24.604
- 701: CP#65 completed / Impacted TSs and TRs: 29.163, 29.165, 29.292
- 702: Triggered by TR 24.802 Study on Indication of Network to Network Interface (NNI) Routeing scenarios in SIP requests UID_580025
- 703: CP#65 completion 09/14=>12/14. Exception in CP-140613. LM: 95->100 / Impacted TSs and TRs: 24.229
- 704: Publication requested / Impacted TSs and TRs: draft-holmberg-dispatch-iotl
- 705: CP#65 completed / Impacted TSs and TRs: 29.079, 29.165
- 706: CP#64 approved WID & completed. Related to R11 USSD simulation service in IMS (delivery of UE originating USSD request using IMS, I.e. introduce 2nd method for delivery of UE originating USSD request to network (additional to USSD using CS domain) / Impacted TSs and TRs: 24.173, 24.390, New TS 24.391
- 707: CP#65 completion 09/14=>12/14. TS 29.201v200 for Approval. Exception in CP-140561. LM: 80->100 / Impacted TSs and TRs: 29.213, 29.214, new TS 29.201

| ID | WBS | Task | Duration | Start | Finish | Complete | Remaining | Baseline start | Baseline finish | Baseline duration | Total slack | Constraint | Resources | Work | Actual work | Acronym | PCG approved | WI rapporteur name | Release | TSG approved | Acronym_3GU_Export | Status Report | MCC resp | Special Focus Doc |
| --- | --- | --- | --- | --- | --- | --- | --- | --- | --- | --- | --- | --- | --- | --- | --- | --- | --- | --- | --- | --- | --- | --- | --- | --- |
| 708 | 187 | **Overload Control for PCC based Diameter applications** | 131d? | 2014-06-13 A | 2014-12-09 | 67% | 43.22d? | 2014-06-13 | 2014-12-05 | 126d? | 657d |  | C3; IETF | 3648h | 2444.54h | DOCME-PCC | PCG-33 | Huawei | Rel-12 | CP-64 | DOCME-PCC |  |  |  |
| 709 | 187.1 | CT3 part of Overload Control for PCC based Diameter applications | 66d? | 2014-06-13 A | 2014-09-11 A | 100% |  | 2014-06-13 | 2014-09-12 | 66d? |  | finish no earlier than 2014-09-12 | C3 | 528h | 528h | DOCME-PCC | PCG-33 | Huawei | Rel-12 | CP-64 |  |  |  |  |
| 710 | 187.2 | (IETF) Overload Control for PCC based Diameter applications | 128d? | 2014-06-13 A | 2014-12-09 | 50% | 64d? | 2014-06-13 | 2014-12-05 | 126d? | 657d | finish no earlier than 2014-12-09 | C3-IETF | 1024h | 512h | DOCME-PCC | PCG-33 | christer.holmberg@ericsson.com | Rel-12 | CP-64 |  |  |  |  |
| 711 | 188 | Network Initiated USSD Simulation Services in IMS | 63d? | 2014-09-12 A | 2014-12-09 A | 100% |  |  |  |  |  | finish no earlier than 2014-12-09 | C1 | 504h | 504h | USSI-NET | PCG-33 | AT&T | Rel-12 | CP-65 | USSI-NET | CP-140610 |  |  |
| 712 | 189 | **Introduction of ER-GSM band for GSM-R** | 651d? | 2011-09-16 A | 2014-02-28 A | 100% |  | 2011-09-16 | 2014-02-28 | 651d? |  |  | G1; C1; G3new | 26496h | 26496h | RT_ERGSM | PCG-27 | Kapsch Carriercom, Sierra Wireless | Rel-12 | GP-51 | RT_ERGSM |  | Paolo |  |
| 713 | 189.1 | GERAN1 part of Introduction of ER-GSM band for GSM-R | 647d? | 2011-09-16 A | 2014-02-28 A | 100% |  | 2011-09-16 | 2014-02-28 | 647d? |  | finish no earlier than 2014-02-28 | G1 | 5168h | 5168h | RT_ERGSM | PCG-27 | Kapsch Carriercom, Sierra Wireless | Rel-12 | GP-51 |  |  | Paolo |  |
| 714 | 189.2 | Test part: Introduction of ER-GSM band for GSM-R | 131d? | 2013-09-02 A | 2014-02-28 A | 100% |  | 2013-09-02 | 2014-02-28 | 131d? |  | finish no earlier than 2014-02-28 | G3new | 1048h | 1048h | RT_ERGSM | PCG-31 | Kapsch Carriercom, Sierra Wireless | Rel-12 | GP-59 |  |  | Ingbert |  |
| 715 | 189.3 | CT1 part of Introduction of ER-GSM band for GSM-R | 582d? | 2011-09-28 A | 2013-12-06 A | 100% |  | 2011-09-28 | 2013-12-06 | 582d? |  | finish no earlier than 2013-12-06 | C1 | 4656h | 4656h | RT_ERGSM | PCG-27 | Kapsch Carriercom, Sierra Wireless | Rel-12 | CP-53 |  |  | Frederic |  |
| 716 | 190 | **Downlink Multi Carrier GERAN** | 666d? | 2012-09-10 A | 2015-03-13 | 91% | 61.92d? | 2012-09-10 | 2014-09-12 | 533d? | 589d |  | G2; G1; C1; G3new | 34536h | 12164.8h | DMCG | PCG-29 | Ericsson | Rel-12 | GP-55 | DMCG |  | Gert |  |
| 717 | 190.1 | Core part: Downlink Multi Carrier GERAN | 229d? | 2013-07-22 A | 2014-05-30 A | 100% |  | 2013-07-22 | 2014-05-30 | 229d? |  | finish no earlier than 2014-05-30 | G2; G1 | 3664h | 3664h | DMCG | PCG-29 | Ericsson | Rel-12 | GP-55 |  |  | Gert |  |
| 718 | 190.2 | CT part: Downlink Multi Carrier GERAN | 533d? | 2012-09-10 A | 2014-09-11 A | 100% |  | 2012-09-10 | 2014-09-12 | 533d? |  | finish no earlier than 2014-09-12 | C1 | 4264h | 4264h | DMCG | PCG-29 | Ericsson | Rel-12 | GP-55 |  |  | Frederic |  |
| 719 | 190.3 | Test part: Downlink Multi Carrier GERAN | 662d? | 2012-09-10 A | 2015-03-13 | 80% | 132.4d? | 2012-09-10 | 2014-08-29 | 522d? | 589d | finish no earlier than 2015-03-13 | G3new | 5296h | 4236.8h | DMCG-MStest | PCG-29 | ST-Ericsson | Rel-12 | GP-55 | DMCG-MStest |  | Ingbert |  |
| 720 | 191 | **Mobile Station Receive Diversity (MSRD) for Voice Services over Adaptive Multi-user channels on One Slot (VAMOS)** | 459d? | 2013-03-01 A | 2014-11-21 A | 100% |  | 2013-03-01 | 2014-08-29 | 396d? |  |  | G1; G2; C1; G3new | 24064h | 24064h | MSRD_VAMOS | PCG-30 | Nokia Networks, Microsoft | Rel-12 | GP-57 | MSRD_VAMOS | GP-140579 | Paolo |  |
| 721 | 191.1 | CT1 introduction of MS capability support for MS supporting MSRD for VAMOS | 205d? | 2013-03-01 A | 2013-12-06 A | 100% |  | 2013-03-01 | 2013-12-06 | 205d? |  | finish no earlier than 2013-12-06 | C1 | 1640h | 1640h | MSRD_VAMOS | PCG-30 | Nokia Networks, Microsoft | Rel-12 | GP-57 |  |  | Frederic |  |
| 722 | 191.2 | MSRD for VAMOS - Performance Requirements | 257.5d? | 2013-11-28 A | 2014-11-21 A | 100% |  | 2013-11-28 | 2014-08-29 | 197.5d? |  | finish no earlier than 2014-11-21 | G1; G2 | 4120h | 4120h | MSRD_VAMOS-PerfReq | PCG-30 | Nokia Networks, Microsoft | Rel-12 | GP-57 | MSRD_VAMOS-PerfReq | GP-140579 | Paolo |  |
| 723 | 191.3 | MSRD for VAMOS - MS Conformance Test | 453d? | 2013-03-06 A | 2014-11-21 A | 100% |  | 2013-03-06 | 2014-08-29 | 393d? |  | finish no earlier than 2014-11-21 | G3new | 3616h | 3616h | MSRD_VAMOS-Test | PCG-30 | Nokia Networks, Microsoft | Rel-12 | GP-57 | MSRD_VAMOS-Test | GP-140579 | Ingbert |  |
| 724 | 192 | **New Training Sequence Codes (TSC) for GERAN** | 277d? | 2013-11-22 A | 2014-12-09 | 76% | 65.75d? | 2013-11-22 | 2014-08-29 | 202d? | 657d |  | G1; G2; C1 | 11184h | 8529.42h | NewToN | PCG-32 | Ericsson | Rel-12 | GP-60 | NewToN | GP-140542 | Paolo |  |
| 725 | 192.1 | GERAN1 part of New Training Sequence Codes (TSC) for GERAN | 261d? | 2013-11-22 A | 2014-11-21 A | 100% |  | 2013-11-22 | 2014-08-29 | 201d? |  | finish no earlier than 2014-11-21 | G1 | 2088h | 2088h | NewToN | PCG-32 | Ericsson | Rel-12 | GP-60 |  | GP-140542 | Paolo |  |
| 726 | 192.2 | GERAN2 part of New Training Sequence Codes (TSC) for GERAN | 261d? | 2013-11-22 A | 2014-11-21 | 80% | 52.2d? | 2013-11-22 | 2014-08-29 | 201d? | 669d | finish no earlier than 2014-11-21 | G2 | 2088h | 1670.4h | NewToN | PCG-32 | Ericsson | Rel-12 | GP-60 |  | GP-140542 | Gert |  |
| 727 | 192.3 | CT1 part of New Training Sequence Codes (TSC) for GERAN (Stage 3) | 273d? | 2013-11-22 A | 2014-12-09 | 50% | 136.5d? | 2013-11-22 | 2014-08-29 | 201d? | 657d | finish no earlier than 2014-12-09 | C1 | 2184h | 1092h | NewToN | PCG-32 | Ericsson | Rel-12 | GP-60 |  | CP-140604 | Frederic |  |
| 728 | 193 | **Verification of radiated multi-antenna reception performance of UEs in LTE/UMTS** | 469d? | 2012-03-05 A | 2013-12-06 A | 100% |  | 2012-03-05 | 2013-12-06 | 469d? |  |  | R4 | 7464h | 7464h | HSPA_LTE_measRP_MIMO | PCG-28 | Vodafone | Rel-12 | RP-55 | HSPA_LTE_measRP_MIMO |  | Issam |  |
| 729 | 193.1 | Perf. Part: Verification of radiated multi-antenna reception performance of UEs in LTE/UMTS | 464d? | 2012-03-05 A | 2013-12-06 A | 100% |  | 2012-03-05 | 2013-12-06 | 464d? |  | finish no earlier than 2013-12-06 | R4 | 3712h | 3712h | HSPA_LTE_measRP_MIMO-Perf | PCG-28 | Vodafone | Rel-12 | RP-55 | HSPA_LTE_measRP_MIMO-Perf | RP-131507 | Issam |  |
| 730 | 194 | **Further enhancements to H(e)NB mobility - Part 3 (Stage 2/3)** | 330d? | 2012-09-12 A | 2013-12-06 A | 100% |  | 2012-09-12 | 2013-12-06 | 330d? |  |  | R3; R2 | 10560h | 10560h | EHNB_enh3 | PCG-29 | Alcatel-Lucent | Rel-12 | RP-57 | EHNB_enh3 |  | Juha | HNB |
| 731 | 194.1 | Core part: Further enhancements to H(e)NB mobility - Part 3 | 330d? | 2012-09-12 A | 2013-12-06 A | 100% |  | 2012-09-12 | 2013-12-06 | 330d? |  | finish no earlier than 2013-12-06 | R3; R2 | 5280h | 5280h | EHNB_enh3-Core | PCG-29 | Alcatel-Lucent | Rel-12 | RP-57 | EHNB_enh3-Core | RP-131508 | Juha | HNB |

Notes:
- 708: Triggered by TR 29.809 Study on Diameter overload control mechanism (FS_DOCME) / WI rapporteur e-mail: Xia Haitao (xiahaitao@huawei.com)
- 709: CP#65 completed / Impacted TSs and TRs: 29.212, 29.213, 29.214 / WI rapporteur e-mail: Xia Haitao (xiahaitao@huawei.com)
- 710: work in progress / Impacted TSs and TRs: draft-ietf-dime-ovli / WI rapporteur e-mail: christer.holmberg@ericsson.com
- 711: CP#65 exception in CP-140610. LM: 75->100 / Impacted TSs and TRs: 24.390 / WI rapporteur e-mail: Martin Dolly (md3135@att.com)
- 712: Use of band 870-876/915-921 MHz for land mobile service on national possibilities/market demand - as per ECC/DEC/(04)06. Introduction of ERGSM band, Performance requirements and Deployment scenarios. / Impacted TSs and TRs: GERAN / WI rapporteur e-mail: thomas.chatelet@kapsch.net, Rémi Lascoux (rlascoux@sierrawireless.com)
- 713: GP#61 completed. GP#51 approved WID / Impacted TSs and TRs: 45.001, 45.005, 45.008, 45.050 / WI rapporteur e-mail: thomas.chatelet@kapsch.net, Rémi Lascoux (rlascoux@sierrawireless.com)
- 714: GP#61 completed / Impacted TSs and TRs: 51.010, 51.021 / WI rapporteur e-mail: thomas.chatelet@kapsch.net, Rémi Lascoux (rlascoux@sierrawireless.com)
- 715: CP#62 completed. Added ERGSM capability indication (24.008 CR#2469R1) / Impacted TSs and TRs: 24.008 / WI rapporteur e-mail: thomas.chatelet@kapsch.net, Rémi Lascoux (rlascoux@sierrawireless.com)
- 716: Linked to Rel-7 Downlink Dual Carrier UID_50579 (Previous work on multiple carriers on the downlink was limited to two). Ref: TR 45.912 Feasibility study for evolved GERAN, TS 43.064 GPRS Stage 2 / Impacted TSs and TRs: GERAN / WI rapporteur e-mail: paul.schliwa-bertling@ericsson.com
- 717: GP#62 completed. GP#55 approved WID / Impacted TSs and TRs: 43.064, 44.004, 44.018, 44.060, 45.002, 45.003, 45.005, 45.008, 48.018 / WI rapporteur e-mail: paul.schliwa-bertling@ericsson.com
- 718: CP#65 completed / Impacted TSs and TRs: 24.008 / WI rapporteur e-mail: paul.schliwa-bertling@ericsson.com
- 719: GP#63 completion 08/14=>11/14. LM: 35->80%, CD:11/14->03/15 / Impacted TSs and TRs: 51.010-1, 51.010-2 / WI rapporteur e-mail: hakan.e.grunditz@stericsson.com
- 720: GP#63 completion 08/14=>11/14. Exception in GP-140579. Linked to Rel-7 Mobile Station Receive Diversity (DARP Phase II) UID_50569, Rel-9 Voice Services over Adaptive Multiuser channels on One Slot (VAMOS) UID_420002 / Impacted TSs and TRs: GERAN / WI rapporteur e-mail: Khairul Hasan (Nokia Networks), Markku Tarkiainen (Nokia=>Microsoft)
- 721: CP#62 completed / Impacted TSs and TRs: 24.008 / WI rapporteur e-mail: Khairul Hasan (Nokia Networks), Markku Tarkiainen (Nokia=>Microsoft)
- 722: GP#63 completion 08/14=>11/14. Exception in GP-140579. LM: 95->100 / Impacted TSs and TRs: 44.018, 45.001, 45.002, 45.005, 45.008, 45.009 / WI rapporteur e-mail: Khairul Hasan (Nokia Networks), Markku Tarkiainen (Nokia=>Microsoft)
- 723: GP#63 completion 08/14=>11/14. Exception in GP-140579. LM: 85->100 / Impacted TSs and TRs: 51.010-1, 51.010-2 / WI rapporteur e-mail: Khairul Hasan (Nokia Networks), Markku Tarkiainen (Nokia=>Microsoft)
- 724: GP#63 completion 08/14=>11/14. Exception in GP-140542. GP#60 approved WID. Triggered by GP-131041, GP#40 GP-081949 (WID VAMOS). Linked to Rel-9 VAMOS (Previous work where new TSCs were defined for GMSK modulation) UID_420002 / Impacted TSs and TRs: GERAN / WI rapporteur e-mail: Mårten Sundberg
- 725: GP#63 completion 08/14=>11/14. Exception in GP-140542. LM: 80->100% / Impacted TSs and TRs: 45.001, 45.002, 45.008, 45.009, 45.050 / WI rapporteur e-mail: Mårten Sundberg
- 726: GP#63 completion 08/14=>11/14. Exception in GP-140542. / Impacted TSs and TRs: 44.018, 44.060 / WI rapporteur e-mail: Mårten Sundberg
- 727: CP#65 completion 09/14=>12/14. CP#65 exception in CP-140604. / Impacted TSs and TRs: 24.008 / WI rapporteur e-mail: Mårten Sundberg
- 728: RP#59 moved to Rel-12. Triggered by FS_HSPA_LTE_measRP_MIMO_multi-antenna. Core functionality exists since Rel-6 & Rel-7 (MIMO). Adds a very generic test method to test UEs with 2 or more Rx antennas / Impacted TSs and TRs: UTRA, LTE / WI rapporteur e-mail: Luis Anaya
- 729: RP#62 completed. Rx diversity (defined as Rel-6 HSDPA RAN4 enhanced type 1 req.) & MIMO (defined as Rel-7 HSDPA MIMO for HSPA). Rx diversity & MIMO (defined as part of Rel-8 basic LTE WI) / Impacted TSs and TRs: new TR 37.977 / WI rapporteur e-mail: luis.anaya@vodafone.com
- 730: Triggered by FS_EHNB_enh (TR 37.803) / Impacted TSs and TRs: UTRA, LTE / WI rapporteur e-mail: Martin.Warner@alcatel-lucent.com
- 731: RP#62 completed / Impacted TSs and TRs: 25.304, 25.331, 25.367, 25.467, 25.469, 36.300, 36.331 / WI rapporteur e-mail: Martin.Warner@alcatel-lucent.com

| ID | WBS | Task | Duration | Start | Finish | Complete | Remaining | Baseline start | Baseline finish | Baseline duration | Total slack | Constraint | Resources | Work | Actual work | Acronym | PCG approved | WI rapporteur name | Release | TSG approved | MCC resp | Acronym_3GU_Export | Status Report | PCG stopped | TSG stopped | Special Focus Doc |
| --- | --- | --- | --- | --- | --- | --- | --- | --- | --- | --- | --- | --- | --- | --- | --- | --- | --- | --- | --- | --- | --- | --- | --- | --- | --- | --- |
| 732 | 195 | **LTE UE Total Radiated Power (TRP) and Total Radiated Sensitivity (TRS) and UTRA Hand Phantom related UE TRP and TRS Requirements** | 790d? | 2012-12-15 A | 2015-12-15 | 29% | 563.41d? | 2013-03-15 | 2015-06-12 | 591d? | 393d |  | R4; R5 | 17692h | 4221.9h | LTE_UTRA_TRP_TRS | PCG-30 | Nokia | Rel-12 | RP-58 | Issam | LTE_UTRA_TRP_TRS |  |  |  |  |
| 733 | 195.1 | Core part: LTE UE TRP and TRS and UTRA Hand Phantom related UE TRP and TRS Requirements | 719d? | 2012-12-15 A | 2015-12-15 | 35% | 467.35d? | 2013-03-15 | 2014-09-12 | 393d? | 393d | finish no earlier than 2015-12-15 | R4 | 5752h | 2013.2h | LTE_UTRA_TRP_TRS-Core | PCG-30 | Nokia | Rel-12 | RP-58 | Issam | LTE_UTRA_TRP_TRS-Core | RP-141158 |  |  |  |
| 734 | 195.2 | Test part: LTE UE TRP and TRS and UTRA Hand Phantom | 332d? | 2014-03-15 A | 2015-06-19 | 15% | 282.2d? | 2014-03-06 | 2015-06-12 | 332d? | 519d | finish no earlier than 2015-06-15 | R5 | 2656h | 398.4h | LTE_UTRA_TRP_TRS-UEConTest | PCG-32 | ZTE | Rel-12 | RP-63 | Ingbert | LTE_UTRA_TRP_TRS-UEConTest | RP-141132 |  |  |  |
| 735 | 196 | **Support for BeiDou Navigation Satellite System (BDS) for UTRA and LTE** | 603d? | 2013-03-04 A | 2015-06-15 | 96% | 23.5d? | 2013-03-04 | 2015-06-12 | 600d? | 524d |  | R2; R3; R4; R5 | 31640h | 16574.4h | LCS_BDS | PCG-30 | CATR | Rel-12 | RP-59 | Yong-Jun | LCS_BDS |  |  |  |  |
| 736 | 196.1 | Core part: Support for BeiDou Navigation Satellite System (BDS) for UTRA | 204d? | 2013-06-02 A | 2014-03-06 A | 100% |  | 2013-06-02 | 2014-03-06 | 204d? |  | finish no earlier than 2014-03-06 | R2; R3 | 3264h | 3264h | LCS_BDS-UTRA-Core | PCG-30 | ZTE | Rel-12 | RP-59 | Yong-Jun | LCS_BDS-UTRA-Core | RP-131500 |  |  |  |
| 737 | 196.2 | Perf. part: Support for BeiDou Navigation Satellite System (BDS) for UTRA | 336d? | 2013-03-07 A | 2014-06-13 A | 100% |  | 2013-03-07 | 2014-06-13 | 336d? |  | finish no earlier than 2014-06-13 | R4 | 2688h | 2688h | LCS_BDS-UTRA-Perf | PCG-30 | ZTE | Rel-12 | RP-59 | Issam | LCS_BDS-UTRA-Perf | RP-140714 |  |  |  |
| 738 | 196.3 | Core part: Support for BeiDou Navigation Satellite System (BDS) for LTE | 202d? | 2013-03-04 A | 2013-12-06 A | 100% |  | 2013-03-04 | 2013-12-06 | 202d? |  | finish no earlier than 2013-12-06 | R2 | 1616h | 1616h | LCS_BDS-LTE-Core | PCG-30 | CATR | Rel-12 | RP-59 | Yong-Jun | LCS_BDS-LTE-Core | RP-131525 |  |  |  |
| 739 | 196.4 | Perf. part: Support for BeiDou Navigation Satellite System (BDS) for LTE | 336d? | 2013-03-07 A | 2014-06-13 A | 100% |  | 2013-03-07 | 2014-06-13 | 336d? |  | finish no earlier than 2014-06-13 | R4 | 2688h | 2688h | LCS_BDS-LTE-Perf | PCG-30 | ZTE | Rel-12 | RP-59 | Issam | LCS_BDS-LTE-Perf | RP-140713 |  |  |  |
| 740 | 196.5 | Test part: BeiDou Navigation Satellite System (BDS) Positioning Support for LTE and UMTS | 261d? | 2014-06-15 A | 2015-06-15 | 80% | 52.2d? | 2014-06-13 | 2015-06-12 | 261d? | 524d | finish no earlier than 2015-06-15 | R5 | 2088h | 1670.4h | LCS_BDS-UEConTest | PCG-33 | CATT | Rel-12 | RP-64 |  | LCS_BDS-UEConTest | RP-141350 |  |  |  |
| 741 | 197 | **Support for BeiDou Navigation Satellite System (BDS) for LCS in GERAN** | 345d? | 2013-11-22 A | 2015-03-13 | 93% | 25.19d? | 2013-11-22 | 2014-11-21 | 262d? | 589d |  | G2; G1; G3new | 14213.2h | 5848.39h | LCS_BDS_GERAN | PCG-32 | ZTE | Rel-12 | GP-60 | Gert | LCS_BDS_GERAN |  |  |  |  |
| 742 | 197.1 | GERAN2 part of Support for BeiDou Navigation Satellite System (BDS) for LCS in GERAN | 201d? | 2013-11-22 A | 2014-08-29 A | 100% |  | 2013-11-22 | 2014-08-29 | 201d? |  | finish no earlier than 2014-08-29 | G2 | 1608h | 1608h | LCS_BDS_GERAN | PCG-32 | ZTE | Rel-12 | GP-60 | Gert |  |  |  |  |  |
| 743 | 197.2 | GERAN1 part of Support for BeiDou Navigation Satellite System (BDS) for LCS in GERAN | 201d? | 2013-11-22 A | 2014-08-29 A | 100% |  | 2013-11-22 | 2014-08-29 | 201d? |  | finish no earlier than 2014-08-29 | G1 | 1608h | 1608h | LCS_BDS_GERAN | PCG-32 | ZTE | Rel-12 | GP-60 | Paolo |  |  |  |  |  |
| 744 | 197.3 | Support for BeiDou Navigation Satellite System (BDS) for LCS in GERAN3new | 272d? | 2014-03-01 A | 2015-03-13 | 80% | 54.4d? | 2014-02-28 | 2014-11-21 | 192d? | 589d | finish no earlier than 2015-03-13 | G3new | 2176h | 1740.8h | LCS_BDS_GERAN-GERAN3new | PCG-32 | CATR | Rel-12 | GP-61 | Ingbert | LCS_BDS_GERAN-GERAN3new |  |  |  |  |
| 745 | 197.4 | Deleted - Test part: Support for BeiDou Navigation Satellite System (BDS) for LCS in GERAN | 71d? | 2013-11-22 A | 2014-02-28 A | 100% |  | 2013-11-22 | 2014-02-28 | 71d? |  | finish no earlier than 2014-08-29 | G3new | 565.19h | 565.19h | LCS_BDS_GERAN-MStest | PCG-32 | ZTE | Rel-12 | GP-60 | Ingbert | LCS_BDS_GERAN-MStest |  | PCG-32 | GP-61 |  |
| 746 | 198 | **Base Station (BS) RF requirements for Active Antenna System (AAS)** | 869d? | 2013-03-04 A | 2016-06-18 | 39% | 527.22d? | 2013-03-04 | 2014-12-05 | 465d? | 258d |  | R4 | 17536h | 5945.56h | AAS_BS_LTE_UTRA | PCG-30 | Huawei | Rel-12 | RP-59 | Issam | AAS_BS_LTE_UTRA |  |  |  |  |
| 747 | 198.1 | Core part: Base Station (BS) RF requirements for Active Antenna System (AAS) | 465d? | 2013-03-04 A | 2014-12-11 | 75% | 116.25d? | 2013-03-04 | 2014-09-12 | 401d? | 655d | finish no earlier than 2014-12-11 | R4 | 3720h | 2790h | AAS_BS_LTE_UTRA-Core | PCG-30 | Huawei | Rel-12 | RP-59 | Issam | AAS_BS_LTE_UTRA-Core | RP-141249 |  |  |  |
| 748 | 198.2 | Perf. part: Base Station (BS) RF requirements for Active Antenna System (AAS) | 858d? | 2013-03-15 A | 2016-06-18 | 20% | 686.4d? | 2013-03-07 | 2014-12-05 | 461d? | 258d | finish no earlier than 2016-06-15 | R4 | 6864h | 1372.8h | AAS_BS_LTE_UTRA-Perf | PCG-30 | Huawei | Rel-12 | RP-59 | Issam | AAS_BS_LTE_UTRA-Perf | RP-141249 |  |  |  |
| 749 | 199 | **Deleted - New Base Station specification structure** | 127d? | 2013-06-18 A | 2013-12-06 A | 100% |  | 2013-06-18 | 2013-12-06 | 127d? |  |  | R4 | 3024h | 3024h | BSspec_struc | PCG-31 | Ericsson | Rel-12 | RP-60 | Issam | BSspec_struc |  | PCG-32 | RP-62 |  |
| 750 | 199.1 | Deleted - Core part: New Base Station specification structure | 126d? | 2013-06-18 A | 2013-12-06 A | 100% |  | 2013-06-18 | 2013-12-06 | 126d? |  | finish no earlier than 2013-12-06 | R4 | 1008h | 1008h | BSspec_struc-Core | PCG-31 | Ericsson | Rel-12 | RP-60 | Issam | BSspec_struc-Core | RP-131513 | PCG-32 | RP-62 |  |
| 751 | 199.2 | Deleted - Perf. part: New Base Station specification structure | 125d? | 2013-06-20 A | 2013-12-06 A | 100% |  | 2013-06-20 | 2013-12-06 | 125d? |  | finish no earlier than 2013-12-06 | R4 | 1000h | 1000h | BSspec_struc-Perf | PCG-31 | Ericsson | Rel-12 | RP-60 | Issam | BSspec_struc-Perf | RP-131514 | PCG-32 | RP-62 |  |
| 752 | 200 | **L-band for Supplemental Downlink in E-UTRA and UTRA** | 264d? | 2013-06-17 A | 2014-06-13 A | 100% |  | 2013-06-17 | 2014-06-13 | 264d? |  |  | R4; R2; R3 | 10544h | 10544h | LTE_UTRA_SDL_BandL | PCG-31 | Orange | Rel-12 | RP-60 | Issam | LTE_UTRA_SDL_BandL |  |  |  |  |
| 753 | 200.1 | Core part: L-band for Supplemental Downlink in E-UTRA and UTRA | 87.33d? | 2014-02-13 A | 2014-06-13 A | 100% |  | 2014-02-13 | 2014-06-13 | 87.33d? |  | finish no earlier than 2014-06-13 | R4; R2; R3 | 2096h | 2096h | LTE_UTRA_SDL_BandL-Core | PCG-31 | Orange | Rel-12 | RP-60 | Issam | LTE_UTRA_SDL_BandL-Core | RP-140633 |  |  |  |
| 754 | 200.2 | Perf. part: L-band for Supplemental Downlink in E-UTRA and UTRA | 264d? | 2013-06-17 A | 2014-06-13 A | 100% |  | 2013-06-17 | 2014-06-13 | 264d? |  | finish no earlier than 2014-06-13 | R4 | 2112h | 2112h | LTE_UTRA_SDL_BandL-Perf | PCG-31 | Orange | Rel-12 | RP-60 | Issam | LTE_UTRA_SDL_BandL-Perf | RP-140633 |  |  |  |
| 755 | 201 | **LTE-HRPD (High Rate Packet Data in 3GPP2) inter-RAT SON** | 263d? | 2013-06-18 A | 2014-06-13 A | 100% |  | 2013-06-18 | 2014-06-13 | 263d? |  |  | R3; S2; C4; G2 | 11096h | 11096h | LTE_HRPD_SON | PCG-31 | China Telecom | Rel-12 | RP-60 | Juha | LTE_HRPD_SON |  |  |  | SON |
| 756 | 201.1 | Stage 2 for LTE-HRPD (High Rate Packet Data in 3GPP2) inter-RAT SON | 67d? | 2013-09-11 A | 2013-12-11 A | 100% |  | 2013-09-11 | 2013-12-11 | 67d? |  | finish no earlier than 2013-09-11 | S2 | 528h | 528h | LTE_HRPD_SON | PCG-31 | Huawei | Rel-12 | SP-61 | Maurice |  |  |  |  |  |
| 757 | 201.2 | Core part: LTE-HRPD (High Rate Packet Data in 3GPP2) inter-RAT SON | 263d? | 2013-06-18 A | 2014-06-13 A | 100% |  | 2013-06-18 | 2014-06-13 | 263d? |  | finish no earlier than 2014-06-13 | R3 | 2088h | 2088h | LTE_HRPD_SON-Core | PCG-31 | China Telecom | Rel-12 | RP-60 | Juha | LTE_HRPD_SON-Core | RP-140745 |  |  |  |
| 758 | 201.3 | CT aspects for LTE-HRPD (High Rate Packet Data in 3GPP2) inter-RAT SON (Stage 3) | 3d? | 2013-09-04 A | 2013-09-06 A | 100% |  | 2013-09-04 | 2013-09-06 | 3d? |  | finish no earlier than 2013-09-06 | C4 | 24h | 24h | LTE_HRPD_SON-CT | PCG-31 | Huawei | Rel-12 | CP-61 | Kimmo | LTE_HRPD_SON-CT |  |  |  |  |
| 759 | 201.4 | GERAN aspects for LTE-HRPD inter-RAT SON, RAN Information Management (RIM) - Stage 3 | 5d? | 2013-08-26 A | 2013-08-30 A | 100% |  | 2013-08-26 | 2013-08-30 | 5d? |  | finish no earlier than 2013-09-06 | G2 | 40h | 40h | LTE_HRPD_SON-RIM | PCG-31 | Alcatel-Lucent | Rel-12 | GP-59 | Gert | LTE_HRPD_SON-RIM |  |  |  |  |

Notes:
- 732: Triggered by Rel-11 TR 37.902 Study on Measurements of radio performances for LTE terminals - TRP and TRS test methodology (FS_LTE_OTA) UID_550022 / Impacted TSs and TRs: UTRA, LTE / WI rapporteur e-mail: petri.j.vasenkari@nokia.com
- 733: Prev CD:Thu 11/12/14; Prev %:30%; WID: RP-130703 => RP-141966 / Impacted TSs and TRs: 25.144, New (TS 37.144, TR 37.844) / WI rapporteur e-mail: petri.j.vasenkari@nokia.com
- 734: Prev CD:Fri 12/06/15; Prev %:10% / Impacted TSs and TRs: New TS 37.544 / WI rapporteur e-mail: TAYLOR Carolyn (carolyn.tayl@zte.com.cn)
- 735: BeiDou = Chinese Navigation Satellite System. Location Services (LCS) TS 22.071 Stage 1, TS 23.271 Stage 2 / Impacted TSs and TRs: UTRA, LTE / WI rapporteur e-mail: Ying Du (duying1@catr.cn)
- 736: RP#62 completed / Impacted TSs and TRs: 25.305, 25.306, 25.331, 25.453, 25.413, 25.423, 25.433 / WI rapporteur e-mail: Huang He (huang.he4@zte.com.cn)
- 737: RP#64 completed. TS 25.173v100 for 1-step Approval / Impacted TSs and TRs: 25.172 (FDD), new TS 25.173 (TDD) / WI rapporteur e-mail: Ling Soonleh (soonleh.ling@zte.com.cn)
- 738: RP#62 completed / Impacted TSs and TRs: 36.305, 36.355 / WI rapporteur e-mail: Ying Du (duying1@catr.cn)
- 739: RP#64 completed / Impacted TSs and TRs: 36.171 / WI rapporteur e-mail: Ling Soonleh (soonleh.ling@zte.com.cn)
- 740: Prev CD:Fri 12/06/15; Prev %:5% / Impacted TSs and TRs: 34.108, 36.508, 37.571-1, 37.571-2, 37.571-3, 37.571-4, 37.571-5 / WI rapporteur e-mail: Chen Xiaiozhong (chenxiaozhong@catt.cn)
- 741: GP#60 approved WID. Based on the same framework used in Rel-8 Support for Additional Navigation Satellite Systems (ANSS) for LCS UID_38001 / Impacted TSs and TRs: GERAN / WI rapporteur e-mail: Wang Xinhui (wangxinhui@zte.com.cn)
- 742: GP#63 completed / Impacted TSs and TRs: 44.031, 49.031, 44.071, 48.031 / WI rapporteur e-mail: Wang Xinhui (wangxinhui@zte.com.cn)
- 743: GP#63 completed / Impacted TSs and TRs: 43.059, 45.005 / WI rapporteur e-mail: Wang Xinhui (wangxinhui@zte.com.cn)
- 744: LM: 25->80%, CD: 11/14->03/15 / Impacted TSs and TRs: 51010-1, 51.010-2, 51.010-7 / WI rapporteur e-mail: Zhou DaiWei, China Academy of Telecommunication Research, zhoudaiwei@catr.cn
- 745: GP#61 stopped / Impacted TSs and TRs: 51.010-1 / WI rapporteur e-mail: Wang Xinhui (wangxinhui@zte.com.cn)
- 746: Triggered by Rel-12 TR 37.840 Study of RF and EMC Requirements for Active Antenna Array System BS (FS_AAS_BS_LTE_UTRA) / Impacted TSs and TRs: UTRA, LTE, GERAN / WI rapporteur e-mail: ronnie.zhang@huawei.com
- 747: RP#65 completion 09/14=>12/14. Exception in RP-141713. TR 37.842v100 for Information; ; WID: RP-130703 => RP-141966 / Impacted TSs and TRs: New TS 37.142 (AAS BS Tx & Rx), New TR 37.842 / WI rapporteur e-mail: ronnie.zhang@huawei.com
- 748: CD:Fri 12/06/15->Wed 15/06/16; Compl:20%20%; ; WID: RP-130703 => RP-141966 / Impacted TSs and TRs: New TS 37.1xy (AAS BS conformance testing) / WI rapporteur e-mail: ronnie.zhang@huawei.com
- 749: Triggered by Rel-12 TR 37.810 Study on Base Station specification structure (FS_BSspec_struc) / Impacted TSs and TRs: UTRA, LTE, MSR / WI rapporteur e-mail: johan.skold@ericsson.com
- 750: RP#62 stopped (at 20% completion) / Impacted TSs and TRs: 25.104, 25.105, 36.104, 37.104, 37.810, New TR 37.811 (New BS specification structure), New TS 37.xya (New RF core specification) / WI rapporteur e-mail: johan.skold@ericsson.com
- 751: RP#62 stopped (at 0% completion) / Impacted TSs and TRs: 25.113, 25.141, 25.142, 36.113, 36.141, 37.113, 37.141, 37.810, New TS 37.xyz (New RF test specification, New TS 37.xyw (ew EMC specification) / WI rapporteur e-mail: johan.skold@ericsson.com
- 752: ECC(12)052 CEPT decision to harmonize 1452-1492 MHz (L-band) for mobile communications Supplemental Downlink (SDL) => standardize L-band and corresponding E-UTRA and UTRA requirements for SDL operation in Region 1 / Impacted TSs and TRs: UTRA, LTE / WI rapporteur e-mail: olfa.benhaddada@orange.com
- 753: RP#64 completed. RP#65 forgotten TR 37.814 v100 for 1-step Approval / Impacted TSs and TRs: 25.101, 25.104, 25.113, 25.133, 25.307, 25.327, 25.461, 25.466, 34.124, 36.101, 36.104, 36.113, 36.124, 36.133, 36.307, 36.331, 37.104, 37.113, new TR 37.814 / WI rapporteur e-mail: olfa.benhaddada@orange.com
- 754: RP#64 completed / Impacted TSs and TRs: 25.133, 25.141, 25.307, 25.327, 36.133, 36.141, 36.307, 37.141 / WI rapporteur e-mail: olfa.benhaddada@orange.com
- 755: Triggered by Rel-12 TR 37.813 (FS_LTE_HRPD_SON). SA2 should verify the architecture solution in TR 37.813 for inter-RAT load balancing between LTE-HRPD. CT4 should specify the RIM extension to support the feature. / Impacted TSs and TRs: UTRA, LTE / WI rapporteur e-mail: Jinlian_wu@189.cn
- 756: SP#62 completed / Impacted TSs and TRs: 23.402 / WI rapporteur e-mail: Huan Li (ivy.lihuan@huawei.com)
- 757: RP#64 completed / Impacted TSs and TRs: 36.300, 36.413 / WI rapporteur e-mail: Jinlian_wu@189.cn
- 758: CP#61 WID approved & Completed / Impacted TSs and TRs: 29.274, 29.276, 29.280 / WI rapporteur e-mail: Xiaoyan SHI (sean.shixiaoyan@huawei.com
- 759: GP#59 WID approved & Completed / Impacted TSs and TRs: 48.018 / WI rapporteur e-mail: marguerite.woch@alcatel-lucent.com

| ID | WBS | Task | Duration | Start | Finish | Complete | Remaining | Baseline start | Baseline finish | Baseline duration | Total slack | Constraint | Resources | Work | Actual work | Acronym | PCG approved | Impacted TSs and TRs | WI rapporteur name | WI rapporteur e-mail | Release | TSG approved | MCC resp | Acronym_3GU_Export | Status Report | Special Focus Doc | PCG stopped | TSG stopped |
| --- | --- | --- | --- | --- | --- | --- | --- | --- | --- | --- | --- | --- | --- | --- | --- | --- | --- | --- | --- | --- | --- | --- | --- | --- | --- | --- | --- | --- |
| 760 | 202 | **Increasing the minimum number of carriers for UE monitoring in UTRA and E-UTRA** | 394d? | 2013-12-15 A | 2015-06-12 | 37% | 246.62d? | 2013-12-09 | 2015-03-13 | 331d? | 524d |  | R4; R2 | 11316.4h | 2126.8h | LTE_UTRA_IncMon | PCG-32 | UTRA, LTE | Ericsson | christopher.callender@ericsson.com | Rel-12 | RP-62 | Issam | LTE_UTRA_IncMon |  |  |  |  |
| 761 | 202.1 | Core part: Increasing the minimum number of carriers for UE monitoring in UTRA and E-UTRA | 204d? | 2013-12-15 A | 2014-12-18 A | 100% |  | 2014-01-06 | 2014-09-12 | 133d? |  | finish no earlier than 2014-12-15 | R4; R2 | 1860.4h | 1860.4h | LTE_UTRA_IncMon-Core | PCG-32 | 25.133, 25.331, 36.133 | Ericsson | christopher.callender@ericsson.com | Rel-12 | RP-62 | Issam | LTE_UTRA_IncMon-Core | RP-141600 |  |  |  |
| 762 | 202.2 | Perf. part: Increasing the minimum number of carriers for UE monitoring in UTRA and E-UTRA | 394d? | 2013-12-15 A | 2015-06-12 | 5% | 374.3d? | 2013-12-09 | 2015-03-13 | 331d? | 524d | start no earlier than 2013-12-15 | R4 | 3152h | 157.6h | LTE_UTRA_IncMon-Perf | PCG-32 | 25.133, 36.133 | Ericsson | christopher.callender@ericsson.com | Rel-12 | RP-62 | Issam | LTE_UTRA_IncMon-Perf | RP-141600 |  |  |  |
| 763 | 203 | **WLAN/3GPP Radio Interworking** | 267d? | 2013-12-06 A | 2014-12-09 | 97% | 8.44d? | 2013-12-06 | 2014-09-17 | 205d? | 657d |  | R2; S2; C1; C4 | 11021h | 8517.21h | UTRA_LTE_WLAN_interw | PCG-32 | UTRA, LTE | Intel | sasha.sirotkin@intel.com | Rel-12 | RP-62 | Yong-Jun | UTRA_LTE_WLAN_interw |  | WLAN |  |  |
| 764 | 203.1 | Core part: WLAN/3GPP Radio Interworking | 202d? | 2013-12-06 A | 2014-09-12 A | 100% |  | 2013-12-06 | 2014-09-12 | 202d? |  | finish no earlier than 2014-09-12 | R2 | 1616h | 1616h | UTRA_LTE_WLAN_interw-Core | PCG-32 | 25.304, 25.306, 25.331, 36.304, 36.306, 36.331 | Intel | sasha.sirotkin@intel.com | Rel-12 | RP-62 | Yong-Jun | UTRA_LTE_WLAN_interw-Core | RP-141310 | WLAN |  |  |
| 765 | 203.2 | SA2 aspects of WLAN/3GPP Radio Interworking | 140d? | 2014-03-07 A | 2014-09-17 A | 100% |  | 2014-03-07 | 2014-09-17 | 139d? |  | finish no earlier than 2014-09-17 | S2 | 1120h | 1120h | UTRA_LTE_WLAN_interw-SA2 | PCG-32 | 23.402, 23.401, 23.060, 23.251 | Alcatel-Lucent | nicolas.drevon@alcatel-lucent.com | Rel-12 | SP-63 | Maurice | UTRA_LTE_WLAN_interw-SA2 |  | WLAN |  |  |
| 766 | 203.3 | **CT aspects of WLAN/3GPP Radio Interworking (Stage 2/3)** | 68d? | 2014-09-09 A | 2014-12-09 | 89% | 7.77d? | 2014-06-13 | 2014-09-12 | 66d? | 657d |  | C1; C4 | 1665.6h | 1444.26h | UTRA_LTE_WLAN_interw-CT | PCG-33 | Stage 2/3 | Alcatel-Lucent | jennifer.liu@alcatel-lucent.com | Rel-12 | CP-64 |  | UTRA_LTE_WLAN_interw-CT |  | WLAN |  |  |
| 767 | 203.3.1 | CT1 part of CT aspects of WLAN/3GPP Radio Interworking (Stage 3) | 68d? | 2014-09-09 A | 2014-12-09 | 78% | 14.96d? | 2014-06-13 | 2014-09-12 | 66d? | 657d | finish no earlier than 2014-12-09 | C1 | 528h | 424.32h | UTRA_LTE_WLAN_interw-CT | PCG-33 | 24.008, 24.301, 24.302, 24.312 | Alcatel-Lucent | jennifer.liu@alcatel-lucent.com | Rel-12 | CP-64 |  |  | CP-140720 | WLAN |  |  |
| 768 | 203.3.2 | CT4 part of CT aspects of WLAN/3GPP Radio Interworking (Stage 2/3) | 63d? | 2014-09-12 A | 2014-12-09 A | 100% |  |  |  |  |  | finish no earlier than 2014-12-09 | C4 | 504h | 504h | UTRA_LTE_WLAN_interw-CT | PCG-33 | 23.008, 29.002, 29.272, 29.274, 29.305 | Alcatel-Lucent | jennifer.liu@alcatel-lucent.com | Rel-12 | CP-65 |  |  | CP-140482 | WLAN |  |  |
| 769 | 204 | **Rel-12 LTE Carrier Aggregation** | 1186d? | 2011-09-19 A | 2016-03-15 | 99% | 16.59d? | 2011-09-19 | 2014-12-11 | 855d? | 327d |  | R4 | 510222h | 491838h | LTE_CA_Rel-12 | PCG-30 | LTE |  |  | Rel-12 | RP-58 | Issam | LTE_CA_Rel-12 |  | CA |  |  |
| 770 | 204.1 | **LTE Advanced inter-band Carrier Aggregation of Band 1 and Band 7** | 792d? | 2011-09-19 A | 2014-09-12 A | 100% |  | 2011-09-19 | 2014-09-12 | 791d? |  |  | R4 | 18896h | 18896h | LTE_CA_B1_B7 | PCG-27 | LTE | Ericsson | christian.bergljung@ericsson.com | Rel-12 | RP-53 | Issam | LTE_CA_B1_B7 |  | CA |  |  |
| 771 | 204.1.1 | Core part: LTE Advanced inter-band Carrier Aggregation of Band 1 and Band 7 | 790d? | 2011-09-19 A | 2014-09-12 A | 100% |  | 2011-09-19 | 2014-09-12 | 790d? |  | finish no earlier than 2014-09-12 | R4 | 6312h | 6312h | LTE_CA_B1_B7-Core | PCG-27 | 36.101, 36.104, new generic TR 36.851 | Ericsson | christian.bergljung@ericsson.com | Rel-12 | RP-53 | Issam | LTE_CA_B1_B7-Core | RP-141084 | CA |  |  |
| 772 | 204.1.2 | Perf. part: LTE Advanced inter-band Carrier Aggregation of Band 1 and Band 7 | 781d? | 2011-10-03 A | 2014-09-12 A | 100% |  | 2011-09-30 | 2014-09-12 | 781d? |  | finish no earlier than 2014-09-12 | R4 | 6248h | 6248h | LTE_CA_B1_B7-Perf | PCG-27 | 36.141, 36.307 | Ericsson | christian.bergljung@ericsson.com | Rel-12 | RP-53 | Issam | LTE_CA_B1_B7-Perf | RP-141084 | CA |  |  |
| 773 | 204.2 | **LTE Advanced intra-band non-contiguous Carrier Aggregation in Band 25** | 462d? | 2011-09-19 A | 2013-06-14 A | 100% |  | 2011-09-19 | 2013-06-14 | 462d? |  |  | R4 | 11056h | 11056h | LTE_CA_NC_B25 | PCG-27 | LTE | Sprint | George.Cummings@sprint.com | Rel-12 | RP-53 | Issam | LTE_CA_NC_B25 |  | CA |  |  |
| 774 | 204.2.1 | Core part: LTE Advanced intra-band non-contiguous Carrier Aggregation in Band 25 | 459d? | 2011-09-19 A | 2013-06-14 A | 100% |  | 2011-09-19 | 2013-06-14 | 459d? |  | finish no earlier than 2013-06-14 | R4 | 3672h | 3672h | LTE_CA_NC_B25-Core | PCG-27 | 36.101, 36.104, 36.133, new TR 36.833-2-25 | Sprint | George.Cummings@sprint.com | Rel-12 | RP-53 | Issam | LTE_CA_NC_B25-Core | RP-130563 | CA |  |  |
| 775 | 204.2.2 | Perf. part: LTE Advanced intra-band non-contiguous Carrier Aggregation in Band 25 | 461d? | 2011-09-19 A | 2013-06-14 A | 100% |  | 2011-09-19 | 2013-06-14 | 461d? |  | finish no earlier than 2013-06-14 | R4 | 3688h | 3688h | LTE_CA_NC_B25-Perf | PCG-27 | 36.141, 36.307 | Sprint | George.Cummings@sprint.com | Rel-12 | RP-53 | Issam | LTE_CA_NC_B25-Perf | RP-130759 | CA |  |  |
| 776 | 204.3 | **Deleted - LTE Advanced inter-band Carrier Aggregation of Band 3 and Band 5 with 2UL** | 265d? | 2012-03-05 A | 2013-03-01 A | 100% |  | 2012-03-05 | 2013-03-01 | 265d? |  |  | R4 | 6296h | 6296h | LTE_CA_B3_B5_2UL | PCG-28 | LTE | SK Telecom | Seungpyo Hong | Rel-12 | RP-55 | Issam | LTE_CA_B3_B5_2UL |  | CA | PCG-30 | RP-59 |
| 777 | 204.3.1 | Deleted - Core part: LTE Advanced inter-band Carrier Aggregation of Band 3 and Band 5 with 2UL | 262d? | 2012-03-05 A | 2013-03-01 A | 100% |  | 2012-03-05 | 2013-03-01 | 262d? |  | finish no earlier than 2013-03-01 | R4 | 2096h | 2096h | LTE_CA_B3_B5_2UL-Core | PCG-28 | 36.101, 36.104, 36.133, 36.307, new generic TR 36.851 | SK Telecom | Seungpyo Hong | Rel-12 | RP-55 | Issam | LTE_CA_B3_B5_2UL-Core | RP-130098 | CA | PCG-30 | RP-59 |
| 778 | 204.3.2 | Deleted - Perf. part: LTE Advanced inter-band Carrier Aggregation of Band 3 and Band 5 with 2UL | 260d? | 2012-03-12 A | 2013-03-01 A | 100% |  | 2012-03-12 | 2013-03-01 | 260d? |  | finish no earlier than 2013-03-01 | R4 | 2080h | 2080h | LTE_CA_B3_B5_2UL-Perf | PCG-28 | 36.133, 36.141 | SK Telecom | Seungpyo Hong | Rel-12 | RP-55 | Issam | LTE_CA_B3_B5_2UL-Perf | RP-130099 | CA | PCG-30 | RP-59 |
| 779 | 204.4 | **LTE Advanced intra-band non-contiguous Carrier Aggregation in Band 3** | 469d? | 2012-03-05 A | 2013-12-06 A | 100% |  | 2012-03-05 | 2013-12-06 | 469d? |  |  | R4 | 11136h | 11136h | LTE_CA_NC_B3 | PCG-28 | LTE | SK Telecom | haesung.park@sk.com | Rel-12 | RP-55 | Issam | LTE_CA_NC_B3 |  | CA |  |  |
| 780 | 204.4.1 | Core part: LTE Advanced intra-band non-contiguous Carrier Aggregation in Band 3 | 462d? | 2012-03-05 A | 2013-12-06 A | 100% |  | 2012-03-05 | 2013-12-06 | 462d? |  | finish no earlier than 2013-12-06 | R4 | 3696h | 3696h | LTE_CA_NC_B3-Core | PCG-28 | 36.101, 36.104, 36.133, new TR 36.833-2-03 | SK Telecom | haesung.park@sk.com | Rel-12 | RP-55 | Issam | LTE_CA_NC_B3-Core | RP-131573 | CA |  |  |
| 781 | 204.4.2 | Perf. part: LTE Advanced intra-band non-contiguous Carrier Aggregation in Band 3 | 461d? | 2012-03-15 A | 2013-12-06 A | 100% |  | 2012-03-15 | 2013-12-06 | 461d? |  | finish no earlier than 2013-12-06 | R4 | 3688h | 3688h | LTE_CA_NC_B3-Perf | PCG-28 | 36.101, 36.104, 36.133, 36.141, 36.307 | SK Telecom | haesung.park@sk.com | Rel-12 | RP-55 | Issam | LTE_CA_NC_B3-Perf | RP-131574 | CA |  |  |
| 782 | 204.5 | **Deleted - LTE Advanced intra-band contiguous Carrier Aggregation in Band 1** | 265d? | 2012-06-18 A | 2013-06-14 A | 100% |  | 2012-06-18 | 2013-06-14 | 265d? |  |  | R4 | 6328h | 6328h | LTE_CA_C_B1 | PCG-29 | LTE | KDDI | Masaaki Obara (ms-obara@kddi.com) | Rel-12 | RP-56 | Issam | LTE_CA_C_B1 |  | CA | PCG-31 | RP-60 |
| 783 | 204.5.1 | Deleted - Core part: LTE Advanced intra-band contiguous Carrier Aggregation in Band 1 | 265d? | 2012-06-18 A | 2013-06-14 A | 100% |  | 2012-06-18 | 2013-06-14 | 265d? |  | finish no earlier than 2013-06-14 | R4 | 2120h | 2120h | LTE_CA_C_B1-Core | PCG-29 | 36.101, 36.104, 36.133, 36.141, 36.307, new TR 36.835 | KDDI | Masaaki Obara (ms-obara@kddi.com) | Rel-12 | RP-56 | Issam | LTE_CA_C_B1-Core | RP-130549 | CA | PCG-31 | RP-60 |
| 784 | 204.5.2 | Deleted - Perf. part: LTE Advanced intra-band contiguous Carrier Aggregation in Band 1 | 261d? | 2012-06-22 A | 2013-06-14 A | 100% |  | 2012-06-22 | 2013-06-14 | 261d? |  | finish no earlier than 2013-06-14 | R4 | 2088h | 2088h | LTE_CA_C_B1-Perf | PCG-29 | 36.101, 36.104, 36.133, 36.141, 36.307 | KDDI | Masaaki Obara (ms-obara@kddi.com) | Rel-12 | RP-56 | Issam | LTE_CA_C_B1-Perf | RP-130550 | CA | PCG-31 | RP-60 |

Notes:
- 760: -
- 761: CD:Tue 09/12/14->Mon 15/12/14; Compl:85%100%
- 762: CD:Thu 18/06/15->Mon 15/06/15; Compl:0%5%
- 763: Triggered by Rel-12 TR 37.834 Study on WLAN/3GPP Radio Interworking (FS_UTRA_LTE_WLAN_interw)
- 764: SP#65 completed
- 765: SP#65 completed
- 766: CP#65 revised WID CP-140287=>CP-140623 (added CT4 part)
- 767: CP#65 completion 09/14=>12/14. Exception in CP-140720. 78%->95%. 12/12: 95->78%
- 768: CP#65 revised WID CP-140287=>CP-140623 (added CT4 part). Exception in CP-140482. LM: 50->100
- 769: LTE_CA_Rel-12
- 770: Inter-band CA 2DL
- 771: RP#65 completed. Updated WID RP-132042=>RP-141487
- 772: RP#65 completed
- 773: Intra-band NC
- 774: RP#60 completed. TR 36.841 for 1-step Approval
- 775: RP#60 completed
- 776: Inter-band 2UL
- 777: RP#59 stopped (covered by new WI LTE_CA_2UL-A4)
- 778: RP#59 stopped (covered by new WI LTE_CA_2UL-A4)
- 779: Intra-band NC
- 780: RP#62 completed
- 781: RP#62 completed
- 782: Intra-band C
- 783: RP#60 stopped at 10% completion (rationale in RP-130670)
- 784: RP#60 stopped at 0% completion

| ID | WBS | Task | Duration | Start | Finish | Complete | Baseline start | Baseline finish | Baseline duration | Constraint | Resources | Work | Actual work | Acronym | PCG approved | Impacted TSs and TRs | WI rapporteur name | WI rapporteur e-mail | Release | TSG approved | MCC resp | Special Focus Doc | Acronym_3GU_Export | Status Report | PCG stopped | TSG stopped |
| --- | --- | --- | --- | --- | --- | --- | --- | --- | --- | --- | --- | --- | --- | --- | --- | --- | --- | --- | --- | --- | --- | --- | --- | --- | --- | --- |
| 785 | 204.6 | **LTE Advanced intra-band non-contiguous Carrier Aggregation in Band 4** | 327d? | 2012-06-18 A | 2013-09-06 A | 100% | 2012-06-18 | 2013-09-06 | 327d? |  | R4 | 7752h | 7752h | LTE_CA_NC_B4 | PCG-29 | LTE | T-Mobile USA | nelson.ueng@t-mobile.com | Rel-12 | RP-56 | Issam | CA | LTE_CA_NC_B4 |  |  |  |
| 786 | 204.6.1 | Core part: LTE Advanced intra-band non-contiguous Carrier Aggregation in Band 4 | 323d? | 2012-06-18 A | 2013-09-06 A | 100% | 2012-06-18 | 2013-09-06 | 323d? | finish no earlier than 2013-09-06 | R4 | 2568h | 2568h | LTE_CA_NC_B4-Core | PCG-29 | 36.101, 36.104, 36.133, new TR 36.833-2-04 | T-Mobile USA | nelson.ueng@t-mobile.com | Rel-12 | RP-56 | Issam | CA | LTE_CA_NC_B4-Core | RP-131039 |  |  |
| 787 | 204.6.2 | Perf. part: LTE Advanced intra-band non-contiguous Carrier Aggregation in Band 4 | 323d? | 2012-06-22 A | 2013-09-06 A | 100% | 2012-06-22 | 2013-09-06 | 323d? | finish no earlier than 2013-09-06 | R4 | 2568h | 2568h | LTE_CA_NC_B4-Perf | PCG-29 | 36.101, 36.104, 36.133, 36.141, 36.307 | T-Mobile USA | nelson.ueng@t-mobile.com | Rel-12 | RP-56 | Issam | CA | LTE_CA_NC_B4-Perf | RP-131040 |  |  |
| 788 | 204.7 | **LTE Advanced inter-band Carrier Aggregation of Band 2 and Band 4** | 327d? | 2012-06-18 A | 2013-09-06 A | 100% | 2012-06-18 | 2013-09-06 | 327d? |  | R4 | 7752h | 7752h | LTE_CA_B2_B4 | PCG-29 | LTE | T-Mobile USA | nelson.ueng@t-mobile.com | Rel-12 | RP-56 | Issam | CA | LTE_CA_B2_B4 |  |  |  |
| 789 | 204.7.1 | Core part: LTE Advanced inter-band Carrier Aggregation of Band 2 and Band 4 | 321d? | 2012-06-18 A | 2013-09-06 A | 100% | 2012-06-18 | 2013-09-06 | 321d? | finish no earlier than 2013-09-06 | R4 | 2568h | 2568h | LTE_CA_B2_B4-Core | PCG-29 | 36.101, 36.104, 36.133, new generic TR 36.851 | T-Mobile USA | nelson.ueng@t-mobile.com | Rel-12 | RP-56 | Issam | CA | LTE_CA_B2_B4-Core | RP-131007 |  |  |
| 790 | 204.7.2 | Perf. part: LTE Advanced inter-band Carrier Aggregation of Band 2 and Band 4 | 321d? | 2012-06-22 A | 2013-09-06 A | 100% | 2012-06-22 | 2013-09-06 | 321d? | finish no earlier than 2013-09-06 | R4 | 2568h | 2568h | LTE_CA_B2_B4-Perf | PCG-29 | 36.101, 36.104, 36.133, 36.141, 36.307 | T-Mobile USA | nelson.ueng@t-mobile.com | Rel-12 | RP-56 | Issam | CA | LTE_CA_B2_B4-Perf | RP-131376 |  |  |
| 791 | 204.8 | **LTE Advanced inter-band Carrier Aggregation of Band 23 and Band 29** | 202d? | 2012-09-12 A | 2013-06-14 A | 100% | 2012-09-12 | 2013-06-14 | 202d? |  | R4 | 4832h | 4832h | LTE_CA_B23_B29 | PCG-29 | LTE | DISH Network | mariam.sorond@dish.com, johny.kim@dish.com | Rel-12 | RP-57 | Issam | CA | LTE_CA_B23_B29 |  |  |  |
| 792 | 204.8.1 | Core part: LTE Advanced inter-band Carrier Aggregation of Band 23 and Band 29 | 201d? | 2012-09-12 A | 2013-06-14 A | 100% | 2012-09-12 | 2013-06-14 | 201d? | finish no earlier than 2013-06-14 | R4 | 1608h | 1608h | LTE_CA_B23_B29-Core | PCG-29 | 36.101, 36.104, 36.133, new generic TR 36.851 | DISH Network | mariam.sorond@dish.com, johny.kim@dish.com | Rel-12 | RP-57 | Issam | CA | LTE_CA_B23_B29-Core | RP-130535 |  |  |
| 793 | 204.8.2 | Perf. part: LTE Advanced inter-band Carrier Aggregation of Band 23 and Band 29 | 201d? | 2012-09-12 A | 2013-06-14 A | 100% | 2012-09-12 | 2013-06-14 | 201d? | finish no earlier than 2013-06-14 | R4 | 1608h | 1608h | LTE_CA_B23_B29-Perf | PCG-29 | 36.141, 36.307 | DISH Network | mariam.sorond@dish.com, johny.kim@dish.com | Rel-12 | RP-57 | Issam | CA | LTE_CA_B23_B29-Perf | RP-130536 |  |  |
| 794 | 204.9 | **LTE Advanced inter-band Carrier Aggregation of Band 3 and Band 26** | 203d? | 2012-09-11 A | 2013-06-14 A | 100% | 2012-09-11 | 2013-06-14 | 203d? |  | R4 | 4840h | 4840h | LTE_CA_B3_B26 | PCG-29 | LTE | KT | Chungwoo HWANG (cwhwang@kt.com) | Rel-12 | RP-57 | Issam | CA | LTE_CA_B3_B26 |  |  |  |
| 795 | 204.9.1 | Core part: LTE Advanced inter-band Carrier Aggregation of Band 3 and Band 26 | 202d? | 2012-09-11 A | 2013-06-14 A | 100% | 2012-09-11 | 2013-06-14 | 202d? | finish no earlier than 2013-06-14 | R4 | 1608h | 1608h | LTE_CA_B3_B26-Core | PCG-29 | 36.101, 36.104, 36.133, 36.307, new generic TR 36.851 | KT | Chungwoo HWANG (cwhwang@kt.com) | Rel-12 | RP-57 | Issam | CA | LTE_CA_B3_B26-Core | RP-130527 |  |  |
| 796 | 204.9.2 | Perf. part: LTE Advanced inter-band Carrier Aggregation of Band 3 and Band 26 | 202d? | 2012-09-11 A | 2013-06-14 A | 100% | 2012-09-11 | 2013-06-14 | 202d? | finish no earlier than 2013-06-14 | R4 | 1608h | 1608h | LTE_CA_B3_B26-Perf | PCG-29 | 36.101, 36.104, 36.133, 36.141, 36.307 | KT | Chungwoo HWANG (cwhwang@kt.com) | Rel-12 | RP-57 | Issam | CA | LTE_CA_B3_B26-Perf | RP-130528 |  |  |
| 797 | 204.10 | **LTE Advanced inter-band Carrier Aggregation of Band 3 and Band 19** | 203d? | 2012-09-11 A | 2013-06-14 A | 100% | 2012-09-11 | 2013-06-14 | 203d? |  | R4 | 4840h | 4840h | LTE_CA_B3_B19 | PCG-29 | LTE | NTT DOCOMO | Kei ANDO | Rel-12 | RP-57 | Issam | CA | LTE_CA_B3_B19 |  |  |  |
| 798 | 204.10.1 | Core part: LTE Advanced inter-band Carrier Aggregation of Band 3 and Band 19 | 201d? | 2012-09-11 A | 2013-06-14 A | 100% | 2012-09-11 | 2013-06-14 | 201d? | finish no earlier than 2013-06-14 | R4 | 1608h | 1608h | LTE_CA_B3_B19-Core | PCG-29 | 36.101, 36.104, 36.133, new generic TR 36.851 | NTT DOCOMO | Kei ANDO | Rel-12 | RP-57 | Issam | CA | LTE_CA_B3_B19-Core | RP-130525 |  |  |
| 799 | 204.10.2 | Perf. part: LTE Advanced inter-band Carrier Aggregation of Band 3 and Band 19 | 201d? | 2012-09-13 A | 2013-06-14 A | 100% | 2012-09-13 | 2013-06-14 | 201d? | finish no earlier than 2013-06-14 | R4 | 1608h | 1608h | LTE_CA_B3_B19-Perf | PCG-29 | 36.141, 36.307 | NTT DOCOMO | Kei ANDO | Rel-12 | RP-57 | Issam | CA | LTE_CA_B3_B19-Perf | RP-130526 |  |  |
| 800 | 204.11 | **Deleted - LTE Advanced inter-band Carrier Aggregation of Band 38 and Band 39** | 66d? | 2012-09-11 A | 2012-12-07 A | 100% | 2012-09-11 | 2012-12-07 | 66d? |  | R4 | 1584h | 1584h | LTE_CA_B38_B39 | PCG-29 | LTE | China Mobile | Pan Qun (panqun@chinamobile.com) | Rel-12 | RP-57 | Issam | CA | LTE_CA_B38_B39 |  | PCG-30 | RP-58 |
| 801 | 204.11.1 | Deleted - Core part: LTE Advanced inter-band Carrier Aggregation of Band 38 and Band 39 | 66d? | 2012-09-11 A | 2012-12-07 A | 100% | 2012-09-11 | 2012-12-07 | 66d? | finish no earlier than 2012-12-07 | R4 | 528h | 528h | LTE_CA_B38_B39-Core | PCG-29 | 36.101, 36.104, 36.307, new generic TR 36.851 | China Mobile | Pan Qun (panqun@chinamobile.com) | Rel-12 | RP-57 | Issam | CA | LTE_CA_B38_B39-Core | RP-121624 | PCG-30 | RP-58 |
| 802 | 204.11.2 | Deleted - Perf. part: LTE Advanced inter-band Carrier Aggregation of Band 38 and Band 39 | 66d? | 2012-09-11 A | 2012-12-07 A | 100% | 2012-09-11 | 2012-12-07 | 66d? | finish no earlier than 2012-12-07 | R4 | 528h | 528h | LTE_CA_B38_B39-Perf | PCG-29 | 36.133, 36.141 | China Mobile | Pan Qun (panqun@chinamobile.com) | Rel-12 | RP-57 | Issam | CA | LTE_CA_B38_B39-Perf | RP-121625 | PCG-30 | RP-58 |
| 803 | 204.12 | **LTE Advanced intra-band contiguous Carrier Aggregation in Band 3** | 265d? | 2012-09-11 A | 2013-09-06 A | 100% | 2012-09-11 | 2013-09-06 | 265d? |  | R4 | 6312h | 6312h | LTE_CA_C_B3 | PCG-29 | LTE | China Unicom | Fei CUI (cuifei1@chinaunicom.cn) | Rel-12 | RP-57 | Issam | CA | LTE_CA_C_B3 |  |  |  |
| 804 | 204.12.1 | Core part: LTE Advanced intra-band contiguous Carrier Aggregation in Band 3 | 263d? | 2012-09-11 A | 2013-09-06 A | 100% | 2012-09-11 | 2013-09-06 | 263d? | finish no earlier than 2013-09-06 | R4 | 2096h | 2096h | LTE_CA_C_B3-Core | PCG-29 | 36.101, 36.104, 36.133, new TR 36.833-1-03 | China Unicom | Fei CUI (cuifei1@chinaunicom.cn) | Rel-12 | RP-57 | Issam | CA | LTE_CA_C_B3-Core | RP-131029 |  |  |
| 805 | 204.12.2 | Perf. part: LTE Advanced intra-band contiguous Carrier Aggregation in Band 3 | 263d? | 2012-09-11 A | 2013-09-06 A | 100% | 2012-09-11 | 2013-09-06 | 263d? | finish no earlier than 2013-09-06 | R4 | 2096h | 2096h | LTE_CA_C_B3-Perf | PCG-29 | 36.141, 36.307 | China Unicom | Fei CUI (cuifei1@chinaunicom.cn) | Rel-12 | RP-57 | Issam | CA | LTE_CA_C_B3-Perf | RP-131030 |  |  |
| 806 | 204.13 | **LTE Advanced inter-band Carrier Aggregation of Band 1 and Band 8** | 362.8d? | 2012-02-02 A | 2013-06-14 A | 100% | 2012-02-02 | 2013-06-14 | 362.8d? |  | R4 | 6118.4h | 6118.4h | LTE_CA_B1_B8 | PCG-29 | LTE | Softbank Mobile | Kenichi Kihara | Rel-12 | RP-57 | Issam | CA | LTE_CA_B1_B8 |  |  |  |
| 807 | 204.13.1 | Core part: LTE Advanced inter-band Carrier Aggregation of Band 1 and Band 8 | 201d? | 2012-02-02 A | 2013-06-14 A | 100% | 2012-02-02 | 2013-06-14 | 201d? | finish no earlier than 2013-06-14 | R4 | 1608h | 1608h | LTE_CA_B1_B8-Core | PCG-29 | 36.101, 36.104, new generic TR 36.851 | Softbank Mobile | Kenichi Kihara | Rel-12 | RP-57 | Issam | CA | LTE_CA_B1_B8-Core | RP-130515 |  |  |
| 808 | 204.13.2 | Perf. part: LTE Advanced inter-band Carrier Aggregation of Band 1 and Band 8 | 202d? | 2012-09-11 A | 2013-06-14 A | 100% | 2012-09-11 | 2013-06-14 | 202d? | finish no earlier than 2013-06-14 | R4 | 1608h | 1608h | LTE_CA_B1_B8-Perf | PCG-29 | 36.141, 36.307 | Softbank Mobile | Kenichi Kihara | Rel-12 | RP-57 | Issam | CA | LTE_CA_B1_B8-Perf | RP-130516 |  |  |

Notes:
- 785: Intra-band NC
- 786: RP#61 completed. Updated WID RP-130842=>RP-131135
- 787: RP#61 completed. Updated WID RP-130842=>RP-131135
- 788: Inter-band 1 UL
- 789: RP#61 completed
- 790: RP#61 completed
- 791: Inter-band 1 UL
- 792: RP#60 completed
- 793: RP#60 completed
- 794: Inter-band 1 UL
- 795: RP#60 completed. Updated WID RP-130199=>RP-130658
- 796: RP#60 completed. Updated WID RP-130199=>RP-130658
- 797: Inter-band 1 UL
- 798: RP#60 completed
- 799: RP#60 completed
- 800: Inter-band 1 UL
- 801: RP#58 stopped at 10% completion following regulatory decisions (see instead new WI LTE_CA_B39_B41)
- 802: RP#58 stopped at 0% completion following regulatory decisions (see instead new WI LTE_CA_B39_B41)
- 803: Intra-band NC
- 804: RP#61 completed. Updated WID RP-130294=>RP-131184 (impacted specs)
- 805: RP#61 completed
- 806: Inter-band 1 UL
- 807: RP#60 completed
- 808: RP#60 completed

| ID | WBS | Task | Duration | Start | Finish | Complete | Baseline start | Baseline finish | Baseline duration | Constraint | Resources | Work | Actual work | Acronym | PCG approved | WI rapporteur name | WI rapporteur e-mail | Release | TSG approved | MCC resp | Special Focus Doc | Acronym_3GU_Export | Status Report |
| --- | --- | --- | --- | --- | --- | --- | --- | --- | --- | --- | --- | --- | --- | --- | --- | --- | --- | --- | --- | --- | --- | --- | --- |
| 809 | 204.14 | **LTE Advanced inter-band Carrier Aggregation of Band 3 and Band 28** | 203d? | 2012-09-11 A | 2013-06-14 A | 100% | 2012-09-11 | 2013-06-14 | 203d? |  | R4 | 4840h | 4840h | LTE_CA_B3_B28 | PCG-29 | eAccess | FukumotoShiro@eaccess.net | Rel-12 | RP-57 | Issam | CA | LTE_CA_B3_B28 |  |
| 810 | 204.14.1 | Core part: LTE Advanced inter-band Carrier Aggregation of Band 3 and Band 28 | 202d? | 2012-09-11 A | 2013-06-14 A | 100% | 2012-09-11 | 2013-06-14 | 202d? | finish no earlier than 2013-06-14 | R4 | 1608h | 1608h | LTE_CA_B3_B28-Core | PCG-29 | eAccess | FukumotoShiro@eaccess.net | Rel-12 | RP-57 | Issam | CA | LTE_CA_B3_B28-Core | RP-130529 |
| 811 | 204.14.2 | Perf. part: LTE Advanced inter-band Carrier Aggregation of Band 3 and Band 28 | 201d? | 2012-09-12 A | 2013-06-14 A | 100% | 2012-09-12 | 2013-06-14 | 201d? | finish no earlier than 2013-06-14 | R4 | 1608h | 1608h | LTE_CA_B3_B28-Perf | PCG-29 | eAccess | FukumotoShiro@eaccess.net | Rel-12 | RP-57 | Issam | CA | LTE_CA_B3_B28-Perf | RP-130530 |
| 812 | 204.15 | **LTE Advanced inter-band Carrier Aggregation of Band 1 and Band 26** | 200d? | 2012-12-07 A | 2013-09-06 A | 100% | 2012-12-07 | 2013-09-06 | 200d? |  | R4 | 4768h | 4768h | LTE_CA_B1_B26 | PCG-30 | KDDI | Masaaki Obara (ms-obara@kddi.com) | Rel-12 | RP-58 | Issam | CA | LTE_CA_B1_B26 |  |
| 813 | 204.15.1 | Core part: LTE Advanced inter-band Carrier Aggregation of Band 1 and Band 26 | 200d? | 2012-12-07 A | 2013-09-06 A | 100% | 2012-12-07 | 2013-09-06 | 200d? | finish no earlier than 2013-09-06 | R4 | 1576h | 1576h | LTE_CA_B1_B26-Core | PCG-30 | KDDI | Masaaki Obara (ms-obara@kddi.com) | Rel-12 | RP-58 | Issam | CA | LTE_CA_B1_B26-Core | RP-131005 |
| 814 | 204.15.2 | Perf. part: LTE Advanced inter-band Carrier Aggregation of Band 1 and Band 26 | 200d? | 2012-12-07 A | 2013-09-06 A | 100% | 2012-12-07 | 2013-09-06 | 200d? | finish no earlier than 2013-09-06 | R4 | 1600h | 1600h | LTE_CA_B1_B26-Perf | PCG-30 | KDDI | Masaaki Obara (ms-obara@kddi.com) | Rel-12 | RP-58 | Issam | CA | LTE_CA_B1_B26-Perf | RP-131006 |
| 815 | 204.16 | **LTE Advanced inter-band Carrier Aggregation of Band 39 and Band 41** | 330d? | 2012-12-10 A | 2014-03-06 A | 100% | 2012-12-10 | 2014-03-06 | 330d? |  | R4 | 7848h | 7848h | LTE_CA_B39_B41 | PCG-30 | China Mobile | Pan Qun (panqun@chinamobile.com) | Rel-12 | RP-58 | Issam | CA | LTE_CA_B39_B41 | RP-140428 |
| 816 | 204.16.1 | Core part: LTE Advanced inter-band Carrier Aggregation of Band 39 and Band 41 | 326d? | 2012-12-10 A | 2014-03-06 A | 100% | 2012-12-10 | 2014-03-06 | 326d? | finish no earlier than 2014-03-06 | R4 | 2608h | 2608h | LTE_CA_B39_B41-Core | PCG-30 | China Mobile | Pan Qun (panqun@chinamobile.com) | Rel-12 | RP-58 | Issam | CA | LTE_CA_B39_B41-Core | RP-140428 |
| 817 | 204.16.2 | Perf. part: LTE Advanced inter-band Carrier Aggregation of Band 39 and Band 41 | 325d? | 2012-12-14 A | 2014-03-06 A | 100% | 2012-12-14 | 2014-03-06 | 325d? | finish no earlier than 2014-03-06 | R4 | 2600h | 2600h | LTE_CA_B39_B41-Perf | PCG-30 | China Mobile | Pan Qun (panqun@chinamobile.com) | Rel-12 | RP-58 | Issam | CA | LTE_CA_B39_B41-Perf | RP-140428 |
| 818 | 204.17 | **LTE Advanced inter-band Carrier Aggregation of Band 2 and Band 12** | 467d? | 2012-12-10 A | 2014-09-12 A | 100% | 2012-12-10 | 2014-09-12 | 466d? |  | R4 | 10040h | 10040h | LTE_CA_B2_B12 | PCG-30 | US Cellular | sebastian.thalanany@uscellular.com | Rel-12 | RP-58 | Issam | CA | LTE_CA_B2_B12 |  |
| 819 | 204.17.1 | Core part: LTE Advanced inter-band Carrier Aggregation of Band 2 and Band 12 | 464d? | 2012-12-10 A | 2014-09-12 A | 100% | 2012-12-10 | 2014-09-12 | 464d? | finish no earlier than 2014-09-12 | R4 | 3704h | 3704h | LTE_CA_B2_B12-Core | PCG-30 | US Cellular | sebastian.thalanany@uscellular.com | Rel-12 | RP-58 | Issam | CA | LTE_CA_B2_B12-Core | RP-141084 |
| 820 | 204.17.2 | Perf. part: LTE Advanced inter-band Carrier Aggregation of Band 2 and Band 12 | 325d? | 2012-12-14 A | 2014-03-06 A | 100% | 2012-12-14 | 2014-03-06 | 325d? | finish no earlier than 2014-06-13 | R4 | 2600h | 2600h | LTE_CA_B2_B12-Perf | PCG-30 | US Cellular | sebastian.thalanany@uscellular.com | Rel-12 | RP-58 | Issam | CA | LTE_CA_B2_B12-Perf | RP-140428 |
| 821 | 204.18 | **LTE Advanced intra-band non-contiguous Carrier Aggregation in Band 7** | 265d? | 2012-12-10 A | 2013-12-06 A | 100% | 2012-12-10 | 2013-12-06 | 265d? |  | R4 | 6296h | 6296h | LTE_CA_NC_B7 | PCG-30 | Ericsson | christian.bergljung@ericsson.com | Rel-12 | RP-58 | Issam | CA | LTE_CA_NC_B7 |  |
| 822 | 204.18.1 | Core part: LTE Advanced intra-band non-contiguous Carrier Aggregation in Band 7 | 261d? | 2012-12-10 A | 2013-12-06 A | 100% | 2012-12-10 | 2013-12-06 | 261d? | finish no earlier than 2013-12-06 | R4 | 2088h | 2088h | LTE_CA_NC_B7-Core | PCG-30 | Ericsson | christian.bergljung@ericsson.com | Rel-12 | RP-58 | Issam | CA | LTE_CA_NC_B7-Core | RP-131575 |
| 823 | 204.18.2 | Perf. part: LTE Advanced intra-band non-contiguous Carrier Aggregation in Band 7 | 261d? | 2012-12-14 A | 2013-12-06 A | 100% | 2012-12-14 | 2013-12-06 | 261d? | finish no earlier than 2013-12-06 | R4 | 2088h | 2088h | LTE_CA_NC_B7-Perf | PCG-30 | Ericsson | christian.bergljung@ericsson.com | Rel-12 | RP-58 | Issam | CA | LTE_CA_NC_B7-Perf | RP-131576 |
| 824 | 204.19 | **LTE Advanced intra-band contiguous Carrier Aggregation in Band 27** | 401d? | 2012-12-10 A | 2014-06-13 A | 100% | 2012-12-10 | 2014-06-13 | 401d? |  | R4 | 8472h | 8472h | LTE_CA_C_B27 | PCG-30 | NII Holdings | bill.shvodian@nii.com | Rel-12 | RP-58 | Issam | CA | LTE_CA_C_B27 |  |
| 825 | 204.19.1 | Core part: LTE Advanced intra-band contiguous Carrier Aggregation in Band 27 | 261d? | 2012-12-10 A | 2013-12-06 A | 100% | 2012-12-10 | 2013-12-06 | 261d? | finish no earlier than 2013-12-06 | R4 | 2088h | 2088h | LTE_CA_C_B27-Core | PCG-30 | NII Holdings | bill.shvodian@nii.com | Rel-12 | RP-58 | Issam | CA | LTE_CA_C_B27-Core | RP-131567 |
| 826 | 204.19.2 | Perf part: LTE Advanced intra-band contiguous Carrier Aggregation in Band 27 | 397d? | 2012-12-14 A | 2014-06-13 A | 100% | 2012-12-14 | 2014-06-13 | 397d? | finish no earlier than 2014-06-13 | R4 | 3176h | 3176h | LTE_CA_C_B27-Perf | PCG-30 | NII Holdings | bill.shvodian@nii.com | Rel-12 | RP-58 | Issam | CA | LTE_CA_C_B27-Perf | RP-140569 |
| 827 | 204.20 | **LTE Advanced inter-band Carrier Aggregation of Band 2 and Band 13** | 76d? | 2013-03-04 A | 2013-06-14 A | 100% | 2013-03-04 | 2013-06-14 | 76d? |  | R4 | 1824h | 1824h | LTE_CA_B2_B13 | PCG-30 | Ericsson | christian.bergljung@ericsson.com | Rel-12 | RP-59 | Issam | CA | LTE_CA_B2_B13 |  |
| 828 | 204.20.1 | Core part: LTE Advanced inter-band Carrier Aggregation of Band 2 and Band 13 | 76d? | 2013-03-04 A | 2013-06-14 A | 100% | 2013-03-04 | 2013-06-14 | 76d? | finish no earlier than 2013-06-14 | R4 | 608h | 608h | LTE_CA_B2_B13-Core | PCG-30 | Ericsson | christian.bergljung@ericsson.com | Rel-12 | RP-59 | Issam | CA | LTE_CA_B2_B13-Core | RP-130523 |
| 829 | 204.20.2 | Perf. part: LTE Advanced inter-band Carrier Aggregation of Band 2 and Band 13 | 76d? | 2013-03-04 A | 2013-06-14 A | 100% | 2013-03-04 | 2013-06-14 | 76d? | finish no earlier than 2013-06-14 | R4 | 608h | 608h | LTE_CA_B2_B13-Perf | PCG-30 | Ericsson | christian.bergljung@ericsson.com | Rel-12 | RP-59 | Issam | CA | LTE_CA_B2_B13-Perf | RP-130524 |
| 830 | 204.21 | **LTE Advanced inter-band Carrier Aggregation of Band 19 and Band 21** | 76d? | 2013-03-04 A | 2013-06-14 A | 100% | 2013-03-04 | 2013-06-14 | 76d? |  | R4 | 1824h | 1824h | LTE_CA_B19_B21 | PCG-30 | NTT DOCOMO | Kei ANDO | Rel-12 | RP-59 | Issam | CA | LTE_CA_B19_B21 |  |
| 831 | 204.21.1 | Core part: LTE Advanced inter-band Carrier Aggregation of Band 19 and Band 21 | 76d? | 2013-03-04 A | 2013-06-14 A | 100% | 2013-03-04 | 2013-06-14 | 76d? | finish no earlier than 2013-06-14 | R4 | 608h | 608h | LTE_CA_B19_B21-Core | PCG-30 | NTT DOCOMO | Kei ANDO | Rel-12 | RP-59 | Issam | CA | LTE_CA_B19_B21-Core | RP-130533 |
| 832 | 204.21.2 | Perf. part: LTE Advanced inter-band Carrier Aggregation of Band 19 and Band 21 | 76d? | 2013-03-04 A | 2013-06-14 A | 100% | 2013-03-04 | 2013-06-14 | 76d? | finish no earlier than 2013-06-14 | R4 | 608h | 608h | LTE_CA_B19_B21-Perf | PCG-30 | NTT DOCOMO | Kei ANDO | Rel-12 | RP-59 | Issam | CA | LTE_CA_B19_B21-Perf | RP-130534 |

Notes:
- 809: Inter-band 1 UL / Impacted TSs and TRs: LTE
- 810: RP#60 completed / Impacted TSs and TRs: 36.101, 36.104, new generic TR 36.851
- 811: RP#60 completed / Impacted TSs and TRs: 36.141, 36.307
- 812: Inter-band 1UL/2DL / Impacted TSs and TRs: LTE
- 813: RP#61 completed / Impacted TSs and TRs: 36.101, 36.104, 36.133, new generic TR 36.851
- 814: RP#61 completed / Impacted TSs and TRs: 36.141, 36.307
- 815: Inter-band 2DL / Impacted TSs and TRs: LTE
- 816: RP#63 completed. Replaces the Stopped WI - LTE Advanced inter-band Carrier Aggregation of Band 38 and Band 39 (LTE_CA_B38_B39) UID_570015 / Impacted TSs and TRs: 36.101, 36.104, 36.307, new generic TR 36.851
- 817: RP#63 completed / Impacted TSs and TRs: 36.133, 36.141
- 818: Inter-band CA 2DL / Impacted TSs and TRs: LTE
- 819: RP#65 completed / Impacted TSs and TRs: 36.101, 36.104, 36.133, 36.141, 36.307, new generic TR 36.851
- 820: RP#63 completed / Impacted TSs and TRs: 36.101, 36.104, 36.133, 36.141, 36.307
- 821: Intra-band NC / Impacted TSs and TRs: LTE
- 822: RP#62 completed / Impacted TSs and TRs: 36.101, 36.104, 36.133, new TR 36.833-2-07
- 823: RP#62 completed / Impacted TSs and TRs: 36.141, 36.307
- 824: Intra-band contig. CA 2DL/1UL / Impacted TSs and TRs: LTE
- 825: RP#62 completed / Impacted TSs and TRs: 36.101, 36.104, new TR 36.833-1-27
- 826: RP#64 completed. TR 36.833-1-27v200 for Approval / Impacted TSs and TRs: 36.101, 36.133, 36.141, 36.307, new TR 36.833-1-27
- 827: Inter-band 1 UL / Impacted TSs and TRs: LTE
- 828: RP#60 completed / Impacted TSs and TRs: 36.101, 36.104, 36.133, new generic TR 36.851
- 829: RP#60 completed / Impacted TSs and TRs: 36.101, 36.104, 36.133, 36.141, 36.307
- 830: Inter-band 1 UL / Impacted TSs and TRs: LTE
- 831: RP#60 completed / Impacted TSs and TRs: 36.101, 36.104, 36.133, new generic TR 36.851
- 832: RP#60 completed / Impacted TSs and TRs: 36.141, 36.307

| ID | WBS | Task | Duration | Start | Finish | Complete | Baseline start | Baseline finish | Baseline duration | Constraint | Resources | Work | Actual work | Acronym | PCG approved | WI rapporteur name | WI rapporteur e-mail | Release | TSG approved | MCC resp | PCG stopped | TSG stopped | Special Focus Doc | Acronym_3GU_Export | Status Report |
| --- | --- | --- | --- | --- | --- | --- | --- | --- | --- | --- | --- | --- | --- | --- | --- | --- | --- | --- | --- | --- | --- | --- | --- | --- | --- |
| 833 | 204.22 | **Deleted - LTE Advanced inter-band Carrier Aggregation of Band 8 and Band 26** | 204d? | 2013-03-04 A | 2013-12-06 A | 100% | 2013-03-04 | 2013-12-06 | 204d? |  | R4 | 4848h | 4848h | LTE_CA_B8_B26 | PCG-30 | KT | Chungwoo HWANG (cwhwang@kt.com) | Rel-12 | RP-59 | Issam | PCG-32 | RP-62 | CA | LTE_CA_B8_B26 |  |
| 834 | 204.22.1 | Deleted - Core part: LTE Advanced inter-band Carrier Aggregation of Band 8 and Band 26 | 201d? | 2013-03-04 A | 2013-12-06 A | 100% | 2013-03-04 | 2013-12-06 | 201d? | finish no earlier than 2013-12-06 | R4 | 1608h | 1608h | LTE_CA_B8_B26-Core | PCG-30 | KT | Chungwoo HWANG (cwhwang@kt.com) | Rel-12 | RP-59 | Issam | PCG-32 | RP-62 | CA | LTE_CA_B8_B26-Core | RP-131549 |
| 835 | 204.22.2 | Deleted - Perf. part: LTE Advanced inter-band Carrier Aggregation of Band 8 and Band 26 | 201d? | 2013-03-04 A | 2013-12-06 A | 100% | 2013-03-04 | 2013-12-06 | 201d? | finish no earlier than 2013-12-06 | R4 | 1608h | 1608h | LTE_CA_B8_B26-Perf | PCG-30 | KT | Chungwoo HWANG (cwhwang@kt.com) | Rel-12 | RP-59 | Issam | PCG-32 | RP-62 | CA | LTE_CA_B8_B26-Perf | RP-131550 |
| 836 | 204.23 | **LTE Advanced dual uplink inter-band Carrier Aggregation Class A1** | 474d? | 2013-03-04 A | 2014-12-15 A | 100% | 2013-03-04 | 2014-09-12 | 405d? |  | R4 | 11272h | 11272h | LTE_CA_2UL-A1 | PCG-30 | Huawei | Liu Ye (leo.liuye@huawei.com) | Rel-12 | RP-59 | Issam |  |  | CA | LTE_CA_2UL-A1 |  |
| 837 | 204.23.1 | Core part: LTE Advanced dual uplink inter-band Carrier Aggregation Class A1 | 468d? | 2013-03-04 A | 2014-12-15 A | 100% | 2013-03-04 | 2014-09-12 | 402d? | finish no earlier than 2014-12-15 | R4 | 3744h | 3744h | LTE_CA_2UL-A1-Core | PCG-30 | Huawei | Liu Ye (leo.liuye@huawei.com) | Rel-12 | RP-59 | Issam |  |  | CA | LTE_CA_2UL-A1-Core | RP-141084 |
| 838 | 204.23.2 | Perf. part: LTE Advanced dual uplink inter-band Carrier Aggregation Class A1 | 467d? | 2013-03-13 A | 2014-12-15 A | 100% | 2013-03-08 | 2014-09-12 | 401d? | finish no earlier than 2014-12-15 | R4 | 3736h | 3736h | LTE_CA_2UL-A1-Perf | PCG-30 | Huawei | Liu Ye (leo.liuye@huawei.com) | Rel-12 | RP-59 | Issam |  |  | CA | LTE_CA_2UL-A1-Perf | RP-141084 |
| 839 | 204.24 | **LTE Advanced dual uplink inter-band Carrier Aggregation Class A2** | 474d? | 2013-03-04 A | 2014-12-15 A | 100% | 2013-03-04 | 2014-09-12 | 405d? |  | R4 | 11272h | 11272h | LTE_CA_2UL-A2 | PCG-30 | Qualcomm | Gene Fong (gfong@qti.qualcomm.com) | Rel-12 | RP-59 | Issam |  |  | CA | LTE_CA_2UL-A2 |  |
| 840 | 204.24.1 | Core part: LTE Advanced dual uplink inter-band Carrier Aggregation Class A2 | 468d? | 2013-03-04 A | 2014-12-15 A | 100% | 2013-03-04 | 2014-09-12 | 402d? | finish no earlier than 2014-12-15 | R4 | 3744h | 3744h | LTE_CA_2UL-A2-Core | PCG-30 | Qualcomm | Gene Fong (gfong@qti.qualcomm.com) | Rel-12 | RP-59 | Issam |  |  | CA | LTE_CA_2UL-A2-Core | RP-141084 |
| 841 | 204.24.2 | Perf. part: LTE Advanced dual uplink inter-band Carrier Aggregation Class A2 | 467d? | 2013-03-13 A | 2014-12-15 A | 100% | 2013-03-08 | 2014-09-12 | 401d? | finish no earlier than 2014-12-15 | R4 | 3736h | 3736h | LTE_CA_2UL-A2-Perf | PCG-30 | Qualcomm | Gene Fong (gfong@qti.qualcomm.com) | Rel-12 | RP-59 | Issam |  |  | CA | LTE_CA_2UL-A2-Perf | RP-141084 |
| 842 | 204.25 | **LTE Advanced dual uplink inter-band Carrier Aggregation Class A3** | 474d? | 2013-03-04 A | 2014-12-15 A | 100% | 2013-03-04 | 2014-09-12 | 405d? |  | R4 | 11264h | 11264h | LTE_CA_2UL-A3 | PCG-30 | Ericsson | christian.bergljung@ericsson.com | Rel-12 | RP-59 | Issam |  |  | CA | LTE_CA_2UL-A3 |  |
| 843 | 204.25.1 | Core part: LTE Advanced dual uplink inter-band Carrier Aggregation Class A3 | 467d? | 2013-03-04 A | 2014-12-15 A | 100% | 2013-03-04 | 2014-09-12 | 401d? | finish no earlier than 2014-12-15 | R4 | 3736h | 3736h | LTE_CA_2UL-A3-Core | PCG-30 | Ericsson | christian.bergljung@ericsson.com | Rel-12 | RP-59 | Issam |  |  | CA | LTE_CA_2UL-A3-Core | RP-141084 |
| 844 | 204.25.2 | Perf. part: LTE Advanced dual uplink inter-band Carrier Aggregation Class A3 | 467d? | 2013-03-13 A | 2014-12-15 A | 100% | 2013-03-08 | 2014-09-12 | 401d? | finish no earlier than 2014-12-15 | R4 | 3736h | 3736h | LTE_CA_2UL-A3-Perf | PCG-30 | Ericsson | christian.bergljung@ericsson.com | Rel-12 | RP-59 | Issam |  |  | CA | LTE_CA_2UL-A3-Perf | RP-141084 |
| 845 | 204.26 | **LTE Advanced dual uplink inter-band Carrier Aggregation Class A4** | 474d? | 2013-03-04 A | 2014-12-15 A | 100% | 2013-03-04 | 2014-09-12 | 405d? |  | R4 | 11272h | 11272h | LTE_CA_2UL-A4 | PCG-30 | Nokia | petri.j.vasenkari@nokia.com | Rel-12 | RP-59 | Issam |  |  | CA | LTE_CA_2UL-A4 |  |
| 846 | 204.26.1 | Core part: LTE Advanced dual uplink inter-band Carrier Aggregation Class A4 | 468d? | 2013-03-04 A | 2014-12-15 A | 100% | 2013-03-04 | 2014-09-12 | 402d? | finish no earlier than 2014-12-15 | R4 | 3744h | 3744h | LTE_CA_2UL-A4-Core | PCG-30 | Nokia | petri.j.vasenkari@nokia.com | Rel-12 | RP-59 | Issam |  |  | CA | LTE_CA_2UL-A4-Core | RP-141084 |
| 847 | 204.26.2 | Perf. part: LTE Advanced dual uplink inter-band Carrier Aggregation Class A4 | 467d? | 2013-03-13 A | 2014-12-15 A | 100% | 2013-03-08 | 2014-09-12 | 401d? | finish no earlier than 2014-12-15 | R4 | 3736h | 3736h | LTE_CA_2UL-A4-Perf | PCG-30 | Nokia | petri.j.vasenkari@nokia.com | Rel-12 | RP-59 | Issam |  |  | CA | LTE_CA_2UL-A4-Perf | RP-141084 |
| 848 | 204.27 | **LTE Advanced dual uplink inter-band Carrier Aggregation Class A5** | 474d? | 2013-03-04 A | 2014-12-15 A | 100% | 2013-03-04 | 2014-09-12 | 405d? |  | R4 | 11264h | 11264h | LTE_CA_2UL-A5 | PCG-30 | NTT DOCOMO | kei.andou.ye@nttdocomo.com | Rel-12 | RP-59 | Issam |  |  | CA | LTE_CA_2UL-A5 |  |
| 849 | 204.27.1 | Core part: LTE Advanced dual uplink inter-band Carrier Aggregation Class A5 | 467d? | 2013-03-04 A | 2014-12-15 A | 100% | 2013-03-04 | 2014-09-12 | 401d? | finish no earlier than 2014-12-15 | R4 | 3736h | 3736h | LTE_CA_2UL-A5-Core | PCG-30 | NTT DOCOMO | kei.andou.ye@nttdocomo.com | Rel-12 | RP-59 | Issam |  |  | CA | LTE_CA_2UL-A5-Core | RP-141084 |
| 850 | 204.27.2 | Perf. part: LTE Advanced dual uplink inter-band Carrier Aggregation Class A5 | 467d? | 2013-03-13 A | 2014-12-15 A | 100% | 2013-03-08 | 2014-09-12 | 401d? | finish no earlier than 2014-12-15 | R4 | 3736h | 3736h | LTE_CA_2UL-A5-Perf | PCG-30 | NTT DOCOMO | kei.andou.ye@nttdocomo.com | Rel-12 | RP-59 | Issam |  |  | CA | LTE_CA_2UL-A5-Perf | RP-141084 |
| 851 | 204.28 | **LTE Advanced intra-band contiguous Carrier Aggregation in Band 39** | 269d? | 2013-03-04 A | 2014-03-06 A | 100% | 2013-03-04 | 2014-03-06 | 269d? |  | R4 | 6400h | 6400h | LTE_CA_C_B39 | PCG-30 | China Mobile | Li Nan (linan@chinamobile.com) | Rel-12 | RP-59 | Issam |  |  | CA | LTE_CA_C_B39 |  |
| 852 | 204.28.1 | Core part: LTE Advanced intra-band contiguous Carrier Aggregation in Band 39 | 266d? | 2013-03-04 A | 2014-03-06 A | 100% | 2013-03-04 | 2014-03-06 | 266d? | finish no earlier than 2014-03-06 | R4 | 2128h | 2128h | LTE_CA_C_B39-Core | PCG-30 | China Mobile | Li Nan (linan@chinamobile.com) | Rel-12 | RP-59 | Issam |  |  | CA | LTE_CA_C_B39-Core | RP-140428 |
| 853 | 204.28.2 | Perf. part: LTE Advanced intra-band contiguous Carrier Aggregation in Band 39 | 265d? | 2013-03-07 A | 2014-03-06 A | 100% | 2013-03-07 | 2014-03-06 | 265d? | finish no earlier than 2014-03-06 | R4 | 2120h | 2120h | LTE_CA_C_B39-Perf | PCG-30 | China Mobile | Li Nan (linan@chinamobile.com) | Rel-12 | RP-59 | Issam |  |  | CA | LTE_CA_C_B39-Perf | RP-140428 |
| 854 | 204.29 | **LTE Advanced intra-band non-contiguous Carrier Aggregation: framework requirements for 2UL** | 397d? | 2013-06-18 A | 2014-12-15 A | 100% | 2013-06-18 | 2014-09-12 | 328d? |  | R4 | 6328h | 6328h | LTE_CA_NC_2UL | PCG-31 | Nokia | petri.j.vasenkari@nokia.com | Rel-12 | RP-60 | Issam |  |  | CA | LTE_CA_NC_2UL |  |
| 855 | 204.29.1 | Core part: LTE Advanced intra-band non-contiguous Carrier Aggregation: framework requirements for 2UL | 394d? | 2013-06-18 A | 2014-12-15 A | 100% | 2013-06-18 | 2014-09-12 | 328d? | finish no earlier than 2014-12-15 | R4 | 3152h | 3152h | LTE_CA_NC_2UL-Core | PCG-31 | Nokia | petri.j.vasenkari@nokia.com | Rel-12 | RP-60 | Issam |  |  | CA | LTE_CA_NC_2UL-Core | RP-141084 |
| 856 | 204.30 | **Deleted - LTE Advanced intra-band non-contiguous Carrier Aggregation in Band 41 for 2UL** | 191d? | 2013-06-19 A | 2014-03-06 A | 100% | 2013-06-19 | 2014-03-06 | 191d? |  | R4 | 4576h | 4576h | LTE_CA_NC_B41_2UL | PCG-31 | Sprint | yang.xu@clearwire.com | Rel-12 | RP-60 | Issam | PCG-32 | RP-63 | CA | LTE_CA_NC_B41_2UL | RP-140428 |
| 857 | 204.30.1 | Deleted - Core part: LTE Advanced intra-band non-contiguous Carrier Aggregation in Band 41 for 2UL | 191d? | 2013-06-19 A | 2014-03-06 A | 100% | 2013-06-19 | 2014-03-06 | 191d? | finish no earlier than 2014-03-06 | R4 | 1528h | 1528h | LTE_CA_NC_B41_2UL-Core | PCG-31 | Sprint | yang.xu@clearwire.com | Rel-12 | RP-60 | Issam | PCG-32 | RP-63 | CA | LTE_CA_NC_B41_2UL-Core | RP-140428 |
| 858 | 204.30.2 | Deleted - Perf. part: LTE Advanced intra-band non-contiguous Carrier Aggregation in Band 41 for 2UL | 190d? | 2013-06-20 A | 2014-03-06 A | 100% | 2013-06-20 | 2014-03-06 | 190d? | finish no earlier than 2014-03-06 | R4 | 1520h | 1520h | LTE_CA_NC_B41_2UL-Perf | PCG-31 | Sprint | yang.xu@clearwire.com | Rel-12 | RP-60 | Issam | PCG-32 | RP-63 | CA | LTE_CA_NC_B41_2UL-Perf | RP-140428 |

Notes:
- 833: Inter-band 1 UL / Impacted TSs and TRs: LTE
- 834: RP#62 stopped (at 20%) / Impacted TSs and TRs: 36.101, 36.104, 36.133, new generic TR 36.851
- 835: RP#62 stopped (at 20%) / Impacted TSs and TRs: 36.141, 36.307
- 836: Inter-band CA 2UL / Impacted TSs and TRs: LTE
- 837: CD:Thu 11/12/14->Mon 15/12/14; Compl:75%->100%; WID:RP-140955->RP-142043; WID:RP-140955->RP-142043; WID:RP-140955->RP-142043; WID:RP-140955->RP-142043 / Impacted TSs and TRs: 36.101, 36.104, New generic TR 36.860
- 838: CD:Thu 11/12/14->Mon 15/12/14; Compl:0%->100%; WID:RP-140955->RP-142043 / Impacted TSs and TRs: 36.133
- 839: Inter-band CA 2UL / Impacted TSs and TRs: LTE
- 840: CD:Thu 11/12/14->Mon 15/12/14; Compl:75%->100% / Impacted TSs and TRs: 36.101, 36.104, 36.133, New generic TR 36.860
- 841: CD:Thu 11/12/14->Mon 15/12/14; Compl:0%->100% / Impacted TSs and TRs: 36.141, 36.307
- 842: Inter-band CA 2UL / Impacted TSs and TRs: LTE
- 843: CD:Thu 11/12/14->Mon 15/12/14; Compl:75%->100% / Impacted TSs and TRs: 36.101, 36.104, 36.133, New generic TR 36.860
- 844: CD:Thu 11/12/14->Mon 15/12/14; Compl:0%->100% / Impacted TSs and TRs: 36.141, 36.307
- 845: Inter-band CA 2UL. RP#65 updated WID RP-140476=>RP-141160. / Impacted TSs and TRs: LTE
- 846: CD:Thu 11/12/14->Mon 15/12/14; Compl:70%->100%; WID:RP-140955->RP-142043 / Impacted TSs and TRs: 36.101, 36.104, 36.133, New generic TR 36.860
- 847: CD:Thu 11/12/14->Mon 15/12/14; Compl:0%->100%; WID:RP-140955->RP-142043 / Impacted TSs and TRs: 36.141, 36.307
- 848: Inter-band CA 2UL. RP#65 updated WID RP-131146=>RP-141195. Changed Rapp Renesas=>Broadcom=>NTT DOCOMO / Impacted TSs and TRs: LTE
- 849: CD:Thu 11/12/14->Mon 15/12/14; Compl:70%->100% / Impacted TSs and TRs: 36.101, 36.104, 36.133, New generic TR 36.860
- 850: CD:Thu 11/12/14->Mon 15/12/14; Compl:0%->100% / Impacted TSs and TRs: 36.141, 36.307
- 851: Intra-band C 2DL/2UL / Impacted TSs and TRs: LTE
- 852: RP#63 completed / Impacted TSs and TRs: 36.101, 36.104, 36.133, New TR 36.833-1-39 [instead of 36.845]
- 853: RP#63 completed / Impacted TSs and TRs: 36.141, 36.307
- 854: Intra-band non-contig. CA 2DL / Impacted TSs and TRs: LTE
- 855: CD:Thu 11/12/14->Mon 15/12/14; Compl:95%->100%; WID:RP-140955->RP-142043 / Impacted TSs and TRs: 36.101, 36.104, 36.133, 36.306, 36.331, New TR 36.833-4
- 856: Intra-band NC 2UL / Impacted TSs and TRs: LTE
- 857: RP#63 stopped (5% complete). Reason: Market conditions have eliminated the need for this feature, at least for the foreseeable future / Impacted TSs and TRs: 36.101, 36.104, 36.133, new TR 36.833-3-41
- 858: RP#63 stopped (0% complete). / Impacted TSs and TRs: 36.101, 36.104, 36.133, 36.141, 36.307

| ID | WBS | Task | Duration | Start | Finish | Complete | Baseline start | Baseline finish | Baseline duration | Constraint | Resources | Work | Actual work | Acronym | PCG approved | WI rapporteur name | WI rapporteur e-mail | Release | TSG approved | MCC resp | Special Focus Doc | Acronym_3GU_Export | Status Report | PCG stopped | TSG stopped |
| --- | --- | --- | --- | --- | --- | --- | --- | --- | --- | --- | --- | --- | --- | --- | --- | --- | --- | --- | --- | --- | --- | --- | --- | --- | --- |
| 859 | 204.31 | **LTE Advanced intra-band non-contiguous Carrier Aggregation in Band 4 for 2UL** | 396d? | 2013-06-19 A | 2014-12-15 A | 100% | 2013-06-19 | 2014-09-12 | 327d? |  | R4 | 9448h | 9448h | LTE_CA_NC_B4_2UL | PCG-31 | T-Mobile USA | nelson.ueng@t-mobile.com | Rel-12 | RP-60 | Issam | CA | LTE_CA_NC_B4_2UL |  |  |  |
| 860 | 204.31.1 | Core part: LTE Advanced intra-band non-contiguous Carrier Aggregation in Band 4 for 2UL | 393d? | 2013-06-19 A | 2014-12-15 A | 100% | 2013-06-19 | 2014-09-12 | 327d? | finish no earlier than 2014-12-15 | R4 | 3144h | 3144h | LTE_CA_NC_B4_2UL-Core | PCG-31 | T-Mobile USA | nelson.ueng@t-mobile.com | Rel-12 | RP-60 | Issam | CA | LTE_CA_NC_B4_2UL-Core | RP-141084 |  |  |
| 861 | 204.31.2 | Perf. part: LTE Advanced intra-band non-contiguous Carrier Aggregation in Band 4 for 2UL | 392d? | 2013-06-25 A | 2014-12-15 A | 100% | 2013-06-20 | 2014-09-12 | 326d? | finish no earlier than 2014-12-15 | R4 | 3136h | 3136h | LTE_CA_NC_B4_2UL-Perf | PCG-31 | T-Mobile USA | nelson.ueng@t-mobile.com | Rel-12 | RP-60 | Issam | CA | LTE_CA_NC_B4_2UL-Perf | RP-141084 |  |  |
| 862 | 204.32 | **LTE Advanced intra-band contiguous Carrier Aggregation in Band 23** | 127d? | 2013-06-18 A | 2013-12-06 A | 100% | 2013-06-18 | 2013-12-06 | 127d? |  | R4 | 3032h | 3032h | LTE_CA_C_B23 | PCG-31 | Dish Network | mariam.sorond@dish.com, johny.kim@dish.com | Rel-12 | RP-60 | Issam | CA | LTE_CA_C_B23 |  |  |  |
| 863 | 204.32.1 | Core part: LTE Advanced intra-band contiguous Carrier Aggregation in Band 23 | 126d? | 2013-06-18 A | 2013-12-06 A | 100% | 2013-06-18 | 2013-12-06 | 126d? | finish no earlier than 2013-12-06 | R4 | 1008h | 1008h | LTE_CA_C_B23-Core | PCG-31 | Dish Network | mariam.sorond@dish.com, johny.kim@dish.com | Rel-12 | RP-60 | Issam | CA | LTE_CA_C_B23-Core | RP-131565 |  |  |
| 864 | 204.32.2 | Perf. part: LTE Advanced intra-band contiguous Carrier Aggregation in Band 23 | 126d? | 2013-06-18 A | 2013-12-06 A | 100% | 2013-06-18 | 2013-12-06 | 126d? | finish no earlier than 2013-12-06 | R4 | 1008h | 1008h | LTE_CA_C_B23-Perf | PCG-31 | Dish Network | mariam.sorond@dish.com, johny.kim@dish.com | Rel-12 | RP-60 | Issam | CA | LTE_CA_C_B23-Perf | RP-131566 |  |  |
| 865 | 204.33 | **LTE Advanced intra-band non-contiguous Carrier Aggregation in Band 23** | 263d? | 2013-06-18 A | 2014-06-13 A | 100% | 2013-06-18 | 2014-06-13 | 263d? |  | R4 | 5216h | 5216h | LTE_CA_NC_B23 | PCG-31 | Dish Network | mariam.sorond@dish.com, johny.kim@dish.com | Rel-12 | RP-60 | Issam | CA | LTE_CA_NC_B23 |  |  |  |
| 866 | 204.33.1 | Core part: LTE Advanced intra-band non-contiguous Carrier Aggregation in Band 23 | 126d? | 2013-06-18 A | 2013-12-06 A | 100% | 2013-06-18 | 2013-12-06 | 126d? | finish no earlier than 2013-12-06 | R4 | 1008h | 1008h | LTE_CA_NC_B23-Core | PCG-31 | Dish Network | mariam.sorond@dish.com, johny.kim@dish.com | Rel-12 | RP-60 | Issam | CA | LTE_CA_NC_B23-Core | RP-131577 |  |  |
| 867 | 204.33.2 | Perf. part: LTE Advanced intra-band non-contiguous Carrier Aggregation in Band 23 | 263d? | 2013-06-18 A | 2014-06-13 A | 100% | 2013-06-18 | 2014-06-13 | 263d? | finish no earlier than 2014-06-13 | R4 | 2104h | 2104h | LTE_CA_NC_B23-Perf | PCG-31 | Dish Network | mariam.sorond@dish.com, johny.kim@dish.com | Rel-12 | RP-60 | Issam | CA | LTE_CA_NC_B23-Perf | RP-140569 |  |  |
| 868 | 204.34 | **LTE Advanced inter-band Carrier Aggregation of Band 12 and Band 25** | 127d? | 2013-06-18 A | 2013-12-06 A | 100% | 2013-06-18 | 2013-12-06 | 127d? |  | R4 | 3032h | 3032h | LTE_CA_B12_B25 | PCG-31 | US Cellular | sebastian.thalanany@uscellular.com | Rel-12 | RP-60 | Issam | CA | LTE_CA_B12_B25 |  |  |  |
| 869 | 204.34.1 | Core part: LTE Advanced inter-band Carrier Aggregation of Band 12 and Band 25 | 126d? | 2013-06-18 A | 2013-12-06 A | 100% | 2013-06-18 | 2013-12-06 | 126d? | finish no earlier than 2013-12-06 | R4 | 1008h | 1008h | LTE_CA_B12_B25-Core | PCG-31 | US Cellular | sebastian.thalanany@uscellular.com | Rel-12 | RP-60 | Issam | CA | LTE_CA_B12_B25-Core | RP-131705 |  |  |
| 870 | 204.34.2 | Perf. part: LTE Advanced inter-band Carrier Aggregation of Band 12 and Band 25 | 126d? | 2013-06-19 A | 2013-12-06 A | 100% | 2013-06-19 | 2013-12-06 | 126d? | finish no earlier than 2013-12-06 | R4 | 1008h | 1008h | LTE_CA_B12_B25-Perf | PCG-31 | US Cellular | sebastian.thalanany@uscellular.com | Rel-12 | RP-60 | Issam | CA | LTE_CA_B12_B25-Perf | RP-131706 |  |  |
| 871 | 204.35 | **LTE Advanced inter-band Carrier Aggregation of Band 1 and Band 18 - Additional bandwidth combination set** | 61d? | 2013-06-18 A | 2013-09-06 A | 100% | 2013-06-18 | 2013-09-06 | 61d? |  | R4 | 1464h | 1464h | LTE_CA_B1_B18_BWset | PCG-31 | KDDI | Masaaki Obara (ms-obara@kddi.com) | Rel-12 | RP-60 | Issam | CA | LTE_CA_B1_B18_BWset |  |  |  |
| 872 | 204.35.1 | Core part: LTE Advanced inter-band Carrier Aggregation of Band 1 and Band 18 - Additional bandwidth combination set | 61d? | 2013-06-18 A | 2013-09-06 A | 100% | 2013-06-18 | 2013-09-06 | 61d? | finish no earlier than 2013-09-06 | R4 | 488h | 488h | LTE_CA_B1_B18_BWset-Core | PCG-31 | KDDI | Masaaki Obara (ms-obara@kddi.com) | Rel-12 | RP-60 | Issam | CA | LTE_CA_B1_B18_BWset-Core | RP-131003 |  |  |
| 873 | 204.35.2 | Perf. part: LTE Advanced inter-band Carrier Aggregation of Band 1 and Band 18 - Additional bandwidth combination set | 61d? | 2013-06-18 A | 2013-09-06 A | 100% | 2013-06-18 | 2013-09-06 | 61d? | finish no earlier than 2013-09-06 | R4 | 488h | 488h | LTE_CA_B1_B18_BWset-Perf | PCG-31 | KDDI | Masaaki Obara (ms-obara@kddi.com) | Rel-12 | RP-60 | Issam | CA | LTE_CA_B1_B18_BWset-Perf | RP-131004 |  |  |
| 874 | 204.36 | **LTE Advanced inter-band Carrier Aggregation of Band 2 and Band 5** | 61d? | 2013-06-18 A | 2013-09-06 A | 100% | 2013-06-18 | 2013-09-06 | 61d? |  | R4 | 1464h | 1464h | LTE_CA_B2_B5 | PCG-31 | AT&T | marc.grant@att.com | Rel-12 | RP-60 | Issam | CA | LTE_CA_B2_B5 |  |  |  |
| 875 | 204.36.1 | Core part: LTE Advanced inter-band Carrier Aggregation of Band 2 and Band 5 | 61d? | 2013-06-18 A | 2013-09-06 A | 100% | 2013-06-18 | 2013-09-06 | 61d? | finish no earlier than 2013-09-06 | R4 | 488h | 488h | LTE_CA_B2_B5-Core | PCG-31 | AT&T | marc.grant@att.com | Rel-12 | RP-60 | Issam | CA | LTE_CA_B2_B5-Core | RP-131009 |  |  |
| 876 | 204.36.2 | Perf. part: LTE Advanced inter-band Carrier Aggregation of Band 2 and Band 5 | 61d? | 2013-06-18 A | 2013-09-06 A | 100% | 2013-06-18 | 2013-09-06 | 61d? | finish no earlier than 2013-12-06 | R4 | 488h | 488h | LTE_CA_B2_B5-Perf | PCG-31 | AT&T | marc.grant@att.com | Rel-12 | RP-60 | Issam | CA | LTE_CA_B2_B5-Perf | RP-131010 |  |  |
| 877 | 204.37 | **LTE Advanced 3 Band Carrier Aggregation (3DL/1UL) of Band 2, Band 5 and Band 30** | 329d? | 2013-06-18 A | 2014-09-12 A | 100% | 2013-06-18 | 2014-09-12 | 328d? |  | R4 | 7872h | 7872h | LTE_CA_B2_B5_B30 | PCG-31 | AT&T | marc.grant@att.com | Rel-12 | RP-60 | Issam | CA | LTE_CA_B2_B5_B30 |  |  |  |
| 878 | 204.37.1 | Core part: LTE Advanced 3 Band Carrier Aggregation (3DL/1UL) of Band 2, Band 5 and Band 30 | 328d? | 2013-06-18 A | 2014-09-12 A | 100% | 2013-06-18 | 2014-09-12 | 328d? | finish no earlier than 2014-09-12 | R4 | 2624h | 2624h | LTE_CA_B2_B5_B30-Core | PCG-31 | AT&T | marc.grant@att.com | Rel-12 | RP-60 | Issam | CA | LTE_CA_B2_B5_B30-Core | RP-141084 |  |  |
| 879 | 204.37.2 | Perf. part: LTE Advanced 3 Band Carrier Aggregation (3DL/1UL) of Band 2, Band 5 and Band 30 | 327d? | 2013-06-18 A | 2014-09-12 A | 100% | 2013-06-18 | 2014-09-12 | 327d? | finish no earlier than 2014-09-12 | R4 | 2616h | 2616h | LTE_CA_B2_B5_B30-Perf | PCG-31 | AT&T | marc.grant@att.com | Rel-12 | RP-60 | Issam | CA | LTE_CA_B2_B5_B30-Perf | RP-141084 |  |  |
| 880 | 204.38 | **Deleted - LTE Advanced 3 Band Carrier Aggregation (3DL/1UL) of Band 2, Band 17 and Band 30** | 127d? | 2013-06-18 A | 2013-12-06 A | 100% | 2013-06-18 | 2013-12-06 | 127d? |  | R4 | 3024h | 3024h | LTE_CA_B2_B17_B30 | PCG-31 | AT&T | marc.grant@att.com | Rel-12 | RP-60 | Issam | CA | LTE_CA_B2_B17_B30 |  | PCG-32 | RP-62 |
| 881 | 204.38.1 | Deleted - Core part: LTE Advanced 3 Band Carrier Aggregation (3DL/1UL) of Band 2, Band 17 and Band 30 | 126d? | 2013-06-18 A | 2013-12-06 A | 100% | 2013-06-18 | 2013-12-06 | 126d? | finish no earlier than 2014-06-13 | R4 | 1008h | 1008h | LTE_CA_B2_B17_B30-Core | PCG-31 | AT&T | marc.grant@att.com | Rel-12 | RP-60 | Issam | CA | LTE_CA_B2_B17_B30-Core | RP-131590 | PCG-32 | RP-62 |
| 882 | 204.38.2 | Deleted - Perf. part: LTE Advanced 3 Band Carrier Aggregation (3DL/1UL) of Band 2, Band 17 and Band 30 | 125d? | 2013-06-19 A | 2013-12-06 A | 100% | 2013-06-19 | 2013-12-06 | 125d? | finish no earlier than 2014-09-12 | R4 | 1000h | 1000h | LTE_CA_B2_B17_B30-Perf | PCG-31 | AT&T | marc.grant@att.com | Rel-12 | RP-60 | Issam | CA | LTE_CA_B2_B17_B30-Perf | RP-131591 | PCG-32 | RP-62 |

Notes:
- 859: Intra-band non-contig. CA 2DL / Impacted TSs and TRs: LTE
- 860: CD:Thu 11/12/14->Mon 15/12/14; Compl:90%->100%; WID:RP-140955->RP-142043 / Impacted TSs and TRs: 36.101, 36.104, 36.133, new TR 36.833-4-04
- 861: CD:Thu 11/12/14->Mon 15/12/14; Compl:0%->100%; WID:RP-140955->RP-142043 / Impacted TSs and TRs: 36.101, 36.104, 36.133, 36.141, 36.307
- 862: Intra-band C CA / Impacted TSs and TRs: LTE
- 863: RP#62 completed / Impacted TSs and TRs: 36.101, 36.104, 36.133, new TR 36.833-1-23 [instead of 36.864]
- 864: RP#62 completed / Impacted TSs and TRs: 36.141, 36.307
- 865: Intra-band non-contig. CA 2DL / Impacted TSs and TRs: LTE
- 866: RP#62 completed / Impacted TSs and TRs: 36.101, 36.104, 36.133, new TR 36.833-2-23
- 867: RP#64 completed. TR 36.833-2-23v200 for Approval / Impacted TSs and TRs: 36.101, 36.133, 36.141, 36.307, new TR 36.833-2-23
- 868: Inter-band 1UL/2DL / Impacted TSs and TRs: LTE
- 869: RP#62 completed / Impacted TSs and TRs: 36.101, 36.104, 36.133, new generic TR 36.851
- 870: RP#62 completed / Impacted TSs and TRs: 36.141, 36.307
- 871: Inter-band 1UL/2DL / Impacted TSs and TRs: LTE
- 872: RP#61 completed / Impacted TSs and TRs: 36.101, new generic TR 36.851
- 873: RP#61 completed / Impacted TSs and TRs: 36.307
- 874: Inter-band 2DL / Impacted TSs and TRs: LTE
- 875: RP#61 completed / Impacted TSs and TRs: 36.101, 36.104, 36.307
- 876: RP#61 completed / Impacted TSs and TRs: 36.101, 36.104, 36.133, 36.141, 36.307
- 877: Inter-band 3DL / Impacted TSs and TRs: LTE
- 878: RP#65 completed. TR 36.853v200 for Approval / Impacted TSs and TRs: 36.101, 36.104, 36.133, 36.141, 36.307, new generic TR 36.853 (3 Band CA with 1UL)
- 879: RP#65 completed / Impacted TSs and TRs: 36.101, 36.104, 36.133, 36.141, 36.307
- 880: Inter-band 3DL / Impacted TSs and TRs: LTE
- 881: RP#62 stopped (25% complete) following RP-131652 discussion / Impacted TSs and TRs: 36.101, 36.104, 36.133, 36.141, 36.307, new generic TR 36.853 (3 Band CA with 1UL)
- 882: RP#62 stopped (25% complete) following RP-131652 discussion / Impacted TSs and TRs: 36.101, 36.104, 36.133, 36.141, 36.307

| ID | WBS | Task | Duration | Start | Finish | Complete | Baseline start | Baseline finish | Baseline duration | Constraint | Resources | Work | Actual work | Acronym | PCG approved | WI rapporteur name | WI rapporteur e-mail | Release | TSG approved | MCC resp | Special Focus Doc | Acronym_3GU_Export | Status Report | PCG stopped | TSG stopped |
| --- | --- | --- | --- | --- | --- | --- | --- | --- | --- | --- | --- | --- | --- | --- | --- | --- | --- | --- | --- | --- | --- | --- | --- | --- | --- |
| 883 | 204.39 | **LTE Advanced 3 Band Carrier Aggregation (3DL/1UL) of Band 2, Band 29 and Band 30** | 328d? | 2013-06-19 A | 2014-09-12 A | 100% | 2013-06-19 | 2014-09-12 | 327d? |  | R4 | 7856h | 7856h | LTE_CA_B2_B29_B30 | PCG-31 | AT&T | marc.grant@att.com | Rel-12 | RP-60 | Issam | CA | LTE_CA_B2_B29_B30 |  |  |  |
| 884 | 204.39.1 | Core part: LTE Advanced 3 Band Carrier Aggregation (3DL/1UL) of Band 2, Band 29 and Band 30 | 327d? | 2013-06-19 A | 2014-09-12 A | 100% | 2013-06-19 | 2014-06-13 | 262d? | finish no earlier than 2014-09-12 | R4 | 2616h | 2616h | LTE_CA_B2_B29_B30-Core | PCG-31 | AT&T | marc.grant@att.com | Rel-12 | RP-60 | Issam | CA | LTE_CA_B2_B29_B30-Core | RP-141084 |  |  |
| 885 | 204.39.2 | Perf. part: LTE Advanced 3 Band Carrier Aggregation (3DL/1UL) of Band 2, Band 29 and Band 30 | 327d? | 2013-06-19 A | 2014-09-12 A | 100% | 2013-06-19 | 2014-09-12 | 327d? | finish no earlier than 2014-09-12 | R4 | 2616h | 2616h | LTE_CA_B2_B29_B30-Perf | PCG-31 | AT&T | marc.grant@att.com | Rel-12 | RP-60 | Issam | CA | LTE_CA_B2_B29_B30-Perf | RP-141084 |  |  |
| 886 | 204.40 | **LTE Advanced 3 Band Carrier Aggregation (3DL/1UL) of Band 4, Band 5 and Band 30** | 331d? | 2013-06-14 A | 2014-09-12 A | 100% | 2013-06-14 | 2014-09-12 | 330d? |  | R4 | 7904h | 7904h | LTE_CA_B4_B5_B30 | PCG-31 | AT&T | marc.grant@att.com | Rel-12 | RP-60 | Issam | CA | LTE_CA_B4_B5_B30 |  |  |  |
| 887 | 204.40.1 | Core part: LTE Advanced 3 Band Carrier Aggregation (3DL/1UL) of Band 4, Band 5 and Band 30 | 330d? | 2013-06-14 A | 2014-09-12 A | 100% | 2013-06-14 | 2014-09-12 | 330d? | finish no earlier than 2014-09-12 | R4 | 2640h | 2640h | LTE_CA_B4_B5_B30-Core | PCG-31 | AT&T | marc.grant@att.com | Rel-12 | RP-60 | Issam | CA | LTE_CA_B4_B5_B30-Core | RP-141084 |  |  |
| 888 | 204.40.2 | Perf. part: LTE Advanced 3 Band Carrier Aggregation (3DL/1UL) of Band 4, Band 5 and Band 30 | 327d? | 2013-06-19 A | 2014-09-12 A | 100% | 2013-06-19 | 2014-09-12 | 327d? | finish no earlier than 2014-09-12 | R4 | 2616h | 2616h | LTE_CA_B4_B5_B30-Perf | PCG-31 | AT&T | marc.grant@att.com | Rel-12 | RP-60 | Issam | CA | LTE_CA_B4_B5_B30-Perf | RP-141084 |  |  |
| 889 | 204.41 | **Deleted - LTE Advanced 3 Band Carrier Aggregation (3DL/1UL) of Band 4, Band 17 and Band 30** | 127d? | 2013-06-18 A | 2013-12-06 A | 100% | 2013-06-18 | 2013-12-06 | 127d? |  | R4 | 3040h | 3040h | LTE_CA_B4_B17_B30 | PCG-31 | AT&T | marc.grant@att.com | Rel-12 | RP-60 | Issam | CA | LTE_CA_B4_B17_B30 |  | PCG-32 | RP-62 |
| 890 | 204.41.1 | Deleted - Core part: LTE Advanced 3 Band Carrier Aggregation (3DL/1UL) of Band 4, Band 17 and Band 30 | 127d? | 2013-06-18 A | 2013-12-06 A | 100% | 2013-06-18 | 2013-12-06 | 127d? | finish no earlier than 2013-12-06 | R4 | 1016h | 1016h | LTE_CA_B4_B17_B30-Core | PCG-31 | AT&T | marc.grant@att.com | Rel-12 | RP-60 | Issam | CA | LTE_CA_B4_B17_B30-Core | RP-131598 | PCG-32 | RP-62 |
| 891 | 204.41.2 | Deleted - Perf. part: LTE Advanced 3 Band Carrier Aggregation (3DL/1UL) of Band 4, Band 17 and Band 30 | 126d? | 2013-06-19 A | 2013-12-06 A | 100% | 2013-06-19 | 2013-12-06 | 126d? | finish no earlier than 2013-12-06 | R4 | 1008h | 1008h | LTE_CA_B4_B17_B30-Perf | PCG-31 | AT&T | marc.grant@att.com | Rel-12 | RP-60 | Issam | CA | LTE_CA_B4_B17_B30-Perf | RP-131599 | PCG-32 | RP-62 |
| 892 | 204.42 | **LTE Advanced 3 Band Carrier Aggregation (3DL/1UL) of Band 4, Band 29 and Band 30** | 331d? | 2013-06-14 A | 2014-09-12 A | 100% | 2013-06-14 | 2014-09-12 | 330d? |  | R4 | 7904h | 7904h | LTE_CA_B4_B29_B30 | PCG-31 | AT&T | marc.grant@att.com | Rel-12 | RP-60 | Issam | CA | LTE_CA_B4_B29_B30 |  |  |  |
| 893 | 204.42.1 | Core part: LTE Advanced 3 Band Carrier Aggregation (3DL/1UL) of Band 4, Band 29 and Band 30 | 330d? | 2013-06-14 A | 2014-09-12 A | 100% | 2013-06-14 | 2014-09-12 | 330d? | finish no earlier than 2014-09-12 | R4 | 2640h | 2640h | LTE_CA_B4_B29_B30-Core | PCG-31 | AT&T | marc.grant@att.com | Rel-12 | RP-60 | Issam | CA | LTE_CA_B4_B29_B30-Core | RP-141084 |  |  |
| 894 | 204.42.2 | Perf. part: LTE Advanced 3 Band Carrier Aggregation (3DL/1UL) of Band 4, Band 29 and Band 30 | 327d? | 2013-06-19 A | 2014-09-12 A | 100% | 2013-06-19 | 2014-09-12 | 327d? | finish no earlier than 2014-09-12 | R4 | 2616h | 2616h | LTE_CA_B4_B29_B30-Perf | PCG-31 | AT&T | marc.grant@att.com | Rel-12 | RP-60 | Issam | CA | LTE_CA_B4_B29_B30-Perf | RP-141084 |  |  |
| 895 | 204.43 | **LTE Advanced 3 Band Carrier Aggregation (3DL/1UL) of Band 2, Band 4 and Band 13** | 331d? | 2013-06-14 A | 2014-09-12 A | 100% | 2013-06-14 | 2014-09-12 | 330d? |  | R4 | 7904h | 7904h | LTE_CA_B2_B4_B13 | PCG-31 | Verizon | zheng.zhao@verizonwireless.com | Rel-12 | RP-60 | Issam | CA | LTE_CA_B2_B4_B13 |  |  |  |
| 896 | 204.43.1 | Core part: LTE Advanced 3 Band Carrier Aggregation (3DL/1UL) of Band 2, Band 4 and Band 13 | 330d? | 2013-06-14 A | 2014-09-12 A | 100% | 2013-06-14 | 2014-09-12 | 330d? | finish no earlier than 2014-09-12 | R4 | 2640h | 2640h | LTE_CA_B2_B4_B13-Core | PCG-31 | Verizon | zheng.zhao@verizonwireless.com | Rel-12 | RP-60 | Issam | CA | LTE_CA_B2_B4_B13-Core | RP-141084 |  |  |
| 897 | 204.43.2 | Perf. part: LTE Advanced 3 Band Carrier Aggregation (3DL/1UL) of Band 2, Band 4 and Band 13 | 327d? | 2013-06-19 A | 2014-09-12 A | 100% | 2013-06-19 | 2014-09-12 | 327d? | finish no earlier than 2014-09-12 | R4 | 2616h | 2616h | LTE_CA_B2_B4_B13-Perf | PCG-31 | Verizon | zheng.zhao@verizonwireless.com | Rel-12 | RP-60 | Issam | CA | LTE_CA_B2_B4_B13-Perf | RP-141084 |  |  |
| 898 | 204.44 | **LTE Advanced 3 Band Carrier Aggregation (3DL/1UL) of Band 2, Band 2 and Band 13** | 329d? | 2013-06-18 A | 2014-09-12 A | 100% | 2013-06-18 | 2014-09-12 | 328d? |  | R4 | 7864h | 7864h | LTE_CA_B2_B2_B13 | PCG-31 | Verizon | zheng.zhao@verizonwireless.com | Rel-12 | RP-60 | Issam | CA | LTE_CA_B2_B2_B13 |  |  |  |
| 899 | 204.44.1 | Core part: LTE Advanced 3 Band Carrier Aggregation (3DL/1UL) of Band 2, Band 2 and Band 13 | 327d? | 2013-06-18 A | 2014-09-12 A | 100% | 2013-06-18 | 2014-09-12 | 327d? | finish no earlier than 2014-09-12 | R4 | 2616h | 2616h | LTE_CA_B2_B2_B13-Core | PCG-31 | Verizon | zheng.zhao@verizonwireless.com | Rel-12 | RP-60 | Issam | CA | LTE_CA_B2_B2_B13-Core | RP-141084 |  |  |
| 900 | 204.44.2 | Perf. part: LTE Advanced 3 Band Carrier Aggregation (3DL/1UL) of Band 2, Band 2 and Band 13 | 327d? | 2013-06-19 A | 2014-09-12 A | 100% | 2013-06-19 | 2014-09-12 | 327d? | finish no earlier than 2014-09-12 | R4 | 2616h | 2616h | LTE_CA_B2_B2_B13-Perf | PCG-31 | Verizon | zheng.zhao@verizonwireless.com | Rel-12 | RP-60 | Issam | CA | LTE_CA_B2_B2_B13-Perf | RP-141084 |  |  |
| 901 | 204.45 | **LTE Advanced 3 Band Carrier Aggregation (3DL/1UL) of Band 4, Band 4 and Band 13** | 331d? | 2013-06-14 A | 2014-09-12 A | 100% | 2013-06-14 | 2014-09-12 | 330d? |  | R4 | 7928h | 7928h | LTE_CA_B4_B4_B13 | PCG-31 | Verizon | zheng.zhao@verizonwireless.com | Rel-12 | RP-60 | Issam | CA | LTE_CA_B4_B4_B13 |  |  |  |
| 902 | 204.45.1 | Core part: LTE Advanced 3 Band Carrier Aggregation (3DL/1UL) of Band 4, Band 4 and Band 13 | 330d? | 2013-06-14 A | 2014-09-12 A | 100% | 2013-06-14 | 2014-09-12 | 330d? | finish no earlier than 2014-09-12 | R4 | 2640h | 2640h | LTE_CA_B4_B4_B13-Core | PCG-31 | Verizon | zheng.zhao@verizonwireless.com | Rel-12 | RP-60 | Issam | CA | LTE_CA_B4_B4_B13-Core | RP-141084 |  |  |
| 903 | 204.45.2 | Perf. part: LTE Advanced 3 Band Carrier Aggregation (3DL/1UL) of Band 4, Band 4 and Band 13 | 330d? | 2013-06-14 A | 2014-09-12 A | 100% | 2013-06-14 | 2014-09-12 | 330d? | finish no earlier than 2014-09-12 | R4 | 2640h | 2640h | LTE_CA_B4_B4_B13-Perf | PCG-31 | Verizon | zheng.zhao@verizonwireless.com | Rel-12 | RP-60 | Issam | CA | LTE_CA_B4_B4_B13-Perf | RP-141084 |  |  |
| 904 | 204.46 | **LTE Advanced inter-band Carrier Aggregation of Band 7 and Band 28** | 66d? | 2013-09-09 A | 2013-12-06 A | 100% | 2013-09-09 | 2013-12-06 | 66d? |  | R4 | 1584h | 1584h | LTE_CA_B7_B28 | PCG-31 | Huawei | Liehai Liu (liuliehai@huawei.com) | Rel-12 | RP-61 | Issam | CA | LTE_CA_B7_B28 |  |  |  |
| 905 | 204.46.1 | Core part: LTE Advanced inter-band Carrier Aggregation of Band 7 and Band 28 | 66d? | 2013-09-09 A | 2013-12-06 A | 100% | 2013-09-09 | 2013-12-06 | 66d? | finish no earlier than 2013-12-06 | R4 | 528h | 528h | LTE_CA_B7_B28-Core | PCG-31 | Huawei | Liehai Liu (liuliehai@huawei.com) | Rel-12 | RP-61 | Issam | CA | LTE_CA_B7_B28-Core | RP-131545 |  |  |
| 906 | 204.46.2 | Perf. part: LTE Advanced inter-band Carrier Aggregation of Band 7 and Band 28 | 66d? | 2013-09-09 A | 2013-12-06 A | 100% | 2013-09-09 | 2013-12-06 | 66d? | finish no earlier than 2013-12-06 | R4 | 528h | 528h | LTE_CA_B7_B28-Perf | PCG-31 | Huawei | Liehai Liu (liuliehai@huawei.com) | Rel-12 | RP-61 | Issam | CA | LTE_CA_B7_B28-Perf | RP-131546 |  |  |

Notes:
- 883: Inter-band 3DL / Impacted TSs and TRs: LTE
- 884: RP#65 completed. Updated WID RP-131697=>RP-141212 / Impacted TSs and TRs: 36.101, 36.104, 36.133, 36.141, 36.307, new generic TR 36.853 (3 Band CA with 1UL)
- 885: RP#65 completed / Impacted TSs and TRs: 36.101, 36.104, 36.133, 36.141, 36.307
- 886: Inter-band CA 3DL / Impacted TSs and TRs: LTE
- 887: RP#65 completed. Updated WID RP-131698=>RP-141213 / Impacted TSs and TRs: 36.101, 36.104, 36.133, 36.141, 36.307, new generic TR 36.853 (3 Band CA with 1UL)
- 888: RP#65 completed / Impacted TSs and TRs: 36.101, 36.104, 36.133, 36.141, 36.307
- 889: Inter-band 3DL / Impacted TSs and TRs: LTE
- 890: RP#62 stopped (25% complete) following RP-131653 discussion / Impacted TSs and TRs: 36.101, 36.104, 36.133, 36.141, 36.307, new generic TR 36.853 (3 Band CA with 1UL)
- 891: RP#62 stopped (25% complete) following RP-131653 discussion / Impacted TSs and TRs: 36.101, 36.104, 36.133, 36.141, 36.307
- 892: Inter-band CA 3DL / Impacted TSs and TRs: LTE
- 893: RP#65 completed. Updated WID RP-131699=>RP- 141215 / Impacted TSs and TRs: 36.101, 36.104, 36.133, 36.141, 36.307, new generic TR 36.853 (3 Band CA with 1UL)
- 894: RP#65 completed / Impacted TSs and TRs: 36.101, 36.104, 36.133, 36.141, 36.307
- 895: Inter-band CA 3DL / Impacted TSs and TRs: LTE
- 896: RP#65 completed. Updated RP-131684=>RP-141434 / Impacted TSs and TRs: 36.101, 36.104, 36.133, new generic TR 36.853 (3 Band CA with 1UL)
- 897: RP#65 completed / Impacted TSs and TRs: 36.101, 36.133, 36.141, 36.307
- 898: Inter-band CA 3DL / Impacted TSs and TRs: LTE
- 899: RP#65 completed. Updated WID RP-131682=>RP-141435 / Impacted TSs and TRs: 36.101, 36.104, 36.133, new generic TR 36.853 (3 Band CA with 1UL)
- 900: RP#65 completed / Impacted TSs and TRs: 36.101, 36.133, 36.141, 36.307
- 901: Inter-band CA 3DL / Impacted TSs and TRs: LTE
- 902: RP#65 completed. Updated WID RP-131683=>RP-141433 / Impacted TSs and TRs: 36.101, 36.104, 36.133, new generic TR 36.853 (3 Band CA with 1UL)
- 903: RP#65 completed / Impacted TSs and TRs: 36.101, 36.133, 36.141, 36.307
- 904: Inter-band 1UL/2DL / Impacted TSs and TRs: LTE
- 905: RP#62 completed / Impacted TSs and TRs: 36.101, 36.104, 36.307
- 906: RP#62 completed / Impacted TSs and TRs: 36.141

| ID | WBS | Task | Duration | Start | Finish | Complete | Remaining | Baseline start | Baseline finish | Baseline duration | Total slack | Constraint | Resources | Work | Actual work | Acronym | PCG approved | Impacted TSs and TRs | WI rapporteur name | WI rapporteur e-mail | Release | TSG approved | MCC resp | Special Focus Doc | Acronym_3GU_Export | Status Report |
| --- | --- | --- | --- | --- | --- | --- | --- | --- | --- | --- | --- | --- | --- | --- | --- | --- | --- | --- | --- | --- | --- | --- | --- | --- | --- | --- |
| 907 | 204.47 | **LTE Advanced inter-band Carrier Aggregation of Band 5 and Band 25** | 66d? | 2013-09-09 A | 2013-12-06 A | 100% |  | 2013-09-09 | 2013-12-06 | 66d? |  |  | R4 | 1584h | 1584h | LTE_CA_B5_B25 | PCG-31 | LTE | U.S. Cellular | sebastian.thalanany@uscellular.com | Rel-12 | RP-61 | Issam | CA | LTE_CA_B5_B25 |  |
| 908 | 204.47.1 | Core part: LTE Advanced inter-band Carrier Aggregation of Band 5 and Band 25 | 66d? | 2013-09-09 A | 2013-12-06 A | 100% |  | 2013-09-09 | 2013-12-06 | 66d? |  | finish no earlier than 2013-12-06 | R4 | 528h | 528h | LTE_CA_B5_B25-Core | PCG-31 | 36.101, 36.104, 36.133, new generic TR 36.851 | U.S. Cellular | sebastian.thalanany@uscellular.com | Rel-12 | RP-61 | Issam | CA | LTE_CA_B5_B25-Core | RP-131543 |
| 909 | 204.47.2 | Perf. part: LTE Advanced inter-band Carrier Aggregation of Band 5 and Band 25 | 66d? | 2013-09-09 A | 2013-12-06 A | 100% |  | 2013-09-09 | 2013-12-06 | 66d? |  | finish no earlier than 2013-12-06 | R4 | 528h | 528h | LTE_CA_B5_B25-Perf | PCG-31 | 36.141, 36.307 | U.S. Cellular | sebastian.thalanany@uscellular.com | Rel-12 | RP-61 | Issam | CA | LTE_CA_B5_B25-Perf | RP-131705 |
| 910 | 204.48 | **LTE Advanced inter-band Carrier Aggregation of Band 1 and Band 11** | 202d? | 2013-09-09 A | 2014-06-13 A | 100% |  | 2013-09-09 | 2014-06-13 | 202d? |  |  | R4 | 4848h | 4848h | LTE_CA_B1_B11 | PCG-31 | LTE | SoftBank Mobile | kenichi.kihara@g.softbank.co.jp | Rel-12 | RP-61 | Issam | CA | LTE_CA_B1_B11 |  |
| 911 | 204.48.1 | Core part: LTE Advanced inter-band Carrier Aggregation of Band 1 and Band 11 | 202d? | 2013-09-09 A | 2014-06-13 A | 100% |  | 2013-09-09 | 2014-06-13 | 202d? |  | finish no earlier than 2014-06-13 | R4 | 1616h | 1616h | LTE_CA_B1_B11-Core | PCG-31 | 36.101, 36.104, new generic TR 36.851 | SoftBank Mobile | kenichi.kihara@g.softbank.co.jp | Rel-12 | RP-61 | Issam | CA | LTE_CA_B1_B11-Core | RP-140569 |
| 912 | 204.48.2 | Perf. part: LTE Advanced inter-band Carrier Aggregation of Band 1 and Band 11 | 202d? | 2013-09-09 A | 2014-06-13 A | 100% |  | 2013-09-09 | 2014-06-13 | 202d? |  | finish no earlier than 2014-06-13 | R4 | 1616h | 1616h | LTE_CA_B1_B11-Perf | PCG-31 | 36.141, 36.307 | SoftBank Mobile | kenichi.kihara@g.softbank.co.jp | Rel-12 | RP-61 | Issam | CA | LTE_CA_B1_B11-Perf | RP-140569 |
| 913 | 204.49 | **LTE Advanced inter-band Carrier Aggregation of Band 8 and Band 11** | 268d? | 2013-09-09 A | 2014-09-12 A | 100% |  | 2013-09-09 | 2014-09-12 | 267d? |  |  | R4 | 6416h | 6416h | LTE_CA_B8_B11 | PCG-31 | LTE | SoftBank Mobile | kenichi.kihara@g.softbank.co.jp | Rel-12 | RP-61 | Issam | CA | LTE_CA_B8_B11 |  |
| 914 | 204.49.1 | Core part: LTE Advanced inter-band Carrier Aggregation of Band 8 and Band 11 | 267d? | 2013-09-09 A | 2014-09-12 A | 100% |  | 2013-09-09 | 2014-09-12 | 267d? |  | finish no earlier than 2014-09-12 | R4 | 2136h | 2136h | LTE_CA_B8_B11-Core | PCG-31 | 36.101, 36.104, new generic TR 36.851 | SoftBank Mobile | kenichi.kihara@g.softbank.co.jp | Rel-12 | RP-61 | Issam | CA | LTE_CA_B8_B11-Core | RP-141084 |
| 915 | 204.49.2 | Perf. part: LTE Advanced inter-band Carrier Aggregation of Band 8 and Band 11 | 267d? | 2013-09-09 A | 2014-09-12 A | 100% |  | 2013-09-09 | 2014-09-12 | 267d? |  | finish no earlier than 2014-09-12 | R4 | 2136h | 2136h | LTE_CA_B8_B11-Perf | PCG-31 | 36.141, 36.307 | SoftBank Mobile | kenichi.kihara@g.softbank.co.jp | Rel-12 | RP-61 | Issam | CA | LTE_CA_B8_B11-Perf | RP-141084 |
| 916 | 204.50 | **LTE Advanced inter-band Carrier Aggregation of Band 5 and Band 7** | 62d? | 2013-09-09 A | 2013-12-02 A | 100% |  | 2013-09-09 | 2013-12-02 | 62d? |  |  | R4 | 1488h | 1488h | LTE_CA_B5_B7 | PCG-31 | LTE | LG Uplus | Yeonsang KOO (yskoo@lguplus.co.kr) | Rel-12 | RP-61 | Issam | CA | LTE_CA_B5_B7 |  |
| 917 | 204.50.1 | Core part: LTE Advanced inter-band Carrier Aggregation of Band 5 and Band 7 | 62d? | 2013-09-09 A | 2013-12-02 A | 100% |  | 2013-09-09 | 2013-12-02 | 62d? |  | finish no earlier than 2013-12-02 | R4 | 496h | 496h | LTE_CA_B5_B7-Core | PCG-31 | 36.101, 36.104, 36.133, new generic TR 36.851 | LG Uplus | Yeonsang KOO (yskoo@lguplus.co.kr) | Rel-12 | RP-61 | Issam | CA | LTE_CA_B5_B7-Core | RP-131541 |
| 918 | 204.50.2 | Perf. part: LTE Advanced inter-band Carrier Aggregation of Band 5 and Band 7 | 62d? | 2013-09-09 A | 2013-12-02 A | 100% |  | 2013-09-09 | 2013-12-02 | 62d? |  | finish no earlier than 2013-12-02 | R4 | 496h | 496h | LTE_CA_B5_B7-Perf | PCG-31 | 36.141, 36.307 | LG Uplus | Yeonsang KOO (yskoo@lguplus.co.kr) | Rel-12 | RP-61 | Issam | CA | LTE_CA_B5_B7-Perf | RP-131542 |
| 919 | 204.51 | **LTE Advanced intra-band contiguous Carrier Aggregation in Band 41 for 3DL** | 400d? | 2013-09-09 A | 2015-03-15 | 82% | 71.74d? | 2013-09-09 | 2014-09-12 | 267d? | 589d |  | R4 | 8512h | 5694.22h | LTE_CA_C_B41_3DL | PCG-31 | LTE | Alcatel-Lucent | man-hung.ng@alcatel-lucent.com | Rel-12 | RP-61 | Issam | CA | LTE_CA_C_B41_3DL |  |
| 920 | 204.51.1 | Core part: LTE Advanced intra-band contiguous Carrier Aggregation in Band 41 for 3DL | 267d? | 2013-09-09 A | 2014-09-12 A | 100% |  | 2013-09-09 | 2014-09-12 | 267d? |  | finish no earlier than 2014-09-12 | R4 | 2136h | 2136h | LTE_CA_C_B41_3DL-Core | PCG-31 | 36.101, 36.104, 36.133, 36.307, New TR 36.833-5-41 | Alcatel-Lucent | man-hung.ng@alcatel-lucent.com | Rel-12 | RP-61 | Issam | CA | LTE_CA_C_B41_3DL-Core | RP-141084 |
| 921 | 204.51.2 | Perf. part: LTE Advanced intra-band contiguous Carrier Aggregation in Band 41 for 3DL | 397d? | 2013-09-09 A | 2015-03-15 | 70% | 119.1d? | 2013-09-09 | 2014-09-12 | 267d? | 589d | finish no earlier than 2015-03-15 | R4 | 3176h | 2223.2h | LTE_CA_C_B41_3DL-Perf | PCG-31 | 36.141 | Alcatel-Lucent | man-hung.ng@alcatel-lucent.com | Rel-12 | RP-61 | Issam | CA | LTE_CA_C_B41_3DL-Perf | RP-141084 |
| 922 | 204.52 | **LTE Advanced intra-band non-contiguous Carrier Aggregation in Band 2** | 202d? | 2013-09-09 A | 2014-06-13 A | 100% |  | 2013-09-09 | 2014-06-13 | 202d? |  |  | R4 | 4840h | 4840h | LTE_CA_NC_B2 | PCG-31 | LTE | Ericsson | imadur.rahman@ericsson.com | Rel-12 | RP-61 | Issam | CA | LTE_CA_NC_B2 |  |
| 923 | 204.52.1 | Core part: LTE Advanced intra-band non-contiguous Carrier Aggregation in Band 2 | 202d? | 2013-09-09 A | 2014-06-13 A | 100% |  | 2013-09-09 | 2014-06-13 | 202d? |  | finish no earlier than 2014-06-13 | R4 | 1616h | 1616h | LTE_CA_NC_B2-Core | PCG-31 | 36.101, 36.104, 36.133, New TR 36.833-2-02 | Ericsson | imadur.rahman@ericsson.com | Rel-12 | RP-61 | Issam | CA | LTE_CA_NC_B2-Core | RP-140569 |
| 924 | 204.52.2 | Perf. part: LTE Advanced intra-band non-contiguous Carrier Aggregation in Band 2 | 201d? | 2013-09-10 A | 2014-06-13 A | 100% |  | 2013-09-10 | 2014-06-13 | 201d? |  | finish no earlier than 2014-06-13 | R4 | 1608h | 1608h | LTE_CA_NC_B2-Perf | PCG-31 | 36.141, 36.307 | Ericsson | imadur.rahman@ericsson.com | Rel-12 | RP-61 | Issam | CA | LTE_CA_NC_B2-Perf | RP-140569 |
| 925 | 204.53 | **LTE Advanced inter-band Carrier Aggregation of Band 1 and Band 3** | 202d? | 2013-12-09 A | 2014-09-12 A | 100% |  | 2013-12-09 | 2014-09-12 | 201d? |  |  | R4 | 4832h | 4832h | LTE_CA_B1_B3 | PCG-32 | LTE | China Unicom | Hao Chen (chenhao49@chinaunicom.cn) | Rel-12 | RP-62 | Issam | CA | LTE_CA_B1_B3 |  |
| 926 | 204.53.1 | Core part: LTE Advanced inter-band Carrier Aggregation of Band 1 and Band 3 | 201d? | 2013-12-09 A | 2014-09-12 A | 100% |  | 2013-12-09 | 2014-09-12 | 201d? |  | finish no earlier than 2014-09-12 | R4 | 1608h | 1608h | LTE_CA_B1_B3-Core | PCG-32 | 36.101, 36.104, 36.133, new generic TR 36.851 | China Unicom | Hao Chen (chenhao49@chinaunicom.cn) | Rel-12 | RP-62 | Issam | CA | LTE_CA_B1_B3-Core | RP-141084 |
| 927 | 204.53.2 | Perf. part: LTE Advanced inter-band Carrier Aggregation of Band 1 and Band 3 | 201d? | 2013-12-09 A | 2014-09-12 A | 100% |  | 2013-12-09 | 2014-09-12 | 201d? |  | finish no earlier than 2014-09-12 | R4 | 1608h | 1608h | LTE_CA_B1_B3-Perf | PCG-32 | 36.141, 36.307 | China Unicom | Hao Chen (chenhao49@chinaunicom.cn) | Rel-12 | RP-62 | Issam | CA | LTE_CA_B1_B3-Perf | RP-141084 |
| 928 | 204.54 | **LTE Advanced inter-band Carrier Aggregation of Band 1 and Band 28** | 270d? | 2013-12-09 A | 2014-12-15 A | 100% |  | 2013-12-09 | 2014-09-12 | 201d? |  |  | R4 | 6432h | 6432h | LTE_CA_B1_B28 | PCG-32 | LTE | KDDI | Masaaki Obara (ms-obara@kddi.com) | Rel-12 | RP-62 | Issam | CA | LTE_CA_B1_B28 |  |
| 929 | 204.54.1 | Core part: LTE Advanced inter-band Carrier Aggregation of Band 1 and Band 28 | 267d? | 2013-12-09 A | 2014-12-15 A | 100% |  | 2013-12-09 | 2014-09-12 | 201d? |  | finish no earlier than 2014-12-15 | R4 | 2136h | 2136h | LTE_CA_B1_B28-Core | PCG-32 | 36.101, 36.104, 36.133, 36.307, new generic TR 36.851 | KDDI | Masaaki Obara (ms-obara@kddi.com) | Rel-12 | RP-62 | Issam | CA | LTE_CA_B1_B28-Core | RP-141084 |
| 930 | 204.54.2 | Perf. part: LTE Advanced inter-band Carrier Aggregation of Band 1 and Band 28 | 267d? | 2013-12-12 A | 2014-12-15 A | 100% |  | 2013-12-09 | 2014-09-12 | 201d? |  | finish no earlier than 2014-12-15 | R4 | 2136h | 2136h | LTE_CA_B1_B28-Perf | PCG-32 | 36.133, 36.141 | KDDI | Masaaki Obara (ms-obara@kddi.com) | Rel-12 | RP-62 | Issam | CA | LTE_CA_B1_B28-Perf | RP-141084 |

Notes:
- 907: Inter-band 1UL/2DL
- 908: RP#62 completed
- 909: RP#62 completed
- 910: Inter-band CA 2DL
- 911: RP#64 completed
- 912: RP#64 completed
- 913: Inter-band CA 2DL
- 914: RP#65 completed
- 915: RP#65 completed
- 916: Inter-band 1UL/2DL
- 917: RP#62 completed
- 918: RP#62 completed
- 919: Intra-band contig. CA 3DL
- 920: RP#65 completed
- 921: CD:Thu 12/03/15->Sun 15/03/15; Compl:60%->70%; WID:RP-140955->RP-142043
- 922: Intra-band non-contig. CA 2DL
- 923: RP#64 completed. TR 36.833-2-02v100 for 1-step Approval
- 924: RP#64 completed
- 925: Inter-band CA 2DL
- 926: RP#65 completed
- 927: RP#65 completed
- 928: Inter-band CA 2DL
- 929: CD:Thu 11/12/14->Mon 15/12/14; Compl:70%->100%; WID:RP-140955->RP-142043
- 930: CD:Thu 11/12/14->Mon 15/12/14; Compl:0%->100%; WID:RP-140955->RP-142043

| ID | WBS | Task | Duration | Start | Finish | Complete | Remaining | Baseline start | Baseline finish | Baseline duration | Total slack | Constraint | Resources | Work | Actual work | Acronym | PCG approved | WI rapporteur name | WI rapporteur e-mail | Release | TSG approved | MCC resp | Special Focus Doc | Acronym_3GU_Export | Status Report |
| --- | --- | --- | --- | --- | --- | --- | --- | --- | --- | --- | --- | --- | --- | --- | --- | --- | --- | --- | --- | --- | --- | --- | --- | --- | --- |
| 931 | 204.55 | **LTE Advanced inter-band Carrier Aggregation of Band 2 and Band 4 - Additional bandwidth combination set** | 65d? | 2013-12-09 A | 2014-03-06 A | 100% |  | 2013-12-09 | 2014-03-06 | 65d? |  |  | R4 | 1560h | 1560h | LTE_CA_B2_B4_BWset | PCG-32 | T-Mobile USA | nelson.ueng@t-mobile.com | Rel-12 | RP-62 | Issam | CA | LTE_CA_B2_B4_BWset |  |
| 932 | 204.55.1 | Core part: LTE Advanced inter-band Carrier Aggregation of Band 2 and Band 4 - Additional bandwidth combination set | 65d? | 2013-12-09 A | 2014-03-06 A | 100% |  | 2013-12-09 | 2014-03-06 | 65d? |  | finish no earlier than 2014-03-06 | R4 | 520h | 520h | LTE_CA_B2_B4_BWset-Core | PCG-32 | T-Mobile USA | nelson.ueng@t-mobile.com | Rel-12 | RP-62 | Issam | CA | LTE_CA_B2_B4_BWset-Core | RP-140428 |
| 933 | 204.55.2 | Perf. part: LTE Advanced inter-band Carrier Aggregation of Band 2 and Band 4 - Additional bandwidth combination set | 65d? | 2013-12-09 A | 2014-03-06 A | 100% |  | 2013-12-09 | 2014-03-06 | 65d? |  | finish no earlier than 2014-03-06 | R4 | 520h | 520h | LTE_CA_B2_B4_BWset-Perf | PCG-32 | T-Mobile USA | nelson.ueng@t-mobile.com | Rel-12 | RP-62 | Issam | CA | LTE_CA_B2_B4_BWset-Perf | RP-140428 |
| 934 | 204.56 | **LTE Advanced inter-band Carrier Aggregation of Band 4 and Band 27** | 136d? | 2013-12-09 A | 2014-06-13 A | 100% |  | 2013-12-09 | 2014-06-13 | 136d? |  |  | R4 | 3264h | 3264h | LTE_CA_B4_B27 | PCG-32 | NII Holdings | bill.shvodian@nii.com | Rel-12 | RP-62 | Issam | CA | LTE_CA_B4_B27 |  |
| 935 | 204.56.1 | Core part: LTE Advanced inter-band Carrier Aggregation of Band 4 and Band 27 | 136d? | 2013-12-09 A | 2014-06-13 A | 100% |  | 2013-12-09 | 2014-06-13 | 136d? |  | finish no earlier than 2014-06-13 | R4 | 1088h | 1088h | LTE_CA_B4_B27-Core | PCG-32 | NII Holdings | bill.shvodian@nii.com | Rel-12 | RP-62 | Issam | CA | LTE_CA_B4_B27-Core | RP-140569 |
| 936 | 204.56.2 | Perf. part: LTE Advanced inter-band Carrier Aggregation of Band 4 and Band 27 | 136d? | 2013-12-09 A | 2014-06-13 A | 100% |  | 2013-12-09 | 2014-06-13 | 136d? |  | finish no earlier than 2014-06-13 | R4 | 1088h | 1088h | LTE_CA_B4_B27-Perf | PCG-32 | NII Holdings | bill.shvodian@nii.com | Rel-12 | RP-62 | Issam | CA | LTE_CA_B4_B27-Perf | RP-140569 |
| 937 | 204.57 | **LTE Advanced inter-band Carrier Aggregation of Band 3 and Band 27** | 65d? | 2013-12-09 A | 2014-03-06 A | 100% |  | 2013-12-09 | 2014-03-06 | 65d? |  |  | R4 | 1560h | 1560h | LTE_CA_B3_B27 | PCG-32 | KT | Chungwoo HWANG (cwhwang@kt.com) | Rel-12 | RP-62 | Issam | CA | LTE_CA_B3_B27 | RP-140428 |
| 938 | 204.57.1 | Core part: LTE Advanced inter-band Carrier Aggregation of Band 3 and Band 27 | 65d? | 2013-12-09 A | 2014-03-06 A | 100% |  | 2013-12-09 | 2014-03-06 | 65d? |  | finish no earlier than 2014-03-06 | R4 | 520h | 520h | LTE_CA_B3_B27-Core | PCG-32 | KT | Chungwoo HWANG (cwhwang@kt.com) | Rel-12 | RP-62 | Issam | CA | LTE_CA_B3_B27-Core | RP-140428 |
| 939 | 204.57.2 | Perf. part: LTE Advanced inter-band Carrier Aggregation of Band 3 and Band 27 | 65d? | 2013-12-09 A | 2014-03-06 A | 100% |  | 2013-12-09 | 2014-03-06 | 65d? |  | finish no earlier than 2014-03-06 | R4 | 520h | 520h | LTE_CA_B3_B27-Perf | PCG-32 | KT | Chungwoo HWANG (cwhwang@kt.com) | Rel-12 | RP-62 | Issam | CA | LTE_CA_B3_B27-Perf | RP-140428 |
| 940 | 204.58 | **LTE Advanced inter-band Carrier Aggregation in Band 8 and Band 20 - Additional channel bandwidth** | 65d? | 2013-12-09 A | 2014-03-06 A | 100% |  | 2013-12-09 | 2014-03-06 | 65d? |  |  | R4 | 1560h | 1560h | LTE_CA_B8_B20_BW | PCG-32 | Vodafone | luis.anaya@vodafone.com | Rel-12 | RP-62 | Issam | CA | LTE_CA_B8_B20_BW | RP-140428 |
| 941 | 204.58.1 | Core part: LTE Advanced inter-band Carrier Aggregation in Band 8 and Band 20 - Additional channel bandwidth | 65d? | 2013-12-09 A | 2014-03-06 A | 100% |  | 2013-12-09 | 2014-03-06 | 65d? |  | finish no earlier than 2014-03-06 | R4 | 520h | 520h | LTE_CA_B8_B20_BW-Core | PCG-32 | Vodafone | luis.anaya@vodafone.com | Rel-12 | RP-62 | Issam | CA | LTE_CA_B8_B20_BW-Core | RP-140428 |
| 942 | 204.58.2 | Perf. part: LTE Advanced inter-band Carrier Aggregation in Band 8 and Band 20 - Additional channel bandwidth | 65d? | 2013-12-09 A | 2014-03-06 A | 100% |  | 2013-12-09 | 2014-03-06 | 65d? |  | finish no earlier than 2014-03-06 | R4 | 520h | 520h | LTE_CA_B8_B20_BW-Perf | PCG-32 | Vodafone | luis.anaya@vodafone.com | Rel-12 | RP-62 | Issam | CA | LTE_CA_B8_B20_BW-Perf | RP-140428 |
| 943 | 204.59 | **LTE Advanced 3 Band Carrier Aggregation (3DL/1UL) for Band 1, Band 3 and Band 8** | 202d? | 2013-12-09 A | 2014-09-12 A | 100% |  | 2013-12-09 | 2014-09-12 | 201d? |  |  | R4 | 4832h | 4832h | LTE_CA_B1_B3_B8 | PCG-32 | KT | Ilwhan Kim (ilwhan.kim@kt.com) | Rel-12 | RP-62 | Issam | CA | LTE_CA_B1_B3_B8 |  |
| 944 | 204.59.1 | Core part: LTE Advanced 3 Band Carrier Aggregation (3DL/1UL) for Band 1, Band 3 and Band 8 | 201d? | 2013-12-09 A | 2014-09-12 A | 100% |  | 2013-12-09 | 2014-09-12 | 201d? |  | finish no earlier than 2014-09-12 | R4 | 1608h | 1608h | LTE_CA_B1_B3_B8-Core | PCG-32 | KT | Ilwhan Kim (ilwhan.kim@kt.com) | Rel-12 | RP-62 | Issam | CA | LTE_CA_B1_B3_B8-Core | RP-141084 |
| 945 | 204.59.2 | Perf. part: LTE Advanced 3 Band Carrier Aggregation (3DL/1UL) for Band 1, Band 3 and Band 8 | 201d? | 2013-12-09 A | 2014-09-12 A | 100% |  | 2013-12-09 | 2014-09-12 | 201d? |  | finish no earlier than 2014-09-12 | R4 | 1608h | 1608h | LTE_CA_B1_B3_B8-Perf | PCG-32 | KT | Ilwhan Kim (ilwhan.kim@kt.com) | Rel-12 | RP-62 | Issam | CA | LTE_CA_B1_B3_B8-Perf | RP-141084 |
| 946 | 204.60 | **LTE Advanced 3 Band Carrier Aggregation (3DL/1UL) for Band 1, Band 5 and Band 7** | 202d? | 2013-12-09 A | 2014-09-12 A | 100% |  | 2013-12-09 | 2014-09-12 | 201d? |  |  | R4 | 4832h | 4832h | LTE_CA_B1_B5_B7 | PCG-32 | LG Uplus | Yeonsang KOO (yskoo@lguplus.co.kr) | Rel-12 | RP-62 | Issam | CA | LTE_CA_B1_B5_B7 |  |
| 947 | 204.60.1 | Core part: LTE Advanced 3 Band Carrier Aggregation (3DL/1UL) for Band 1, Band 5 and Band 7 | 201d? | 2013-12-09 A | 2014-09-12 A | 100% |  | 2013-12-09 | 2014-09-12 | 201d? |  | finish no earlier than 2014-09-12 | R4 | 1608h | 1608h | LTE_CA_B1_B5_B7-Core | PCG-32 | LG Uplus | Yeonsang KOO (yskoo@lguplus.co.kr) | Rel-12 | RP-62 | Issam | CA | LTE_CA_B1_B5_B7-Core | RP-141084 |
| 948 | 204.60.2 | Perf. part: LTE Advanced 3 Band Carrier Aggregation (3DL/1UL) for Band 1, Band 5 and Band 7 | 201d? | 2013-12-09 A | 2014-09-12 A | 100% |  | 2013-12-09 | 2014-09-12 | 201d? |  | finish no earlier than 2014-09-12 | R4 | 1608h | 1608h | LTE_CA_B1_B5_B7-Perf | PCG-32 | LG Uplus | Yeonsang KOO (yskoo@lguplus.co.kr) | Rel-12 | RP-62 | Issam | CA | LTE_CA_B1_B5_B7-Perf | RP-141084 |
| 949 | 204.61 | **LTE Advanced 3 Band Carrier Aggregation (3DL/1UL) for Band 2, Band 4 and Band 5** | 202d? | 2013-12-09 A | 2014-09-12 A | 100% |  | 2013-12-09 | 2014-09-12 | 201d? |  |  | R4 | 4832h | 4832h | LTE_CA_B2_B4_B5 | PCG-32 | U.S. Cellular | sebastian.thalanany@uscellular.com | Rel-12 | RP-62 | Issam | CA | LTE_CA_B2_B4_B5 |  |
| 950 | 204.61.1 | Core part: LTE Advanced 3 Band Carrier Aggregation (3DL/1UL) for Band 2, Band 4 and Band 5 | 201d? | 2013-12-09 A | 2014-09-12 A | 100% |  | 2013-12-09 | 2014-09-12 | 201d? |  | finish no earlier than 2014-09-12 | R4 | 1608h | 1608h | LTE_CA_B2_B4_B5-Core | PCG-32 | U.S. Cellular | sebastian.thalanany@uscellular.com | Rel-12 | RP-62 | Issam | CA | LTE_CA_B2_B4_B5-Core | RP-141084 |
| 951 | 204.61.2 | Perf. part: LTE Advanced 3 Band Carrier Aggregation (3DL/1UL) for Band 2, Band 4 and Band 5 | 201d? | 2013-12-09 A | 2014-09-12 A | 100% |  | 2013-12-09 | 2014-09-12 | 201d? |  | finish no earlier than 2014-09-12 | R4 | 1608h | 1608h | LTE_CA_B2_B4_B5-Perf | PCG-32 | U.S. Cellular | sebastian.thalanany@uscellular.com | Rel-12 | RP-62 | Issam | CA | LTE_CA_B2_B4_B5-Perf | RP-141084 |
| 952 | 204.62 | **LTE Advanced 3 Band Carrier Aggregation (3DL/1UL) for Band 2, Band 4 and Band 12** | 268d? | 2013-12-09 A | 2014-12-11 | 99% | 3.04d? | 2013-12-09 | 2014-09-12 | 201d? | 655d |  | R4 | 5872h | 5204.78h | LTE_CA_B2_B4_B12 | PCG-32 | U.S. Cellular | sebastian.thalanany@uscellular.com | Rel-12 | RP-62 | Issam | CA | LTE_CA_B2_B4_B12 |  |
| 953 | 204.62.1 | Core part: LTE Advanced 3 Band Carrier Aggregation (3DL/1UL) for Band 2, Band 4 and Band 12 | 201d? | 2013-12-09 A | 2014-09-12 A | 100% |  | 2013-12-09 | 2014-09-12 | 201d? |  | finish no earlier than 2014-09-12 | R4 | 1608h | 1608h | LTE_CA_B2_B4_B12-Core | PCG-32 | U.S. Cellular | sebastian.thalanany@uscellular.com | Rel-12 | RP-62 | Issam | CA | LTE_CA_B2_B4_B12-Core | RP-141084 |
| 954 | 204.62.2 | Perf. part: LTE Advanced 3 Band Carrier Aggregation (3DL/1UL) for Band 2, Band 4 and Band 12 | 265d? | 2013-12-09 A | 2014-12-11 | 98% | 5.3d? | 2013-12-09 | 2014-09-12 | 201d? | 655d | finish no earlier than 2014-12-11 | R4 | 2120h | 2077.6h | LTE_CA_B2_B4_B12-Perf | PCG-32 | U.S. Cellular | sebastian.thalanany@uscellular.com | Rel-12 | RP-62 | Issam | CA | LTE_CA_B2_B4_B12-Perf | RP-141084 |

Notes:
- 931: Inter-band 2DL / Impacted TSs and TRs: LTE
- 932: RP#63 completed / Impacted TSs and TRs: 36.101, new generic TR 36.851
- 933: RP#63 completed / Impacted TSs and TRs: 36.307
- 934: Inter-band CA 2DL / Impacted TSs and TRs: LTE
- 935: RP#64 completed / Impacted TSs and TRs: 36.101, 36.104, 36.133, new generic TR 36.851
- 936: RP#64 completed / Impacted TSs and TRs: 36.141, 36.307
- 937: Inter-band CA 2DL/1UL / Impacted TSs and TRs: LTE
- 938: RP#63 completed. Updated WID RP-131752=>RP-140119 / Impacted TSs and TRs: 36.101, 36.104, 36.133, 36.307, New generic TR 36.851
- 939: RP#63 completed. Updated WID RP-131752=>RP-140119 / Impacted TSs and TRs: 36.101, 36.104, 36.133, 36.141
- 940: Inter-band 2DL / Impacted TSs and TRs: LTE
- 941: RP#63 completed / Impacted TSs and TRs: 36.101, 36.104, 36.307
- 942: RP#63 completed / Impacted TSs and TRs: 36.141
- 943: Inter-band CA 3DL / Impacted TSs and TRs: LTE
- 944: RP#65 completed. Updated WID RP-131753=>RP-141654 / Impacted TSs and TRs: 36.101, 36.104, 36.133, 36.141, 36.307, new generic TR 36.853 (3 Band CA with 1UL)
- 945: RP#65 completed / Impacted TSs and TRs: 36.101, 36.104, 36.133, 36.141, 36.307
- 946: Inter-band CA 3DL / Impacted TSs and TRs: LTE
- 947: RP#65 completed. Updated WID RP-140209=>RP-141462 / Impacted TSs and TRs: 36.101, 36.104, 36.133, new generic TR 36.853 (3 Band CA with 1UL)
- 948: RP#65 completed / Impacted TSs and TRs: 36.141, 36.307
- 949: Inter-band CA 3DL / Impacted TSs and TRs: LTE
- 950: RP#65 completed / Impacted TSs and TRs: 36.101, 36.104, 36.133, new generic TR 36.853 (3 Band CA with 1UL)
- 951: RP#65 completed / Impacted TSs and TRs: 36.141, 36.307
- 952: Inter-band CA 3DL / Impacted TSs and TRs: LTE
- 953: RP#65 completed / Impacted TSs and TRs: 36.101, 36.104, 36.133, new generic TR 36.853 (3 Band CA with 1UL)
- 954: RP#65 completion 09/14=>12/14 / Impacted TSs and TRs: 36.141, 36.307

| ID | WBS | Task | Duration | Start | Finish | Complete | Baseline start | Baseline finish | Baseline duration | Constraint | Resources | Work | Actual work | Acronym | PCG approved | WI rapporteur name | WI rapporteur e-mail | Release | TSG approved | MCC resp | Special Focus Doc | Acronym_3GU_Export | Status Report |
| --- | --- | --- | --- | --- | --- | --- | --- | --- | --- | --- | --- | --- | --- | --- | --- | --- | --- | --- | --- | --- | --- | --- | --- |
| 955 | 204.63 | **LTE Advanced 3 Band Carrier Aggregation (3DL/1UL) for Band 2, Band 5 and Band 12** | 202d? | 2013-12-09 A | 2014-09-12 A | 100% | 2013-12-09 | 2014-09-12 | 201d? |  | R4 | 4832h | 4832h | LTE_CA_B2_B5_B12 | PCG-32 | U.S. Cellular | sebastian.thalanany@uscellular.com | Rel-12 | RP-62 | Issam | CA | LTE_CA_B2_B5_B12 |  |
| 956 | 204.63.1 | Core part: LTE Advanced 3 Band Carrier Aggregation (3DL/1UL) for Band 2, Band 5 and Band 12 | 201d? | 2013-12-09 A | 2014-09-12 A | 100% | 2013-12-09 | 2014-09-12 | 201d? | finish no earlier than 2014-09-12 | R4 | 1608h | 1608h | LTE_CA_B2_B5_B12-Core | PCG-32 | U.S. Cellular | sebastian.thalanany@uscellular.com | Rel-12 | RP-62 | Issam | CA | LTE_CA_B2_B5_B12-Core | RP-141084 |
| 957 | 204.63.2 | Perf. part: LTE Advanced 3 Band Carrier Aggregation (3DL/1UL) for Band 2, Band 5 and Band 12 | 201d? | 2013-12-10 A | 2014-09-12 A | 100% | 2013-12-09 | 2014-09-12 | 201d? | finish no earlier than 2014-09-12 | R4 | 1608h | 1608h | LTE_CA_B2_B5_B12-Perf | PCG-32 | U.S. Cellular | sebastian.thalanany@uscellular.com | Rel-12 | RP-62 | Issam | CA | LTE_CA_B2_B5_B12-Perf | RP-141084 |
| 958 | 204.64 | **LTE Advanced 3 Band Carrier Aggregation (3DL/1UL) for Band 2, Band 12 and Band 12** | 202d? | 2013-12-09 A | 2014-09-12 A | 100% | 2013-12-09 | 2014-09-12 | 201d? |  | R4 | 4832h | 4832h | LTE_CA_B2_B12_B12 | PCG-32 | AT&T | marc.grant@att.com | Rel-12 | RP-62 | Issam | CA | LTE_CA_B2_B12_B12 |  |
| 959 | 204.64.1 | Core part: LTE Advanced 3 Band Carrier Aggregation (3DL/1UL) for Band 2, Band 12 and Band 12 | 201d? | 2013-12-09 A | 2014-09-12 A | 100% | 2013-12-09 | 2014-09-12 | 201d? | finish no earlier than 2014-09-12 | R4 | 1608h | 1608h | LTE_CA_B2_B12_B12-Core | PCG-32 | AT&T | marc.grant@att.com | Rel-12 | RP-62 | Issam | CA | LTE_CA_B2_B12_B12-Core | RP-141084 |
| 960 | 204.64.2 | Perf. part: LTE Advanced 3 Band Carrier Aggregation (3DL/1UL) for Band 2, Band 12 and Band 12 | 201d? | 2013-12-09 A | 2014-09-12 A | 100% | 2013-12-09 | 2014-09-12 | 201d? | finish no earlier than 2014-09-12 | R4 | 1608h | 1608h | LTE_CA_B2_B12_B12-Perf | PCG-32 | AT&T | marc.grant@att.com | Rel-12 | RP-62 | Issam | CA | LTE_CA_B2_B12_B12-Perf | RP-141084 |
| 961 | 204.65 | **LTE Advanced 3 Band Carrier Aggregation (3DL/1UL) for Band 2, Band 12 and Band 30** | 202d? | 2013-12-09 A | 2014-09-12 A | 100% | 2013-12-09 | 2014-09-12 | 201d? |  | R4 | 4832h | 4832h | LTE_CA_B2_B12_B30 | PCG-32 | AT&T | marc.grant@att.com | Rel-12 | RP-62 | Issam | CA | LTE_CA_B2_B12_B30 |  |
| 962 | 204.65.1 | Core part: LTE Advanced 3 Band Carrier Aggregation (3DL/1UL) for Band 2, Band 12 and Band 30 | 201d? | 2013-12-09 A | 2014-09-12 A | 100% | 2013-12-09 | 2014-09-12 | 201d? | finish no earlier than 2014-09-12 | R4 | 1608h | 1608h | LTE_CA_B2_B12_B30-Core | PCG-32 | AT&T | marc.grant@att.com | Rel-12 | RP-62 | Issam | CA | LTE_CA_B2_B12_B30-Core | RP-141084 |
| 963 | 204.65.2 | Perf. part: LTE Advanced 3 Band Carrier Aggregation (3DL/1UL) for Band 2, Band 12 and Band 30 | 201d? | 2013-12-09 A | 2014-09-12 A | 100% | 2013-12-09 | 2014-09-12 | 201d? | finish no earlier than 2014-09-12 | R4 | 1608h | 1608h | LTE_CA_B2_B12_B30-Perf | PCG-32 | AT&T | marc.grant@att.com | Rel-12 | RP-62 | Issam | CA | LTE_CA_B2_B12_B30-Perf | RP-141084 |
| 964 | 204.66 | **LTE Advanced 3 Band Carrier Aggregation (3DL/1UL) for Band 3, Band 7 and Band 20** | 202d? | 2013-12-09 A | 2014-09-12 A | 100% | 2013-12-09 | 2014-09-12 | 201d? |  | R4 | 4832h | 4832h | LTE_CA_B3_B7_B20 | PCG-32 | Vodafone | luis.anaya@vodafone.com | Rel-12 | RP-62 | Issam | CA | LTE_CA_B3_B7_B20 |  |
| 965 | 204.66.1 | Core part: LTE Advanced 3 Band Carrier Aggregation (3DL/1UL) for Band 3, Band 7 and Band 20 | 201d? | 2013-12-09 A | 2014-09-12 A | 100% | 2013-12-09 | 2014-09-12 | 201d? | finish no earlier than 2014-09-12 | R4 | 1608h | 1608h | LTE_CA_B3_B7_B20-Core | PCG-32 | Vodafone | luis.anaya@vodafone.com | Rel-12 | RP-62 | Issam | CA | LTE_CA_B3_B7_B20-Core | RP-141084 |
| 966 | 204.66.2 | Perf. part: LTE Advanced 3 Band Carrier Aggregation (3DL/1UL) for Band 3, Band 7 and Band 20 | 201d? | 2013-12-10 A | 2014-09-12 A | 100% | 2013-12-09 | 2014-09-12 | 201d? | finish no earlier than 2014-09-12 | R4 | 1608h | 1608h | LTE_CA_B3_B7_B20-Perf | PCG-32 | Vodafone | luis.anaya@vodafone.com | Rel-12 | RP-62 | Issam | CA | LTE_CA_B3_B7_B20-Perf | RP-141084 |
| 967 | 204.67 | **LTE Advanced 3 Band Carrier Aggregation (3DL/1UL) for Band 4, Band 5 and Band 12** | 202d? | 2013-12-09 A | 2014-09-12 A | 100% | 2013-12-09 | 2014-09-12 | 201d? |  | R4 | 4832h | 4832h | LTE_CA_B4_B5_B12 | PCG-32 | U.S. Cellular | sebastian.thalanany@uscellular.com | Rel-12 | RP-62 | Issam | CA | LTE_CA_B4_B5_B12 |  |
| 968 | 204.67.1 | Core part: LTE Advanced 3 Band Carrier Aggregation (3DL/1UL) for Band 4, Band 5 and Band 12 | 201d? | 2013-12-09 A | 2014-09-12 A | 100% | 2013-12-09 | 2014-09-12 | 201d? | finish no earlier than 2014-09-12 | R4 | 1608h | 1608h | LTE_CA_B4_B5_B12-Core | PCG-32 | U.S. Cellular | sebastian.thalanany@uscellular.com | Rel-12 | RP-62 | Issam | CA | LTE_CA_B4_B5_B12-Core | RP-141084 |
| 969 | 204.67.2 | Perf. part: LTE Advanced 3 Band Carrier Aggregation (3DL/1UL) for Band 4, Band 5 and Band 12 | 201d? | 2013-12-09 A | 2014-09-12 A | 100% | 2013-12-09 | 2014-09-12 | 201d? | finish no earlier than 2014-09-12 | R4 | 1608h | 1608h | LTE_CA_B4_B5_B12-Perf | PCG-32 | U.S. Cellular | sebastian.thalanany@uscellular.com | Rel-12 | RP-62 | Issam | CA | LTE_CA_B4_B5_B12-Perf | RP-141084 |
| 970 | 204.68 | **LTE Advanced 3 Band Carrier Aggregation (3DL/1UL) for Band 4, Band 12 and Band 12** | 202d? | 2013-12-09 A | 2014-09-12 A | 100% | 2013-12-09 | 2014-09-12 | 201d? |  | R4 | 4832h | 4832h | LTE_CA_B4_B12_B12 | PCG-32 | AT&T | marc.grant@att.com | Rel-12 | RP-62 | Issam | CA | LTE_CA_B4_B12_B12 |  |
| 971 | 204.68.1 | Core part: LTE Advanced 3 Band Carrier Aggregation (3DL/1UL) for Band 4, Band 12 and Band 12 | 201d? | 2013-12-09 A | 2014-09-12 A | 100% | 2013-12-09 | 2014-09-12 | 201d? | finish no earlier than 2014-09-12 | R4 | 1608h | 1608h | LTE_CA_B4_B12_B12-Core | PCG-32 | AT&T | marc.grant@att.com | Rel-12 | RP-62 | Issam | CA | LTE_CA_B4_B12_B12-Core | RP-141084 |
| 972 | 204.68.2 | Perf. part: LTE Advanced 3 Band Carrier Aggregation (3DL/1UL) for Band 4, Band 12 and Band 12 | 201d? | 2013-12-09 A | 2014-09-12 A | 100% | 2013-12-09 | 2014-09-12 | 201d? | finish no earlier than 2014-09-12 | R4 | 1608h | 1608h | LTE_CA_B4_B12_B12-Perf | PCG-32 | AT&T | marc.grant@att.com | Rel-12 | RP-62 | Issam | CA | LTE_CA_B4_B12_B12-Perf | RP-141084 |
| 973 | 204.69 | **LTE Advanced 3 Band Carrier Aggregation (3DL/1UL) for Band 4, Band 12 and Band 30** | 202d? | 2013-12-09 A | 2014-09-12 A | 100% | 2013-12-09 | 2014-09-12 | 201d? |  | R4 | 4832h | 4832h | LTE_CA_B4_B12_B30 | PCG-32 | AT&T | marc.grant@att.com | Rel-12 | RP-62 | Issam | CA | LTE_CA_B4_B12_B30 |  |
| 974 | 204.69.1 | Core part: LTE Advanced 3 Band Carrier Aggregation (3DL/1UL) for Band 4, Band 12 and Band 30 | 201d? | 2013-12-09 A | 2014-09-12 A | 100% | 2013-12-09 | 2014-09-12 | 201d? | finish no earlier than 2014-09-12 | R4 | 1608h | 1608h | LTE_CA_B4_B12_B30-Core | PCG-32 | AT&T | marc.grant@att.com | Rel-12 | RP-62 | Issam | CA | LTE_CA_B4_B12_B30-Core | RP-141084 |
| 975 | 204.69.2 | Perf. part: LTE Advanced 3 Band Carrier Aggregation (3DL/1UL) for Band 4, Band 12 and Band 30 | 201d? | 2013-12-09 A | 2014-09-12 A | 100% | 2013-12-09 | 2014-09-12 | 201d? | finish no earlier than 2014-09-12 | R4 | 1608h | 1608h | LTE_CA_B4_B12_B30-Perf | PCG-32 | AT&T | marc.grant@att.com | Rel-12 | RP-62 | Issam | CA | LTE_CA_B4_B12_B30-Perf | RP-141084 |
| 976 | 204.70 | **LTE Advanced intra-band contiguous Carrier Aggregation in Band 42** | 136d? | 2013-12-09 A | 2014-06-13 A | 100% | 2013-12-09 | 2014-06-13 | 136d? |  | R4 | 3264h | 3264h | LTE_CA_C_B42 | PCG-32 | CATT | Yuexia Song (songyuexia@catt.cn) | Rel-12 | RP-62 | Issam | CA | LTE_CA_C_B42 |  |
| 977 | 204.70.1 | Core part: LTE Advanced intra-band contiguous Carrier Aggregation in Band 42 | 136d? | 2013-12-09 A | 2014-06-13 A | 100% | 2013-12-09 | 2014-06-13 | 136d? | finish no earlier than 2014-06-13 | R4 | 1088h | 1088h | LTE_CA_C_B42-Core | PCG-32 | CATT | Yuexia Song (songyuexia@catt.cn) | Rel-12 | RP-62 | Issam | CA | LTE_CA_C_B42-Core | RP-140569 |
| 978 | 204.70.2 | Perf. part: LTE Advanced intra-band contiguous Carrier Aggregation in Band 42 | 136d? | 2013-12-09 A | 2014-06-13 A | 100% | 2013-12-09 | 2014-06-13 | 136d? | finish no earlier than 2014-06-13 | R4 | 1088h | 1088h | LTE_CA_C_B42-Perf | PCG-32 | CATT | Yuexia Song (songyuexia@catt.cn) | Rel-12 | RP-62 | Issam | CA | LTE_CA_C_B42-Perf | RP-140569 |

Notes:
- 955: Inter-band CA 3DL / Impacted TSs and TRs: LTE
- 956: RP#65 completed / Impacted TSs and TRs: 36.101, 36.104, 36.133, new generic TR 36.853 (3 Band CA with 1UL)
- 957: RP#65 completed / Impacted TSs and TRs: 36.141, 36.307
- 958: Inter-band CA 3DL / Impacted TSs and TRs: LTE
- 959: RP#65 completed / Impacted TSs and TRs: 36.101, 36.104, 36.133, 36.141, 36.307, new generic TR 36.853
- 960: RP#65 completed / Impacted TSs and TRs: 36.101, 36.104, 36.133, 36.141, 36.307
- 961: Inter-band CA 3DL / Impacted TSs and TRs: LTE
- 962: RP#65 completed. Updated WID RP-131652=>RP-141211. / Impacted TSs and TRs: 36.101, 36.104, 36.133, 36.141, 36.307, new generic TR 36.853 (3 Band CA with 1UL)
- 963: RP#65 completed / Impacted TSs and TRs: 36.101, 36.104, 36.133, 36.141, 36.307
- 964: Inter-band CA 3DL / Impacted TSs and TRs: LTE
- 965: RP#65 completed. Updated WID RP-140244=>RP-141224 / Impacted TSs and TRs: 36.101, 36.104, 36.133, new generic TR 36.853 (3 Band CA with 1UL)
- 966: RP#65 completed / Impacted TSs and TRs: 36.101, 36.133, 36.141, 36.307
- 967: Inter-band CA 3DL / Impacted TSs and TRs: LTE
- 968: RP#65 completed / Impacted TSs and TRs: 36.101, 36.104, 36.133, new generic TR 36.853 (3 Band CA with 1UL)
- 969: RP#65 completed / Impacted TSs and TRs: 36.141, 36.307
- 970: Inter-band CA 3DL / Impacted TSs and TRs: LTE
- 971: RP#65 completed / Impacted TSs and TRs: 36.101, 36.104, 36.133, 36.141, 36.307, new generic TR 36.853 (3 Band CA with 1UL)
- 972: RP#65 completed / Impacted TSs and TRs: 36.101, 36.104, 36.133, 36.141, 36.307
- 973: Inter-band CA 3DL / Impacted TSs and TRs: LTE
- 974: RP#65 completed. Updated WID RP-131653=>RP-141214 / Impacted TSs and TRs: 36.101, 36.104, 36.133, 36.141, 36.307, new generic TR 36.853 (3 Band CA with 1UL)
- 975: RP#65 completed / Impacted TSs and TRs: 36.101, 36.104, 36.133, 36.141, 36.307
- 976: Intra-band contig. CA 2DL/2UL / Impacted TSs and TRs: LTE
- 977: RP#64 completed. TR 36.833-1-42v100 for 1-step Approval. Updated WID RP-132029=>RP-140728 / Impacted TSs and TRs: 36.101, 36.104, 36.133, new TR 36.833-1-42
- 978: RP#64 completed. TR 36.833-1-42v100 for 1-step Approval. Updated WID RP-132029=>RP-140728 / Impacted TSs and TRs: 36.141, 36.307

| ID | WBS | Task | Duration | Start | Finish | Complete | Remaining | Baseline start | Baseline finish | Baseline duration | Total slack | Constraint | Resources | Work | Actual work | Acronym | PCG approved | WI rapporteur name | WI rapporteur e-mail | Release | TSG approved | MCC resp | Special Focus Doc | Acronym_3GU_Export | Status Report |
| --- | --- | --- | --- | --- | --- | --- | --- | --- | --- | --- | --- | --- | --- | --- | --- | --- | --- | --- | --- | --- | --- | --- | --- | --- | --- |
| 979 | 204.71 | **LTE Advanced intra-band contiguous Carrier Aggregation in Band 7 - Additional bandwidth combinations** | 136d? | 2013-12-09 A | 2014-06-13 A | 100% |  | 2013-12-09 | 2014-06-13 | 136d? |  |  | R4 | 3264h | 3264h | LTE_CA_C_B7_BW | PCG-32 | Orange | Olfa BEN HADDADA | Rel-12 | RP-62 | Issam | CA | LTE_CA_C_B7_BW |  |
| 980 | 204.71.1 | Core part: LTE Advanced intra-band contiguous Carrier Aggregation in Band 7 - Additional bandwidth combinations | 136d? | 2013-12-09 A | 2014-06-13 A | 100% |  | 2013-12-09 | 2014-06-13 | 136d? |  | finish no earlier than 2014-06-13 | R4 | 1088h | 1088h | LTE_CA_C_B7_BW-Core | PCG-32 | Orange | Olfa BEN HADDADA | Rel-12 | RP-62 | Issam | CA | LTE_CA_C_B7_BW-Core | RP-140569 |
| 981 | 204.71.2 | Perf. part: LTE Advanced intra-band contiguous Carrier Aggregation in Band 7 - Additional bandwidth combinations | 136d? | 2013-12-09 A | 2014-06-13 A | 100% |  | 2013-12-09 | 2014-06-13 | 136d? |  | finish no earlier than 2014-06-13 | R4 | 1088h | 1088h | LTE_CA_C_B7_BW-Perf | PCG-32 | Orange | Olfa BEN HADDADA | Rel-12 | RP-62 | Issam | CA | LTE_CA_C_B7_BW-Perf | RP-140569 |
| 982 | 204.72 | **LTE Advanced intra-band non-contiguous Carrier Aggregation in Band 41 for 3 DL** | 334d? | 2013-12-09 A | 2015-03-15 | 81% | 62.46d? | 2013-12-09 | 2014-09-12 | 200d? | 589d |  | R4 | 6920h | 4338h | LTE_CA_NC_B41_3DL | PCG-32 | Sprint, Alcatel-Lucent | man-hung.ng@alcatel-lucent.com | Rel-12 | RP-62 | Issam | CA | LTE_CA_NC_B41_3DL |  |
| 983 | 204.72.1 | Core part: LTE Advanced intra-band non-contiguous Carrier Aggregation in Band 41 for 3 DL | 200d? | 2013-12-09 A | 2014-09-11 A | 100% |  | 2013-12-09 | 2014-09-12 | 200d? |  | finish no earlier than 2014-09-12 | R4 | 1600h | 1600h | LTE_CA_NC_B41_3DL-Core | PCG-32 | Sprint, Alcatel-Lucent | man-hung.ng@alcatel-lucent.com | Rel-12 | RP-62 | Issam | CA | LTE_CA_NC_B41_3DL-Core | RP-141084 |
| 984 | 204.72.2 | Perf. part: LTE Advanced intra-band non-contiguous Carrier Aggregation in Band 41 for 3 DL | 331d? | 2013-12-09 A | 2015-03-15 | 70% | 99.3d? | 2013-12-09 | 2014-09-12 | 200d? | 589d | finish no earlier than 2015-03-15 | R4 | 2648h | 1853.6h | LTE_CA_NC_B41_3DL-Perf | PCG-32 | Sprint, Alcatel-Lucent | man-hung.ng@alcatel-lucent.com | Rel-12 | RP-62 | Issam | CA | LTE_CA_NC_B41_3DL-Perf | RP-141084 |
| 985 | 204.73 | **LTE Advanced intra-band non-contiguous Carrier Aggregation in Band 42** | 136d? | 2013-12-09 A | 2014-06-13 A | 100% |  | 2013-12-09 | 2014-06-13 | 136d? |  |  | R4 | 3264h | 3264h | LTE_CA_NC_B42 | PCG-32 | Huawei | Liu Liehai (liuliehai@huawei.com) | Rel-12 | RP-62 | Issam | CA | LTE_CA_NC_B42 |  |
| 986 | 204.73.1 | Core part: LTE Advanced intra-band non-contiguous Carrier Aggregation in Band 42 | 136d? | 2013-12-09 A | 2014-06-13 A | 100% |  | 2013-12-09 | 2014-06-13 | 136d? |  | finish no earlier than 2014-06-13 | R4 | 1088h | 1088h | LTE_CA_NC_B42-Core | PCG-32 | Huawei | Liu Liehai (liuliehai@huawei.com) | Rel-12 | RP-62 | Issam | CA | LTE_CA_NC_B42-Core | RP-140569 |
| 987 | 204.73.2 | Perf. part: LTE Advanced intra-band non-contiguous Carrier Aggregation in Band 42 | 136d? | 2013-12-09 A | 2014-06-13 A | 100% |  | 2013-12-09 | 2014-06-13 | 136d? |  | finish no earlier than 2014-06-13 | R4 | 1088h | 1088h | LTE_CA_NC_B42-Perf | PCG-32 | Huawei | Liu Liehai (liuliehai@huawei.com) | Rel-12 | RP-62 | Issam | CA | LTE_CA_NC_B42-Perf | RP-140569 |
| 988 | 204.74 | **LTE Advanced 3 Band Carrier Aggregation (3DL/1UL) for Band 1, Band 3 and Band 5** | 203d? | 2013-12-06 A | 2014-09-12 A | 100% |  | 2013-12-06 | 2014-09-12 | 202d? |  |  | R4 | 4856h | 4856h | LTE_CA_B1_B3_B5 | PCG-32 | SK Telecom | haesung.park@sk.com | Rel-12 | RP-62 | Issam | CA | LTE_CA_B1_B3_B5 |  |
| 989 | 204.74.1 | Core part: LTE Advanced 3 Band Carrier Aggregation(3DL/1UL) for Band 1, Band 3 and Band 5 | 202d? | 2013-12-06 A | 2014-09-12 A | 100% |  | 2013-12-06 | 2014-09-12 | 202d? |  | finish no earlier than 2014-09-12 | R4 | 1616h | 1616h | LTE_CA_B1_B3_B5-Core | PCG-32 | SK Telecom | haesung.park@sk.com | Rel-12 | RP-62 | Issam | CA | LTE_CA_B1_B3_B5-Core | RP-141084 |
| 990 | 204.74.2 | Perf. part: LTE Advanced 3 Band Carrier Aggregation(3DL/1UL) for Band 1, Band 3 and Band 5 | 202d? | 2013-12-06 A | 2014-09-12 A | 100% |  | 2013-12-06 | 2014-09-12 | 202d? |  | finish no earlier than 2014-09-12 | R4 | 1616h | 1616h | LTE_CA_B1_B3_B5-Perf | PCG-32 | SK Telecom | haesung.park@sk.com | Rel-12 | RP-62 | Issam | CA | LTE_CA_B1_B3_B5-Perf | RP-141084 |
| 991 | 204.75 | **LTE Advanced 3 Band Carrier Aggregation (3DL/1UL) for Band 1, Band 3 and Band 20** | 202d? | 2013-12-09 A | 2014-09-12 A | 100% |  | 2013-12-09 | 2014-09-12 | 201d? |  |  | R4 | 4832h | 4832h | LTE_CA_B1_B3_B20 | PCG-32 | Vodafone | luis.anaya@vodafone.com | Rel-12 | RP-62 | Issam | CA | LTE_CA_B1_B3_B20 |  |
| 992 | 204.75.1 | Core part: LTE Advanced 3 Band Carrier Aggregation (3DL/1UL) for Band 1, Band 3 and Band 20 | 201d? | 2013-12-09 A | 2014-09-12 A | 100% |  | 2013-12-09 | 2014-09-12 | 201d? |  | finish no earlier than 2014-09-12 | R4 | 1608h | 1608h | LTE_CA_B1_B3_B20-Core | PCG-32 | Vodafone | luis.anaya@vodafone.com | Rel-12 | RP-62 | Issam | CA | LTE_CA_B1_B3_B20-Core | RP-141084 |
| 993 | 204.75.2 | Perf. part: LTE Advanced 3 Band Carrier Aggregation (3DL/1UL) for Band 1, Band 3 and Band 20 | 201d? | 2013-12-10 A | 2014-09-12 A | 100% |  | 2013-12-09 | 2014-09-12 | 201d? |  | finish no earlier than 2014-09-12 | R4 | 1608h | 1608h | LTE_CA_B1_B3_B20-Perf | PCG-32 | Vodafone | luis.anaya@vodafone.com | Rel-12 | RP-62 | Issam | CA | LTE_CA_B1_B3_B20-Perf | RP-141084 |
| 994 | 204.76 | **LTE Advanced 3 Band Carrier Aggregation (3DL/1UL) for Band 1, Band 7 and Band 20** | 202d? | 2013-12-09 A | 2014-09-12 A | 100% |  | 2013-12-09 | 2014-09-12 | 201d? |  |  | R4 | 4832h | 4832h | LTE_CA_B1_B7_B20 | PCG-32 | Vodafone | luis.anaya@vodafone.com | Rel-12 | RP-62 | Issam | CA | LTE_CA_B1_B7_B20 |  |
| 995 | 204.76.1 | Core part: LTE Advanced 3 Band Carrier Aggregation (3DL/1UL) for Band 1, Band 7 and Band 20 | 201d? | 2013-12-09 A | 2014-09-12 A | 100% |  | 2013-12-09 | 2014-09-12 | 201d? |  | finish no earlier than 2014-09-12 | R4 | 1608h | 1608h | LTE_CA_B1_B7_B20-Core | PCG-32 | Vodafone | luis.anaya@vodafone.com | Rel-12 | RP-62 | Issam | CA | LTE_CA_B1_B7_B20-Core | RP-141084 |
| 996 | 204.76.2 | Perf. part: LTE Advanced 3 Band Carrier Aggregation (3DL/1UL) for Band 1, Band 7 and Band 20 | 201d? | 2013-12-10 A | 2014-09-12 A | 100% |  | 2013-12-09 | 2014-09-12 | 201d? |  | finish no earlier than 2014-09-12 | R4 | 1608h | 1608h | LTE_CA_B1_B7_B20-Perf | PCG-32 | Vodafone | luis.anaya@vodafone.com | Rel-12 | RP-62 | Issam | CA | LTE_CA_B1_B7_B20-Perf | RP-141084 |
| 997 | 204.77 | **LTE Advanced 3 Band Carrier Aggregation (3DL/1UL) for Band 7, Band 8 and Band 20** | 270d? | 2013-12-09 A | 2014-12-15 A | 100% |  | 2013-12-09 | 2014-09-12 | 201d? |  |  | R4 | 6432h | 6432h | LTE_CA_B7_B8_B20 | PCG-32 | Vodafone | luis.anaya@vodafone.com | Rel-12 | RP-62 | Issam | CA | LTE_CA_B7_B8_B20 |  |
| 998 | 204.77.1 | Core part: LTE Advanced 3 Band Carrier Aggregation (3DL/1UL) for Band 7, Band 8 and Band 20 | 267d? | 2013-12-09 A | 2014-12-15 A | 100% |  | 2013-12-09 | 2014-09-12 | 201d? |  | finish no earlier than 2014-12-15 | R4 | 2136h | 2136h | LTE_CA_B7_B8_B20-Core | PCG-32 | Vodafone | luis.anaya@vodafone.com | Rel-12 | RP-62 | Issam | CA | LTE_CA_B7_B8_B20-Core | RP-141084 |
| 999 | 204.77.2 | Perf. part: LTE Advanced 3 Band Carrier Aggregation (3DL/1UL) for Band 7, Band 8 and Band 20 | 267d? | 2013-12-12 A | 2014-12-15 A | 100% |  | 2013-12-09 | 2014-09-12 | 201d? |  | finish no earlier than 2014-12-15 | R4 | 2136h | 2136h | LTE_CA_B7_B8_B20-Perf | PCG-32 | Vodafone | luis.anaya@vodafone.com | Rel-12 | RP-62 | Issam | CA | LTE_CA_B7_B8_B20-Perf | RP-141084 |
| 1000 | 204.78 | **Additional bandwidth combinations for LTE Advanced inter-band Carrier Aggregation of Band 2 and Band 29 and of Band 4 and Band 29** | 4d? | 2014-03-03 A | 2014-03-06 A | 100% |  | 2014-03-03 | 2014-03-06 | 4d? |  |  | R4 | 64h | 64h | LTE_DL_FDD700_B29_Bwset | PCG-32 | AT&T | marc.grant@att.com | Rel-12 | RP-63 | Issam | CA | LTE_DL_FDD700_B29_Bwset |  |
| 1001 | 204.78.1 | Core part: Additional bandwidth combinations for LTE Advanced inter-band Carrier Aggregation of Band 2 and Band 29 and of Band 4 and Band 29 | 4d? | 2014-03-03 A | 2014-03-06 A | 100% |  | 2014-03-03 | 2014-03-06 | 4d? |  | finish no earlier than 2014-03-06 | R4 | 32h | 32h | LTE_DL_FDD700_B29_BWset-Core | PCG-32 | AT&T | marc.grant@att.com | Rel-12 | RP-63 | Issam | CA | LTE_DL_FDD700_B29_BWset-Core | RP-140428 |
| 1002 | 204.79 | **Additional bandwidth combination set for LTE Advanced inter-band Carrier Aggregation of Band 3 and Band 20** | 72d? | 2014-03-06 A | 2014-06-13 A | 100% |  | 2014-03-06 | 2014-06-13 | 72d? |  |  | R4 | 1152h | 1152h | LTE_CA_B3_B20_BWset | PCG-32 | NSN | iwajlo.angelow@nsn.com | Rel-12 | RP-63 | Issam | CA | LTE_CA_B3_B20_BWset |  |
| 1003 | 204.79.1 | Core part: Additional bandwidth combination set for LTE Advanced inter-band Carrier Aggregation of Band 3 and Band 20 | 72d? | 2014-03-06 A | 2014-06-13 A | 100% |  | 2014-03-06 | 2014-06-13 | 72d? |  | finish no earlier than 2014-06-13 | R4 | 576h | 576h | LTE_CA_B3_B20_BWset-Core | PCG-32 | NSN | iwajlo.angelow@nsn.com | Rel-12 | RP-63 | Issam | CA | LTE_CA_B3_B20_BWset-Core | RP-140569 |

Notes:
- 979: Intra-band contig. CA 2DL/2UL / Impacted TSs and TRs: LTE
- 980: RP#64 completed / Impacted TSs and TRs: 36.101, 36.307
- 981: RP#64 completed / Impacted TSs and TRs: 36.307
- 982: Intra-band non-contig. CA 3DL / Impacted TSs and TRs: LTE
- 983: RP#65 completed / Impacted TSs and TRs: 36.101, 36.104, 36.133, 36.307, new TR 36.833-6-xy
- 984: CD:Thu 12/03/15->Sun 15/03/15; Compl:60%->70% / Impacted TSs and TRs: 36.141
- 985: Intra-band non-contig. CA 2DL / Impacted TSs and TRs: LTE
- 986: RP#64 completed. Updated WID RP-140404=>RP-140671. TR 36.833-2-42v100 for 1-step Approval / Impacted TSs and TRs: 36.101, 36.104, 36.133, new TR 36.833-2-42
- 987: RP#64 completed / Impacted TSs and TRs: 36.141, 36.307
- 988: Inter-band CA 3DL / Impacted TSs and TRs: LTE
- 989: RP#65 completed. Updated WID RP-132121=>RP-141454 / Impacted TSs and TRs: 36.101, 36.104, 36.133, new generic TR 36.853 (3 Band CA with 1UL)
- 990: RP#65 completed. Updated WID RP-132121=>RP-141454 / Impacted TSs and TRs: 36.141, 36.307
- 991: Inter-band CA 3DL / Impacted TSs and TRs: LTE
- 992: RP#65 completed. Updated WID RP-141017=>RP-141222 / Impacted TSs and TRs: 36.101, 36.104, 36.133, new generic TR 36.851 (2 Band CA with 1UL), TR 36.853 (3 Band CA with 1UL)
- 993: RP#65 completed / Impacted TSs and TRs: 36.101, 36.133, 36.141, 36.307
- 994: Inter-band CA 3DL / Impacted TSs and TRs: LTE
- 995: RP#65 completed. Updated WID RP-140243=>RP-141223 / Impacted TSs and TRs: 36.101, 36.104, 36.133, new generic TR 36.853 (3 Band CA with 1UL), TR 36.851 (2 Band CA with 1UL)
- 996: RP#65 completed / Impacted TSs and TRs: 36.101, 36.133, 36.141, 36.307
- 997: Inter-band CA 3DL / Impacted TSs and TRs: LTE
- 998: CD:Thu 11/12/14->Mon 15/12/14; Compl:85%->100% / Impacted TSs and TRs: 36.101, 36.104, 36.133, new generic TR 36.853 (3 Band CA with 1UL), TR 36.851 (2 Band CA with 1UL)
- 999: CD:Thu 11/12/14->Mon 15/12/14; Compl:0%->100% / Impacted TSs and TRs: 36.101, 36.133, 36.141, 36.307
- 1000: Inter-band 2DL/1UL / Impacted TSs and TRs: LTE
- 1001: RP#63 approved WI (no Perf. Part) & completed. Rel-10 and Rel-11 versions of 36.307 affected / Impacted TSs and TRs: 36.101, 36.307
- 1002: Inter-band CA 2DL / Impacted TSs and TRs: LTE
- 1003: RP#64 completed / Impacted TSs and TRs: 36.101, TR 36.851

| ID | WBS | Task | Duration | Start | Finish | Complete | Baseline start | Baseline finish | Baseline duration | Constraint | Resources | Work | Actual work | Acronym | PCG approved | WI rapporteur name | WI rapporteur e-mail | Release | TSG approved | MCC resp | Special Focus Doc | Acronym_3GU_Export | Status Report | PCG stopped | TSG stopped |
| --- | --- | --- | --- | --- | --- | --- | --- | --- | --- | --- | --- | --- | --- | --- | --- | --- | --- | --- | --- | --- | --- | --- | --- | --- | --- |
| 1004 | 204.80 | **Additional bandwidth combination set for LTE Advanced inter-band Carrier Aggregation of Band 7 and Band 20** | 72d? | 2014-03-06 A | 2014-06-13 A | 100% | 2014-03-06 | 2014-06-13 | 72d? |  | R4 | 1152h | 1152h | LTE_CA_B7_B20_BWset | PCG-32 | NSN | iwajlo.angelow@nsn.com | Rel-12 | RP-63 | Issam | CA | LTE_CA_B7_B20_BWset |  |  |  |
| 1005 | 204.80.1 | Core part: Additional bandwidth combination set for LTE Advanced inter-band Carrier Aggregation of Band 7 and Band 20 | 72d? | 2014-03-06 A | 2014-06-13 A | 100% | 2014-03-06 | 2014-06-13 | 72d? | finish no earlier than 2014-06-13 | R4 | 576h | 576h | LTE_CA_B7_B20_BWset-Core | PCG-32 | NSN | iwajlo.angelow@nsn.com | Rel-12 | RP-63 | Issam | CA | LTE_CA_B7_B20_BWset-Core | RP-140569 |  |  |
| 1006 | 204.81 | **Additional bandwidth combinations for LTE Advanced inter-band Carrier Aggregation to support 3DL fallback** | 72d? | 2014-03-06 A | 2014-06-13 A | 100% | 2014-03-06 | 2014-06-13 | 72d? |  | R4 | 1152h | 1152h | LTE_CA_3DL_FB_BW | PCG-32 | Qualcomm | Fong Gene (gfong@qti.qualcomm.com) | Rel-12 | RP-63 | Issam | CA | LTE_CA_3DL_FB_BW |  |  |  |
| 1007 | 204.81.1 | Core part: Additional bandwidth combinations for LTE Advanced inter-band Carrier Aggregation to support 3DL fallback | 72d? | 2014-03-06 A | 2014-06-13 A | 100% | 2014-03-06 | 2014-06-13 | 72d? | finish no earlier than 2014-06-13 | R4 | 576h | 576h | LTE_CA_3DL_FB_BW-Core | PCG-32 | Qualcomm | Fong Gene (gfong@qti.qualcomm.com) | Rel-12 | RP-63 | Issam | CA | LTE_CA_3DL_FB_BW-Core | RP-140569 |  |  |
| 1008 | 204.82 | **LTE Advanced 3 Band Carrier Aggregation (3DL/1UL) of Band 3, Band 7 and Band 7** | 138d? | 2014-03-06 A | 2014-09-12 A | 100% | 2014-03-06 | 2014-09-12 | 137d? |  | R4 | 3296h | 3296h | LTE_CA_B3_B7_B7 | PCG-32 | Nokia Networks | iwajlo.angelow@nsn.com | Rel-12 | RP-63 | Issam | CA | LTE_CA_B3_B7_B7 |  |  |  |
| 1009 | 204.82.1 | Core part: LTE Advanced 3 Band Carrier Aggregation (3DL/1UL) of Band 3, Band 7 and Band 7 | 137d? | 2014-03-06 A | 2014-09-12 A | 100% | 2014-03-06 | 2014-09-12 | 137d? | finish no earlier than 2014-09-12 | R4 | 1096h | 1096h | LTE_CA_B3_B7_B7-Core | PCG-32 | Nokia Networks | iwajlo.angelow@nsn.com | Rel-12 | RP-63 | Issam | CA | LTE_CA_B3_B7_B7-Core | RP-141084 |  |  |
| 1010 | 204.82.2 | Perf. part: LTE Advanced 3 Band Carrier Aggregation (3DL/1UL) of Band 3, Band 7 and Band 7 | 137d? | 2014-03-06 A | 2014-09-12 A | 100% | 2014-03-06 | 2014-09-12 | 137d? | finish no earlier than 2014-09-12 | R4 | 1096h | 1096h | LTE_CA_B3_B7_B7-Perf | PCG-32 | Nokia Networks | iwajlo.angelow@nsn.com | Rel-12 | RP-63 | Issam | CA | LTE_CA_B3_B7_B7-Perf | RP-141084 |  |  |
| 1011 | 204.83 | **LTE Advanced 3 Band Carrier Aggregation (3DL/1UL) of Band 1, Band 19 and Band 21** | 138d? | 2014-03-06 A | 2014-09-12 A | 100% | 2014-03-06 | 2014-09-12 | 137d? |  | R4 | 3296h | 3296h | LTE_CA_B1_B19_B21 | PCG-32 | NTT DOCOMO | teruaki.toeda.zf@nttdocomo.com | Rel-12 | RP-63 | Issam | CA | LTE_CA_B1_B19_B21 |  |  |  |
| 1012 | 204.83.1 | Core part: LTE Advanced 3 Band Carrier Aggregation (3DL/1UL) of Band 1, Band 19 and Band 21 | 137d? | 2014-03-06 A | 2014-09-12 A | 100% | 2014-03-06 | 2014-09-12 | 137d? | finish no earlier than 2014-09-12 | R4 | 1096h | 1096h | LTE_CA_B1_B19_B21-Core | PCG-32 | NTT DOCOMO | teruaki.toeda.zf@nttdocomo.com | Rel-12 | RP-63 | Issam | CA | LTE_CA_B1_B19_B21-Core | RP-141084 |  |  |
| 1013 | 204.83.2 | Perf. part: LTE Advanced 3 Band Carrier Aggregation (3DL/1UL) of Band 1, Band 19 and Band 21 | 137d? | 2014-03-06 A | 2014-09-12 A | 100% | 2014-03-06 | 2014-09-12 | 137d? | finish no earlier than 2014-09-12 | R4 | 1096h | 1096h | LTE_CA_B1_B19_B21-Perf | PCG-32 | NTT DOCOMO | teruaki.toeda.zf@nttdocomo.com | Rel-12 | RP-63 | Issam | CA | LTE_CA_B1_B19_B21-Perf | RP-141084 |  |  |
| 1014 | 204.84 | **LTE Advanced 3 Band Carrier Aggregation (3DL/1UL) of Band 3, Band 3 and Band 7** | 138d? | 2014-03-06 A | 2014-09-12 A | 100% | 2014-03-06 | 2014-09-12 | 137d? |  | R4 | 3296h | 3296h | LTE_CA_B3_B3_B7 | PCG-32 | TeliaSonera | Ralf.Schuh@TeliaSonera.com | Rel-12 | RP-63 | Issam | CA | LTE_CA_B3_B3_B7 |  |  |  |
| 1015 | 204.84.1 | Core part: LTE-Advanced 3 Band Carrier Aggregation (3DL/1UL) of Band 3, Band 3 and Band 7 | 137d? | 2014-03-06 A | 2014-09-12 A | 100% | 2014-03-06 | 2014-09-12 | 137d? | finish no earlier than 2014-09-12 | R4 | 1096h | 1096h | LTE_CA_B3_B3_B7-Core | PCG-32 | TeliaSonera | Ralf.Schuh@TeliaSonera.com | Rel-12 | RP-63 | Issam | CA | LTE_CA_B3_B3_B7-Core | RP-141084 |  |  |
| 1016 | 204.84.2 | Perf. part: LTE-Advanced 3 Band Carrier Aggregation (3DL/1UL) of Band 3, Band 3 and Band 7 | 137d? | 2014-03-06 A | 2014-09-12 A | 100% | 2014-03-06 | 2014-09-12 | 137d? | finish no earlier than 2014-09-12 | R4 | 1096h | 1096h | LTE_CA_B3_B3_B7-Perf | PCG-32 | TeliaSonera | Ralf.Schuh@TeliaSonera.com | Rel-12 | RP-63 | Issam | CA | LTE_CA_B3_B3_B7-Perf | RP-141084 |  |  |
| 1017 | 204.85 | **LTE Advanced intra-band contiguous Carrier Aggregation in Band 40 for 3DL** | 72d? | 2014-03-06 A | 2014-06-13 A | 100% | 2014-03-06 | 2014-06-13 | 72d? |  | R4 | 1728h | 1728h | LTE_CA_C_B40_3DL | PCG-32 | China Mobile | Pan Qun (panqun@chinamobile.com) | Rel-12 | RP-63 | Issam | CA | LTE_CA_C_B40_3DL |  |  |  |
| 1018 | 204.85.1 | Core part: LTE Advanced intra-band contiguous Carrier Aggregation in Band 40 for 3DL | 72d? | 2014-03-06 A | 2014-06-13 A | 100% | 2014-03-06 | 2014-06-13 | 72d? | finish no earlier than 2014-06-13 | R4 | 576h | 576h | LTE_CA_C_B40_3DL-Core | PCG-32 | China Mobile | Pan Qun (panqun@chinamobile.com) | Rel-12 | RP-63 | Issam | CA | LTE_CA_C_B40_3DL-Core | RP-140569 |  |  |
| 1019 | 204.85.2 | Perf. part: LTE Advanced intra-band contiguous Carrier Aggregation in Band 40 for 3DL | 72d? | 2014-03-06 A | 2014-06-13 A | 100% | 2014-03-06 | 2014-06-13 | 72d? | finish no earlier than 2014-06-13 | R4 | 576h | 576h | LTE_CA_C_B40_3DL-Perf | PCG-32 | China Mobile | Pan Qun (panqun@chinamobile.com) | Rel-12 | RP-63 | Issam | CA | LTE_CA_C_B40_3DL-Perf | RP-140569 |  |  |
| 1020 | 204.86 | **Additional bandwidth combination set for LTE Advanced inter-band Carrier Aggregation of Band 4 and Band 12** | 137d? | 2014-03-07 A | 2014-09-12 A | 100% | 2014-03-06 | 2014-12-05 | 197d? |  | R4 | 3288h | 3288h | LTE_CA_B4_B12_BWset | PCG-32 | T-Mobile USA | nelson.ueng@t-mobile.com | Rel-12 | RP-63 | Issam | CA | LTE_CA_B4_B12_BWset |  |  |  |
| 1021 | 204.86.1 | Core part: Additional bandwidth combination set for LTE Advanced inter-band Carrier Aggregation of Band 4 and Band 12 | 137d? | 2014-03-07 A | 2014-09-12 A | 100% | 2014-03-06 | 2014-12-05 | 197d? | finish no earlier than 2014-09-12 | R4 | 1096h | 1096h | LTE_CA_B4_B12_BWset-Core | PCG-32 | T-Mobile USA | nelson.ueng@t-mobile.com | Rel-12 | RP-63 | Issam | CA | LTE_CA_B4_B12_BWset-Core | RP-141084 |  |  |
| 1022 | 204.86.2 | Deleted - Perf. part: Additional bandwidth combination set for LTE Advanced inter-band Carrier Aggregation of Band 4 and Band 12 | 137d? | 2014-03-07 A | 2014-09-12 A | 100% | 2014-03-06 | 2014-12-05 | 197d? | finish no earlier than 2014-09-12 | R4 | 1096h | 1096h | LTE_CA_B4_B12_BWset-Perf | PCG-32 | T-Mobile USA | nelson.ueng@t-mobile.com | Rel-12 | RP-63 | Issam | CA | LTE_CA_B4_B12_BWset-Perf | RP-141084 | PCG-33 | RP-65 |
| 1023 | 204.87 | **LTE Advanced inter-band Carrier Aggregation of Band 41 and Band 42** | 138d? | 2014-03-06 A | 2014-09-12 A | 100% | 2014-03-06 | 2014-09-12 | 137d? |  | R4 | 2776h | 2776h | LTE_CA_B41_B42 | PCG-32 | Huawei | leo.liuye@huawei.com | Rel-12 | RP-63 | Issam | CA | LTE_CA_B41_B42 |  |  |  |
| 1024 | 204.87.1 | Core part: LTE Advanced inter-band Carrier Aggregation of Band 41 and Band 42 | 72d? | 2014-03-06 A | 2014-09-12 A | 100% | 2014-03-06 | 2014-09-12 | 72d? | finish no earlier than 2014-09-12 | R4 | 576h | 576h | LTE_CA_B41_B42-Core | PCG-32 | Huawei | leo.liuye@huawei.com | Rel-12 | RP-63 | Issam | CA | LTE_CA_B41_B42-Core | RP-141084 |  |  |
| 1025 | 204.87.2 | Perf. Part: LTE Advanced inter-band Carrier Aggregation of Band 41 and Band 42 | 137d? | 2014-03-07 A | 2014-09-12 A | 100% | 2014-03-06 | 2014-09-12 | 137d? | finish no earlier than 2014-09-12 | R4 | 1096h | 1096h | LTE_CA_B41_B42-Perf | PCG-32 | Huawei | leo.liuye@huawei.com | Rel-12 | RP-63 | Issam | CA | LTE_CA_B41_B42-Perf | RP-141084 |  |  |
| 1026 | 204.88 | **LTE Advanced 3 Band Carrier Aggregation (3DL/1UL) of Band 4, Band 4, and Band 12** | 138d? | 2014-03-06 A | 2014-09-12 A | 100% | 2014-03-06 | 2014-12-05 | 197d? |  | R4 | 3296h | 3296h | LTE_CA_B4_B4_B12 | PCG-32 | T-Mobile USA | nelson.ueng@t-mobile.com | Rel-12 | RP-63 | Issam | CA | LTE_CA_B4_B4_B12 |  |  |  |
| 1027 | 204.88.1 | Core part: LTE Advanced 3 Band Carrier Aggregation (3DL/1UL) of Band 4, Band 4, and Band 12 | 137d? | 2014-03-06 A | 2014-09-12 A | 100% | 2014-03-06 | 2014-12-05 | 197d? | finish no earlier than 2014-09-12 | R4 | 1096h | 1096h | LTE_CA_B4_B4_B12-Core | PCG-32 | T-Mobile USA | nelson.ueng@t-mobile.com | Rel-12 | RP-63 | Issam | CA | LTE_CA_B4_B4_B12-Core | RP-141084 |  |  |
| 1028 | 204.88.2 | Perf. part: LTE Advanced 3 Band Carrier Aggregation (3DL/1UL) of Band 4, Band 4, and Band 12 | 137d? | 2014-03-07 A | 2014-09-12 A | 100% | 2014-03-06 | 2014-12-05 | 197d? | finish no earlier than 2014-09-12 | R4 | 1096h | 1096h | LTE_CA_B4_B4_B12-Perf | PCG-32 | T-Mobile USA | nelson.ueng@t-mobile.com | Rel-12 | RP-63 | Issam | CA | LTE_CA_B4_B4_B12-Perf | RP-141084 |  |  |

Notes:
- 1004: Inter-band CA 2DL / Impacted TSs and TRs: LTE
- 1005: RP#64 completed / Impacted TSs and TRs: 36.101, TR 36.851
- 1006: Inter-band CA 2DL / Impacted TSs and TRs: LTE
- 1007: RP#64 completed, Additional BW combinations added for 6 Wis: 3 open Rel-12 Wis (B1_B5_B7, B2_B29_B30, B4_B29_B30) and 3 completed Rel-11 Wis (B3_B5, B4_B5, B4_B12) / Impacted TSs and TRs: 36.101, 36.307
- 1008: Inter-band CA 3DL / Impacted TSs and TRs: LTE
- 1009: RP#65 completed. Updated WID RP-140095=>RP-141196 / Impacted TSs and TRs: 36.101, 36.104, 36.133, new generic TR 36.853 (3 Band CA with 1UL)
- 1010: RP#65 completed. Updated WID RP-140095=>RP-141196 / Impacted TSs and TRs: 36.141, 36.307
- 1011: Inter-band CA 3DL / Impacted TSs and TRs: LTE
- 1012: RP#65 completed. Updated WID RP-140106=>RP-141193 / Impacted TSs and TRs: 36.101, 36.104, 36.133, new generic TR 36.853 (3 Band CA with 1UL)
- 1013: RP#65 completed. Updated WID RP-140106=>RP-141193 / Impacted TSs and TRs: 36.141, 36.307
- 1014: Inter-band CA 3DL / Impacted TSs and TRs: LTE
- 1015: RP#65 completed. Updated RP-140390=>RP-141126 / Impacted TSs and TRs: 36.101, 36.104, 36.133, new generic TR 36.853 (3 Band CA with 1UL)
- 1016: RP#65 completed. Updated RP-140390=>RP-141126 / Impacted TSs and TRs: 36.141, 36.307
- 1017: Intra-band contig. CA 3DL / Impacted TSs and TRs: LTE
- 1018: RP#64 completed. Updated WID RP-140453=>RP-140948 / Impacted TSs and TRs: 36.101, 36.104, 36.133, New TR 36.833-5-40
- 1019: RP#64 completed. Updated WID RP-140453=>RP-140948 / Impacted TSs and TRs: 36.141, 36.307
- 1020: Inter-band CA 2DL / Impacted TSs and TRs: LTE
- 1021: RP#65 completed. Updated WID RP-140987=>RP-141235 (removed Perf. Part) / Impacted TSs and TRs: 36.101, generic TR 36.850
- 1022: RP#65 stopped. Updated WID RP-140987=>RP-141235 (removed Perf. Part) / Impacted TSs and TRs: 36.307
- 1023: Inter-band CA 2DL / Impacted TSs and TRs: LTE
- 1024: RP#65 completed / Impacted TSs and TRs: 36.101, 36.104, TR 36.851
- 1025: RP#65 completed / Impacted TSs and TRs: 36.141
- 1026: Inter-band CA 3DL / Impacted TSs and TRs: LTE
- 1027: RP#65 completed. Updated WID RP-140116=>RP-141709 / Impacted TSs and TRs: 36.101, 36.104, 36.133, 36.141, 36.307, generic TR 36.853 (3 Band CA with 1UL)
- 1028: RP#65 completed / Impacted TSs and TRs: 36.101, 36.104, 36.133, 36.141, 36.307

| ID | WBS | Task | Duration | Start | Finish | Complete | Remaining | Baseline start | Baseline finish | Baseline duration | Total slack | Constraint | Resources | Work | Actual work | Acronym | PCG approved | WI rapporteur name | WI rapporteur e-mail | Release | TSG approved | MCC resp | Special Focus Doc | Acronym_3GU_Export | Status Report |
| --- | --- | --- | --- | --- | --- | --- | --- | --- | --- | --- | --- | --- | --- | --- | --- | --- | --- | --- | --- | --- | --- | --- | --- | --- | --- |
| 1029 | 204.89 | **LTE Advanced 3 Band Carrier Aggregation (3DL/1UL) of Band 2, Band 4, and Band 4** | 138d? | 2014-03-06 A | 2014-09-12 A | 100% |  | 2014-03-06 | 2014-12-05 | 197d? |  |  | R4 | 3296h | 3296h | LTE_CA_B2_B4_B4 | PCG-32 | T-Mobile USA | nelson.ueng@T-Mobile.com | Rel-12 | RP-63 | Issam | CA | LTE_CA_B2_B4_B4 |  |
| 1030 | 204.89.1 | Core part: LTE Advanced 3 Band Carrier Aggregation (3DL/1UL) of Band 2, Band 4, and Band 4 | 137d? | 2014-03-06 A | 2014-09-12 A | 100% |  | 2014-03-06 | 2014-12-05 | 197d? |  | finish no earlier than 2014-09-12 | R4 | 1096h | 1096h | LTE_CA_B2_B4_B4-Core | PCG-32 | T-Mobile USA | nelson.ueng@T-Mobile.com | Rel-12 | RP-63 | Issam | CA | LTE_CA_B2_B4_B4-Core | RP-141084 |
| 1031 | 204.89.2 | Perf. part: LTE Advanced 3 Band Carrier Aggregation (3DL/1UL) of Band 2, Band 4, and Band 4 | 137d? | 2014-03-07 A | 2014-09-12 A | 100% |  | 2014-03-06 | 2014-12-05 | 197d? |  | finish no earlier than 2014-09-12 | R4 | 1096h | 1096h | LTE_CA_B2_B4_B4-Perf | PCG-32 | T-Mobile USA | nelson.ueng@T-Mobile.com | Rel-12 | RP-63 | Issam | CA | LTE_CA_B2_B4_B4-Perf | RP-141084 |
| 1032 | 204.90 | **Additional bandwidth combinations for LTE Advanced intra-band non-contiguous Carrier Aggregation in Band 25** | 138d? | 2014-03-06 A | 2014-09-12 A | 100% |  | 2014-03-06 | 2014-09-12 | 137d? |  |  | R4 | 3296h | 3296h | LTE_CA_NC_B25_BWset | PCG-32 | Huawei | Liu Liehai (liuliehai@huawei.com) | Rel-12 | RP-63 | Issam | CA | LTE_CA_NC_B25_BWset |  |
| 1033 | 204.90.1 | Core part: Additional bandwidth combinations for LTE Advanced intra-band non-contiguous Carrier Aggregation in Band 25 | 137d? | 2014-03-06 A | 2014-09-12 A | 100% |  | 2014-03-06 | 2014-09-12 | 137d? |  | finish no earlier than 2014-09-12 | R4 | 1096h | 1096h | LTE_CA_NC_B25_BWset-Core | PCG-32 | Huawei | Liu Liehai (liuliehai@huawei.com) | Rel-12 | RP-63 | Issam | CA | LTE_CA_NC_B25_BWset-Core | RP-141084 |
| 1034 | 204.90.2 | Perf. part: Additional bandwidth combinations for LTE Advanced intra-band non-contiguous Carrier Aggregation in Band 25 | 137d? | 2014-03-07 A | 2014-09-12 A | 100% |  | 2014-03-06 | 2014-09-12 | 137d? |  | finish no earlier than 2014-09-12 | R4 | 1096h | 1096h | LTE_CA_NC_B25_BWset-Perf | PCG-32 | Huawei | Liu Liehai (liuliehai@huawei.com) | Rel-12 | RP-63 | Issam | CA | LTE_CA_NC_B25_BWset-Perf | RP-141084 |
| 1035 | 204.91 | **Additional bandwidth combination set for LTE Advanced inter-band Carrier Aggregation of Band 2 and Band 4** | 66d? | 2014-06-15 A | 2014-09-15 A | 100% |  | 2014-06-13 | 2014-09-12 | 66d? |  |  | R4 | 1056h | 1056h | LTE_CA_B2_B4_BWset | PCG-33 | T-Mobile USA | nelson.ueng@T-Mobile.com | Rel-12 | RP-64 |  | CA | LTE_CA_B2_B4_BWset |  |
| 1036 | 204.91.1 | Core part: Additional bandwidth combination set 2 for LTE Advanced inter-band Carrier Aggregation of Band 2 and Band 4 | 66d? | 2014-06-15 A | 2014-09-15 A | 100% |  | 2014-06-13 | 2014-09-12 | 66d? |  | finish no earlier than 2014-09-15 | R4 | 528h | 528h | LTE_CA_B2_B4_BWset2-Core | PCG-33 | T-Mobile USA | nelson.ueng@T-Mobile.com | Rel-12 | RP-64 |  | CA | LTE_CA_B2_B4_BWset-Core | RP-141084 |
| 1037 | 204.92 | **Additional bandwidth combination set for LTE Advanced inter-band Carrier Aggregation of Band 2 and Band 5** | 132d? | 2014-06-18 A | 2014-12-15 | 50% | 66d? | 2014-06-13 | 2014-09-12 | 66d? | 653d |  | R4 | 3168h | 1584h | LTE_CA_B2_B5_BWset | PCG-33 | AT&T | marc.grant@att.com | Rel-12 | RP-64 |  | CA | LTE_CA_B2_B5_BWset |  |
| 1038 | 204.92.1 | Core part: Additional bandwidth combination set for LTE Advanced inter-band Carrier Aggregation of Band 2 and Band 5 | 132d? | 2014-06-18 A | 2014-12-15 A | 100% |  | 2014-06-13 | 2014-09-12 | 66d? |  | finish no earlier than 2014-12-15 | R4 | 1056h | 1056h | LTE_CA_B2_B5_Bwset-Core | PCG-33 | AT&T | marc.grant@att.com | Rel-12 | RP-64 |  | CA | LTE_CA_B2_B5_Bwset-Core | RP-141084 |
| 1039 | 204.92.2 | Perf. Part: Additional bandwidth combination set for LTE Advanced inter-band Carrier Aggregation of Band 2 and Band 5 | 132d? | 2014-06-18 | 2014-12-15 |  |  | 2014-06-13 | 2014-09-12 | 66d? | 653d | finish no earlier than 2014-12-15 | R4 | 1056h |  | LTE_CA_B2_B5_BWset-Perf | PCG-33 | AT&T | marc.grant@att.com | Rel-12 | RP-64 |  | CA | LTE_CA_B2_B5_BWset-Perf | RP-141084 |
| 1040 | 204.93 | **E-UTRA UE demodulation/Channel State Information (CSI) performance requirements for multiple Carrier Aggregation configurations** | 198d? | 2014-06-16 A | 2015-03-15 | 90% | 19.79d? | 2014-06-13 | 2015-03-13 | 196d? | 589d |  | R4 | 3152h | 2836.92h | LTE_CA_Mult | PCG-33 | China Mobile | Zhang Xiaoran (zhangxiaoran@chinamobile.com) | Rel-12 | RP-64 |  | CA | LTE_CA_Mult |  |
| 1041 | 204.93.1 | Perf. Part: E-UTRA UE demodulation/Channel State Information (CSI) performance requirements for multiple Carrier Aggregation configurations | 196d? | 2014-06-16 A | 2015-03-15 | 90% | 19.6d? | 2014-06-13 | 2015-03-13 | 196d? | 589d | finish no earlier than 2015-03-15 | R4 | 1568h | 1411.2h | LTE_CA_Mult-Perf | PCG-33 | China Mobile | Zhang Xiaoran (zhangxiaoran@chinamobile.com) | Rel-12 | RP-64 |  | CA | LTE_CA_Mult-Perf | RP-141303 |
| 1042 | 204.94 | **LTE Advanced 3 Band Carrier Aggregation (3DL/1UL) of Band 1, Band 3 and Band 19** | 66d? | 2014-06-16 A | 2014-09-12 A | 100% |  | 2014-06-13 | 2014-09-12 | 66d? |  |  | R4 | 1584h | 1584h | LTE_CA_B1_B3_B19 | PCG-33 | NTT DOCOMO | teruaki.toeda.zf@nttdocomo.com | Rel-12 | RP-64 |  | CA | LTE_CA_B1_B3_B19 |  |
| 1043 | 204.94.1 | Core part: LTE Advanced 3 Band Carrier Aggregation (3DL/1UL) of Band 1, Band 3 and Band 19 | 66d? | 2014-06-16 A | 2014-09-12 A | 100% |  | 2014-06-13 | 2014-09-12 | 66d? |  | finish no earlier than 2014-09-12 | R4 | 528h | 528h | LTE_CA_B1_B3_B19-Core | PCG-33 | NTT DOCOMO | teruaki.toeda.zf@nttdocomo.com | Rel-12 | RP-64 |  | CA | LTE_CA_B1_B3_B19-Core | RP-141084 |
| 1044 | 204.94.2 | Perf. Part: LTE Advanced 3 Band Carrier Aggregation (3DL/1UL) of Band 1, Band 3 and Band 19 | 66d? | 2014-06-16 A | 2014-09-12 A | 100% |  | 2014-06-13 | 2014-09-12 | 66d? |  | finish no earlier than 2014-09-12 | R4 | 528h | 528h | LTE_CA_B1_B3_B19-Perf | PCG-33 | NTT DOCOMO | teruaki.toeda.zf@nttdocomo.com | Rel-12 | RP-64 |  | CA | LTE_CA_B1_B3_B19-Perf | RP-141084 |
| 1045 | 204.95 | **LTE Advanced 3 Band Carrier Aggregation (3DL/1UL) of Band 19, Band 42 and Band 42** | 66d? | 2014-06-16 A | 2014-09-12 A | 100% |  | 2014-06-13 | 2014-09-12 | 66d? |  |  | R4 | 1584h | 1584h | LTE_CA_B19_B42_B42 | PCG-33 | NTT DOCOMO | teruaki.toeda.zf@nttdocomo.com | Rel-12 | RP-64 |  | CA | LTE_CA_B19_B42_B42 |  |
| 1046 | 204.95.1 | Core part: LTE Advanced 3 Band Carrier Aggregation (3DL/1UL) of Band 19, Band 42 and Band 42 | 66d? | 2014-06-16 A | 2014-09-12 A | 100% |  | 2014-06-13 | 2014-09-12 | 66d? |  | finish no earlier than 2014-09-12 | R4 | 528h | 528h | LTE_CA_B19_B42_B42-Core | PCG-33 | NTT DOCOMO | teruaki.toeda.zf@nttdocomo.com | Rel-12 | RP-64 |  | CA | LTE_CA_B19_B42_B42-Core | RP-141084 |
| 1047 | 204.95.2 | Perf. Part: LTE Advanced 3 Band Carrier Aggregation (3DL/1UL) of Band 19, Band 42 and Band 42 | 66d? | 2014-06-16 A | 2014-09-12 A | 100% |  | 2014-06-13 | 2014-09-12 | 66d? |  | finish no earlier than 2014-09-12 | R4 | 528h | 528h | LTE_CA_B19_B42_B42-Perf | PCG-33 | NTT DOCOMO | teruaki.toeda.zf@nttdocomo.com | Rel-12 | RP-64 |  | CA | LTE_CA_B19_B42_B42-Perf | RP-141084 |
| 1048 | 204.96 | **LTE Advanced 3 Band Carrier Aggregation (3DL/1UL) of Band 3, Band 42 and Band 42** | 460d? | 2014-06-16 A | 2016-03-15 | 70% | 138d? | 2014-06-13 | 2014-09-12 | 66d? | 327d |  | R4 | 8912h | 4190.4h | LTE_CA_B3_B42_B42 | PCG-33 | NTT DOCOMO | ANDO Kei (kei.andou.ye@nttdocomo.com) | Rel-12 | RP-64 |  | CA | LTE_CA_B3_B42_B42 |  |
| 1049 | 204.96.1 | Core part: LTE Advanced 3 Band Carrier Aggregation (3DL/1UL) of Band 3, Band 42 and Band 42 | 196d? | 2014-06-16 A | 2015-03-15 | 70% | 58.8d? | 2014-06-13 | 2014-09-12 | 66d? | 589d | finish no earlier than 2015-03-15 | R4 | 1568h | 1097.6h | LTE_CA_B3_B42_B42-Core | PCG-33 | NTT DOCOMO | ANDO Kei (kei.andou.ye@nttdocomo.com) | Rel-12 | RP-64 |  | CA | LTE_CA_B3_B42_B42-Core | RP-141084 |
| 1050 | 204.96.2 | Perf. Part: LTE Advanced 3 Band Carrier Aggregation (3DL/1UL) of Band 3, Band 42 and Band 42 | 458d? | 2014-06-16 A | 2016-03-15 | 70% | 137.4d? | 2014-06-13 | 2014-09-12 | 66d? | 327d | finish no earlier than 2016-03-15 | R4 | 3664h | 2564.8h | LTE_CA_B3_B42_B42-Perf | PCG-33 | NTT DOCOMO | ANDO Kei (kei.andou.ye@nttdocomo.com) | Rel-12 | RP-64 |  | CA | LTE_CA_B3_B42_B42-Perf | RP-141084 |
| 1051 | 204.97 | **LTE Advanced 3 Band Carrier Aggregation (3DL/1UL) of Band 1, Band 42 and Band 42** | 66d? | 2014-06-16 A | 2014-09-12 A | 100% |  | 2014-06-13 | 2014-09-12 | 66d? |  |  | R4 | 1584h | 1584h | LTE_CA_B1_B42_B42 | PCG-33 | NTT DOCOMO | ANDO Kei (kei.andou.ye@nttdocomo.com) | Rel-12 | RP-64 |  | CA | LTE_CA_B1_B42_B42 |  |
| 1052 | 204.97.1 | Core part: LTE Advanced 3 Band Carrier Aggregation (3DL/1UL) of Band 1, Band 42 and Band 42 | 66d? | 2014-06-16 A | 2014-09-12 A | 100% |  | 2014-06-13 | 2014-09-12 | 66d? |  | finish no earlier than 2014-09-12 | R4 | 528h | 528h | LTE_CA_B1_B42_B42-Core | PCG-33 | NTT DOCOMO | ANDO Kei (kei.andou.ye@nttdocomo.com) | Rel-12 | RP-64 |  | CA | LTE_CA_B1_B42_B42-Core | RP-141084 |
| 1053 | 204.97.2 | Perf. Part: LTE Advanced 3 Band Carrier Aggregation (3DL/1UL) of Band 1, Band 42 and Band 42 | 66d? | 2014-06-16 A | 2014-09-12 A | 100% |  | 2014-06-13 | 2014-09-12 | 66d? |  | finish no earlier than 2014-09-12 | R4 | 528h | 528h | LTE_CA_B1_B42_B42-Perf | PCG-33 | NTT DOCOMO | ANDO Kei (kei.andou.ye@nttdocomo.com) | Rel-12 | RP-64 |  | CA | LTE_CA_B1_B42_B42-Perf | RP-141084 |

Notes:
- 1029: Inter-band CA 3DL / Impacted TSs and TRs: LTE
- 1030: RP#65 completed. Updated WID RP-140117=>RP-141236 / Impacted TSs and TRs: 36.101, 36.104, 36.133, 36.141, 36.307, generic TR 36.853 (3 Band CA with 1UL)
- 1031: RP#65 completed / Impacted TSs and TRs: 36.101, 36.104, 36.133, 36.141, 36.307
- 1032: Intra-band non-contig. CA 2DL / Impacted TSs and TRs: LTE
- 1033: RP#65 completed / Impacted TSs and TRs: 36.101, 36.307, TR 36.833-2-25
- 1034: RP#65 completed / Impacted TSs and TRs: 36.307
- 1035: Inter-band CA 2DL / Impacted TSs and TRs: LTE
- 1036: Prev CD:Fri 12/09/14; Prev %:100%, title changed / Impacted TSs and TRs: 36.101, 36.851
- 1037: 2DL/1UL / Impacted TSs and TRs: LTE
- 1038: CD:Thu 11/12/14->Mon 15/12/14; Compl:0%->100% / Impacted TSs and TRs: 36.101, 36.851
- 1039: CD:Thu 11/12/14->Mon 15/12/14; Compl:0%->0% / Impacted TSs and TRs: 36.307
- 1040: LTE / Impacted TSs and TRs: LTE
- 1041: CD:Thu 12/03/15->Sun 15/03/15; Compl:10%->90% / Impacted TSs and TRs: 36.101
- 1042: Inter-band CA 3DL / Impacted TSs and TRs: LTE
- 1043: RP#65 completed / Impacted TSs and TRs: 36.101, 36.104, 36.133, generic TR 36.853 (3 Band CA with 1UL)
- 1044: RP#65 completed / Impacted TSs and TRs: 36.141, 36.307
- 1045: Inter-band CA 3DL / Impacted TSs and TRs: LTE
- 1046: RP#65 completed / Impacted TSs and TRs: 36.101, 36.104, 36.133, generic TR 36.853 (3 Band CA with 1UL)
- 1047: RP#65 completed / Impacted TSs and TRs: 36.141, 36.307
- 1048: 3DL/1UL / Impacted TSs and TRs: LTE
- 1049: CD:Thu 11/12/14->Sun 15/03/15; Compl:50%->70% / Impacted TSs and TRs: 36.101, 36.104, 36.133, generic TR 36.853 (3 Band CA with 1UL)
- 1050: CD:Thu 11/12/14->Tue 15/03/16; Compl:50%->70% / Impacted TSs and TRs: 36.141, 36.307
- 1051: Inter-band CA 3DL / Impacted TSs and TRs: LTE
- 1052: RP#65 completed / Impacted TSs and TRs: 36.101, 36.104, 36.133, generic TR 36.853 (3 Band CA with 1UL)
- 1053: RP#65 completed / Impacted TSs and TRs: 36.141, 36.307

| ID | WBS | Task | Duration | Start | Finish | Complete | Remaining | Baseline start | Baseline finish | Baseline duration | Total slack | Constraint | Resources | Work | Actual work | Acronym | PCG approved | WI rapporteur name | WI rapporteur e-mail | Release | TSG approved | Special Focus Doc | Acronym_3GU_Export | Status Report | MCC resp | PCG stopped | TSG stopped |
| --- | --- | --- | --- | --- | --- | --- | --- | --- | --- | --- | --- | --- | --- | --- | --- | --- | --- | --- | --- | --- | --- | --- | --- | --- | --- | --- | --- |
| 1054 | 204.98 | **Additional bandwidth combination set for LTE Advanced intra-band contiguous Carrier Aggregation in Band 40 for 3DL** | 66d? | 2014-06-16 A | 2014-09-12 A | 100% |  | 2014-06-13 | 2014-09-12 | 66d? |  |  | R4 | 1096h | 1096h | LTE_CA_C_B40_3DL_BW | PCG-33 | TeliaSonera | Ralf.Schuh@TeliaSonera.com | Rel-12 | RP-64 | CA | LTE_CA_C_B40_3DL_BW |  |  |  |  |
| 1055 | 204.98.1 | Core part: Additional bandwidth combination set for LTE Advanced intra-band contiguous Carrier Aggregation in Band 40 for 3DL | 66d? | 2014-06-16 A | 2014-09-12 A | 100% |  | 2014-06-13 | 2014-09-12 | 66d? |  | finish no earlier than 2014-09-12 | R4 | 528h | 528h | LTE_CA_C_B40_3DL_BW-Core | PCG-33 | TeliaSonera | Ralf.Schuh@TeliaSonera.com | Rel-12 | RP-64 | CA | LTE_CA_C_B40_3DL_BW-Core | RP-141084 |  |  |  |
| 1056 | 204.98.2 | Perf. part: Additional bandwidth combination set for LTE Advanced intra-band contiguous Carrier Aggregation in Band 40 for 3DL | 5d? | 2014-09-08 A | 2014-09-12 A | 100% |  |  |  |  |  | finish no earlier than 2014-09-12 | R4 | 40h | 40h | LTE_CA_C_B40_3DL_BW-Perf | PCG-33 | TeliaSonera | Ralf.Schuh@TeliaSonera.com | Rel-12 | RP-65 |  | LTE_CA_C_B40_3DL_BW-Perf | RP-141084 |  |  |  |
| 1057 | 204.99 | **LTE Advanced inter-band Carrier Aggregation of Band 18 and Band 28** | 3d? | 2014-09-10 A | 2014-09-12 A | 100% |  | 2014-03-06 | 2015-03-13 | 267d? |  |  | R4 | 72h | 72h | LTE_CA_B18_B28 | PCG-33 | KDDI | Masaaki Obara (ms-obara@kddi.com) | Rel-12 | RP-65 | CA | LTE_CA_B18_B28 |  | Issam |  |  |
| 1058 | 204.99.1 | Core part: LTE Advanced inter-band Carrier Aggregation of Band 18 and Band 28 | 3d? | 2014-09-10 A | 2014-09-12 A | 100% |  | 2014-03-06 | 2015-03-13 | 267d? |  | finish no earlier than 2014-09-12 | R4 | 24h | 24h | LTE_CA_B18_B28-Core | PCG-33 | KDDI | Masaaki Obara (ms-obara@kddi.com) | Rel-12 | RP-65 | CA | LTE_CA_B18_B28-Core |  | Issam |  |  |
| 1059 | 204.99.2 | Perf. Part: LTE Advanced inter-band Carrier Aggregation of Band 18 and Band 28 | 3d? | 2014-09-10 A | 2014-09-12 A | 100% |  | 2014-03-06 | 2015-03-13 | 267d? |  | finish no earlier than 2014-09-12 | R4 | 24h | 24h | LTE_CA_B18_B28-Perf | PCG-33 | KDDI | Masaaki Obara (ms-obara@kddi.com) | Rel-12 | RP-65 | CA | LTE_CA_B18_B28-Perf |  | Issam |  |  |
| 1060 | 205 | UE Conformance Test Aspects – Further Rel-12 configurations for LTE Advanced Carrier Aggregation | 397d? | 2013-09-15 A | 2015-03-19 | 75% | 99.25d? | 2013-09-09 | 2014-12-05 | 327d? | 585d | finish no earlier than 2015-03-15 | R5 | 3176h | 2382h | LTE_CA_Rel12-UEConTest | PCG-31 | Microsoft | jussi.kuusisto@microsoft.com | Rel-12 | RP-61 | CA | LTE_CA_Rel12-UEConTest | RP-141444 | Ingbert |  |  |
| 1061 | 206 | UE Conformance Test Aspects – Further Rel-12 configurations for LTE Advanced Carrier Aggregation with 3DL | 263d? | 2014-09-15 A | 2015-09-14 | 6% | 247.22d? |  |  |  | 458d | start no earlier than 2014-09-15 | R5 | 2104h | 126.24h | LTE_CA_Rel12_3DL-UEConTest | PCG-33 | Microsoft | jussi.kuusisto@microsoft.com | Rel-12 | RP-65 | CA | LTE_CA_Rel12_3DL-UEConTest |  |  |  |  |
| 1062 | 207 | **Deleted - Carrier based HetNet ICIC for LTE** | 595d? | 2011-03-18 A | 2013-06-14 A | 100% |  | 2011-03-18 | 2013-06-14 | 595d? |  |  | R3; R1; R2 | 28560h | 28560h | LTE_CA_HetNet_ICIC | PCG-26 | Nokia Siemens Networks | krzysztof.kordybach@nsn.com | Rel-12 | RP-51 |  | LTE_CA_HetNet_ICIC |  | Juha | PCG-31 | RP-60 |
| 1063 | 207.1 | Deleted - Core part: Carrier based HetNet ICIC for LTE | 595d? | 2011-03-18 A | 2013-06-14 A | 100% |  | 2011-03-18 | 2013-06-14 | 595d? |  | finish no earlier than 2013-06-14 | R3; R1; R2 | 14280h | 14280h | LTE_CA_HetNet_ICIC-Core | PCG-26 | Nokia Siemens Networks | krzysztof.kordybach@nsn.com | Rel-12 | RP-51 |  | LTE_CA_HetNet_ICIC-Core | RP-130500 | Juha | PCG-31 | RP-60 |
| 1064 | 208 | **LTE in the US Wireless Communications Service (WCS) Band 30** | 599d? | 2012-09-12 A | 2014-12-15 A | 100% |  | 2012-09-12 | 2014-12-05 | 591d? |  |  | R4; R2; R5 | 20280h | 20280h | LTE_WCS_band | PCG-29 | AT&T | marc.grant@att.com | Rel-12 | RP-57 |  | LTE_WCS_band |  | Issam |  |  |
| 1065 | 208.1 | Core part: LTE in the US Wireless Communications Service (WCS) Band 30 | 202d? | 2012-09-12 A | 2013-06-14 A | 100% |  | 2012-09-12 | 2013-06-14 | 202d? |  | finish no earlier than 2013-06-14 | R4; R2 | 3232h | 3232h | LTE_WCS_band-Core | PCG-29 | AT&T | marc.grant@att.com | Rel-12 | RP-57 |  | LTE_WCS_band-Core | RP-130569 | Issam |  |  |
| 1066 | 208.2 | Perf. Part: LTE in the US Wireless Communications Service (WCS) Band 30 | 201d? | 2012-09-13 A | 2013-06-14 A | 100% |  | 2012-09-13 | 2013-06-14 | 201d? |  | finish no earlier than 2013-06-14 | R4 | 1608h | 1608h | LTE_WCS_band-Perf | PCG-29 | AT&T | marc.grant@att.com | Rel-12 | RP-57 |  | LTE_WCS_band-Perf | RP-130570 | Issam |  |  |
| 1067 | 208.3 | Test Part: LTE in the US Wireless Communications Service (WCS) Band 30 | 133d? | 2014-06-15 A | 2014-12-15 A | 100% |  | 2014-06-13 | 2014-12-05 | 126d? |  | finish no earlier than 2014-12-15 | R5 | 1064h | 1064h | LTE_WCS_band-UEConTest | PCG-33 | Ericsson | fredrik.sundstrom@ericsson.com | Rel-12 | RP-64 |  | LTE_WCS_band-UEConTest | RP-141166 |  |  |  |
| 1068 | 209 | **Introduction of LTE 450 MHz band in Brazil** | 331d? | 2012-09-11 A | 2013-12-06 A | 100% |  | 2012-09-11 | 2013-12-06 | 331d? |  |  | R4; R5 | 10000h | 10000h | LTE450_Brazil | PCG-29 | Huawei | Liehai Liu (liuliehai@huawei.com) | Rel-12 | RP-57 |  | LTE450_Brazil |  | Issam |  |  |
| 1069 | 209.1 | Core part: Introduction of LTE 450 MHz band in Brazil | 201d? | 2012-09-11 A | 2013-06-14 A | 100% |  | 2012-09-11 | 2013-06-14 | 201d? |  | finish no earlier than 2013-06-14 | R4 | 1608h | 1608h | LTE450_Brazil-Core | PCG-29 | Huawei | Liehai Liu (liuliehai@huawei.com) | Rel-12 | RP-57 |  | LTE450_Brazil-Core | RP-130567 | Issam |  |  |
| 1070 | 209.2 | Perf. part: Introduction of LTE 450 MHz band in Brazil | 261d? | 2012-09-13 A | 2013-09-06 A | 100% |  | 2012-09-13 | 2013-09-06 | 261d? |  | finish no earlier than 2013-09-06 | R4 | 2088h | 2088h | LTE450_Brazil-Perf | PCG-29 | Huawei | Liehai Liu (liuliehai@huawei.com) | Rel-12 | RP-57 |  | LTE450_Brazil-Perf | RP-131070 | Issam |  |  |
| 1071 | 209.3 | Test part: Introduction of LTE 450 MHz band in Brazil | 126d? | 2013-06-18 A | 2013-12-06 A | 100% |  | 2013-06-18 | 2013-12-06 | 126d? |  | finish no earlier than 2013-12-06 | R5 | 1008h | 1008h | LTE450_Brazil-UEConTest | PCG-31 | Huawei | Xiang Li (tricia.li@huawei.com) | Rel-12 | RP-60 |  | LTE450_Brazil-UEConTest | RP-131457 | Ingbert |  |  |
| 1072 | 210 | **Further Downlink MIMO Enhancement for LTE Advanced** | 600d? | 2012-09-11 A | 2014-12-15 A | 100% |  | 2012-09-11 | 2014-09-12 | 532d? |  |  | R1; R4 | 18048.8h | 18048.8h | LTE_eDL_MIMO_enh | PCG-29 | Alcatel-Lucent | Min Zhang (min.hs.zhang@alcatel-lucent.com) | Rel-12 | RP-57 |  | LTE_eDL_MIMO_enh |  | Patrick |  |  |
| 1073 | 210.1 | Core part: Further Downlink MIMO Enhancement for LTE Advanced | 464d? | 2012-09-11 A | 2014-06-13 A | 100% |  | 2012-09-11 | 2014-06-13 | 464d? |  | finish no earlier than 2014-06-13 | R1 | 3696.76h | 3696.76h | LTE_eDL_MIMO_enh-Core | PCG-29 | Alcatel-Lucent | Min Zhang (min.hs.zhang@alcatel-lucent.com) | Rel-12 | RP-57 |  | LTE_eDL_MIMO_enh-Core | RP-140652 | Patrick |  |  |
| 1074 | 210.2 | Perf. part: Further Downlink MIMO Enhancement for LTE Advanced | 594d? | 2012-09-15 A | 2014-12-15 A | 100% |  | 2012-09-18 | 2014-09-12 | 526d? |  | finish no earlier than 2014-12-15 | R4 | 4752h | 4752h | LTE_eDL_MIMO_enh-Perf | PCG-29 | Alcatel-Lucent | ren.da@alcatel-lucent.com | Rel-12 | RP-57 |  | LTE_eDL_MIMO_enh-Perf | RP-141378 | Issam |  |  |
| 1075 | 211 | **Deleted - New Carrier Type for LTE** | 265d? | 2012-09-11 A | 2013-09-06 A | 100% |  | 2012-09-11 | 2013-09-06 | 265d? |  |  | R1; R2; R4 | 14808h | 14808h | LTE_NCT | PCG-29 | Ericsson | daniel.n.larsson@ericsson.com | Rel-12 | RP-57 |  | LTE_NCT |  | Patrick | PCG-31 | RP-61 |
| 1076 | 211.1 | Deleted - Core part: New Carrier Type for LTE | 265d? | 2012-09-11 A | 2013-09-06 A | 100% |  | 2012-09-11 | 2013-09-06 | 265d? |  | finish no earlier than 2013-09-06 | R1; R2; R4 | 6360h | 6360h | LTE_NCT-Core | PCG-29 | Ericsson | daniel.n.larsson@ericsson.com | Rel-12 | RP-57 |  | LTE_NCT-Core | RP-130984 | Patrick | PCG-31 | RP-61 |
| 1077 | 211.2 | Deleted - Perf. part: New Carrier Type for LTE | 261d? | 2012-09-17 A | 2013-09-06 A | 100% |  | 2012-09-17 | 2013-09-06 | 261d? |  | finish no earlier than 2013-09-06 | R4 | 2088h | 2088h | LTE_NCT-Perf | PCG-29 | Ericsson | daniel.n.larsson@ericsson.com | Rel-12 | RP-57 |  | LTE_NCT-Perf | RP-130985 | Issam | PCG-31 | RP-61 |

Notes:
- 1054: Inter-band CA 3DL / Impacted TSs and TRs: LTE
- 1055: RP#65 completed. Updated WID RP-140950=>RP-141127 / Impacted TSs and TRs: 36.101
- 1056: RP#65 updated WID RP-140950=>RP-141127 (added Perf. Part). Completed. / Impacted TSs and TRs: 36.307
- 1057: Inter-band CA 2DL / Impacted TSs and TRs: LTE
- 1058: RP#65 WID approved & completed. Triggered by revised Rel-13 WID RP-140451=>RP-141610 (take out B18_B28 for Rel-12 from the Rel-13 B1_B18_B28) / Impacted TSs and TRs: 36.101, 36.104, 36.133
- 1059: - / Impacted TSs and TRs: 36.141, 36.307
- 1060: Prev CD:Thu 11/12/14; Prev %:70% / Impacted TSs and TRs: 36.508, 36.521-1, 36.521-2, 36.521-3, 36.523-1, 36.523-2, 36.523-3, 37.571-1, 37.571-3, 37.571-5
- 1061: Prev CD:Fri 11/09/15; Prev %:0%; WID: RP-141445 => RP-141776 / Impacted TSs and TRs: 36.508, 36.521-1, 36.521-2, 36.521-3, 36.523-1, 36.523-2, 36.523-3, 37.571-1, 37.571-3, 37.571-5
- 1062: RP#60 stopped. RP#58 on hold til June 2013 / Impacted TSs and TRs: LTE
- 1063: RP#60 stopped at 40% completion. RP#58 on hold til June 2013 / Impacted TSs and TRs: 36.300, 36.413, 36.420, 36.423
- 1064: RP#58 RP-121701 work can start based on FCC Order (FCC-12-130) http://hraunfoss.fcc.gov/edocs_public/attachmatch/FCC-12-130A1.pdf / Impacted TSs and TRs: LTE
- 1065: RP#60 completed. Updated WID RP-121419=>RP-130843 / Impacted TSs and TRs: 36.101, 36.104, 36.113, 36.124, 36.133, 36.307, 36.331, new TR 36.846
- 1066: RP#60 completed. Updated WID RP-121419=>RP-130843 / Impacted TSs and TRs: 36.101, 36.133, 36.141
- 1067: Prev CD:Thu 11/12/14; Prev %:40% / Impacted TSs and TRs: 36.508, 36.521-1, 36.521-2, 36.521-3, 36.523-2, 36.523-3, 37.571-1
- 1068: - / Impacted TSs and TRs: LTE
- 1069: RP#60 completed. TR 36.840 v100 for 1-step Approval / Impacted TSs and TRs: 36.101, 36.104, 36.113, 36.124, 36.133, 37.104, 37.113, 36.307, new TR 36.840
- 1070: RP#61 completed / Impacted TSs and TRs: 36.133, 36.141, 37.141
- 1071: RP#62 completed / Impacted TSs and TRs: 36.508, 36.521-1, 36.521-2, 36.521-3
- 1072: Stage 3 / Impacted TSs and TRs: LTE
- 1073: RP#64 completed / Impacted TSs and TRs: 36.211, 36.212, 36.213, 36.331
- 1074: CD:Thu 11/12/14->Mon 15/12/14; Compl:85%100% / Impacted TSs and TRs: 36.101
- 1075: RP#61 stopped. Continue discussion on use cases and requirements for a NCT in LTE beyond Rel-12. Action: Ericsson to provide at RP#62 a summary of work done so far / Impacted TSs and TRs: LTE
- 1076: RP#61 stopped at 20% completion / Impacted TSs and TRs: 36.101, 36.104, 36.133, 36.211, 36.212, 36.213, 36.321, 36.331
- 1077: RP#61 stopped at 0% completion / Impacted TSs and TRs: 36.101, 36.104, 36.133, 36.141

| ID | WBS | Task | Duration | Start | Finish | Complete | Remaining | Baseline start | Baseline finish | Baseline duration | Total slack | Constraint | Resources | Work | Actual work | Acronym | PCG approved | WI rapporteur name | Release | TSG approved | MCC resp | Special Focus Doc | Acronym_3GU_Export | Status Report |
| --- | --- | --- | --- | --- | --- | --- | --- | --- | --- | --- | --- | --- | --- | --- | --- | --- | --- | --- | --- | --- | --- | --- | --- | --- |
| 1078 | 212 | **Further Enhancements to LTE TDD for DL-UL Interference Management and Traffic Adaptation** | 669d? | 2012-12-07 A | 2015-06-18 | 33% | 451.56d? | 2012-12-07 | 2014-12-05 | 527d? | 520d |  | R1; R2; R3; R4 | 27490.6h | 6382.06h | LTE_TDD_eIMTA | PCG-30 | CATT | Rel-12 | RP-58 | Patrick | Small cell | LTE_TDD_eIMTA |  |
| 1079 | 212.1 | Core part: Further Enhancements to LTE TDD for DL-UL Interference Management and Traffic Adaptation | 24.58d? | 2012-12-07 A | 2014-06-13 A | 100% |  | 2012-12-07 | 2014-06-13 | 24.58d? |  | finish no earlier than 2014-06-13 | R1; R2; R3; R4 | 786.56h | 786.56h | LTE_TDD_eIMTA-Core | PCG-30 | CATT | Rel-12 | RP-58 | Patrick | Small cell | LTE_TDD_eIMTA-Core | RP-140724 |
| 1080 | 212.2 | Perf. part: Further Enhancements to LTE TDD for DL-UL Interference Management and Traffic Adaptation | 662d? | 2012-12-15 A | 2015-06-18 | 30% | 463.4d? | 2012-12-07 | 2014-12-05 | 527d? | 520d | finish no earlier than 2015-06-15 | R4 | 5296h | 1588.8h | LTE_TDD_eIMTA-Perf | PCG-30 | CATT | Rel-12 | RP-58 | Patrick | Small cell | LTE_TDD_eIMTA-Perf | RP-141342 |
| 1081 | 213 | **HetNet Mobility enhancements for LTE** | 641.65d? | 2012-04-13 A | 2014-09-12 A | 100% |  | 2012-04-13 | 2014-09-12 | 640.65d? |  |  | R2; R4 | 11624h | 11624h | HetNet_eMOB_LTE | PCG-30 | Alcatel-Lucent | Rel-12 | RP-58 | Yong-Jun |  | HetNet_eMOB_LTE |  |
| 1082 | 213.1 | Core part: HetNet Mobility enhancements for LTE | 263.5d? | 2012-04-13 A | 2014-09-12 A | 100% |  | 2012-04-13 | 2014-09-12 | 263.5d? |  | finish no earlier than 2014-09-12 | R2; R4 | 4216h | 4216h | HetNet_eMOB_LTE-Core | PCG-30 | Alcatel-Lucent | Rel-12 | RP-58 | Yong-Jun |  | HetNet_eMOB_LTE-Core | RP-141413 |
| 1083 | 214 | **Further enhancements for HeNB mobility-X2-GW** | 401d? | 2012-12-10 A | 2014-06-13 A | 100% |  | 2012-12-10 | 2014-06-13 | 401d? |  |  | R3 | 6408h | 6408h | EHNB_enh2_X2GW | PCG-30 | Alcatel-Lucent | Rel-12 | RP-58 | Juha | HNB | EHNB_enh2_X2GW |  |
| 1084 | 214.1 | Core part: Further enhancements for HeNB mobility-X2-GW | 400d? | 2012-12-10 A | 2014-06-13 A | 100% |  | 2012-12-10 | 2014-06-13 | 400d? |  | finish no earlier than 2014-06-13 | R3 | 3200h | 3200h | EHNB_enh2_X2GW-Core | PCG-30 | Alcatel-Lucent | Rel-12 | RP-58 | Juha | HNB | EHNB_enh2_X2GW-Core | RP-140592 |
| 1085 | 215 | **8 Rx Antennas for LTE UL** | 265d? | 2012-12-10 A | 2013-12-06 A | 100% |  | 2012-12-10 | 2013-12-06 | 265d? |  |  | R4 | 4208h | 4208h | LTE_UL_8Rx | PCG-30 | China Telecom | Rel-12 | RP-58 | Issam |  | LTE_UL_8Rx |  |
| 1086 | 215.1 | Perf. part: 8 Rx Antennas for LTE UL | 261d? | 2012-12-10 A | 2013-12-06 A | 100% |  | 2012-12-10 | 2013-12-06 | 261d? |  | finish no earlier than 2013-12-06 | R4 | 2088h | 2088h | LTE_UL_8Rx-Perf | PCG-30 | China Telecom | Rel-12 | RP-58 | Issam |  | LTE_UL_8Rx-Perf | RP-131523 |
| 1087 | 216 | **Low cost & enhanced coverage MTC UE for LTE** | 462d? | 2013-06-15 A | 2015-03-15 | 75% | 117.09d? | 2013-06-20 | 2015-03-13 | 456d? | 589d |  | R1; R2; R4 | 18832h | 7086.4h | LC_MTC_LTE | PCG-31 | Vodafone | Rel-12 | RP-60 | Patrick | MTC, M2M | LC_MTC_LTE |  |
| 1088 | 216.1 | Core part: Low cost & enhanced coverage MTC UE for LTE | 173.67d? | 2013-06-15 A | 2014-12-15 A | 100% |  | 2013-10-15 | 2014-09-12 | 108.67d? |  | finish no earlier than 2014-12-15 | R1; R2; R4 | 4168h | 4168h | LC_MTC_LTE-Core | PCG-31 | Vodafone | Rel-12 | RP-60 | Patrick | MTC, M2M | LC_MTC_LTE-Core | RP-141221 |
| 1089 | 216.2 | Perf. part: Low cost & enhanced coverage MTC UE for LTE | 456d? | 2013-06-15 A | 2015-03-15 | 65% | 159.6d? | 2013-06-20 | 2015-03-13 | 456d? | 589d | finish no earlier than 2015-03-15 | R4 | 3648h | 2371.2h | LC_MTC_LTE-Perf | PCG-31 | Vodafone | Rel-12 | RP-60 | Issam | MTC, M2M | LC_MTC_LTE-Perf | RP-141221 |
| 1090 | 217 | **LTE TDD-FDD joint operation including Carrier Aggregation** | 443.03d? | 2013-04-12 A | 2014-12-15 A | 100% |  | 2013-04-12 | 2014-12-05 | 435.03d? |  |  | R1; R2; R4 | 14744h | 14744h | LTE_CA_TDD_FDD | PCG-31 | Nokia | Rel-12 | RP-60 | Patrick |  | LTE_CA_TDD_FDD |  |
| 1091 | 217.1 | Core part: LTE TDD-FDD joint operation including Carrier Aggregation | 87.33d? | 2013-04-12 A | 2014-06-13 A | 100% |  | 2013-04-12 | 2014-06-13 | 87.33d? |  | finish no earlier than 2014-06-13 | R1; R2; R4 | 2096h | 2096h | LTE_CA_TDD_FDD-Core | PCG-31 | Nokia, China Mobile (for TR) | Rel-12 | RP-60 | Patrick |  | LTE_CA_TDD_FDD-Core | RP-140982 |
| 1092 | 217.2 | Perf. part: LTE TDD-FDD joint operation including Carrier Aggregation | 396d? | 2013-06-15 A | 2014-12-15 A | 100% |  | 2013-06-20 | 2014-12-05 | 386d? |  | finish no earlier than 2014-12-15 | R4 | 3168h | 3168h | LTE_CA_TDD_FDD-Perf | PCG-31 | Nokia | Rel-12 | RP-60 | Issam |  | LTE_CA_TDD_FDD-Perf | RP-141374 |
| 1093 | 218 | **LTE Coverage Enhancements** | 669.17d? | 2013-03-01 A | 2015-09-14 | 67% | 224.11d? | 2013-03-01 | 2014-12-05 | 465.17d? | 458d |  | R1; R2; R4; R5 | 28773.4h | 11060h | Cov_Enh_LTE | PCG-31 | China Telecom | Rel-12 | RP-60 | Patrick |  | Cov_Enh_LTE |  |
| 1094 | 218.1 | Core part: LTE Coverage Enhancements | 87d? | 2013-03-01 A | 2014-06-13 A | 100% |  | 2013-03-01 | 2014-06-13 | 87d? |  | finish no earlier than 2014-06-13 | R1; R2; R4 | 2088h | 2088h | Cov_Enh_LTE-Core | PCG-31 | China Telecom | Rel-12 | RP-60 | Patrick |  | Cov_Enh_LTE-Core | RP-140683 |
| 1095 | 218.2 | Perf. part: LTE Coverage Enhancements | 396d? | 2013-06-15 A | 2014-12-15 A | 100% |  | 2013-06-20 | 2014-12-05 | 386d? |  | finish no earlier than 2014-12-15 | R4 | 3168h | 3168h | Cov_Enh_LTE-Perf | PCG-31 | China Telecom | Rel-12 | RP-60 | Issam |  | Cov_Enh_LTE-Perf | RP-141149 |
| 1096 | 218.3 | Test part: LTE Coverage Enhancements | 263d? | 2014-09-15 A | 2015-09-14 | 5% | 249.85d? |  |  |  | 458d | start no earlier than 2014-09-15 | R5 | 2104h | 105.2h | Cov_Enh_LTE-UEConTest | PCG-33 | China Telecom | Rel-12 | RP-65 |  |  | Cov_Enh_LTE-UEConTest |  |
| 1097 | 219 | **Further MBMS operations support for E-UTRAN** | 332d? | 2013-09-15 A | 2014-12-17 A | 100% |  | 2013-12-09 | 2014-09-12 | 201d? |  |  | R2; R1; R3; R4 | 21328h | 21328h | MBMS_LTE_OS | PCG-31 | Verizon | Rel-12 | RP-61 | Yong-Jun |  | MBMS_LTE_OS |  |
| 1098 | 219.1 | Core part: Further MBMS operations support for E-UTRAN | 328d? | 2013-09-15 A | 2014-12-15 A | 100% |  | 2014-04-04 | 2014-09-12 | 115.25d? |  | finish no earlier than 2014-12-15 | R2; R1; R3; R4 | 10496h | 10496h | MBMS_LTE_OS-Core | PCG-31 | Verizon | Rel-12 | RP-61 | Yong-Jun |  | MBMS_LTE_OS-Core | RP-141431 |
| 1099 | 219.2 | Perf. part: Further MBMS operations support for E-UTRAN | 266d? | 2013-12-15 A | 2014-12-17 A | 100% |  | 2013-12-09 | 2014-09-12 | 201d? |  | finish no earlier than 2014-12-15 | R4 | 2128h | 2128h | MBMS_LTE_OS-Perf | PCG-32 | Verizon | Rel-12 | RP-62 | Issam |  | MBMS_LTE_OS-Perf | RP-141431 |
| 1100 | 220 | **Dual connectivity for LTE** | 396d? | 2013-12-15 A | 2015-06-16 | 61% | 156.26d? | 2013-12-09 | 2014-12-05 | 261d? | 522d |  | R2; R1; R3; R4; S2; C4 | 32144h | 14584.3h | LTE_SC_enh_dualC | PCG-32 | NTT DOCOMO | Rel-12 | RP-62 | Yong-Jun | Small cell | LTE_SC_enh_dualC |  |
| 1101 | 220.1 | Core part: Dual connectivity for LTE | 263d? | 2013-12-15 A | 2014-12-15 A | 100% |  | 2014-04-29 | 2014-09-12 | 99d? |  | finish no earlier than 2014-12-15 | R2; R1; R3; R4 | 8416h | 8416h | LTE_SC_enh_dualC-Core | PCG-32 | NTT DOCOMO, NEC | Rel-12 | RP-62 | Yong-Jun | Small cell | LTE_SC_enh_dualC-Core | RP-141264 |
| 1102 | 220.2 | Perf. part: Dual Connectivity for LTE | 396d? | 2013-12-15 A | 2015-06-16 | 15% | 336.6d? | 2013-12-09 | 2014-12-05 | 261d? | 522d | finish no earlier than 2015-06-15 | R4 | 3168h | 475.2h | LTE_SC_enh_dualC-Perf | PCG-32 | NTT DOCOMO | Rel-12 | RP-62 | Issam | Small cell | LTE_SC_enh_dualC-Perf | RP-141264 |
| 1103 | 220.3 | SA2 part of Dual connectivity for LTE | 131d? | 2014-03-19 A | 2014-09-17 A | 100% |  | 2014-03-19 | 2014-09-17 | 131d? |  | finish no earlier than 2014-09-17 | S2 | 1048h | 1048h |  | PCG-32 |  | Rel-12 | RP-63 |  | Small cell |  |  |
| 1104 | 220.4 | CT aspects of Dual connectivity for LTE | 63d? | 2014-09-12 A | 2014-12-09 A | 100% |  |  |  |  |  | finish no earlier than 2014-12-09 | C4 | 504h | 504h | LTE_SC_enh_dualC-CT | PCG-33 | Huawei | Rel-12 | CP-65 |  | Small cell | LTE_SC_enh_dualC-CT | CP-140487 |

Notes:
- 1078: Stage 3. Triggered by Rel-11 TR 36.828 Study on Further Enhancements to LTE TDD for DL-UL Interference Management and Traffic Adaptation (FS_LTE_TDD_eIMTA) UID_510039 / Impacted TSs and TRs: LTE / WI rapporteur e-mail: Zukang Shen (shenzukang@catt.cn)
- 1079: RP#64 completed / Impacted TSs and TRs: 36.101, 36.104, 36.133, 36.211, 36.212, 36.213, 36.214, 36.300, 36.321, 36.331, 36.413, 36.423 / WI rapporteur e-mail: Zukang Shen (shenzukang@catt.cn)
- 1080: CD:Thu 11/12/14->Mon 15/06/15; Compl:20%->30% / Impacted TSs and TRs: 36.101, 36.104, 36.133, 36.141 / WI rapporteur e-mail: Zukang Shen (shenzukang@catt.cn)
- 1081: Stage 3. Triggered by Rel-11 TR 36.839 Study on HetNet mobility enhancements for LTE (FS_HetNet_eMOB_LTE) / Impacted TSs and TRs: LTE / WI rapporteur e-mail: sudeep.palat@alcatel-lucent.com
- 1082: SP#65 completed / Impacted TSs and TRs: 36.133, 36.304, 36.331 / WI rapporteur e-mail: sudeep.palat@alcatel-lucent.com
- 1083: Rel-10 H(e)NB Mobility Enhancements adds signalling via horizontal RAN interfaces (Iurh, X2) to support H(e)NB to H(e)NB mobility. Rel-11 TR37.803 triggered WI UID_560014 partly completed in Rel-11; remaining work including solution definition is Rel-12 / Impacted TSs and TRs: LTE / WI rapporteur e-mail: Philippe.Godin@alcatel-lucent.com
- 1084: RP#64 completed / Impacted TSs and TRs: 36.300, 36.413, 36.423 / WI rapporteur e-mail: Philippe.Godin@alcatel-lucent.com
- 1085: WI has perf. part only (as change from 4Rx to 8Rx has no Core spec impact) / Impacted TSs and TRs: LTE / WI rapporteur e-mail: Shan Yang (yangshan@ctbri.com.cn)
- 1086: RP#62 completed / Impacted TSs and TRs: 36.104, 36.141 / WI rapporteur e-mail: Shan Yang (yangshan@ctbri.com.cn)
- 1087: Triggered by Rel-11 TR 36.888 (FS_LC_MTC_UE) / Impacted TSs and TRs: LTE / WI rapporteur e-mail: eric.bouton@vodafone.com
- 1088: CD:Thu 11/12/14->Mon 15/12/14; Compl:90%->100% / Impacted TSs and TRs: 36.101, 36.104, 36.133, 36.201, 36.211, 36.212, 36.213, 36.300, 36.302, 36.306, 36.321, 36.331 / WI rapporteur e-mail: eric.bouton@vodafone.com
- 1089: CD:Fri 13/03/15->Sun 15/03/15; Compl:55%->65% / Impacted TSs and TRs: 36.101, 36.104, 36.133 / WI rapporteur e-mail: eric.bouton@vodafone.com
- 1090: - / Impacted TSs and TRs: LTE / WI rapporteur e-mail: lars.e.lindh@nokia.com
- 1091: RP#64 completed / Impacted TSs and TRs: 36.101, 36.104, 36.133, 36.201, 36.211, 36.212, 36.213, 36.300, 36.302, 36.306, 36.331, new TR 36.847 / WI rapporteur e-mail: lars.e.lindh@nokia.com, Xiaodong Shen (shenxiaodong@chinamobile.com)
- 1092: CD:Thu 11/12/14->Mon 15/12/14; Compl:30%->100% / Impacted TSs and TRs: 36.101, 36.104, 36.133 / WI rapporteur e-mail: lars.e.lindh@nokia.com
- 1093: Triggered by Rel-11 TR 36.824 (FS_Cov_Enh_LTE) / Impacted TSs and TRs: LTE / WI rapporteur e-mail: Xiaoming She (shexm@ctbri.com.cn)
- 1094: RP#64 completed / Impacted TSs and TRs: 36.101, 36.104, 36.133, 36.211, 36.212, 36.213, 36.300, 36.321, 36.331 / WI rapporteur e-mail: Xiaoming She (shexm@ctbri.com.cn)
- 1095: CD:Thu 11/12/14->Mon 15/12/14; Compl:70%->100% / Impacted TSs and TRs: 36.101, 36.104, 36.133, 36.141 / WI rapporteur e-mail: Xiaoming She (shexm@ctbri.com.cn)
- 1096: Prev CD:Fri 11/09/15; Prev %:0% / Impacted TSs and TRs: 36.508, 36.523-1, 36.523-2, 36.523-3 / WI rapporteur e-mail: YANG Shan (yangshan@ctbri.com.cn)
- 1097: Solutions for Minimization of Drive Tests (MDT), in order to reduce the need for manual drive testing for MBMS. / Impacted TSs and TRs: LTE / WI rapporteur e-mail: yeesin.chan@verizonwireless.com
- 1098: CD:Thu 11/12/14->Mon 15/12/14; Compl:95%->100% / Impacted TSs and TRs: 36.133, 36.214, 36.300, 36.304, 36.306, 36.331, 36.413, 36.423, 37.320 / WI rapporteur e-mail: yeesin.chan@verizonwireless.com
- 1099: CD:Thu 11/12/14->Mon 15/12/14; Compl:75%->100% / Impacted TSs and TRs: 36.133 / WI rapporteur e-mail: yeesin.chan@verizonwireless.com
- 1100: Triggered by TR 36.842 Study on Small Cell Enhancements for E-UTRA and E-UTRAN Higher-layer aspects (UID_580044) / Impacted TSs and TRs: LTE / WI rapporteur e-mail: tooru.uchino.fv@nttdocomo.com
- 1101: CD:Thu 11/12/14->Mon 15/12/14; Compl:65%->100%; WID: RP-141266 => RP-141797 / Impacted TSs and TRs: 36.101, 36.104, 36.133, 36.211, 36.212, 36.213, 36.300, 36.302, 36.306, 36.321, 36.322, 36.323, 36.331, 36.410, 36.413, 36.420, 36.423, new RAN3 TS 36.425 / WI rapporteur e-mail: RAN1/2/4 tooru.uchino.fv@nttdocomo.com, RAN3 Chenghock Ng (ngcheng@da.jp.nec.com)
- 1102: CD:Fri 12/06/15->Mon 15/06/15; Compl:10%->15%; WID: RP-141266 => RP-141797 / Impacted TSs and TRs: 36.101, 36.104, 36.133 / WI rapporteur e-mail: kunihiko.teshima.hg@nttdocomo.com
- 1103: SP#64 Three CRs agreed in SP-140262 (23.251CR0099, 23.401CR2658&CR2707). LM:99->100% / Impacted TSs and TRs: 23.251, 23.401
- 1104: Stage 2/3. CP#65 exception in CP-140487. LM70->100 / Impacted TSs and TRs: 23.007, 23.008, 29.274, 29.281 / WI rapporteur e-mail: Xiaoyan SHI (sean.shixiaoyan@huawei.com)

| ID | WBS | Task | Duration | Start | Finish | Complete | Remaining | Baseline start | Baseline finish | Baseline duration | Total slack | Constraint | Resources | Work | Actual work | Acronym | PCG approved | WI rapporteur name | WI rapporteur e-mail | Release | TSG approved | MCC resp | Special Focus Doc | Acronym_3GU_Export | Status Report |
| --- | --- | --- | --- | --- | --- | --- | --- | --- | --- | --- | --- | --- | --- | --- | --- | --- | --- | --- | --- | --- | --- | --- | --- | --- | --- |
| 1105 | 221 | **E-UTRA Small cell enhancements - Physical layer aspects** | 370.75d? | 2013-12-15 A | 2015-05-12 | 67% | 123.12d? | 2013-07-19 | 2014-12-05 | 364.75d? | 547.25d |  | R1; R2; R4 | 17040.7h | 9385.2h | LTE_SC_enh_L1 | PCG-32 | Huawei | Elean FAN (fanxiaoan@huawei.com) | Rel-12 | RP-62 | Patrick | Small cell | LTE_SC_enh_L1 |  |
| 1106 | 221.1 | Core part: E-UTRA Small cell enhancements - Physical layer aspects | 267d? | 2013-12-15 A | 2015-05-12 A | 100% |  | 2013-07-19 | 2014-09-12 | 202d? |  | finish no earlier than 2014-12-15 | R1; R2; R4 | 6408h | 6408h | LTE_SC_enh_L1-Core | PCG-32 | Huawei | Elean FAN (fanxiaoan@huawei.com) | Rel-12 | RP-62 | Patrick | Small cell | LTE_SC_enh_L1-Core | RP-141632 |
| 1107 | 221.2 | Perf. part: E-UTRA Small cell enhancements - Physical layer aspects | 331d? | 2013-12-15 A | 2015-03-18 | 40% | 198.6d? | 2013-12-09 | 2014-12-05 | 261d? | 586d | finish no earlier than 2015-03-15 | R4 | 2648h | 1059.2h | LTE_SC_enh_L1-Perf | PCG-32 | Huawei | Elean FAN (fanxiaoan@huawei.com) | Rel-12 | RP-62 | Issam | Small cell | LTE_SC_enh_L1-Perf | RP-141632 |
| 1108 | 222 | **Inter-eNB Coordinated Multi-Point (CoMP) for LTE** | 264d? | 2013-12-15 A | 2014-12-15 A | 100% |  | 2014-03-14 | 2014-09-12 | 130.65d? |  |  | R3; R1 | 4738.38h | 4738.38h | COMP_LTE_IeNB | PCG-32 | Samsung | Sung Hwan Won (sunghwan.won@samsung.com) | Rel-12 | RP-62 | Juha |  | COMP_LTE_IeNB |  |
| 1109 | 222.1 | Core part: Inter-eNB Coordinated Multi-Point (CoMP) for LTE | 165.5d? | 2013-12-15 A | 2014-12-15 A | 100% |  | 2014-03-14 | 2014-09-12 | 100.5d? |  | finish no earlier than 2014-12-15 | R3; R1 | 2648h | 2648h | COMP_LTE_IeNB-Core | PCG-32 | Samsung | Sung Hwan Won (sunghwan.won@samsung.com) | Rel-12 | RP-62 | Juha |  | COMP_LTE_IeNB-Core | RP-140597 |
| 1110 | 223 | **Smart Congestion Mitigation in E-UTRAN** | 139d? | 2014-03-05 A | 2014-09-12 A | 100% |  | 2014-03-05 | 2014-09-12 | 138d? |  |  | R2; S1; C1 | 4984h | 4984h | SCM_LTE | PCG-32 | LG Electronics | youngdae.lee@lge.com | Rel-12 | RP-63 | Yong-Jun |  | SCM_LTE |  |
| 1111 | 223.1 | Core part: Smart Congestion Mitigation in E-UTRAN | 137d? | 2014-03-06 A | 2014-09-12 A | 100% |  | 2014-03-06 | 2014-09-12 | 137d? |  | finish no earlier than 2014-09-12 | R2 | 1096h | 1096h | SCM_LTE-Core | PCG-32 | LG Electronics | youngdae.lee@lge.com | Rel-12 | RP-63 | Yong-Jun |  | SCM_LTE-Core | RP-141292 |
| 1112 | 223.2 | Stage 1 Prioritization of Multimedia Telephony (MMTel) and Mobile Originating-SMS for Access Class Barring (ACB) | 3d? | 2014-03-05 A | 2014-03-07 A | 100% |  | 2014-03-05 | 2014-03-07 | 3d? |  | finish no earlier than 2013-12-11 | S1 | 24h | 24h |  | PCG-33 |  |  | Rel-12 | CP-64 |  |  |  |  |
| 1113 | 223.3 | CT aspects of Smart Congestion Mitigation in E-UTRAN (Stage 3) | 66d? | 2014-06-13 A | 2014-09-11 A | 100% |  | 2014-06-13 | 2014-09-12 | 66d? |  | start no earlier than 2014-06-13 | C1 | 528h | 528h | SCM_LTE-CT | PCG-33 | LG Electronics | Kim, Jaehyun (jaehyun7.kim@lge.com) | Rel-12 | CP-64 |  |  | SCM_LTE-CT |  |
| 1114 | 224 | **Positioning Enhancements for RF Pattern Matching in E-UTRA** | 36d? | 2014-04-25 A | 2014-06-13 A | 100% |  | 2014-04-25 | 2014-06-13 | 36d? |  |  | R3; R2 | 1152h | 1152h | LCS_LTE_RFPMT | PCG-32 | Polaris Wireless | Gordon Scot (sgordon@polariswireless.com) | Rel-12 | RP-63 | Juha |  | LCS_LTE_RFPMT |  |
| 1115 | 224.1 | Core part: Positioning Enhancements for RF Pattern Matching in E-UTRA | 36d? | 2014-04-25 A | 2014-06-13 A | 100% |  | 2014-04-25 | 2014-06-13 | 36d? |  | finish no earlier than 2014-06-13 | R3; R2 | 576h | 576h | LCS_LTE_RFPMT-Core | PCG-32 | Polaris Wireless | Gordon Scot (sgordon@polariswireless.com) | Rel-12 | RP-63 | Juha |  | LCS_LTE_RFPMT-Core | RP-140591 |
| 1116 | 225 | **Network-Assisted Interference Cancellation and Suppression for LTE** | 333d? | 2014-03-11 A | 2015-06-15 | 44% | 186.19d? | 2014-03-06 | 2015-06-12 | 332d? | 523d |  | R1; R2; R4; R3 | 16123.9h | 4644.31h | LTE_NAICS | PCG-32 | MediaTek | Craig.Burnet@mediatek.com | Rel-12 | RP-63 | Patrick |  | LTE_NAICS |  |
| 1117 | 225.1 | Core part: Network-Assisted Interference Cancellation and Suppression for LTE | 113.67d? | 2014-07-11 A | 2014-12-15 A | 100% |  | 2014-07-11 | 2014-09-12 | 45.67d? |  | finish no earlier than 2014-12-15 | R1; R2; R4; R3 | 2803.87h | 2803.87h | LTE_NAICS-Core | PCG-32 | MediaTek | Craig.Burnet@mediatek.com | Rel-12 | RP-63 | Patrick |  | LTE_NAICS-Core | RP-141621 |
| 1118 | 225.2 | Perf. part: Network-Assisted Interference Cancellation and Suppression for LTE | 333d? | 2014-03-11 A | 2015-06-15 | 25% | 249.75d? | 2014-03-06 | 2015-06-12 | 332d? | 523d | finish no earlier than 2015-06-15 | R4 | 2664h | 666h | LTE_NAICS-Perf | PCG-32 | MediaTek | Craig.Burnet@mediatek.com | Rel-12 | RP-63 | Issam |  | LTE_NAICS-Perf | RP-141621 |
| 1119 | 226 | **Performance requirements of interference cancellation and suppression receiver for SU-MIMO** | 270d? | 2014-03-06 A | 2015-03-15 | 80% | 54d? | 2014-03-06 | 2015-03-13 | 267d? | 589d |  | R4 | 4296h | 3436.8h | LTE_SUMIMO_RX | PCG-32 | Huawei | Qian Cheng (Q.Cheng@Huawei.com) | Rel-12 | RP-63 | Issam |  | LTE_SUMIMO_RX |  |
| 1120 | 226.1 | Perf. part: Performance requirements of interference cancellation and suppression receiver for SU-MIMO | 267d? | 2014-03-06 A | 2015-03-15 | 80% | 53.4d? | 2014-03-06 | 2015-03-13 | 267d? | 589d | finish no earlier than 2015-03-15 | R4 | 2136h | 1708.8h | LTE_SUMIMO_RX-Perf | PCG-32 | Huawei | Qian Cheng (Q.Cheng@Huawei.com) | Rel-12 | RP-63 | Issam |  | LTE_SUMIMO_RX-Perf | RP-141255 |
| 1121 | 227 | **HSPA signalling enhancements for more efficient resource usage for LCR** | 274d? | 2012-12-11 A | 2013-12-20 A | 100% |  | 2012-12-10 | 2013-12-06 | 265d? |  |  | R1; R2; R3; R4 | 16832h | 16832h | LCR_TDD_HSPA_sign_enh | PCG-30 | CATT | Yanping Xing (xingyanping@catt.cn) | Rel-12 | RP-58 | Patrick |  | LCR_TDD_HSPA_sign_enh |  |
| 1122 | 227.1 | Core part: HSPA signalling enhancements for more efficient resource usage for LCR TDD | 270d? | 2012-12-15 A | 2013-12-20 A | 100% |  | 2012-12-10 | 2013-12-06 | 265d? |  | finish no earlier than 2013-12-15 | R1; R2; R3 | 6480h | 6480h | LCR_TDD_HSPA_sign_enh-Core | PCG-30 | CATT | Yanping Xing (xingyanping@catt.cn) | Rel-12 | RP-58 | Patrick |  | LCR_TDD_HSPA_sign_enh-Core | RP-131499 |
| 1123 | 227.2 | Perf. part: HSPA signalling enhancements for more efficient resource usage for LCR TDD | 198d? | 2012-12-11 A | 2013-09-06 A | 100% |  | 2012-12-11 | 2013-09-06 | 198d? |  | finish no earlier than 2013-09-06 | R4 | 1584h | 1584h | LCR_TDD_HSPA_sign_enh-Perf | PCG-30 | CATT | Yanping Xing (xingyanping@catt.cn) | Rel-12 | RP-58 | Issam |  | LCR_TDD_HSPA_sign_enh-Perf | RP-130968 |
| 1124 | 228 | **HNB Positioning for UTRA** | 127d? | 2013-06-18 A | 2013-12-06 A | 100% |  | 2013-06-18 | 2013-12-06 | 127d? |  |  | R3 | 2032h | 2032h | UTRA_HNB_Pos | PCG-31 | Alcatel-Lucent | Martin.Warner@alcatel-lucent.com | Rel-12 | RP-60 | Juha | HNB | UTRA_HNB_Pos |  |
| 1125 | 228.1 | Core part: HNB Positioning for UTRA | 127d? | 2013-06-18 A | 2013-12-06 A | 100% |  | 2013-06-18 | 2013-12-06 | 127d? |  | finish no earlier than 2013-12-06 | R3 | 1016h | 1016h | UTRA_HNB_Pos-Core | PCG-31 | Alcatel-Lucent | Martin.Warner@alcatel-lucent.com | Rel-12 | RP-60 | Juha | HNB | UTRA_HNB_Pos-Core | RP-131974 |
| 1126 | 229 | **Dedicated Channel (DCH) enhancements for UMTS** | 332d? | 2013-09-15 A | 2014-12-17 A | 100% |  | 2013-09-10 | 2014-12-05 | 326d? |  |  | R1; R2; R3; R4 | 16960h | 16960h | UTRA_DCHenh | PCG-31 | Qualcomm | arjunb@qti.qualcomm.com | Rel-12 | RP-61 | Patrick |  | UTRA_DCHenh |  |
| 1127 | 229.1 | Core part: Dedicated Channel (DCH) enhancements for UMTS | 115.25d? | 2013-11-18 A | 2014-09-12 A | 100% |  | 2013-11-18 | 2014-09-12 | 115.25d? |  | finish no earlier than 2014-09-12 | R1; R2; R3; R4 | 3688h | 3688h | UTRA_DCHenh-Core | PCG-31 | Qualcomm | arjunb@qti.qualcomm.com | Rel-12 | RP-61 | Patrick |  | UTRA_DCHenh-Core | RP-141137 |
| 1128 | 229.2 | Perf. part: Dedicated Channel (DCH) enhancements for UMTS | 331d? | 2013-09-15 A | 2014-12-17 A | 100% |  | 2013-09-10 | 2014-12-05 | 326d? |  | finish no earlier than 2014-12-15 | R4 | 2648h | 2648h | UTRA_DCHenh-Perf | PCG-31 | Qualcomm | arjunb@qti.qualcomm.com | Rel-12 | RP-61 | Issam |  | UTRA_DCHenh-Perf | RP-141137 |

Notes:
- 1105: Triggered by TR 36.872 Study on Small Cell Enhancements for E-UTRA and E-UTRAN Physical-layer aspects (UID_580041) / Impacted TSs and TRs: LTE
- 1106: CD:Thu 11/12/14->Mon 15/12/14; Compl:78%->100% / Impacted TSs and TRs: 36.101, 36.104, 36.133, 36.211, 36.212, 36.213, 36.214, 36.300, 36.306, 36.321, 36.331, 36.413, 36.423, 36.443
- 1107: CD:Fri 13/03/15->Sun 15/03/15; Compl:20%->40% / Impacted TSs and TRs: 36.101, 36.104, 36.133, 36.141
- 1108: Stage 3. Rel-11 did not address support of a network interface for CoMP involving multiple eNBs with non-ideal backhaul (affected operators might not take advantage of performance benefit from inter-eNB CoMP operation). / Impacted TSs and TRs: LTE
- 1109: CD:Thu 11/12/14->Mon 15/12/14; Compl:85%->100% / Impacted TSs and TRs: 36.300, 36.423
- 1110: follow-up of TR 36.848 FS_SCM_LTE / Impacted TSs and TRs: LTE
- 1111: RP#65 completed / Impacted TSs and TRs: 36.331
- 1112: SP#63 SP-140065 CR under TEI12 / Impacted TSs and TRs: 22.011
- 1113: CP#65 completed / Impacted TSs and TRs: 24.173, 24.301, 24.341, 27.007
- 1114: follow-up of TR 36.809 FS_LCS_LTE_RFPMT / Impacted TSs and TRs: LTE
- 1115: RP#64 completed / Impacted TSs and TRs: 36.305, 36.455
- 1116: follow-up of TR 36.866 FS_LTE_NAICS / Impacted TSs and TRs: LTE
- 1117: CD:Mon 08/12/14->Mon 15/12/14; Compl:95%->100% / Impacted TSs and TRs: 36.211, 36.213, 36.300, 36.331, 36.423
- 1118: CD:Fri 12/06/15->Mon 15/06/15; Compl:0%->25% / Impacted TSs and TRs: 36.101
- 1119: no Core part / Impacted TSs and TRs: LTE
- 1120: CD:Fri 13/03/15->Sun 15/03/15; Compl:50%->80% / Impacted TSs and TRs: 36.101
- 1121: Stage 2/3. Triggered by Rel-11 TR 25.874 Study on HSPA feedback and signalling efficiency enhancements for LCR TDD (FS_LCRTDD_HSPAenh) UID_540026 / Impacted TSs and TRs: UTRA
- 1122: Prev CD:Fri 06/12/13; Prev %:100% / Impacted TSs and TRs: 25.222, 25.224, 25.331, 25.423, 25.433
- 1123: RP#61 completed / Impacted TSs and TRs: 25.102
- 1124: RP#62 completed / Impacted TSs and TRs: UTRA
- 1125: RP#62 closed at 85% completion. Not completed work on HNB positioning / No consensus (may be TEI12, if contribution and support). Updated WID RP-130868=>RP-132037 (HNB positiong was not addressed in this WI, however it was NOT remoded from the WID) / Impacted TSs and TRs: 25.305, 25.467, new TS 25.470
- 1126: Triggered by Rel-12 TR 25.702 Study on Dedicated Channel (DCH) enhancements for UMTS (FS_UTRA_DCHenh) UID_580040. Stage 2/3 / Impacted TSs and TRs: UTRA
- 1127: RP#65 completed / Impacted TSs and TRs: 25.101, 25.104, 25.133, 25.211, 25.212, 25.213, 25.214, 25.215, 25.306, 25.308, 25.321, 25.331, 25.423, 25.433
- 1128: Prev CD:Thu 11/12/14; Prev %:35% / Impacted TSs and TRs: 25.101, 25.104, 25.133

| ID | WBS | Task | Duration | Start | Finish | Complete | Remaining | Baseline start | Baseline finish | Baseline duration | Total slack | Constraint | Resources | Work | Actual work | Acronym | PCG approved | WI rapporteur name | WI rapporteur e-mail | Release | TSG approved | MCC resp | Acronym_3GU_Export | Status Report | Special Focus Doc | PCG stopped | TSG stopped |
| --- | --- | --- | --- | --- | --- | --- | --- | --- | --- | --- | --- | --- | --- | --- | --- | --- | --- | --- | --- | --- | --- | --- | --- | --- | --- | --- | --- |
| 1129 | 230 | **UMTS Mobility enhancements for heterogeneous networks** | 237.85d? | 2013-07-23 A | 2014-06-13 A | 100% |  | 2013-07-23 | 2014-06-13 | 237.85d? |  |  | R2; R3; R4 | 8040h | 8040h | UTRA_HetNet_mob | PCG-31 | Huawei | Xudong Yang (yangxudong@huawei.com) | Rel-12 | RP-61 | Yong-Jun | UTRA_HetNet_mob |  |  |  |  |
| 1130 | 230.1 | Core part: UMTS Mobility enhancements for heterogeneous networks | 67d? | 2013-07-23 A | 2014-06-13 A | 100% |  | 2013-07-23 | 2014-06-13 | 67d? |  | finish no earlier than 2014-06-13 | R2; R3; R4 | 1608h | 1608h | UTRA_HetNet_mob-Core | PCG-31 | Huawei | Xudong Yang (yangxudong@huawei.com) | Rel-12 | RP-61 | Yong-Jun | UTRA_HetNet_mob-Core | RP-140636 |  |  |  |
| 1131 | 230.2 | Perf. part: UMTS Mobility enhancements for heterogeneous networks | 201d? | 2013-09-09 A | 2014-06-13 A | 100% |  | 2013-09-09 | 2014-06-13 | 201d? |  | finish no earlier than 2014-06-13 | R4 | 1608h | 1608h | UTRA_HetNet_mob-Perf | PCG-31 | Huawei | Xudong Yang (yangxudong@huawei.com) | Rel-12 | RP-61 | Issam | UTRA_HetNet_mob-Perf | RP-140636 |  |  |  |
| 1132 | 231 | **UMTS Heterogeneous Networks enhancements** | 270d? | 2013-12-06 A | 2014-12-15 A | 100% |  | 2013-12-06 | 2014-12-05 | 262d? |  |  | R1; R2; R3; R4 | 12368h | 12368h | UTRA_HetNet_enh | PCG-32 | Huawei | carmela.cozzo@huawei.com | Rel-12 | RP-62 | Patrick | UTRA_HetNet_enh |  |  |  |  |
| 1133 | 231.1 | Core part: Heterogeneous Networks enhancements | 202d? | 2013-12-06 A | 2014-09-12 A | 100% |  | 2013-12-06 | 2014-09-12 | 202d? |  | finish no earlier than 2014-09-15 | R1 | 1616h | 1616h | UTRA_HetNet_enh-Core | PCG-32 | Huawei | carmela.cozzo@huawei.com | Rel-12 | RP-62 | Patrick | UTRA_HetNet_enh-Core | RP-141702 |  |  |  |
| 1134 | 231.2 | Perf. part: Heterogeneous Networks enhancements | 264d? | 2013-12-15 A | 2014-12-15 A | 100% |  | 2013-12-09 | 2014-12-05 | 261d? |  | start no earlier than 2013-12-15 | R4 | 2112h | 2112h | UTRA_HetNet_enh-Perf | PCG-32 | Huawei | carmela.cozzo@huawei.com | Rel-12 | RP-62 | Issam | UTRA_HetNet_enh-Perf | RP-141702 |  |  |  |
| 1135 | 232 | **Enhanced Broadcast of System Information** | 272d? | 2013-12-06 A | 2014-12-16 A | 100% |  | 2013-12-06 | 2014-12-05 | 262d? |  |  | R2; R1; R3; R4 | 16425.6h | 16425.6h | UTRA_SIBenh | PCG-32 | Ericsson | martin.van.der.zee@ericsson.com | Rel-12 | RP-62 | Yong-Jun | UTRA_SIBenh |  |  |  |  |
| 1136 | 232.1 | Core part: Enhanced Broadcast of System Information | 174.8d? | 2013-12-06 A | 2014-09-12 A | 100% |  | 2013-12-06 | 2014-09-12 | 174.8d? |  | finish no earlier than 2014-09-12 | R2; R1; R3; R4 | 5593.6h | 5593.6h | UTRA_SIBenh-Core | PCG-32 | Ericsson | martin.van.der.zee@ericsson.com | Rel-12 | RP-62 | Yong-Jun | UTRA_SIBenh-Core | RP-141230 |  |  |  |
| 1137 | 232.2 | Perf. part: Enhanced Broadcast of System Information | 266d? | 2013-12-15 A | 2014-12-16 A | 100% |  | 2013-12-09 | 2014-12-05 | 261d? |  | finish no earlier than 2014-12-15 | R4 | 2128h | 2128h | UTRA_SIBenh-Perf | PCG-32 | Ericsson | martin.van.der.zee@ericsson.com | Rel-12 | RP-62 | Issam | UTRA_SIBenh-Perf | RP-141230 |  |  |  |
| 1138 | 233 | **Further Enhanced Uplink (EUL) enhancements** | 332d? | 2013-12-15 A | 2015-03-18 | 86% | 46.25d? | 2013-12-09 | 2014-12-05 | 261d? | 586d |  | R2 | 13720h | 11152.6h | EDCH_enh | PCG-32 | Ericsson | mark.curran@ericsson.com | Rel-12 | RP-62 | Yong-Jun | EDCH_enh |  |  |  |  |
| 1139 | 233.1 | Core part: Further Enhanced Uplink (EUL) enhancements | 263d? | 2013-12-15 A | 2014-12-15 A | 100% |  | 2014-04-29 | 2014-09-12 | 99d? |  | finish no earlier than 2014-12-15 | R2; R1; R3; R4 | 8416h | 8416h | EDCH_enh-Core | PCG-32 | Ericsson | mark.curran@ericsson.com | Rel-12 | RP-62 | Yong-Jun | EDCH_enh-Core | RP-141684 |  |  |  |
| 1140 | 233.2 | Perf. part: Further Enhanced Uplink (EUL) enhancements | 331d? | 2013-12-15 A | 2015-03-18 | 75% | 82.75d? | 2013-12-09 | 2014-12-05 | 261d? | 586d | finish no earlier than 2015-03-15 | R4 | 2648h | 1986h | EDCH_enh-Perf | PCG-32 | Ericsson | mark.curran@ericsson.com | Rel-12 | RP-62 | Issam | EDCH_enh-Perf | RP-141684 |  |  |  |
| 1141 | 234 | (Small) Technical Enhancements and Improvements for Rel-12 | 197.5d? | 2012-12-25 A | 2014-09-16 A | 100% |  | 2012-12-25 | 2014-09-17 | 197.5d? |  | finish no earlier than 2014-09-17 | SP; CP; RP; GP | 6320h | 6320h | TEI12 | PCG-29 |  |  | Rel-12 | RP-56 |  | TEI12 |  |  |  |  |
| 1142 | 235 | (IETF) (Small) Technical Enhancements and Improvements for Rel-12 (draft-ietf-insipid-session-id) | 131d? | 2014-06-13 A | 2014-12-09 | 50% | 65.5d? |  |  |  | 657d | start no earlier than 2014-06-13 | C1-IETF | 1048h | 524h | TEI12_IETF |  | Alcatel-Lucent |  | Rel-12 |  |  |  |  |  |  |  |
| 1143 | 236 | Test - (Small) Technical Enhancements and Improvements for Rel-12 | 295.5d? | 2014-10-24 A | 2015-12-11 A | 100% |  | 2014-10-24 | 2015-12-11 | 295.5d? |  | finish no earlier than 2015-12-11 | R5; G3new | 4728h | 4728h | TEI12_Test | PCG-31 |  |  | Rel-12 | RP-61 | Ingbert | TEI12_Test |  |  |  |  |
| 1144 | 237 | Release 12 Studies | 296.5d? | 2013-08-05 A | 2014-09-17 | 80% | 59.3d? | 2013-08-05 | 2014-09-17 | 296.5d? | 718d | finish no earlier than 2014-09-17 | SP; CP; GP; RP | 9488h | 7590.4h |  |  |  |  | Rel-12 |  |  |  |  |  |  |  |
| 1145 | 238 | Study on Alternatives to E.164 for Machine-Type Communications | 513d? | 2010-03-25 A | 2012-03-07 A | 100% |  | 2010-03-25 | 2012-03-07 | 513d? |  | finish no earlier than 2012-03-07 | S1 | 4080h | 4080h | FS_AMTC | PCG-24 | T-Mobile USA | gary.jones@T-Mobile.com | Rel-12 | SP-47 | Alain | FS_AMTC |  | MTC, M2M |  |  |
| 1146 | 239 | Study on enhancements for Machine-Type Communications (MTC) | 720d? | 2010-06-10 A | 2013-03-06 A | 100% |  | 2010-06-10 | 2013-03-06 | 720d? |  | finish no earlier than 2013-03-06 | S1 | 5751.26h | 5751.26h | FS_MTCe | PCG-25 | Huawei | laurence.meriau@huawei.com | Rel-12 | SP-48 | Alain | FS_MTCe |  | MTC, M2M |  |  |
| 1147 | 240 | Study on Integration of Single Sign-On (SSO) frameworks with 3GPP networks | 383d? | 2010-09-23 A | 2012-03-07 A | 100% |  | 2010-09-23 | 2012-03-07 | 383d? |  | finish no earlier than 2011-09-08 | S1 | 3041.15h | 3041.15h | FS_SSO_Int | PCG-25 | InterDigital | christopher.wallace@interdigital.com | Rel-12 | SP-49 | Alain | FS_SSO_Int |  |  |  |  |
| 1148 | 241 | Study on Continuity of Data Sessions to Local Networks | 262.85d? | 2010-12-16 A | 2011-12-14 A | 100% |  | 2010-12-16 | 2011-12-14 | 262.85d? |  | finish no earlier than 2011-12-14 | S1 | 2084.27h | 2084.27h | FS_CSN | PCG-26 | NEC | joerg.swetina@neclab.eu | Rel-12 | SP-50 | Alain | FS_CSN |  |  |  |  |
| 1149 | 242 | Study on non-MTC Mobile Data Applications Impacts | 262.77d? | 2010-12-16 A | 2011-12-14 A | 100% |  | 2010-12-16 | 2011-12-14 | 262.77d? |  | finish no earlier than 2011-12-14 | S1 | 2083.59h | 2083.59h | FS_MODAI | PCG-26 | Huawei, China Mobile | Amar Deol (adeol@huawei.com), Gang Li | Rel-12 | SP-50 | Alain | FS_MODAI |  |  |  |  |
| 1150 | 243 | Study on Proximity-based Services | 384d? | 2011-09-22 A | 2013-03-05 A | 100% |  | 2011-09-22 | 2013-03-05 | 384d? |  | finish no earlier than 2012-12-12 | S1 | 3045.82h | 3045.82h | FS_ProSe | PCG-27 | Qualcomm | Rich Hovey (rhovey@qualcomm.com) | Rel-12 | SP-53 | Alain | FS_ProSe |  | Public Safety (A-A) |  |  |
| 1151 | 244 | Study on User Plane Congestion management | 198d? | 2011-12-14 A | 2012-09-12 A | 100% |  | 2011-12-14 | 2012-09-12 | 198d? |  | finish no earlier than 2012-09-12 | S1 | 1568h | 1568h | FS_UPCON | PCG-28 | KDDI | John Visser (jvisser@rogers.com) | Rel-12 | SP-54 | Alain | FS_UPCON |  |  |  |  |
| 1152 | 245 | Study on RAN Sharing Enhancements | 401d? | 2011-12-14 A | 2013-06-19 A | 100% |  | 2011-12-14 | 2013-06-19 | 401d? |  | finish no earlier than 2013-06-19 | S1 | 3192h | 3192h | FS_RSE | PCG-28 | NEC | joerg.swetina@neclab.eu | Rel-12 | SP-54 | Alain | FS_RSE |  |  |  |  |
| 1153 | 246 | Deleted - Study on UICC/USIM enhancements | 588d? | 2009-12-10 A | 2012-03-07 A | 100% |  | 2009-12-10 | 2012-03-07 | 588d? |  | finish no earlier than 2012-03-07 | S1 | 4704h | 4704h | FS_U2e | PCG-24 | Giesecke & Devrient | ilario.macchi@gi-de.com | Rel-12 | SP-46 | Alain | FS_U2e |  |  | PCG-28 | SP-55 |

Notes:
- 1129: Triggered by Rel-12 TR 25.800 Study on UMTS heterogeneous networks (FS_UTRA_hetnet) UID_570024. Stage 2/3 / Impacted TSs and TRs: UTRA
- 1130: RP#64 completed. TS 25.300v100 for 1-step Approval / Impacted TSs and TRs: 25.101, 25.104, 25.133, 25.141, 25.304, 25.306, 25.331, 25.433, new TS 25.300
- 1131: RP#64 completed / Impacted TSs and TRs: 25.101, 25.104, 25.133, 25.141
- 1132: Triggered by the 2nd part of TR 25.800 (FS_UTRA_HetNet); the 1st part is addressed by UTRA_HetNet_mob UID_610026 / Impacted TSs and TRs: UTRA
- 1133: RP#65 completed. Updated WID RP-140463=>RP-141701 / Impacted TSs and TRs: 25.101, 25.211, 25.212, 25.213, 25.214, 25.300, 25.302, 25.306, 25.308, 25.319, 25.331, 25.423, 25.433
- 1134: Prev CD:Thu 11/12/14; Prev %:0% / Impacted TSs and TRs: 25.101, 25.104, 25.133, 25.141
- 1135: Triggered by Rel-12 UTRA TR 25.704 Study on Enhanced Broadcast of System Information (FS_UTRA_SIBenh) / Impacted TSs and TRs: UTRA
- 1136: RP#65 completed / Impacted TSs and TRs: 25.211, 25.212 , 25.213, 25.214, 25.301, 25.302, 25.304, 25.306, 25.321, 25.331, 25.433
- 1137: Prev CD:Thu 11/12/14; Prev %:30% / Impacted TSs and TRs: 25.101, 25.104, 25.133, 25.141
- 1138: Triggered by Rel-12 UTRA TR 25.700 Study on Further Enhanced Uplink (EUL) enhancements (FS_EDCH_enh) / Impacted TSs and TRs: UTRA
- 1139: Prev CD:Thu 11/12/14; Prev %:95% / Impacted TSs and TRs: 25.211, 25.212, 25.214, 25.304, 25.306, 25.308, 25.319, 25.321, 25.331, 25.423, 25.425, 25.433, 25.435
- 1140: Prev CD:Thu 11/12/14; Prev %:50% / Impacted TSs and TRs: 25.101, 25.104, 25.133, 25.141
- 1141: -
- 1142: work in progress / Impacted TSs and TRs: draft-ietf-insipid-session-id
- 1143: -
- 1144: -
- 1145: SP#55 completed. Determine an alternative to E.164 for identifying individual devices and route messages between those devices / Impacted TSs and TRs: 22.988
- 1146: SP#59 completed. TR 22.888 v100 for Information & Approval. Study addition of new MTC-related use cases and functionality and improvements to existing requirements in TS 22.368 / Impacted TSs and TRs: 22.888
- 1147: SP#55 completed. Linked to SA3 Study on Single Sign On (SSO) Application Security for IMS - based on SIP Digest (UID_480048), SA3 TR 33.924 Extended Identity Management (GBA-IdM) and SA3 TR 33.980 (LibSec) / Impacted TSs and TRs: 22.895
- 1148: SP#54 completed. Linked to SA1 Rel-11 Feature UID_490030 SIPTO Service Continuity of IP Data Session (SIPTO_SC) / Impacted TSs and TRs: 22.896
- 1149: SP#54 completed. Linked to UID_490036 SA2 Rel-11 TR 23.843 Study on Core Network Overload solutions (FS_CNO) / Impacted TSs and TRs: 22.801
- 1150: SP#59 completed / Impacted TSs and TRs: 22.803
- 1151: SP#57 completed. Linked to SAPP (Service Awareness and Privacy Policies), FS_UMONC (Study on Usage Monitoring Control Enhancement), QoS_SSL (QoS Control Based on Subscriber Spending Limits) / Impacted TSs and TRs: 22.805
- 1152: SP#60 completed. Extend Rel-6 Network Sharing UID_31018 (basic scenarios of network/RAN sharing) to cover more complex scenarios that arise due to recent needs for more dynamic co-operation among operators / Impacted TSs and TRs: 22.852
- 1153: SP#55 work stopped. Triggered by GSMA Smart SIM and 3GNBK projects, and to evolve from traditional USAT to multimedia USIM toolkit support, particularly to Smart Card Web Server / Impacted TSs and TRs: 22.817

| ID | WBS | Task | Duration | Start | Finish | Complete | Remaining | Baseline start | Baseline finish | Baseline duration | Total slack | Constraint | Resources | Work | Actual work | Acronym | PCG approved | Impacted TSs and TRs | WI rapporteur name | WI rapporteur e-mail | Release | TSG approved | MCC resp | Acronym_3GU_Export | Special Focus Doc | PCG stopped | TSG stopped | Status Report |
| --- | --- | --- | --- | --- | --- | --- | --- | --- | --- | --- | --- | --- | --- | --- | --- | --- | --- | --- | --- | --- | --- | --- | --- | --- | --- | --- | --- | --- |
| 1154 | 247 | **Study on IMS based Peer-to-Peer Content Distribution Services (Stage 2)** | 587d? | 2010-09-23 A | 2012-12-12 A | 100% |  | 2010-09-23 | 2012-12-12 | 587d? |  |  | S2; S1; S3 | 19472h | 19472h | FS_IMS_P2P_CDS | PCG-25 | 23.844 | China Mobile | Yu Qing (yuqing@chinamobile.com) | Rel-12 | SP-49 | Maurice | FS_IMS_P2P_CDS |  |  |  |  |
| 1155 | 247.1 | SA1 part of Study on IMS based Peer-to-Peer Content Distribution Services (Stage 2) | 262d? | 2010-09-23 A | 2011-09-21 A | 100% |  | 2010-09-23 | 2011-09-21 | 262d? |  | finish no earlier than 2011-09-21 | S1 | 2080h | 2080h | FS_IMS_P2P_CDS | PCG-25 | 23.844 | China Mobile | Yu Qing (yuqing@chinamobile.com) | Rel-12 | SP-49 | Maurice |  |  |  |  |  |
| 1156 | 247.2 | SA2 part of Study on IMS based Peer-to-Peer Content Distribution Services (Stage 2) | 347d? | 2010-09-23 A | 2012-06-20 A | 100% |  | 2010-09-23 | 2012-06-20 | 347d? |  | finish no earlier than 2012-06-08 | S2 | 2776h | 2776h | FS_IMS_P2P_CDS | PCG-25 | 23.844 | China Mobile | Yu Qing (yuqing@chinamobile.com) | Rel-12 | SP-49 | Maurice |  |  |  |  |  |
| 1157 | 247.3 | SA3 part of Study on IMS based Peer-to-Peer Content Distribution Services (Stage 2) | 68d? | 2012-09-12 A | 2012-12-12 A | 100% |  | 2012-09-12 | 2012-12-12 | 68d? |  | finish no earlier than 2012-12-12 | S3 | 528h | 528h | FS_IMS_P2P_CDS | PCG-29 | 33.844 | China Mobile | Zhu Judy(zhuhongru@chinamobile.com) | Rel-12 | SP-57 | Mirko |  |  |  |  |  |
| 1158 | 248 | **Study on Core Network Overload solutions** | 852d? | 2010-09-23 A | 2013-12-11 A | 100% |  | 2010-09-23 | 2013-12-11 | 852d? |  |  | S2 | 18240.6h | 18240.6h | FS_CNO | PCG-25 | 23.843 | Huawei | Mirko.Schramm@huawei.com | Rel-12 | SP-49 | Maurice | FS_CNO |  |  |  |  |
| 1159 | 248.1 | Study on Core Network Overload solutions (Phase 1) | 587d? | 2010-09-23 A | 2012-12-12 A | 100% |  | 2010-09-23 | 2012-12-12 | 587d? |  | finish no earlier than 2012-12-12 | S2 | 4684.11h | 4684.11h | FS_CNO | PCG-25 | 23.843 | Huawei | Mirko.Schramm@huawei.com | Rel-12 | SP-49 | Maurice |  |  |  |  |  |
| 1160 | 248.2 | Study on Core Network Overload solutions (Phase 2) | 844d? | 2010-09-23 A | 2013-12-11 A | 100% |  | 2010-09-23 | 2013-12-11 | 844d? |  | finish no earlier than 2013-12-11 | S2 | 6744h | 6744h | FS_CNO | PCG-25 | 23.843 | Huawei | Mirko.Schramm@huawei.com | Rel-12 | SP-49 | Maurice |  |  |  |  |  |
| 1161 | 249 | Study on System Enhancements for Energy Efficiency | 399d? | 2010-12-16 A | 2012-06-20 A | 100% |  | 2010-12-16 | 2012-06-20 | 399d? |  | finish no earlier than 2012-06-20 | S2 | 3192h | 3192h | FS_SEEE | PCG-26 | 23.866 | Huawei | frank.mademann@huawei.com | Rel-12 | SP-50 | Maurice | FS_SEEE |  |  |  |  |
| 1162 | 250 | Study on S2a Mobility based On GTP and WLAN access to EPC | 657d? | 2011-03-23 A | 2013-09-11 A | 100% |  | 2011-03-23 | 2013-09-11 | 657d? |  | finish no earlier than 2013-09-11 | S2 | 5165.94h | 5165.94h | FS_SaMOG | PCG-26 | 23.852 | ZTE | Tricci So (tso@zteusa.com) | Rel-12 | SP-51 | Maurice | FS_SaMOG | WLAN |  |  |  |
| 1163 | 251 | Study on Optimized Offloading to WLAN in 3GPP-RAT Mobility | 326d? | 2012-06-18 A | 2013-09-11 A | 100% |  | 2012-06-18 | 2013-09-11 | 326d? |  | finish no earlier than 2013-09-11 | S2 | 2592h | 2592h | FS_WORM | PCG-29 | 23.890 | BlackBerry | Steve Barrett (sbarrett@blackberry.com) | Rel-12 | SP-56 | Maurice | FS_WORM | WLAN |  |  |  |
| 1164 | 252 | Study on Application Based Charging | 190d? | 2012-06-18 A | 2013-03-06 A | 100% |  | 2012-06-18 | 2013-03-06 | 190d? |  | finish no earlier than 2013-03-06 | S2 | 1520h | 1520h | FS_ABC | PCG-29 | 23.800 | Allot | Alla Goldner (agoldner@allot.com) | Rel-12 | SP-56 | Maurice | FS_ABC |  |  |  |  |
| 1165 | 253 | **Study on Multi Access PDN connectivity and IP flow Mobility** | 1141.96d? | 2008-08-08 A | 2012-12-12 A | 100% |  | 2008-08-08 | 2012-12-12 | 1141.96d? |  |  | S2; S1 | 27327.4h | 27327.4h | FS_MAPIM | PCG-21 | 23.861 | Qualcomm | Gerardo Giaretta (gerardog@qualcomm.com) | Rel-12 | SP-41 | Maurice | FS_MAPIM |  |  |  |  |
| 1166 | 253.1 | SA1 part of Study on Multi Access PDN connectivity and IP flow Mobility | 22d? | 2008-08-08 A | 2011-09-21 A | 100% |  | 2008-08-08 | 2011-09-21 | 22d? |  | finish no earlier than 2011-09-21 | S1 | 160h | 160h | FS_MAPIM | PCG-21 | 23.861 | Qualcomm | Gerardo Giaretta (gerardog@qualcomm.com) | Rel-12 | SP-41 | Maurice |  |  |  |  |  |
| 1167 | 253.2 | SA2 part of Study on Multi Access PDN connectivity and IP flow Mobility | 1113d? | 2008-09-18 A | 2012-12-12 A | 100% |  | 2008-09-18 | 2012-12-12 | 1113d? |  | finish no earlier than 2012-12-12 | S2 | 8896h | 8896h | FS_MAPIM | PCG-21 | 23.861 | Qualcomm | Gerardo Giaretta (gerardog@qualcomm.com) | Rel-12 | SP-41 | Maurice |  |  |  |  |  |
| 1168 | 254 | Deleted - Study on IP Flow Mobility support for S2a and S2b Interfaces | 190d? | 2012-06-18 A | 2013-03-06 A | 100% |  | 2012-06-18 | 2013-03-06 | 190d? |  | finish no earlier than 2013-03-06 | S2 | 1520h | 1520h | FS_NBIFOM | PCG-29 | 23.861 | ZTE | Tricci So (tso@zteusa.com) | Rel-12 | SP-56 | Maurice | FS_NBIFOM |  | PCG-30 | SP-59 |  |
| 1169 | 255 | Study on Extended IMS Media Plane Security features | 719d? | 2010-06-10 A | 2013-03-06 A | 100% |  | 2010-06-10 | 2013-03-06 | 719d? |  | finish no earlier than 2013-03-06 | S3 | 5736h | 5736h | FS_eMEDIASEC | PCG-25 | 33.829 | Vodafone | Aguibou.Barry@vodafone.com | Rel-12 | SP-48 | Mirko | FS_eMEDIASEC |  |  |  |  |
| 1170 | 256 | Deleted - Study on Firewall traversal (Stage 2) | 854d? | 2011-06-17 A | 2014-09-17 A | 100% |  | 2011-06-17 | 2014-09-17 | 854d? |  | finish no earlier than 2014-09-17 | S3 | 6832h | 6832h | FS_Fire | PCG-27 | 33.830 | Acme Packet | Prashant Kumar (PKumar@acmepacket.com) | Rel-12 | SP-53 | Mirko | FS_Fire |  | PCG-33 | SP-65 |  |
| 1171 | 257 | Study on Security on spoofed call detection and prevention (Stage 2) | 662d? | 2012-03-07 A | 2014-09-17 A | 100% |  | 2012-03-07 | 2014-09-17 | 662d? |  | finish no earlier than 2014-09-17 | S3 | 5296h | 5296h | FS_SPOOF | PCG-28 | 33.831 | China Mobile | lixiangjun@chinamobile.com | Rel-12 | SP-55 | Mirko | FS_SPOOF |  |  |  |  |
| 1172 | 258 | Study on Security Assurance Methodology for 3GPP Network Elements | 466d? | 2012-09-13 A | 2014-06-18 A | 100% |  | 2012-09-13 | 2014-06-18 | 466d? |  | finish no earlier than 2014-03-07 | S3 | 3696h | 3696h | FS_SECAM | PCG-29 | 33.805 | Orange | loic.habermacher@orange.com | Rel-12 | SP-57 | Mirko | FS_SECAM |  |  |  |  |
| 1173 | 259 | Study on Improved Support for Dynamic Adaptive Streaming over HTTP in 3GPP | 729d? | 2011-12-14 A | 2014-09-16 A | 100% |  | 2011-12-14 | 2014-09-17 | 729d? |  | finish no earlier than 2014-09-17 | S4 | 5824h | 5824h | FS_IS_DASH | PCG-28 | 26.938 | Qualcomm | c_tstock@qualcomm.com | Rel-12 | RP-54 | Paolo | FS_IS_DASH |  |  |  |  |
| 1174 | 260 | Study on HTML5 for a new presentation layer in 3GPP services | 266d? | 2013-09-12 A | 2014-09-16 A | 100% |  | 2013-09-12 | 2014-09-17 | 266d? |  | finish no earlier than 2014-09-17 | S4 | 2128h | 2128h | FS_HTML5 | PCG-31 | 26.907 | Samsung | Imed Bouazizi (i.bouazizi@sta.samsung.com) | Rel-12 | RP-61 | Paolo | FS_HTML5 |  |  |  |  |
| 1175 | 261 | Study on version handling | 716d? | 2010-03-25 A | 2012-12-12 A | 100% |  | 2010-03-25 | 2012-12-12 | 716d? |  | finish no earlier than 2012-12-12 | S5 | 5704h | 5704h | FS_OAM_VH | PCG-24 | 32.830 | Ericsson | thomas.tovinger@ericsson.com | Rel-12 | SP-47 | Mirko | FS_OAM_VH |  |  |  |  |
| 1176 | 262 | Study on management of Heterogeneous Networks | 852d? | 2011-03-23 A | 2014-06-18 A | 100% |  | 2011-03-23 | 2014-06-18 | 852d? |  | finish no earlier than 2014-06-18 | S5 | 6816h | 6816h | FS_OAM_HetNet | PCG-26 | 32.835 | Ericsson | ulf.hubinette@ericsson.com | Rel-12 | SP-51 | Mirko | FS_OAM_HetNet |  |  |  |  |
| 1177 | 263 | Study on OAM aspects of Network Sharing | 464d? | 2011-12-07 A | 2013-09-11 A | 100% |  | 2011-12-07 | 2013-09-11 | 464d? |  | finish no earlier than 2013-09-11 | S5 | 3696h | 3696h | FS_OAM_SHARE | PCG-28 | 32.851 | Alcatel-Lucent, Huawei | Padma.Sudarsan@alcatel-lucent.com, zoulan@huawei.com | Rel-12 | SP-54 | Mirko | FS_OAM_SHARE |  |  |  |  |
| 1178 | 264 | Study on Enhanced Network Management (NM) centralized Coverage and Capacity Optimization | 590d? | 2011-09-21 A | 2014-09-17 A | 100% |  | 2011-09-21 | 2014-09-17 | 590d? |  | finish no earlier than 2014-09-17 | S5 | 4712h | 4712h | FS_SON_NM_CCO | PCG-29 | 32.836 | Ericsson | robert.petersen@ericsson.com | Rel-12 | SP-56 | Mirko | FS_SON_NM_CCO | SON |  |  |  |
| 1179 | 265 | Study on WLAN management | 788d? | 2011-09-21 A | 2014-09-17 A | 100% |  | 2012-06-20 | 2014-09-17 | 590d? |  | finish no earlier than 2014-09-17 | S5 | 6304h | 6304h | FS_WLAN_OAM | PCG-29 | 32.841 | Intel | joey.chou@intel.com | Rel-12 | SP-56 | Mirko | FS_WLAN_OAM | WLAN |  |  |  |
| 1180 | 266 | Study on Alarm Management | 201d? | 2012-12-07 A | 2013-09-11 A | 100% |  | 2012-12-07 | 2013-09-11 | 201d? |  | finish no earlier than 2013-09-11 | S5 | 1592h | 1592h | FS_OAM_AM | PCG-30 | 32.859 | TeliaSonera | tommy.berggren@teliasonera.com | Rel-12 | SP-58 | Mirko | FS_OAM_AM |  |  |  |  |
| 1181 | 267 | Study on Indication of Network to Network Interface (NNI) Routeing scenarios in SIP requests | 400d? | 2012-12-10 A | 2014-06-13 A | 100% |  | 2012-12-10 | 2014-06-13 | 400d? |  | finish no earlier than 2014-03-06 | C3 | 3190.27h | 3190.27h | FS_NNI_RS | PCG-30 | 24.802 | Ericsson | Jan.Holm@ericsson.com | Rel-12 | CP-58 | Adrian | FS_NNI_RS |  |  |  |  |
| 1182 | 268 | Study on Diameter Overload Control Mechanisms | 464d? | 2012-01-05 A | 2014-09-11 A | 100% |  | 2012-01-05 | 2014-09-12 | 464d? |  | finish no earlier than 2014-09-12 | C4 | 3712h | 3712h | FS_DOCME | PCG-30 | 29.809 | Orange | lionel.morand@orange.com | Rel-12 | CP-58 | Kimmo | FS_DOCME |  |  |  |  |
| 1183 | 269 | Study on XML based access of AF to the PCRF | 203d? | 2013-03-01 A | 2013-12-04 A | 100% |  | 2013-03-01 | 2014-06-13 | 341d? |  | finish no earlier than 2014-06-13 | C3 | 1608h | 1608h | FS_XML_AF_PCRF | PCG-30 | 29.817 | Alcatel-Lucent | horst.brinkman@alcatel-lucent.com | Rel-12 | CP-59 | Adrian | FS_XML_AF_PCRF |  |  |  |  |
| 1184 | 270 | Study on Technical aspects on Roaming End-to-end scenarios with VoLTE IMS and other networks | 328d? | 2013-09-09 A | 2014-12-09 A | 100% |  | 2013-09-09 | 2014-09-12 | 266d? |  | finish no earlier than 2014-12-09 | C3 | 2624h | 2624h | FS_REVOLTE_IMS | PCG-31 | 29.949 | Deutsche Telekom | Roland Jesske (r.jesske@telekom.de) | Rel-12 | CP-61 | Adrian | FS_REVOLTE_IMS |  |  |  |  |
| 1185 | 271 | Study on Development of conformance requirements for the IP Multimedia Services Identity Module (ISIM) application support in ME | 263d? | 2013-12-09 A | 2014-12-09 | 30% | 184.1d? | 2013-12-09 | 2014-09-12 | 201d? | 657d | finish no earlier than 2014-12-09 | C6 | 2104h | 631.2h | FS_ISIM_CR | PCG-32 | 31.829 | Gemalto | ly-thanh.phan@gemalto.com | Rel-12 | CP-62 | Xavier | FS_ISIM_CR |  |  |  |  |
| 1186 | 272 | Study on Shared Data Update for Multiple Subscribers | 263d? | 2013-12-06 A | 2014-12-09 | 85% | 39.45d? | 2013-12-06 | 2014-09-12 | 201d? | 657d | finish no earlier than 2014-12-09 | C4 | 2104h | 1788.4h | FS_SHARED_SubData_UPD | PCG-32 | 29.854 | Huawei | Susan Shi (susan.shishufeng@huawei.com) | Rel-12 | CP-62 | Kimmo | FS_SHARED_SubData_UPD |  |  |  |  |
| 1187 | 273 | Study on GERAN improvements for Machine-Type Communications | 661d? | 2010-05-24 A | 2012-11-23 A | 100% |  | 2010-05-24 | 2012-11-23 | 661d? |  | finish no earlier than 2012-11-23 | G1; G2 | 10576h | 10576h | FS_NIMTC_GERAN | PCG-24 | 43.868 | Ericsson | paul.schliwa-bertling@ericsson.com | Rel-12 | GP-44 | Paolo | FS_NIMTC_GERAN | MTC, M2M |  |  |  |
| 1188 | 274 | Study on Voice services over Adaptive Multi-user channels on One Slot (VAMOS) enhancements | 267.67d? | 2010-10-27 A | 2014-05-30 A | 100% |  | 2010-10-27 | 2014-05-30 | 267.67d? |  | finish no earlier than 2014-05-30 | GP; G2; G1 | 6424h | 6424h | FS_eVAMOS | PCG-27 | 43.801 | China Mobile, Huawei | Chao Luo (chluo@huawei.com), dengjuan@chinamobile.com | Rel-12 | GP-50 | Paolo | FS_eVAMOS |  |  |  |  |
| 1189 | 275 | Study on GERAN enhancements for Mobile Data Applications | 430d? | 2011-04-04 A | 2014-08-29 A | 100% |  | 2011-04-04 | 2014-08-29 | 430d? |  | finish no earlier than 2014-08-29 | G2; G1 | 6880h | 6880h | FS_GERAN_eMDA | PCG-27 | 43.802 | Huawei | ming.fang@huawei.com | Rel-12 | GP-50 | Gert | FS_GERAN_eMDA |  |  |  |  |
| 1190 | 276 | Study on Inclusion of RF Pattern Matching Technologies as a positioning method in the E-UTRAN | 722d? | 2010-12-10 A | 2013-09-06 A | 100% |  | 2010-12-10 | 2013-09-06 | 722d? |  | finish no earlier than 2013-09-06 | R4 | 5776h | 5776h | FS_LCS_LTE_RFPMT | PCG-26 | LTE 36.809 | Polaris Wireless | Scot Gordon (sgordon@polariswireless.com) | Rel-12 | RP-50 | Issam | FS_LCS_LTE_RFPMT |  |  |  | RP-131082 |
| 1191 | 277 | Study on Provision of low-cost MTC UEs based on LTE | 462d? | 2011-09-19 A | 2013-06-14 A | 100% |  | 2011-09-19 | 2013-06-14 | 462d? |  | finish no earlier than 2013-06-14 | R1; R2; R4 | 11088h | 11088h | FS_LC_MTC_LTE | PCG-27 | LTE 36.888 | Vodafone | prakash.bhat@vodafone.com | Rel-12 | RP-53 | Patrick | FS_LC_MTC_LTE | MTC, M2M |  |  | RP-130583 |
| 1192 | 278 | Deleted - Study on Mobile Relay for E-UTRA | 881.5d? | 2005-05-19 A | 2014-06-23 A | 100% |  | 2005-05-19 | 2014-06-23 | 881.5d? |  | finish no earlier than 2014-06-23 | R3; R1 | 14104h | 14104h | FS_LTE_mobRelay | PCG-27 | LTE 36.836 | CATT | Haijing Hu (huhaijing@catt.cn) | Rel-12 | RP-53 | Juha | FS_LTE_mobRelay |  | PCG-33 | RP-64 | RP-140726 |
| 1193 | 279 | Study on Scenarios and Requirements of LTE Small Cell Enhancements for E-UTRA and E-UTRAN | 66d? | 2012-09-11 A | 2012-12-07 A | 100% |  | 2012-09-11 | 2012-12-07 | 66d? |  | finish no earlier than 2012-12-07 | RP | 528h | 528h | FS_LTE_SC_enh_req | PCG-29 | LTE 36.932 | China Mobile | Hai TANG (tanghai@chinamobile.com) | Rel-12 | RP-57 | Yong-Jun | FS_LTE_SC_enh_req | Small cell |  |  | RP-121651 |
| 1194 | 280 | Study on Small Cell Enhancements for E-UTRA and E-UTRAN – Physical-layer aspects | 265d? | 2012-09-11 A | 2013-09-06 A | 100% |  | 2012-09-11 | 2013-09-06 | 265d? |  | finish no earlier than 2013-09-06 | R1; R2; R4 | 6360h | 6360h | FS_LTE_SC_enh_L1 | PCG-30 | LTE 36.872 | Huawei | Elean Fan (fanxiaoan@huawei.com) | Rel-12 | RP-58 | Patrick | FS_LTE_SC_enh_L1 | Small cell |  |  | RP-131618 |
| 1195 | 281 | Study on Small Cell Enhancements for E-UTRA and E-UTRAN – Higher-layer aspects | 265d? | 2012-12-10 A | 2013-12-06 A | 100% |  | 2012-12-10 | 2013-12-06 | 265d? |  | finish no earlier than 2013-12-06 | R2; R3 | 4240h | 4240h | FS_LTE_SC_enh_hilayer | PCG-30 | LTE 36.842 | NTT DOCOMO | Hideaki Takahashi (h-takahashi@nttdocomo.co.jp) | Rel-12 | RP-58 | Yong-Jun | FS_LTE_SC_enh_hilayer | Small cell |  |  | RP-131619 |
| 1196 | 282 | Study on LTE Device-to-Device Proximity Services - Radio Aspects | 325d? | 2012-12-17 A | 2014-03-06 A | 100% |  | 2012-12-17 | 2014-03-06 | 325d? |  | finish no earlier than 2014-03-06 | R1; R2; R3; R4 | 10400h | 10400h | FS_LTE_D2D_Prox | PCG-30 | LTE 36.843 | Qualcomm | Shailesh Patil (patil@qti.qualcomm.com) | Rel-12 | RP-58 | Patrick | FS_LTE_D2D_Prox | Public Safety (A-A) |  |  | RP-140416 |
| 1197 | 283 | Study on 3D-channel model for Elevation Beamforming and FD-MIMO studies for LTE | 463d? | 2012-12-10 A | 2014-09-12 A | 100% |  | 2012-12-10 | 2014-09-12 | 463d? |  | finish no earlier than 2014-09-12 | R1 | 3704h | 3704h | FS_LTE_3D_channel | PCG-30 | LTE 36.873 | Nokia Networks | bishwarup.mondal@nsn.com | Rel-12 | RP-58 | Patrick | FS_LTE_3D_channel |  |  |  | RP-141206 |
| 1198 | 284 | Study on Energy Saving Enhancement for E-UTRAN | 397d? | 2012-12-10 A | 2014-06-13 A | 100% |  | 2012-12-10 | 2014-06-13 | 397d? |  | finish no earlier than 2014-06-13 | R3 | 3176h | 3176h | FS_Netw_Energy_enh_LTE | PCG-30 | LTE 36.887 | China Mobile | Kimba Dit Adamou, Boubacar (jinba@chinamobile.com) | Rel-12 | RP-58 | Juha | FS_Netw_Energy_enh_LTE |  |  |  | RP-140604 |
| 1199 | 285 | Study on Expansion of LTE_FDD_1670_US to include 1670-1680MHz Band for LTE in the US | 469d? | 2013-03-01 A | 2014-12-15 A | 100% |  | 2013-03-01 | 2014-09-12 | 403d? |  | finish no earlier than 2014-12-15 | R4 | 3752h | 3752h | FS_LTE_FDD_1670_US | PCG-30 | LTE 36.844 | LightSquared | masoud.olfat@lightsquared.com | Rel-13 | RP-59 | Issam | FS_LTE_FDD_1670_US |  |  |  | RP-141453 |
| 1200 | 286 | Study on Cell-specific Reference Signals (CRS) Interference Mitigation for homogenous deployments for LTE | 201d? | 2013-03-04 A | 2013-12-06 A | 100% |  | 2013-03-04 | 2013-12-06 | 201d? |  | finish no earlier than 2013-12-06 | R4 | 1608h | 1608h | FS_LTE_CRSIC | PCG-30 | LTE 36.863 | Ericsson | shaohua.li@ericsson.com | Rel-12 | RP-59 | Issam | FS_LTE_CRSIC |  |  |  | RP-131623 |
| 1201 | 287 | Study on Network-Assisted Interference Cancellation and Suppression for LTE | 265d? | 2013-03-08 A | 2014-03-06 A | 100% |  | 2013-03-08 | 2014-03-06 | 265d? |  | finish no earlier than 2014-03-06 | R1; R4 | 4240h | 4240h | FS_LTE_NAICS | PCG-30 | LTE 36.866 | MediaTek | jeff.zhuang@mediatek.com | Rel-12 | RP-59 | Patrick | FS_LTE_NAICS |  |  |  | RP-132108 |
| 1202 | 288 | Study on Coordinated Multi-Point (CoMP) operation for LTE with Non-Ideal Backhaul | 126d? | 2013-06-18 A | 2013-12-06 A | 100% |  | 2013-06-18 | 2013-12-06 | 126d? |  | finish no earlier than 2013-12-06 | R1 | 1008h | 1008h | FS_COMP_LTE_nibackhaul | PCG-31 | LTE 36.874 | Samsung | Hyojin Lee (hyojin257.lee@samsung.com) | Rel-12 | RP-60 | Patrick | FS_COMP_LTE_nibackhaul |  |  |  | RP-131626 |
| 1203 | 289 | Study on Group Communication for LTE | 130d? | 2013-09-10 A | 2014-03-06 A | 100% |  | 2013-09-10 | 2014-03-06 | 130d? |  | finish no earlier than 2014-03-06 | R2; R3 | 2080h | 2080h | FS_LTE_GC | PCG-31 | LTE 36.868 | Alcatel-Lucent | chandrika.worrall@alcatel-lucent.com | Rel-12 | RP-61 | Yong-Jun | FS_LTE_GC | Public Safety (A-A) |  |  | RP-140182 |
| 1204 | 290 | Study on Smart Congestion Mitigation in E-UTRAN | 130d? | 2013-09-09 A | 2014-03-06 A | 100% |  | 2013-09-09 | 2014-03-06 | 130d? |  | finish no earlier than 2014-03-06 | R2 | 1040h | 1040h | FS_SCM_LTE | PCG-31 | LTE 36.848 | LG Electronics | youngdae.lee@lge.com | Rel-12 | RP-61 | Yong-Jun | FS_SCM_LTE |  |  |  | RP-140102 |
| 1205 | 291 | Study on RAN aspects of RAN Sharing Enhancements for LTE | 136d? | 2013-12-06 A | 2014-06-13 A | 100% |  | 2013-12-06 | 2014-06-13 | 136d? |  | finish no earlier than 2014-06-13 | R3 | 1088h | 1088h | FS_RSE-RAN_LTE | PCG-32 | LTE 36.856 | NEC | Siva.Vakeesar@emea.nec.com | Rel-12 | RP-62 | Juha | FS_RSE-RAN_LTE |  |  |  | RP-140746 |
| 1206 | 292 | Study on RF and EMC requirements for active Antenna Array System (AAS) Base Station | 386d? | 2011-09-19 A | 2013-03-01 A | 100% |  | 2011-09-19 | 2013-03-01 | 386d? |  | finish no earlier than 2013-03-01 | R4; R1 | 6176h | 6176h | FS_AAS_BS_LTE_UTRA | PCG-27 | UTRA, LTE 37.840 | Huawei | Ronnie.zhang@huawei.com | Rel-12 | RP-53 | Issam | FS_AAS_BS_LTE_UTRA |  |  |  | RP-130124 |
| 1207 | 293 | Study on LTE-HRPD (High Rate Packet Data in 3GPP2) inter-RAT SON | 340d? | 2012-03-02 A | 2013-06-14 A | 100% |  | 2012-03-02 | 2013-06-14 | 340d? |  | finish no earlier than 2013-06-14 | R3 | 2712h | 2712h | FS_LTE_HRPD_SON | PCG-28 | UTRA, LTE 37.813 | China Telecom | Wu Jinlian (wujl@gsta.com) | Rel-12 | RP-55 | Juha | FS_LTE_HRPD_SON | SON |  |  | RP-130585 |
| 1208 | 294 | Study on Passive InterModulation (PIM) handling for UTRA and LTE Base Stations | 403d? | 2012-03-05 A | 2013-09-06 A | 100% |  | 2012-03-05 | 2013-09-06 | 403d? |  | finish no earlier than 2013-09-06 | R4; G1 | 6448h | 6448h | FS_BS_PIM | PCG-28 | UTRA, LTE 37.808 | Ericsson | johan.skold@ericsson.com | Rel-12 | RP-55 | Issam | FS_BS_PIM |  |  |  | RP-131076 |
| 1209 | 295 | Study on WLAN/3GPP Radio Interworking | 264d? | 2012-12-10 A | 2013-12-06 A | 100% |  | 2012-12-10 | 2013-12-06 | 264d? |  | finish no earlier than 2013-12-06 | R2 | 2104h | 2104h | FS_UTRA_LTE_WLAN_interw | PCG-30 | UTRA, LTE 37.834 | Intel | sasha.sirotkin@intel.com | Rel-12 | RP-58 | Yong-Jun | FS_UTRA_LTE_WLAN_interw | WLAN |  |  | RP-131611 |
| 1210 | 296 | Study on RAN Enhancements for UMTS/HSPA and LTE Interworking | 261d? | 2012-12-10 A | 2013-12-06 A | 100% |  | 2012-12-10 | 2013-12-06 | 261d? |  | finish no earlier than 2013-12-06 | R3 | 2088h | 2088h | FS_HSPA_LTE_interworking | PCG-30 | UTRA, LTE 37.852 | China Unicom | Meng Zhang (zhangmeng68@chinaunicom.cn) | Rel-12 | RP-58 | Juha | FS_HSPA_LTE_interworking |  |  |  | RP-131612 |
| 1211 | 297 | Study on Next-Generation SON for UTRA and LTE | 397d? | 2012-12-10 A | 2014-06-13 A | 100% |  | 2012-12-10 | 2014-06-13 | 397d? |  | finish no earlier than 2014-06-13 | R3 | 3176h | 3176h | FS_UTRA_LTE_NG_SON | PCG-30 | UTRA, LTE 37.822 | NSN | krzysztof.kordybach@nsn.com | Rel-12 | RP-58 | Juha | FS_UTRA_LTE_NG_SON | SON |  |  | RP-140747 |
| 1212 | 298 | Study on 2GHz FDD for UTRA and LTE in Region 1 (1980-2010MHz and 2170-2200MHz Bands) | 462d? | 2012-12-11 A | 2014-09-12 A | 100% |  | 2012-12-11 | 2014-09-12 | 462d? |  | finish no earlier than 2014-09-12 | R4 | 3696h | 3696h | FS_UTRA_LTE_1980_2170_REG1 | PCG-30 | UTRA, LTE 37.846 | DISH Network | johny.kim@dish.com, mariam.sorond@dish.com | Rel-12 | RP-58 | Issam | FS_UTRA_LTE_1980_2170_REG1 |  |  |  | RP-141099 |
| 1213 | 299 | Study on Base Station specification structure | 136d? | 2012-12-10 A | 2013-06-14 A | 100% |  | 2012-12-10 | 2013-06-14 | 136d? |  | finish no earlier than 2013-06-14 | R4 | 1088h | 1088h | FS_BSspec_struc | PCG-30 | UTRA, LTE, MSR 37.810 | Ericsson | johan.skold@ericsson.com | Rel-12 | RP-58 | Issam | FS_BSspec_struc |  |  |  | RP-130580 |
| 1214 | 300 | Study on RAN aspects of Machine Type and other mobile data applications Communications enhancements | 137d? | 2013-03-01 A | 2013-09-06 A | 100% |  | 2013-03-01 | 2013-09-06 | 137d? |  | finish no earlier than 2013-09-06 | R2 | 1096h | 1096h | FS_MTCe_RAN | PCG-30 | UTRA, LTE 37.869 | ZTE | sergio.parolari@zteitaly.com | Rel-12 | RP-59 | Yong-Jun | FS_MTCe_RAN | MTC, M2M |  |  | RP-131081 |
| 1215 | 301 | Study on UMTS heterogeneous networks | 331d? | 2012-06-12 A | 2013-09-06 A | 100% |  | 2012-06-12 | 2013-09-06 | 331d? |  | finish no earlier than 2013-09-06 | R1; R2; R3 | 7944h | 7944h | FS_UTRA_HetNet | PCG-29 | UTRA 25.800 | Huawei | carmela.cozzo@huawei.com | Rel-12 | RP-57 | Patrick | FS_UTRA_HetNet |  |  |  | RP-131606 |
| 1216 | 302 | Study on Scalable UMTS FDD bandwidth | 265d? | 2012-12-10 A | 2013-12-06 A | 100% |  | 2012-12-10 | 2013-12-06 | 265d? |  | finish no earlier than 2013-12-06 | R1; R4 | 4240h | 4240h | FS_UTRA_SCAL | PCG-30 | UTRA TR 25.701 | China Unicom | Han Xiao (hanxiao91@chinaunicom.cn) | Rel-12 | RP-58 | Patrick | FS_UTRA_SCAL |  |  |  | RP-132035 |
| 1217 | 303 | Deleted - Study on Scalable UMTS FDD bandwidth by Filtering | 136d? | 2013-12-09 A | 2014-06-13 A | 100% |  | 2013-12-09 | 2014-06-13 | 136d? |  | finish no earlier than 2014-06-13 | R1 | 1088h | 1088h | FS_UTRA_SCAL_FILT | PCG-32 | UTRA TR 25.701 | China Unicom | Han Xiao (hanxiao91@chinaunicom.cn) | Rel-12 | RP-62 | Patrick | FS_UTRA_SCAL_FILT |  | PCG-33 | RP-64 | RP-140988 |
| 1218 | 304 | Study on Dedicated Channel (DCH) enhancements for UMTS | 197d? | 2012-12-10 A | 2013-09-06 A | 100% |  | 2012-12-10 | 2013-09-06 | 197d? |  | finish no earlier than 2013-09-06 | R1 | 1576h | 1576h | FS_UTRA_DCHenh | PCG-30 | UTRA TR 25.702 | Qualcomm | Arjun Bharadwaj (arjunb@qti.qualcomm.com) | Rel-12 | RP-58 | Patrick | FS_UTRA_DCHenh |  |  |  | RP-131073 |
| 1219 | 305 | Study on Further Enhanced Uplink (EUL) enhancements | 265d? | 2012-12-10 A | 2013-12-06 A | 100% |  | 2012-12-10 | 2013-12-06 | 265d? |  | finish no earlier than 2013-12-06 | R2; R1; R3 | 6360h | 6360h | FS_EDCH_enh | PCG-30 | UTRA TR 25.700 | Ericsson | alessandro.caverni@ericsson.com | Rel-12 | RP-58 | Yong-Jun | FS_EDCH_enh |  |  |  | RP-131608 |
| 1220 | 306 | Study on HNB Emergency Warning Area for UTRA | 191d? | 2013-06-18 A | 2014-03-06 A | 100% |  | 2013-06-18 | 2014-03-06 | 191d? |  | finish no earlier than 2014-03-06 | R3 | 1520h | 1520h | FS_HNB_warn_area | PCG-31 | UTRA TR 25.703 | Alcatel-Lucent, Ip.access | Martin.Warner@alcatel-lucent.com, Kit.kilgour@ipaccess.com | Rel-12 | RP-60 | Juha | FS_HNB_warn_area | HNB |  |  | RP-140129 |
| 1221 | 307 | Study on Enhanced Broadcast of System Information | 66d? | 2013-09-09 A | 2013-12-06 A | 100% |  | 2013-09-09 | 2013-12-06 | 66d? |  | finish no earlier than 2013-12-06 | R2; R1 | 1056h | 1056h | FS_UTRA_SIBenh | PCG-31 | UTRA TR 25.704 | Ericsson | martin.van.der.zee@ericsson.com | Rel-12 | RP-61 | Yong-Jun | FS_UTRA_SIBenh |  |  |  | RP-131610 |
| 1222 | 308 | Release 11 Features | 342.75d? | 2013-06-02 A | 2014-09-16 A | 100% |  | 2013-06-02 | 2014-09-17 | 342.75d? |  | finish no earlier than 2014-09-17 | SP; CP; GP; RP | 10968h | 10968h |  |  |  |  |  | Rel-11 |  | All |  |  |  |  |  |

Notes:
- 1154: Triggered by TR 22.906 SA1 Study on IMS based Peer-to-Peer Content Distribution Services UID_450047
- 1155: SP#53 completed
- 1156: SP#56 completed. TR 23.844v100 for Information and Approval
- 1157: SP#58 completed. TR 33.844 v100 for Information and Approval
- 1158: SP#62 completed. Linked to CT4 TR 23.857 Study on EPC Nodes Restoration (UID_490014)
- 1159: Phase 1: complete study of overload control related to MAP /Diameter signalling, other 3GPP Core Network signalling optimization
- 1160: SP#62 completed
- 1161: SP#56 completed
- 1162: SP#61 completed. Covers generic non-3GPP access (e.g. WLAN, WIMAX, CDMA/HRPD). Spin-off Feature SaMOG_WLAN. Linked to Rel-8 Support for non-3GPP accesses, Rel-10 SMOG, Rel-11 BBAI
- 1163: SP#61 completed. Linked to UID_350027 SAE for support for non-3GPP accesses (SAES-SA-FP_n3GPP), UID_410043 MAPIM, UID_450041 IFOM, UID_530046 SaMOG
- 1164: SP#59 completed. Linked to Rel-11 Feature UID_500032 Service Awareness and Privacy Policies (SAPP)
- 1165: Spin-off Features MAPCON, IFOM. SP#58 completed FS_MAPIM part of 23.861 (continued under FS_NBIFOM)
- 1166: SP#53 completed
- 1167: SP#43 TR 23.861v100 for Information. SP#56 Rel-9 TR 23.861v130 renamed & progressed under new Study FS_NBIFOM. SP#58 completed the FS_MAPIM part of TR 23.861 (TR continued under FS_NBIFOM).
- 1168: SP#59 stopped (at 40% completion). SP#56 revives dormant Study FS_MAPIM. TR 23.861 title changed from (Multi Access PDN connectivity and IP flow mobility) to (Network based IP flow mobility)
- 1169: SP#59 completed. Continuation of Rel-9 Feature UID_430036 IMS Media Plane Security (MEDIASEC). Study solutions and extensions to features and functionality described in TR 33.828 and TS 33.328
- 1170: SP#65 stopped. Linked to Rel-12 Service and Media Reachability for Users over Restrictive Firewalls (SMURFs) UID_530043
- 1171: SP#65 completed. TR 33.831v100 for 1-step Approval. Linked to Rel-11 SPUCI TR 33.838
- 1172: SP#64 completed. Spin-off Rel-13 Feature SCAS. Study methodologies for specifying product security assurance and hardening requirements on 3GPP network elements (with associated test cases when feasible)
- 1173: SP#65 completed. TR 26.938v200 for Approval. SP#60 TR 26.938v100 for Information. Linked to Feature UID_470034 HTTP-based Streaming and Download Services
- 1174: SP#65 completed. TR 26.907v200 for Approval. SP#64 TR 26.907v100 for Information.
- 1175: SP#58 completed
- 1176: SP#64 completed
- 1177: SP#61 completed. Linked to Network Sharing UID_31018, SA1 22.951 (Service aspects and requirements for network sharing), SA2 23.251 (Network Sharing; Architecture)
- 1178: SP#65 completed. TR 32.836v200 for Approval. SP#63 split of Rel-12 SP-130045 WID (Enhanced NM Centralized Coverage and Capacity Optimization) into a Rel-12 Study (SP-140028) and a Rel-13 Normative WID (SP-140060)
- 1179: SP#65 revised WID SP-130042=>SP-140536 (split into Rel-12 Study & Rel-13 normative WI). Changed Title from "TR on WLAN impacts to Type-2 management interface to the 3GPP Network Manager". TR 32.841v200 for Approval. Completed
- 1180: SP#61 completed
- 1181: CP#64 completed
- 1182: CP#65 completed. TR 29.809 v200 for Approval. Triggered by SA2 Rel-12 TR 23.843 Study on Core Network Overload solutions (FS_CNO) UID_490036. Coordinate with CT3, SA5
- 1183: CP#64 completed. Investigate introducing an XML-based protocol (e.g. SOAP, Restful HTTP, etc.) between AF and PCRF for non-IMS applications
- 1184: CP#65 completion 09/14=>12/14. CP#64 TR 29.949v100 for Information.LM:95->100
- 1185: CP#65 completion 09/14=>12/14. Gathering of all ISIM-related conformance requirements and the assessment of CT6 coverage
- 1186: CP#65 TR 29.854v200 for Approval. Completion 09/14=>12/14. LM: 80->85%
- 1187: GP#56 completed. GP#44 approved WID
- 1188: GP#62 completed. TR 43.801v100 for 1-step Approval. GP#50 approved WID. Triggered by Rel-8 TR 45.914 Study Multi-User-Reusing One Timeslot (MUROS) UID_50590 and Rel-9 VAMOS UID_420002
- 1189: GP#63 completed. TR~43.802v200 for Approval. GP#50 approved WID (mobile coucou). Triggered by RAN#51 (Mar 2011) WID in RP-110454 (LTE RAN Enhancements for Diverse Data Applications) UID_510031
- 1190: RP#61 completed. Linked to Rel-10 WI on Inclusion of RF Pattern Matching Technologies as a positioning method in the UTRAN (LCS_UMTS_RFPMT) UID_460005
- 1191: RP#60 completed
- 1192: RP#64 stopped at 80% completion
- 1193: RP#58 completed. TR 36.932 v100 for Information and Approval
- 1194: RP#62 completed. RP#61 TR 36.872v100 for 1-step approval. Triggered by Rel-12 TR 36.932 Study on Scenarios and Requirements of LTE Small Cell Enhancements for E-UTRA and E-UTRAN UID_570023
- 1195: RP#62 completed. Triggered by Rel-12 TR 36.932 Study on Scenarios and Requirements of LTE Small Cell Enhancements for E-UTRA and E-UTRAN UID_570023
- 1196: RP#63 completed. TR 36.843 for 1-step approval (90% complete). Started normative work. Linked to Rel-12 TR 22.803 Study on Proximity-based Services (FS_ProSe) and Feature ProSe
- 1197: RP#65 completed. Updated WID RP-130811=>RP-141237. TR 36.873v210 for Approval. Enhance performance with 3D-beamforming or with FD-MIMO. Study new channel modelling in both vertical and horizontal dimensions awa user locations in the network
- 1198: RP#64 completed. Identify potential solutions for energy saving in E-UTRAN non-overlapping scenario. Evaluate possible enhancements in overlapping scenario, so that a subset can be used for further investigation/standardization
- 1199: CD:Thu 11/12/14->Mon 15/12/14; Compl:80%->100%
- 1200: RP#62 completed. Updated WID RP-130393=>RP-131840
- 1201: RP#63 completed. TR 36.866 (90% complete) for Approval. Started normative work
- 1202: RP#62 completed. Extension of Rel-11 CoMP Operation for LTE Downlink UID_530332)
- 1203: RP#63 completed. Evaluate ability of LTE to meet public safety requirements agreed in SA for GC (GC is a key functionality of Land Mobile Radio/Private Mobile Radio and public safety systems)
- 1204: RP#63 completed
- 1205: RP#64 completed. TR 36.856v100 for 1-step approval. Triggered by SA1 Re-12 TR 22.852 Study on RAN Sharing Enhancements (FS_RSE) and Rel-13 Feature RSE (TS 22.101 Stage 1)
- 1206: RP#59 completed
- 1207: RP#60 completed
- 1208: RP#61 completed (Conclusion: no spin-off WI). Linked to Rel-10 WI on Multi-standard radio Base Station RF requirements for non-contiguous spectrum deployments (MSR_NC) UID_480025
- 1209: RP#62 completed. Evaluate LTE-WLAN/UTRA-WLAN i/w procedures while improving (non-)seamless mobility. Deployed WLAN often under-utilized; User experience suboptimal when UE connects to overloaded WLAN.
- 1210: RP#62 completed. TR 37.852v100 for Information & Approval
- 1211: RP#64 completed. The study of SON features for small cell functionality covered by the Rel-12 small cell enhancement SIs (e.g. dual connectivity) is not in the scope of this study item
- 1212: RP#65 completed. Within EU these bands can be used for terrestrial mobile as a complement to mobile satellite services. Study adding an FDD band into UTRA/E-UTRA in applicable countries of Region 1
- 1213: RP#60 completed (1-step approval). Study new BS spec structure to avoid duplicate work for new RF features (in case of identical features among different RATs); avoid future discussions on how to implement new features in single-RAT/multi-RAT specs
- 1214: RP#61 completed
- 1215: RP#62 completed
- 1216: RP#62 completed. TR 25.701v200 for Approval
- 1217: RP#64 stopped at 85% completion. Follow-up of Rel-12 Study on scalable UMTS FDD bandwidth (FS_UTRA_SCAL). The result is captured in the same TR 25.701
- 1218: RP#61 completed
- 1219: RP#62 completed. TR 25.700v100 for Approval. Identify potential solutions to increase the uplink capacity, coverage and end-user performance (e.g. latency, achievable rates, etc.)
- 1220: RP#63 completed. TR 25.703 v100 for 1-step approval
- 1221: RP#62 completed. TR 25.704v100 for Information & Approval. Study need to add capacity to present SI Broadcast mechanism unchanged since R99
- 1222: -

| ID | WBS | Task | Duration | Start | Finish | Complete | Baseline start | Baseline finish | Baseline duration | Constraint | Resources | Work | Actual work | Acronym | PCG approved | WI rapporteur name | WI rapporteur e-mail | Release | TSG approved | MCC resp | Acronym_3GU_Export | Special Focus Doc | PCG stopped | TSG stopped |
| --- | --- | --- | --- | --- | --- | --- | --- | --- | --- | --- | --- | --- | --- | --- | --- | --- | --- | --- | --- | --- | --- | --- | --- | --- |
| 1223 | 309 | **Advanced IP Interconnection of Services** | 650d? | 2010-03-25 A | 2012-09-12 A | 100% | 2010-03-25 | 2012-09-12 | 650d? |  | S1; S2; C1; C3 | 34381.9h | 34381.9h | IPXS | PCG-24 | Telefónica | chris.friel@O2.com | Rel-11 | SP-47 | Alain | IPXS |  |  |  |
| 1224 | 309.1 | Stage 1 for Advanced IP Interconnection of Services | 392d | 2010-03-25 A | 2011-09-21 A | 100% | 2010-03-25 | 2011-09-21 | 392d | finish no earlier than 2011-09-21 | S1 | 3120h | 3120h | IPXS | PCG-24 | Telefónica | chris.friel@O2.com | Rel-11 | SP-47 | Alain |  |  |  |  |
| 1225 | 309.2 | Stage 2 for Advanced IP Interconnection of Services | 263d? | 2010-12-16 A | 2011-12-14 A | 100% | 2010-12-16 | 2011-12-14 | 263d? | finish no earlier than 2012-03-21 | S2 | 2085.91h | 2085.91h | IPXS | PCG-26 | Ericsson | fredrik.lindholm@ericsson.com | Rel-11 | SP-50 | Maurice |  |  |  |  |
| 1226 | 309.3 | **Stage 3 for Advanced IP Interconnection of Services** | 265d? | 2011-09-13 A | 2012-09-12 A | 100% | 2011-09-13 | 2012-09-12 | 265d? |  | C1; C3 | 8376h | 8376h | IPXS | PCG-27 | Ericsson | christer.holmberg@ericsson.com | Rel-11 | CP-53 | Frederic |  |  |  |  |
| 1227 | 309.3.1 | CT1 part of Stage 3 for Advanced IP Interconnection of Services | 262d? | 2011-09-16 A | 2012-09-12 A | 100% | 2011-09-16 | 2012-09-12 | 262d? | finish no earlier than 2012-12-07 | C1 | 2048h | 2048h | IPXS | PCG-27 | Ericsson | christer.holmberg@ericsson.com | Rel-11 | CP-53 | Frederic |  |  |  |  |
| 1228 | 309.3.2 | CT3 part of Stage 3 for Advanced IP Interconnection of Services | 262d? | 2011-09-13 A | 2012-09-07 A | 100% | 2011-09-13 | 2012-09-07 | 262d? | finish no earlier than 2012-09-07 | C3 | 2088h | 2088h | IPXS | PCG-27 | Ericsson | christer.holmberg@ericsson.com | Rel-11 | CP-53 | Adrian |  |  |  |  |
| 1229 | 310 | **System Improvements to Machine-Type Communications** | 1119d? | 2009-12-10 A | 2014-03-06 A | 100% | 2009-12-10 | 2014-03-06 | 1119d? |  | S1; S2; S5; C1; C3; C4; C6; R2; R3; R5 | 198763h | 198763h | SIMTC | PCG-25 | KPN | toon.norp@tno.nl | Rel-11 | SP-48 | Alain | SIMTC | MTC, M2M |  |  |
| 1230 | 310.1 | Stage 1 for SIMTC | 337d? | 2010-06-10 A | 2011-09-21 A | 100% | 2010-06-10 | 2011-09-21 | 337d? |  | S1 | 2683.46h | 2683.46h | SIMTC | PCG-25 | KPN | toon.norp@tno.nl | Rel-11 | SP-48 | Alain |  | MTC, M2M |  |  |
| 1231 | 310.2 | TR on Stage 2 for SIMTC | 593d? | 2010-06-10 A | 2012-09-12 A | 100% | 2010-06-10 | 2012-09-12 | 593d? | finish no earlier than 2012-09-12 | S2 | 4736h | 4736h | SIMTC | PCG-25 | Intel | puneet.jain@intel.com | Rel-11 | SP-48 | Maurice |  | MTC, M2M |  |  |
| 1232 | 310.3 | **BB1: Stage 2 Reachability Aspects of SIMTC** | 274d? | 2011-06-09 A | 2012-06-20 A | 100% | 2011-06-09 | 2012-06-20 | 274d? |  | S2 | 10773.1h | 10773.1h | SIMTC-Reach | PCG-27 | Intel | puneet.jain@intel.com | Rel-11 | SP-52 | Maurice | SIMTC-Reach | MTC, M2M |  |  |
| 1233 | 310.3.1 | Deleted - MTC Feature Control (described in TS 22.368, clause 7.1.1 and 23.888, clause 5.7) | 137d? | 2011-06-10 A | 2011-12-14 A | 100% | 2011-06-10 | 2011-12-14 | 137d? | finish no earlier than 2011-11-09 | S2 | 1088h | 1088h | SIMTC-Reach | PCG-27 | Intel | puneet.jain@intel.com | Rel-11 | SP-52 | Maurice |  | MTC, M2M | PCG-28 | SP-54 |
| 1234 | 310.3.2 | On-line device trigger | 273d? | 2011-06-09 A | 2012-06-20 A | 100% | 2011-06-09 | 2012-06-20 | 273d? | finish no earlier than 2012-06-20 | S2 | 2170.29h | 2170.29h | SIMTC-Reach | PCG-27 | Intel | puneet.jain@intel.com | Rel-11 | SP-52 | Maurice |  | MTC, M2M |  |  |
| 1235 | 310.3.3 | MTC Addressing | 138d? | 2011-06-09 A | 2011-12-14 A | 100% | 2011-06-09 | 2011-12-14 | 138d? | finish no earlier than 2012-03-21 | S2 | 1097.24h | 1097.24h | SIMTC-Reach | PCG-27 | Intel | puneet.jain@intel.com | Rel-11 | SP-52 | Maurice |  | MTC, M2M |  |  |
| 1236 | 310.3.4 | Identifiers – especially removal of MSISDN dependencies in the architecture | 273d? | 2011-06-09 A | 2012-06-20 A | 100% | 2011-06-09 | 2012-06-20 | 273d? | finish no earlier than 2012-06-20 | S2 | 2169.53h | 2169.53h | SIMTC-Reach | PCG-27 | Intel | puneet.jain@intel.com | Rel-11 | SP-52 | Maurice |  | MTC, M2M |  |  |
| 1237 | 310.3.5 | MSISDN-less / PS-Only | 196d? | 2011-06-13 A | 2012-03-07 A | 100% | 2011-06-13 | 2012-03-07 | 196d? | finish no earlier than 2012-03-07 | S2 | 1568h | 1568h | SIMTC-Reach | PCG-27 | Intel | puneet.jain@intel.com | Rel-11 | SP-52 | Maurice |  | MTC, M2M |  |  |
| 1238 | 310.3.6 | MTC related interfaces and functional entities to support above features (MTCsp, etc.) | 61d? | 2011-12-14 A | 2012-03-07 A | 100% | 2011-12-14 | 2012-03-07 | 61d? | finish no earlier than 2012-03-07 | S2 | 488h | 488h | SIMTC-Reach | PCG-28 | Intel | puneet.jain@intel.com | Rel-11 | SP-54 | Maurice |  | MTC, M2M |  |  |
| 1239 | 310.4 | **BB1: Stage 3 (CS+PS) Reachability Aspects of SIMTC** | 325d? | 2011-09-19 A | 2012-12-07 A | 100% | 2011-09-19 | 2012-12-07 | 325d? |  | C1; C3; C4; C6 | 19112h | 19112h | SIMTC-Reach | PCG-27 | Ericsson | mikael.wass@ericsson.com | Rel-11 | CP-53 | Frederic |  | MTC, M2M |  |  |
| 1240 | 310.4.1 | CT1 part of Stage 3 BB1: Reachability Aspects of SIMTC | 257d? | 2011-09-19 A | 2012-09-07 A | 100% | 2011-09-19 | 2012-09-07 | 257d? | finish no earlier than 2012-09-07 | C1 | 2048h | 2048h | SIMTC-Reach | PCG-27 | Ericsson | mikael.wass@ericsson.com | Rel-11 | CP-53 | Frederic |  | MTC, M2M |  |  |
| 1241 | 310.4.2 | CT3 part of Stage 3 BB1: Reachability Aspects of SIMTC | 257d? | 2011-09-19 A | 2012-09-07 A | 100% | 2011-09-19 | 2012-09-07 | 257d? | finish no earlier than 2012-09-07 | C3 | 2048h | 2048h | SIMTC-Reach | PCG-27 | Ericsson | mikael.wass@ericsson.com | Rel-11 | CP-53 | Adrian |  | MTC, M2M |  |  |
| 1242 | 310.4.3 | CT4 part of Stage 3 BB1: Reachability Aspects of SIMTC | 324d? | 2011-09-19 A | 2012-12-07 A | 100% | 2011-09-19 | 2012-12-07 | 324d? | finish no earlier than 2012-12-07 | C4 | 2568h | 2568h | SIMTC-Reach | PCG-27 | Ericsson | mikael.wass@ericsson.com | Rel-11 | CP-53 | Kimmo |  | MTC, M2M |  |  |
| 1243 | 310.4.4 | CT6 part of Stage 3 BB1: Reachability Aspects of SIMTC | 257d? | 2011-09-19 A | 2012-09-07 A | 100% | 2011-09-19 | 2012-09-07 | 257d? | finish no earlier than 2012-09-07 | C6 | 2048h | 2048h | SIMTC-Reach | PCG-27 | ST Ericsson | Andrzej Winiarski | Rel-11 | CP-53 | Xavier |  | MTC, M2M |  |  |
| 1244 | 310.5 | **Stage 2/3 for CS aspects for SIMTC** | 259d? | 2011-09-16 A | 2012-09-07 A | 100% | 2011-09-16 | 2012-09-07 | 259d? |  | C4; C1; C6 | 16544h | 16544h | SIMTC-CS | PCG-27 | Ericsson | mikael.wass@ericsson.com | Rel-11 | CP-53 | Kimmo | SIMTC-CS | MTC, M2M |  |  |
| 1245 | 310.5.1 | Deleted - Stage 2 CS aspects for SIMTC | 258d? | 2011-09-16 A | 2012-09-06 A | 100% | 2011-09-16 | 2012-09-06 | 258d? | finish no earlier than 2012-09-07 | C4 | 2056h | 2056h | SIMTC-CS | PCG-27 | Ericsson | mikael.wass@ericsson.com | Rel-11 | CP-53 | Kimmo |  | MTC, M2M | PCG-29 | CP-57 |
| 1246 | 310.5.2 | **Stage 3 CS aspects for SIMTC** | 259d? | 2011-09-16 A | 2012-09-07 A | 100% | 2011-09-16 | 2012-09-07 | 259d? |  | C1; C6 | 8272h | 8272h | SIMTC-CS | PCG-27 | Ericsson | mikael.wass@ericsson.com | Rel-11 | CP-53 | Frederic |  | MTC, M2M |  |  |
| 1247 | 310.5.2.1 | CT1 part of Stage 3 CS aspects for SIMTC | 259d? | 2011-09-16 A | 2012-09-07 A | 100% | 2011-09-16 | 2012-09-07 | 259d? | start no earlier than 2011-09-16 | C1 | 2064h | 2064h | SIMTC-CS | PCG-27 | Ericsson | mikael.wass@ericsson.com | Rel-11 | CP-53 | Frederic |  | MTC, M2M |  |  |
| 1248 | 310.5.2.2 | Deleted - CT6 part of Stage 3 CS aspects for SIMTC | 259d? | 2011-09-16 A | 2012-09-07 A | 100% | 2011-09-16 | 2012-09-07 | 259d? | start no earlier than 2011-09-16 | C6 | 2064h | 2064h | SIMTC-CS | PCG-27 | Ericsson | mikael.wass@ericsson.com | Rel-11 | CP-53 | Xavier |  | MTC, M2M | PCG-29 | CP-57 |

Notes:
- 1223: CP#58 completed. Triggered by Rel-10 TR 22.893 UID_380083 Study on advanced requirements for IP interconnect (FS_IPXS)
- 1224: SP#53 completed / Impacted TSs and TRs: 22.101, 22.228
- 1225: SP#54 completed / Impacted TSs and TRs: 23.228
- 1226: CP#58 completed / Impacted TSs and TRs: Stage 3
- 1227: CP#58 completed / Impacted TSs and TRs: 24.229
- 1228: CP#57 completed / Impacted TSs and TRs: 29.165
- 1229: SP#58 completed. Updated WID SP-110877=>SP-120848. Enhancements to Rel-10 Feature UID_410031 (NIMTC) based on Rel-11 Study on enhancements to MTC
- 1230: SP#53 completed. SP#57 added MTC definitions in 21.905 / Impacted TSs and TRs: 22.368, 21.905 (MTC definitions)
- 1231: SP#57 completed. TR 23.888v200 for Approval. Was Rel-10 UID_450028 (TR on Stage 2 for NIMTC) / Impacted TSs and TRs: New TR 23.888
- 1232: SP#56 completed. SP#58 updated WID SP-110877=>S3-121111 (SA3 normative work on Security aspects of SIMTC incorporated in SA2 TS 23.682) / Impacted TSs and TRs: 23.221, New 23.368
- 1233: SP#54 work stopped
- 1234: SP#56 completed / Impacted TSs and TRs: New 23.682
- 1235: SP#54 completed / Impacted TSs and TRs: 23.221, New 23.682
- 1236: SP#56 completed / Impacted TSs and TRs: New 23.682
- 1237: SP#55 completed / Impacted TSs and TRs: 23.060, 23.272, New 23.682
- 1238: SP#55 completed / Impacted TSs and TRs: New 23.682
- 1239: SP#58 completed / Impacted TSs and TRs: Stage 3
- 1240: CP#57 completed / Impacted TSs and TRs: 23.040, 24.008, 24.301, 24.341, 24.368
- 1241: CP#57 completed. TS 29.368 v200 for Approval / Impacted TSs and TRs: 29.061, New TS 29.368
- 1242: CP#58 completed / Impacted TSs and TRs: 23.003, 23.008, 29.002, 29.060, 29.230, New TS (29.336, 29.337)
- 1243: CP#57 completed / Impacted TSs and TRs: 31.102
- 1244: CP#57 completed. Updated WID CP-120418=>CP-120617 / Impacted TSs and TRs: Stage 2/3
- 1245: CP#57 stopped / Impacted TSs and TRs: 23.012
- 1246: CP#57 completed / Impacted TSs and TRs: Stage 3
- 1247: CP#57 completed / Impacted TSs and TRs: 24.008, 24.301
- 1248: CP#57 stopped / Impacted TSs and TRs: 31.102

| ID | WBS | Task | Duration | Start | Finish | Complete | Baseline start | Baseline finish | Baseline duration | Constraint | Resources | Work | Actual work | Acronym | PCG approved | WI rapporteur name | WI rapporteur e-mail | Release | TSG approved | MCC resp | Special Focus Doc | Acronym_3GU_Export | Status Report | PCG stopped | TSG stopped |
| --- | --- | --- | --- | --- | --- | --- | --- | --- | --- | --- | --- | --- | --- | --- | --- | --- | --- | --- | --- | --- | --- | --- | --- | --- | --- |
| 1249 | 310.6 | **Stage 2/3 for SMS in MME architecture option and related PS-only service subscription** | 129d? | 2012-06-15 A | 2012-12-07 A | 100% | 2012-06-15 | 2012-12-07 | 129d? |  | C1; C4 | 3560h | 3560h | SIMTC-PS_Only | PCG-29 | Ericsson | mikael.wass@ericsson.com | Rel-11 | CP-56 | Frederic | MTC, M2M | SIMTC-PS_Only |  |  |  |
| 1250 | 310.6.1 | CT1 part of Stage 2/3 for SMS in MME architecture option and related PS-only service subscription | 62d? | 2012-06-15 A | 2012-09-07 A | 100% | 2012-06-15 | 2012-09-07 | 62d? | finish no earlier than 2012-09-07 | C1 | 488h | 488h | SIMTC-PS_Only | PCG-29 | Ericsson | mikael.wass@ericsson.com | Rel-11 | CP-56 | Frederic | MTC, M2M |  |  |  |  |
| 1251 | 310.6.2 | CT4 part of Stage 2/3 for SMS in MME architecture option and related PS-only service subscription | 129d? | 2012-06-15 A | 2012-12-07 A | 100% | 2012-06-15 | 2012-12-07 | 129d? | finish no earlier than 2012-12-07 | C4 | 1008h | 1008h | SIMTC-PS_Only | PCG-29 | Ericsson | mikael.wass@ericsson.com | Rel-11 | CP-56 | Kimmo | MTC, M2M |  |  |  |  |
| 1252 | 310.7 | **RAN overload control for Machine-Type Communications** | 259d? | 2011-09-16 A | 2012-09-07 A | 100% | 2011-09-16 | 2012-09-07 | 259d? |  | R2; R3; C1; C6 | 20178.3h | 20178.3h | SIMTC-RAN_OC | PCG-27 | Huawei | Jeff Gao (gaoyongqiang@huawei.com) | Rel-11 | RP-53 | Yong-Jun | MTC, M2M | SIMTC-RAN_OC |  |  |  |
| 1253 | 310.7.1 | Core part: RAN overload control for Machine-Type Communications | 258d? | 2011-09-19 A | 2012-09-07 A | 100% | 2011-09-19 | 2012-09-07 | 258d? | finish no earlier than 2012-09-07 | R2; R3 | 4128h | 4128h | SIMTC-RAN_OC-Core | PCG-27 | Huawei | Jeff Gao (gaoyongqiang@huawei.com) | Rel-11 | RP-53 | Yong-Jun | MTC, M2M | SIMTC-RAN_OC-Core |  |  |  |
| 1254 | 310.7.2 | **Stage 3 (CS+PS) Extended Access Barring for UTRAN and E-UTRAN** | 259d? | 2011-09-16 A | 2012-09-07 A | 100% | 2011-09-16 | 2012-09-07 | 259d? |  | C1; C6 | 7762.29h | 7762.29h | SIMTC-RAN_OC | PCG-27 | Ericsson | mikael.wass@ericsson.com | Rel-11 | CP-53 | Frederic | MTC, M2M |  |  |  |  |
| 1255 | 310.7.2.1 | CT1 part of Stage 3 Extended Access Barring for UTRAN and E-UTRAN | 198d? | 2011-09-16 A | 2012-06-15 A | 100% | 2011-09-16 | 2012-06-15 | 198d? | finish no earlier than 2012-09-14 | C1 | 1570.29h | 1570.29h | SIMTC-RAN_OC | PCG-27 | Ericsson | mikael.wass@ericsson.com | Rel-11 | CP-53 | Frederic | MTC, M2M |  |  |  |  |
| 1256 | 310.7.2.2 | CT6 part of Stage 3 Extended Access Barring for UTRAN and E-UTRAN | 257d? | 2011-09-20 A | 2012-09-07 A | 100% | 2011-09-20 | 2012-09-07 | 257d? | finish no earlier than 2012-09-07 | C6 | 2048h | 2048h | SIMTC-RAN_OC | PCG-27 | ST Ericsson | Andrzej Winiarski | Rel-11 | CP-53 | Xavier | MTC, M2M |  |  |  |  |
| 1257 | 310.8 | Test part: System Improvements for Machine-Type Communications | 130d? | 2013-09-09 A | 2014-03-06 A | 100% | 2013-09-09 | 2014-03-06 | 130d? | finish no earlier than 2014-03-06 | R5 | 1040h | 1040h | SIMTC-UEConTest | PCG-31 | Ericsson | calle.hagenfeldt@ericsson.com | Rel-11 | RP-61 | Ingbert | MTC, M2M | SIMTC-UEConTest | RP-140075 |  |  |
| 1258 | 310.9 | BB5: Charging of SIMTC (Stage 2/3) | 269d? | 2011-12-07 A | 2012-12-12 A | 100% | 2011-12-07 | 2012-12-12 | 269d? | finish no earlier than 2012-12-12 | S5 | 2144h | 2144h | SIMTC-CH | PCG-28 | Ericsson | patrik.teppo@ericsson.com | Rel-11 | SP-54 | Mirko | MTC, M2M | SIMTC-CH |  |  |  |
| 1259 | 310.10 | **Deleted - BB2: Stage 2 Signalling Optimizations of SIMTC** | 137d? | 2011-06-10 A | 2011-12-14 A | 100% | 2011-06-10 | 2011-12-14 | 137d? |  | S2 | 5240h | 5240h | SIMTC-Sig | PCG-27 | Intel | puneet.jain@intel.com | Rel-11 | SP-52 | Maurice | MTC, M2M | SIMTC-Sig |  | PCG-28 | SP-55 |
| 1260 | 310.10.1 | Deleted - Effectively maintain connectivity for a large number of MTC Devices (TS 22.368, 7.1.1) | 137d? | 2011-06-10 A | 2011-12-14 A | 100% | 2011-06-10 | 2011-12-14 | 137d? | finish no earlier than 2011-12-07 | S2 | 1088h | 1088h | SIMTC-Sig | PCG-27 | Intel | puneet.jain@intel.com | Rel-11 | SP-52 | Maurice | MTC, M2M |  |  | PCG-28 | SP-55 |
| 1261 | 310.10.2 | Deleted - Small Data Transmissions (TS 22.368, 7.2.5) | 137d? | 2011-06-10 A | 2011-12-14 A | 100% | 2011-06-10 | 2011-12-14 | 137d? | finish no earlier than 2011-12-07 | S2 | 1088h | 1088h | SIMTC-Sig | PCG-27 | Intel | puneet.jain@intel.com | Rel-11 | SP-52 | Maurice | MTC, M2M |  |  | PCG-28 | SP-55 |
| 1262 | 310.10.3 | **Deleted - Stage 3 (CS+PS) Signalling Optimizations of SIMTC** | 62d? | 2011-09-16 A | 2011-12-09 A | 100% | 2011-09-16 | 2011-12-09 | 62d? |  | C1; C6 | 1968h | 1968h | SIMTC-Sig | PCG-27 | Ericsson | mikael.wass@ericsson.com | Rel-11 | CP-53 | Frederic | MTC, M2M |  |  | PCG-28 | CP-55 |
| 1263 | 310.10.3.1 | Deleted - CT1 part of Stage 3 Signalling Optimizations of SIMTC | 62d? | 2011-09-16 A | 2011-12-09 A | 100% | 2011-09-16 | 2011-12-09 | 62d? | finish no earlier than 2011-12-02 | C1 | 488h | 488h | SIMTC-Sig | PCG-27 | Ericsson | mikael.wass@ericsson.com | Rel-11 | CP-53 | Frederic | MTC, M2M |  |  | PCG-28 | CP-55 |
| 1264 | 310.10.3.2 | Deleted - CT6 part of Stage 3 Signalling Optimizations of SIMTC | 62d? | 2011-09-16 A | 2011-12-09 A | 100% | 2011-09-16 | 2011-12-09 | 62d? | finish no earlier than 2011-12-02 | C6 | 488h | 488h | SIMTC-Sig | PCG-27 | ST Ericsson | Andrzej Winiarski | Rel-11 | CP-53 | Xavier | MTC, M2M |  |  | PCG-28 | CP-55 |
| 1265 | 310.11 | **Deleted - BB3: Stage 2 CN-based requirements and Power Considerations of SIMTC** | 139d? | 2011-06-08 A | 2011-12-14 A | 100% | 2011-06-08 | 2011-12-14 | 139d? |  | S2 | 6360h | 6360h | SIMTC-CN_Pow | PCG-27 | Intel | puneet.jain@intel.com | Rel-11 | SP-52 | Maurice | MTC, M2M | SIMTC-CN_Pow |  | PCG-28 | SP-55 |
| 1266 | 310.11.1 | Deleted - Charging Requirements (TS 22.368, 7.1.5) | 137d? | 2011-06-10 A | 2011-12-14 A | 100% | 2011-06-10 | 2011-12-14 | 137d? | finish no earlier than 2012-03-21 | S2 | 1088h | 1088h | SIMTC-CN_Pow | PCG-27 | Intel | puneet.jain@intel.com | Rel-11 | SP-52 | Maurice | MTC, M2M |  |  | PCG-28 | SP-55 |
| 1267 | 310.11.2 | Deleted - Lower Power Consumption (TS 22.368, 7.1.1) | 137d? | 2011-06-10 A | 2011-12-14 A | 100% | 2011-06-10 | 2011-12-14 | 137d? | finish no earlier than 2011-12-07 | S2 | 1088h | 1088h | SIMTC-CN_Pow | PCG-27 | Intel | puneet.jain@intel.com | Rel-11 | SP-52 | Maurice | MTC, M2M |  |  | PCG-28 | SP-55 |
| 1268 | 310.11.3 | Deleted - MTC Monitoring (TS 22.368, 7.2.8) | 139d? | 2011-06-08 A | 2011-12-14 A | 100% | 2011-06-08 | 2011-12-14 | 139d? | finish no earlier than 2011-12-07 | S2 | 1104h | 1104h | SIMTC-CN_Pow | PCG-27 | Intel | puneet.jain@intel.com | Rel-11 | SP-52 | Maurice | MTC, M2M |  |  | PCG-28 | SP-55 |
| 1269 | 310.11.4 | **Deleted - Stage 3 (CS+PS) CN-based requirements and Power Considerations of SIMTC** | 62d? | 2011-09-16 A | 2011-12-09 A | 100% | 2011-09-16 | 2011-12-09 | 62d? |  | C1; C6 | 1968h | 1968h | SIMTC-CN_Pow | PCG-27 | Ericsson | mikael.wass@ericsson.com | Rel-11 | CP-53 | Frederic | MTC, M2M |  |  | PCG-28 | CP-55 |
| 1270 | 310.11.4.1 | Deleted - CT1 part of Stage 3 CN-based requirements and Power Considerations of SIMTC | 62d? | 2011-09-16 A | 2011-12-09 A | 100% | 2011-09-16 | 2011-12-09 | 62d? | finish no earlier than 2011-12-02 | C1 | 488h | 488h | SIMTC-CN_Pow | PCG-27 | Ericsson | mikael.wass@ericsson.com | Rel-11 | CP-53 | Frederic | MTC, M2M |  |  | PCG-28 | CP-55 |
| 1271 | 310.11.4.2 | Deleted - CT6 part of Stage 3 CN-based requirements and Power Considerations of SIMTC | 62d? | 2011-09-16 A | 2011-12-09 A | 100% | 2011-09-16 | 2011-12-09 | 62d? | finish no earlier than 2011-12-02 | C6 | 488h | 488h | SIMTC-CN_Pow | PCG-27 | ST Ericsson | Andrzej Winiarski | Rel-11 | CP-53 | Xavier | MTC, M2M |  |  | PCG-28 | CP-55 |
| 1272 | 310.12 | Deleted - TR on Security aspects of Machine-Type Communications | 662d? | 2009-12-10 A | 2012-06-20 A | 100% | 2009-12-10 | 2012-06-20 | 662d? | finish no earlier than 2012-06-20 | S3 | 5288h | 5288h | SIMTC-CN_Pow | PCG-25 | Samsung | Rajavelsamy R (rajvel@samsung.com) | Rel-11 | SP-49 | Mirko | MTC, M2M |  |  | PCG-29 | SP-56 |

Notes:
- 1249: CP#58 completed / Impacted TSs and TRs: Stage 2/3
- 1250: CP#57 completed / Impacted TSs and TRs: 23.040, 24.008, 24.011, 24.301, 29.018, 29.118
- 1251: CP#58 completed. TS 29.338 v200 for Approval / Impacted TSs and TRs: 23.003, 23.008, 23.012, 29.002, 29.272, 29.305, New TS 29.338
- 1252: Stage 2,3. TSG#57 completed / Impacted TSs and TRs: UTRA, LTE
- 1253: RP#57 completed / Impacted TSs and TRs: 25.304, 25.331, 25.413, 36.304, 36.331, 36.413
- 1254: CP#57 completed. Updated WID CP-120418=>CP-120617 / Impacted TSs and TRs: Stage 3
- 1255: CP#56 completed / Impacted TSs and TRs: 23.122, 24.008, 24.301
- 1256: CP#57 completed / Impacted TSs and TRs: 31.102
- 1257: RP#63 completed. Updated WID RP-131341=>RP-140077 (added affected TS 36.508). Testing for core part: SIMTC-Reach, SIMTC-CS, SIMTC-PS_Only, SIMTC-RAN_OC / Impacted TSs and TRs: 34.123-1, 34.123-2, 34.123-3, 36.508, 36.523-1, 36.523-2, 36.523-3
- 1258: SP#58 completed / Impacted TSs and TRs: 32.240, 32.251, 32.298, 32.299
- 1259: SP#54 work stopped. SP#58 updated WID SP-110877=>SP-120848 / Impacted TSs and TRs: TBD
- 1260: SP#54 work stopped / Impacted TSs and TRs: TBD
- 1261: SP#54 work stopped / Impacted TSs and TRs: TBD
- 1262: CP#54 work stopped / Impacted TSs and TRs: Stage 3
- 1263: - / Impacted TSs and TRs: 23.122, 24.008, 24.301, 24.368
- 1264: - / Impacted TSs and TRs: 31.102
- 1265: SP#54 work stopped / Impacted TSs and TRs: TBD
- 1266: SP#54 work stopped / Impacted TSs and TRs: TBD
- 1267: SP#54 work stopped / Impacted TSs and TRs: TBD
- 1268: SP#54 work stopped / Impacted TSs and TRs: TBD
- 1269: CP#54 work stopped / Impacted TSs and TRs: Stage 3
- 1270: - / Impacted TSs and TRs: 23.122, 24.008, 24.301, 24.368
- 1271: - / Impacted TSs and TRs: 31.101, 31.102
- 1272: Was Rel-10 UID_460023 (Security for NIMTC). SP#56 stopped (activity transferred to Rel-12 Feature MTCe under UID_560722). / Impacted TSs and TRs: New TR 33.868

| ID | WBS | Task | Type | Duration | Start | Finish | Complete | Baseline start | Baseline finish | Baseline duration | Constraint | Resources | Work | Actual work | Acronym | PCG approved | Impacted TSs and TRs | WI rapporteur name | Release | TSG approved | MCC resp | PCG stopped | TSG stopped | Special Focus Doc | Acronym_3GU_Export |
| --- | --- | --- | --- | --- | --- | --- | --- | --- | --- | --- | --- | --- | --- | --- | --- | --- | --- | --- | --- | --- | --- | --- | --- | --- | --- |
| 1273 | 310.13 | **Deleted - BB4: Secure Connection and Privacy of SIMTC** |  | 336d? | 2011-06-08 A | 2012-09-12 A | 100% | 2011-06-08 | 2012-09-12 | 336d? |  | S3 | 7424h | 7424h | SIMTC-Sec | PCG-27 | TBD | Samsung | Rel-11 | SP-52 | Mirko | PCG-29 | CP-57 | MTC, M2M | SIMTC-Sec |
| 1274 | 310.13.1 | Deleted - Secure Connection MTC Feature (TS 22.368, 7.2.10) |  | 333d? | 2011-06-08 A | 2012-09-12 A | 100% | 2011-06-08 | 2012-09-12 | 333d? | finish no earlier than 2012-09-12 | S3 | 2656h | 2656h | SIMTC-Sec | PCG-27 | TBD | Samsung | Rel-11 | SP-52 | Mirko | PCG-29 | CP-57 | MTC, M2M |  |
| 1275 | 310.13.2 | Deleted - MTC Location Privacy |  | 261d? | 2011-09-19 A | 2012-09-12 A | 100% | 2011-09-19 | 2012-09-12 | 261d? | finish no earlier than 2012-09-12 | S3 | 2080h | 2080h | SIMTC-Priv | PCG-27 | TBD | Samsung | Rel-11 | SP-53 | Mirko | PCG-29 | CP-57 | MTC, M2M | SIMTC-Priv |
| 1276 | 310.14 | Deleted - Stage 2 on SA2 part for System Improvements to Machine-Type Communications |  | 260d? | 2010-06-10 A | 2011-06-08 A | 100% | 2010-06-10 | 2011-06-08 | 260d? | finish no earlier than 2011-06-08 | S2 | 2080h | 2080h | SIMTC | PCG-25 | TBD | Intel | Rel-11 | SP-48 | Maurice | PCG-27 | SP-52 | MTC, M2M |  |
| 1277 | 310.15 | Deleted - Stage 2 on Security part for System Improvements to Machine-Type Communications |  | 260d? | 2010-06-10 A | 2011-06-08 A | 100% | 2010-06-10 | 2011-06-08 | 260d? | finish no earlier than 2011-06-08 | S3 | 2080h | 2080h | SIMTC | PCG-25 | TBD | Samsung | Rel-11 | SP-48 | Mirko | PCG-27 | SP-52 | MTC, M2M |  |
| 1278 | 311 | **Unstructured Supplementary Service Data (USSD) simulation service in IMS** |  | 659d? | 2010-06-10 A | 2012-12-07 A | 100% | 2010-06-10 | 2012-12-07 | 659d? |  | S1; C1; C3 | 28112.1h | 28112.1h | USSI | PCG-25 |  | Deutsche Telekom | Rel-11 | SP-48 | Alain |  |  |  | USSI |
| 1279 | 311.1 | Stage 1 for USSD simulation service in IMS | milestone | 0d? | 2010-06-10 A | 2010-06-10 A | 100% | 2010-06-10 | 2010-06-10 | 0d? | finish no earlier than 2010-06-10 | S1 |  |  | USSI | PCG-25 | 22.173 | Deutsche Telekom | Rel-11 | SP-48 | Alain |  |  |  |  |
| 1280 | 311.2 | **Stage 3 for USSD simulation service in IMS** |  | 403d? | 2011-06-03 A | 2012-12-07 A | 100% | 2011-06-03 | 2012-12-07 | 403d? |  | C1; C3 | 12296.1h | 12296.1h | USSI | PCG-27 |  | Deutsche Telekom | Rel-11 | CP-52 | Frederic |  |  |  |  |
| 1281 | 311.2.1 | CT1 part of Stage 3 for USSD simulation service in IMS |  | 402d? | 2011-06-03 A | 2012-12-07 A | 100% | 2011-06-03 | 2012-12-07 | 402d? | finish no earlier than 2012-12-07 | C1 | 3184.06h | 3184.06h | USSI | PCG-27 | 24.173, 24.229, new TS 24.390 | Deutsche Telekom | Rel-11 | CP-52 | Frederic |  |  |  |  |
| 1282 | 311.2.2 | CT3 part of Stage 3 for USSD simulation service in IMS |  | 334d? | 2011-06-07 A | 2012-09-07 A | 100% | 2011-06-07 | 2012-09-07 | 334d? | finish no earlier than 2012-09-07 | C3 | 2664h | 2664h | USSI | PCG-27 | 29.165 | Deutsche Telekom | Rel-11 | CP-52 | Adrian |  |  |  |  |
| 1283 | 312 | **QoS Control Based on Subscriber Spending Limits** |  | 459d? | 2010-09-23 A | 2012-06-20 A | 100% | 2010-09-23 | 2012-06-20 | 459d? |  | S1; S2; S5; C3 | 23152h | 23152h | QoS_SSL | PCG-25 |  | Vodafone | Rel-11 | SP-49 | Alain |  |  |  | QoS_SSL |
| 1284 | 312.1 | Stage 1 for QoS Control Based on Subscriber Spending Limits |  | 262d? | 2010-09-23 A | 2011-09-21 A | 100% | 2010-09-23 | 2011-09-21 | 262d? | finish no earlier than 2011-09-21 | S1 | 2080h | 2080h | QoS_SSL | PCG-25 | 22.115 | Vodafone | Rel-11 | SP-49 | Alain |  |  |  |  |
| 1285 | 312.2 | Stage 2 for QoS Control Based on Subscriber Spending Limits |  | 133d? | 2011-03-23 A | 2011-09-21 A | 100% | 2011-03-23 | 2011-09-21 | 133d? | finish no earlier than 2011-12-14 | S2 | 1048h | 1048h | QoS_SSL | PCG-26 | 23.203 | Huawei | Rel-11 | SP-51 | Maurice |  |  |  |  |
| 1286 | 312.3 | Charging for QoS Control Based on Subscriber Spending Limits (Stage 2) |  | 397d? | 2010-12-16 A | 2012-06-20 A | 100% | 2010-12-16 | 2012-06-20 | 397d? | finish no earlier than 2012-06-20 | S5 | 3168h | 3168h | QoS_SSL | PCG-26 | 32.240, 32.296 | Nokia Siemens Networks, Huawei | Rel-11 | SP-50 | Mirko |  |  |  |  |
| 1287 | 312.4 | CT3 aspects of QoS Control Based on Subscriber Spending Limits (Stage 3) |  | 273d? | 2011-06-03 A | 2012-06-15 A | 100% | 2011-06-03 | 2012-06-15 | 273d? | finish no earlier than 2012-06-15 | C3 | 2168h | 2168h | QoS_SSL-CT3 | PCG-27 | 29.212, 29.213, 29.214, 29.215, new TS 29.219 | Huawei | Rel-11 | CP-52 | Adrian |  |  |  | QoS_SSL-CT3 |
| 1288 | 313 | **Optimized Service Charging and Allocation of Resources in IMS whilst Roaming** |  | 383d? | 2010-09-23 A | 2012-03-07 A | 100% | 2010-09-23 | 2012-03-07 | 383d? |  | S1; S2 | 14288h | 14288h | OSCAR | PCG-25 |  | Vodafone | Rel-11 | SP-49 | Alain |  |  |  | OSCAR |
| 1289 | 313.1 | TR on Stage 2 aspects of Optimized Service Charging and Allocation of Resources in IMS whilst Roaming |  | 383d? | 2010-09-23 A | 2012-03-07 A | 100% | 2010-09-23 | 2012-03-07 | 383d? | finish no earlier than 2011-12-07 | S2 | 3040h | 3040h | OSCAR | PCG-25 | new TR 23.849 | Vodafone | Rel-11 | SP-49 | Maurice |  |  |  |  |
| 1290 | 313.2 | Stage 1 for Optimized Service Charging and Allocation of Resources in IMS whilst Roaming |  | 262d? | 2010-09-23 A | 2011-09-21 A | 100% | 2010-09-23 | 2011-09-21 | 262d? | finish no earlier than 2011-09-21 | S1 | 2080h | 2080h | OSCAR | PCG-25 | 22.115, 22.173, 22.228 | Vodafone | Rel-11 | SP-49 | Alain |  |  |  |  |
| 1291 | 313.3 | Deleted - Stage 2 for Optimized Service Charging and Allocation of Resources in IMS whilst Roaming |  | 380d? | 2010-09-28 A | 2012-03-07 A | 100% | 2010-09-28 | 2012-03-07 | 380d? | finish no earlier than 2012-03-07 | S2 | 3040h | 3040h | OSCAR | PCG-25 | None | Vodafone | Rel-11 | SP-49 | Maurice | PCG-28 | SP-55 |  |  |
| 1292 | 314 | **Inclusion of Media Resource Broker (Stage 2/3)** |  | 463d? | 2011-09-16 A | 2013-06-14 A | 100% | 2011-09-16 | 2013-06-14 | 463d? |  | C1; C3; IETF | 30500h | 30500h | MRB | PCG-27 | Stage 2/3 | AT&T | Rel-11 | CP-53 | Frederic |  |  |  | MRB |
| 1293 | 314.1 | Stage 2 for Inclusion of Media Resource Broker |  | 259d? | 2011-09-16 A | 2012-09-07 A | 100% | 2011-09-16 | 2012-09-07 | 259d? | finish no earlier than 2012-09-07 | C1 | 2049.98h | 2049.98h | MRB | PCG-27 | 23.218 | AT&T | Rel-11 | CP-53 | Frederic |  |  |  |  |
| 1294 | 314.2 | **Stage 3 for Inclusion of Media Resource Broker** |  | 463d? | 2011-09-16 A | 2013-06-14 A | 100% | 2011-09-16 | 2013-06-14 | 463d? |  | C1; C3; IETF | 17338h | 17338h | MRB | PCG-27 |  | AT&T | Rel-11 | CP-53 | Frederic |  |  |  |  |
| 1295 | 314.2.1 | CT1 part of Stage 3 for Inclusion of Media Resource Broker |  | 258d? | 2011-09-16 A | 2012-09-07 A | 100% | 2011-09-16 | 2012-09-07 | 258d? | finish no earlier than 2012-09-07 | C1 | 2049.98h | 2049.98h | MRB | PCG-27 | 24.229, 29.165 | AT&T | Rel-11 | CP-53 | Frederic |  |  |  |  |
| 1296 | 314.2.2 | (IETF) Inclusion of Media Resource Broker [RFC 6917 (was draft-ietf-mediactrl-mrb)] |  | 462d? | 2011-09-16 A | 2013-06-14 A | 100% | 2011-09-16 | 2013-06-14 | 462d? | finish no earlier than 2013-06-14 | C1-IETF | 3688h | 3688h | MRB | PCG-27 | RFC 6917 (was draft-ietf-mediactrl-mrb) | Keith Drage | Rel-11 | CP-53 | Frederic |  |  |  |  |
| 1297 | 314.2.3 | CT3 part of Stage 3 for Inclusion of Media Resource Broker |  | 62d? | 2012-06-15 A | 2012-09-07 A | 100% | 2012-06-15 | 2012-09-07 | 62d? | finish no earlier than 2012-09-07 | C3 | 488h | 488h | MRB | PCG-29 | 29.165 | AT&T | Rel-11 | CP-56 | Adrian |  |  |  |  |

Notes:
- 1273: SP#57 stopped (activity transferred to Rel-12 Feature MTCe under UID_560522) / WI rapporteur e-mail: Rajavelsamy R (rajvel@samsung.com)
- 1274: SP#57 stopped (activity transferred to Rel-12 Feature MTCe / WI rapporteur e-mail: Rajavelsamy R (rajvel@samsung.com)
- 1275: SP#57 stopped (activity transferred to Rel-12 Feature MTCe / WI rapporteur e-mail: Rajavelsamy R (rajvel@samsung.com)
- 1276: SP#52 stopped / WI rapporteur e-mail: puneet.jain@intel.com
- 1277: SP#52 stopped / WI rapporteur e-mail: Rajavelsamy R (rajvel@samsung.com)
- 1278: CP#58 completed / WI rapporteur e-mail: kurt.bischinger@t-mobile.at
- 1279: SP#48 completed. Specify a CS domain USSD like service over IMS (see GSM Mobile User Initiated USSD) / WI rapporteur e-mail: kurt.bischinger@t-mobile.at
- 1280: SP#58 completed. No stage 2 impact, as reuse existing IMS architecture in TS 23.228 / WI rapporteur e-mail: reinhard.lauster@t-mobile.at
- 1281: CP#58 completed / WI rapporteur e-mail: reinhard.lauster@t-mobile.at, TS 24.390 Rapp: lili.yang@huawei.com
- 1282: CP#57 completed / WI rapporteur e-mail: reinhard.lauster@t-mobile.at
- 1283: TSG#56 completed / WI rapporteur e-mail: mona.mustapha@vodafone.com
- 1284: SP#53 completed. Use cases & service requirements to allow: 1) modification of QoS based on subscribers spending limits 2) enforcing of spending limits for roaming subscribers without having dedicated support in the visited network / WI rapporteur e-mail: mona.mustapha@vodafone.com
- 1285: SP#53 completed / WI rapporteur e-mail: Xu Xia (xiatony@huawei.com)
- 1286: SP#56 completed / WI rapporteur e-mail: Gerald.Goermer@nsn.com, shan.mingjun@huawei.com
- 1287: CP#56 completed / WI rapporteur e-mail: QiaoWeihua@huawei.com
- 1288: SP#55 completed (Stage 2/3 specified under CT1 Rel-11 Feature MRB (Inclusion of Media Resource Broker) UID_530021. Triggered by S1-102236/GSMA RILTE 10_007r1 (IREG LS_038 to 3GPP on Optimal Media Routing drawbacks) / WI rapporteur e-mail: mona.mustapha@vodafone.com
- 1289: SP#55 completed / WI rapporteur e-mail: Susana.Sabater@vodafone.com
- 1290: SP#53 completed / WI rapporteur e-mail: mona.mustapha@vodafone.com
- 1291: SP#55 no normative work in SA2. Stage 2/3 to be done in under CT1 Rel-11 Feature MRB (Inclusion of Media Resource Broker) UID_530021 / WI rapporteur e-mail: Susana.Sabater@vodafone.com
- 1292: Stage 1 and TR on Stage 2 in Rel-11 Feature OSCAR UID_490032 / WI rapporteur e-mail: Martin Dolly (md3135@att.com)
- 1293: CP#57 completed / WI rapporteur e-mail: Martin Dolly (md3135@att.com)
- 1294: CP#60 completed / WI rapporteur e-mail: Martin Dolly (md3135@att.com)
- 1295: CP#57 completed / WI rapporteur e-mail: Martin Dolly (md3135@att.com)
- 1296: CP#60 completed
- 1297: CP#57 completed / WI rapporteur e-mail: Martin Dolly (md3135@att.com)

| ID | WBS | Task | Duration | Start | Finish | Complete | Baseline start | Baseline finish | Baseline duration | Constraint | Resources | Work | Actual work | Acronym | PCG approved | WI rapporteur name | WI rapporteur e-mail | Release | TSG approved | MCC resp | Acronym_3GU_Export | Special Focus Doc | PCG stopped | TSG stopped |
| --- | --- | --- | --- | --- | --- | --- | --- | --- | --- | --- | --- | --- | --- | --- | --- | --- | --- | --- | --- | --- | --- | --- | --- | --- |
| 1298 | 315 | **Non Voice Emergency Services** | 323d? | 2010-12-16 A | 2012-03-07 A | 100% | 2010-12-16 | 2012-03-07 | 323d? |  | S1; S2 | 7736h | 7736h | NOVES | PCG-26 | Qualcomm | dwilliams@qualcomm.com | Rel-11 | SP-50 | Alain | NOVES |  |  |  |
| 1299 | 315.1 | Stage 1 for Non Voice Emergency Services | 202d? | 2010-12-16 A | 2011-09-21 A | 100% | 2010-12-16 | 2011-09-21 | 202d? | finish no earlier than 2011-09-21 | S1 | 1600h | 1600h | NOVES | PCG-26 | Qualcomm | dwilliams@qualcomm.com | Rel-11 | SP-50 | Alain |  |  |  |  |
| 1300 | 315.2 | Stage 2 for Non Voice Emergency Services (Support of IMS Emergency Sessions with Other Media on UTRAN and E-UTRAN) | 121d? | 2011-09-22 A | 2012-03-07 A | 100% | 2011-09-22 | 2012-03-07 | 121d? | finish no earlier than 2012-03-07 | S2 | 968h | 968h | NOVES-IMSESOM | PCG-27 | Alcatel-Lucent | Deb.Barclay@alcatel-lucent.com | Rel-11 | SP-53 | Maurice | NOVES-IMSESOM |  |  |  |
| 1301 | 316 | **Support for 3GPP Voice Interworking with Enterprise IP-PBX** | 516d? | 2011-03-23 A | 2013-03-01 A | 100% | 2011-03-23 | 2013-03-01 | 516d? |  | S1; C1 | 12376h | 12376h | VINE | PCG-26 | Tatara Systems | Phillip Brown (pbrown@tatarasystems.com) | Rel-11 | SP-51 | Alain | VINE |  |  |  |
| 1302 | 316.1 | Stage 1 for Support for 3GPP Voice Interworking with Enterprise IP-PBX | 133d? | 2011-03-23 A | 2011-09-21 A | 100% | 2011-03-23 | 2011-09-21 | 133d? | finish no earlier than 2011-09-21 | S1 | 1048h | 1048h | VINE | PCG-26 | Tatara Systems | Phillip Brown (pbrown@tatarasystems.com) | Rel-11 | SP-51 | Alain |  |  |  |  |
| 1303 | 316.2 | Stage 2/3 for Support for 3GPP Voice Interworking with Enterprise IP-PBX | 385d? | 2011-09-20 A | 2013-03-01 A | 100% | 2011-09-20 | 2013-03-01 | 385d? | finish no earlier than 2013-03-01 | C1 | 3072h | 3072h | VINE-CT1 | PCG-27 | Alcatel-Lucent | keith.drage@alcatel-lucent.com | Rel-11 | CP-53 | Frederic | VINE-CT1 |  |  |  |
| 1304 | 317 | **Anonymous Call Rejection in the CS domain** | 132d? | 2011-06-07 A | 2011-12-02 A | 100% | 2011-06-07 | 2011-12-02 | 132d? |  | S1; C4; C3 | 4616h | 4616h | ACR_CS | PCG-27 | Alcatel-Lucent | Betsy.Covell@alcatel-lucent.com | Rel-11 | SP-52 | Alain | ACR_CS |  |  |  |
| 1305 | 317.1 | Stage 1 for Anonymous Call Rejection in the CS domain | 2d? | 2011-06-07 A | 2011-06-08 A | 100% | 2011-06-07 | 2011-06-08 | 2d? | finish no earlier than 2011-06-07 | S1 | 16h | 16h | ACR_CS | PCG-27 | Alcatel-Lucent | Betsy.Covell@alcatel-lucent.com | Rel-11 | SP-52 | Alain |  |  |  |  |
| 1306 | 317.2 | **Core Network aspects of Anonymous Call Rejection in the CS domain** | 59d? | 2011-09-14 A | 2011-12-02 A | 100% | 2011-09-14 | 2011-12-02 | 59d? |  | C4; C3 | 1432h | 1432h | ACR_CS-CN | PCG-27 | Alcatel-Lucent | bruno.landais@alcatel-lucent.com | Rel-11 | CP-53 | Kimmo | ACR_CS-CN |  |  |  |
| 1307 | 317.2.1 | CT4 part of Core Network aspects of Anonymous Call Rejection in the CS domain (Stage 2/3) | 59d? | 2011-09-14 A | 2011-12-02 A | 100% | 2011-09-14 | 2011-12-02 | 59d? | finish no earlier than 2011-12-02 | C4 | 464h | 464h | ACR_CS-CN | PCG-27 | Alcatel-Lucent | bruno.landais@alcatel-lucent.com | Rel-11 | CP-53 | Kimmo |  |  |  |  |
| 1308 | 317.2.2 | CT3 part of Core Network aspects of Anonymous Call Rejection in the CS domain (Stage 3) | 3d? | 2011-09-14 A | 2011-09-16 A | 100% | 2011-09-14 | 2011-09-16 | 3d? | start no earlier than 2011-09-14 | C3 | 24h | 24h | ACR_CS-CN | PCG-27 | Alcatel-Lucent | bruno.landais@alcatel-lucent.com | Rel-11 | CP-53 | Adrian |  |  |  |  |
| 1309 | 318 | **Support for BroadBand Forum Accesses Interworking** | 792d? | 2009-12-10 A | 2012-12-12 A | 100% | 2009-12-10 | 2012-12-12 | 792d? |  | S2; S1; C1; C3; C4; IETF | 97983.8h | 97983.8h | BBAI | PCG-24 | Ericsson | peter.bleckert@ericsson.com | Rel-11 | SP-46 | Alain | BBAI | HNB, WLAN |  |  |
| 1310 | 318.1 | Stage 1 BB I: BBF interworking with home routed traffic for WLAN and H(e)NB | 76d? | 2009-12-10 A | 2010-03-25 A | 100% | 2009-12-10 | 2010-03-25 | 76d? | start no earlier than 2009-12-10 | S1 | 608h | 608h | BBAI | PCG-24 | Ericsson | Olle.Eriksson@ericsson.com | Rel-11 | SP-46 | Alain |  | HNB, WLAN |  |  |
| 1311 | 318.2 | TR on Stage 2 for BBAI | 588d? | 2010-03-26 A | 2012-06-20 A | 100% | 2010-03-26 | 2012-06-20 | 588d? | finish no earlier than 2012-06-19 | S2 | 4704h | 4704h | BBAI | PCG-24 | Ericsson | marco.spini@huawei.com | Rel-11 | SP-47 | Maurice |  | HNB, WLAN |  |  |
| 1312 | 318.3 | Stage 2 BB I: BBF interworking with home routed traffic for WLAN and H(e)NB | 588d? | 2010-03-26 A | 2012-06-20 A | 100% | 2010-03-26 | 2012-06-20 | 588d? | finish no earlier than 2012-06-20 | S2 | 4688.06h | 4688.06h | BBAI | PCG-24 | Ericsson | stefan.rommer@ericsson.com | Rel-11 | SP-47 | Maurice |  | HNB, WLAN |  |  |
| 1313 | 318.4 | (IETF) Stage 2 BB I: BBF interworking with home routed traffic for WLAN and H(e)NB | 266d? | 2011-12-12 A | 2012-12-12 A | 100% | 2011-12-12 | 2012-12-12 | 266d? | finish no earlier than 2012-11-24 | S2-IETF | 2119.59h | 2119.59h | BBAI | PCG-28 | Lionel Morand | Lionel Morand | Rel-11 | SP-54 | Maurice |  | HNB, WLAN |  |  |
| 1314 | 318.5 | **Stage 3 BB I - Core Network impacts: BBF interworking with home routed traffic for WLAN and H(e)NB** | 326d? | 2011-09-16 A | 2012-12-07 A | 100% | 2011-09-16 | 2012-12-07 | 326d? |  | C1; C3; C4 | 17288.2h | 17288.2h | BBAI_BBI-CT | PCG-27 | Ericsson | Zu.Qiang@Ericsson.com | Rel-11 | CP-53 | Frederic | BBAI_BBI-CT | HNB, WLAN |  |  |
| 1315 | 318.5.1 | TR on Stage 3 BB I for BBAI; UE to network protocols | 198d? | 2011-09-16 A | 2012-06-15 A | 100% | 2011-09-16 | 2012-06-15 | 198d? | finish no earlier than 2012-06-15 | C1 | 1568.15h | 1568.15h | BBAI_BBI-CT | PCG-27 | Ericsson | Zu.Qiang@Ericsson.com | Rel-11 | CP-53 | Frederic |  | HNB, WLAN |  |  |
| 1316 | 318.5.2 | TR on Stage 3 BB I for BBAI; Home (e)Node B – Security Gateway Interface | 77d? | 2012-03-02 A | 2012-06-15 A | 100% | 2012-03-02 | 2012-06-15 | 77d? | finish no earlier than 2012-06-01 | C4 | 608h | 608h | BBAI_BBI-CT | PCG-28 | Ericsson | Zu.Qiang@Ericsson.com | Rel-11 | CP-55 | Kimmo |  | HNB, WLAN |  |  |
| 1317 | 318.5.3 | Deleted - (IETF) on Stage 3 BB I for BBAI; Home (e)Node B – Security Gateway Interface | 77d? | 2012-03-02 A | 2012-06-15 A | 100% | 2012-03-02 | 2012-06-15 | 77d? | finish no earlier than 2012-06-15 | C4-IETF | 616h | 616h | BBAI_BBI-CT | PCG-28 | Lionel Morand |  | Rel-11 | CP-55 | Kimmo |  | HNB, WLAN | PCG-29 | CP-56 |
| 1318 | 318.5.4 | CT1 part of Stage 3 BB I: BBF interworking with home routed traffic for WLAN and H(e)NB | 258d? | 2011-09-16 A | 2012-09-07 A | 100% | 2011-09-16 | 2012-09-07 | 258d? | finish no earlier than 2012-09-07 | C1 | 2048h | 2048h | BBAI_BBI-CT | PCG-27 | Ericsson | Zu.Qiang@Ericsson.com | Rel-11 | CP-53 | Frederic |  | HNB, WLAN |  |  |
| 1319 | 318.5.5 | CT3 part of Stage 3 BB I: BBF interworking with home routed traffic for WLAN and H(e)NB | 259d? | 2011-09-16 A | 2012-09-07 A | 100% | 2011-09-16 | 2012-09-07 | 259d? | finish no earlier than 2012-09-07 | C3 | 2048h | 2048h | BBAI_BBI-CT | PCG-27 | Ericsson | Zu.Qiang@Ericsson.com | Rel-11 | CP-53 | Adrian |  | HNB, WLAN |  |  |
| 1320 | 318.5.6 | CT4 part of Stage 3 BB I: BBF interworking with home routed traffic for WLAN and H(e)NB | 326d? | 2011-09-16 A | 2012-12-07 A | 100% | 2011-09-16 | 2012-12-07 | 326d? | finish no earlier than 2012-12-07 | C4 | 2576h | 2576h | BBAI_BBI-CT | PCG-27 | Ericsson | Zu.Qiang@Ericsson.com | Rel-11 | CP-53 | Kimmo |  | HNB, WLAN |  |  |
| 1321 | 318.6 | Stage 1 BB II: BBF interworking with offload in access network for WLAN and for H(e)NB | 262d? | 2010-09-23 A | 2011-09-21 A | 100% | 2010-09-23 | 2011-09-21 | 262d? | finish no earlier than 2011-09-21 | S1 | 2080h | 2080h | BBAI_BBI-CT | PCG-25 | Ericsson | Olle.Eriksson@ericsson.com | Rel-11 | SP-49 | Alain |  | HNB, WLAN |  |  |
| 1322 | 318.7 | Stage 2 BB II: BBF interworking with offload in access network for WLAN and for H(e)NB | 455d? | 2010-09-28 A | 2012-06-20 A | 100% | 2010-09-28 | 2012-06-20 | 455d? | finish no earlier than 2012-06-20 | S2 | 3640h | 3640h | BBAI_BBI-CT | PCG-24 | Ericsson | stefan.rommer@ericsson.com | Rel-11 | SP-47 | Maurice |  | HNB, WLAN |  |  |

Notes:
- 1298: SP#55 Stage 2 completed. Triggered by SA1 Rel-11 TR 22.871 Study on Non Voice Emergency Services (FS_NOVES)
- 1299: SP#53 completed / Impacted TSs and TRs: 22.101
- 1300: SP#55 completed / Impacted TSs and TRs: 23.060, 23.167, 23.203, 23.401
- 1301: SP#53 Stage 1 completed. CP#59 completed. Triggered by Rel-11 TR 22.809 Study on Support for 3GPP Voice Interworking with Enterprise IP-PBX (FS_VINE) UID_480033
- 1302: SP#53 completed / Impacted TSs and TRs: 22.228
- 1303: CP#59 completed / Impacted TSs and TRs: 23.218, 24.229
- 1304: CP#54 completed
- 1305: SP#52 completed under TEI11. Approved WID and CRs in SP-110376 (22.082 CR#0005, 22.085 CR#0004, 22.081 CR#0007, 22.088 CR#0003, 22.004 CR#0013) / Impacted TSs and TRs: 22.004, 22.081, 22.082, 22.085, 22.088
- 1306: CP#54 completed / Impacted TSs and TRs: Stage 2/3
- 1307: CP#54 completed / Impacted TSs and TRs: 23.018, 23.081, 23.082, 23.085, 23.088, 23.205, 23.231, 24.088, 29.002, 29.011
- 1308: CP#53 completed / Impacted TSs and TRs: 29.163, 29.292
- 1309: SP#57 updated WID SP-120419=>SP-120539 (removed BB3 objectives not implemented in Stage 2). SP#56 completed. Triggered by BBF WT 203, WT-134 (interworking btw 3GPP EPS and BBF's fixed broadband accesses)
- 1310: SP#57 updated WID SP-120419=>SP-120539 (removed BB3 objectives not implemented in Stage 2). SP#47 completed. Provide service requirements for supporting interworking between 3GPP EPS and the fixed broadband accesses defined by BBF / Impacted TSs and TRs: 22.278 CR#0058
- 1311: TR 23.839 not Approved in Rel-11; progressed in Rel-12 under P4C-TI (UID_560824) / Impacted TSs and TRs: new TR 23.839
- 1312: SP#56 completed / Impacted TSs and TRs: 23.203, new 23.139
- 1313: Solved by IANA-registration. No RFC needed
- 1314: CP#58 completed / Impacted TSs and TRs: Stage 3
- 1315: CP#56 completed. Identify additional FMC specific procedures in addition to those in 24.302 (on access authentication & authorization and tunnel management; IP mobility mode selection; security aspects) / Impacted TSs and TRs: new TR 24.820
- 1316: CP#56 completed / Impacted TSs and TRs: new TR 29.839
- 1317: Draft removed from 3GPP documentation / Impacted TSs and TRs: draft-so-ipsecme-ikev2-cpext
- 1318: CP#57 completed / Impacted TSs and TRs: 24.229, new TS 24.139
- 1319: CP#57 completed / Impacted TSs and TRs: 29.212, 29.213, 29.215
- 1320: CP#58 completed / Impacted TSs and TRs: 23.008, 29.273, 29.274, new TS 29.139
- 1321: SP#53 completed / Impacted TSs and TRs: 22.278
- 1322: SP#56 completed / Impacted TSs and TRs: 23.203, 23.401, 23.402, 23.139

| ID | WBS | Task | Duration | Start | Finish | Complete | Baseline start | Baseline finish | Baseline duration | Constraint | Resources | Work | Actual work | Acronym | PCG approved | Impacted TSs and TRs | WI rapporteur name | WI rapporteur e-mail | Release | TSG approved | MCC resp | Special Focus Doc | Acronym_3GU_Export | PCG stopped | TSG stopped |
| --- | --- | --- | --- | --- | --- | --- | --- | --- | --- | --- | --- | --- | --- | --- | --- | --- | --- | --- | --- | --- | --- | --- | --- | --- | --- |
| 1323 | 318.8 | **Stage 3 BB II - Core Network impacts: BBF interworking with offload in access network for WLAN and for H(e)NB** | 259d? | 2011-09-16 A | 2012-09-07 A | 100% | 2011-09-16 | 2012-09-07 | 259d? |  | C3; C1; C4 | 12888h | 12888h | BBAI_BBII-CT | PCG-27 | Stage 3 | Ericsson | Susana.Fernandez@ericsson.com | Rel-11 | CP-53 | Adrian | HNB, WLAN | BBAI_BBII-CT |  |  |
| 1324 | 318.8.1 | TR on Stage 3 BB II for 3GPP System to Fixed Broadband Access Network Interworking; UE to network protocols | 198d? | 2011-09-16 A | 2012-06-15 A | 100% | 2011-09-16 | 2012-06-15 | 198d? | finish no earlier than 2012-06-15 | C1 | 1576h | 1576h | BBAI_BBII-CT | PCG-27 | 24.820 | Ericsson | Susana.Fernandez@ericsson.com | Rel-11 | CP-53 | Frederic | HNB, WLAN |  |  |  |
| 1325 | 318.8.2 | CT1 part of Stage 3 BB II: BBF interworking with offload in access network for WLAN and for H(e)NB | 259d? | 2011-09-16 A | 2012-09-07 A | 100% | 2011-09-16 | 2012-09-07 | 259d? | finish no earlier than 2012-09-07 | C1 | 2064h | 2064h | BBAI_BBII-CT | PCG-27 | new TS 24.320 | Ericsson | Susana.Fernandez@ericsson.com | Rel-11 | CP-53 | Frederic | HNB, WLAN |  |  |  |
| 1326 | 318.8.3 | CT3 part of Stage 3 BB II: BBF interworking with offload in access network for WLAN and for H(e)NB | 259d? | 2011-09-16 A | 2012-09-07 A | 100% | 2011-09-16 | 2012-09-07 | 259d? | start no earlier than 2011-09-16 | C3 | 2056h | 2056h | BBAI_BBII-CT | PCG-27 | 29.212, 29.213, 29.215 | Ericsson | Susana.Fernandez@ericsson.com | Rel-11 | CP-53 | Adrian | HNB, WLAN |  |  |  |
| 1327 | 318.8.4 | CT4 part of Stage 3 BB II: BBF interworking with offload in access network for WLAN and for H(e)NB | 122d? | 2011-09-16 A | 2012-03-02 A | 100% | 2011-09-16 | 2012-03-02 | 122d? | start no earlier than 2011-09-16 | C4 | 976h | 976h | BBAI_BBII-CT | PCG-27 | 23.008, 29.273 | Ericsson | Susana.Fernandez@ericsson.com | Rel-11 | CP-53 | Kimmo | HNB, WLAN |  |  |  |
| 1328 | 318.9 | Deleted - Stage 1 BB III: BBF convergence and network based mobility | 262d? | 2010-09-23 A | 2011-09-21 A | 100% | 2010-09-23 | 2011-09-21 | 262d? | finish no earlier than 2011-09-21 | S1 | 2080h | 2080h | BBAI_BBII-CT | PCG-25 | 22.278 | Huawei | Amar Deol (adeol@huawei.com) | Rel-11 | SP-49 | Alain | HNB, WLAN |  | PCG-29 | SP-57 |
| 1329 | 318.10 | Deleted - Stage 2 BB III: BBF convergence and network based mobility | 380d? | 2010-09-28 A | 2012-03-07 A | 100% | 2010-09-28 | 2012-03-07 | 380d? | finish no earlier than 2012-03-07 | S2 | 3040h | 3040h | BBAI_BBII-CT | PCG-24 | 23.203, 23.401, 23.402, 23.139 | Huawei | marco.spini@huawei.com | Rel-11 | SP-47 | Maurice | HNB, WLAN |  | PCG-28 | SP-55 |
| 1330 | 318.11 | **Deleted - Stage 3 BB III - Core Network impacts: BBF convergence and network based mobility** | 122d? | 2011-09-16 A | 2012-03-02 A | 100% | 2011-09-16 | 2012-03-02 | 122d? |  | C3; C1; C4 | 6832h | 6832h | BBAI_BBIII-CT | PCG-27 | Stage 3 | Huawei | qiaoweihua@huawei.com | Rel-11 | CP-53 | Adrian | HNB, WLAN | BBAI_BBIII-CT | PCG-28 | CP-55 |
| 1331 | 318.11.1 | Deleted - TR on Stage 3 BB III for 3GPP System to Fixed Broadband Access Network Interworking; UE to network protocols | 122d? | 2011-09-16 A | 2012-03-02 A | 100% | 2011-09-16 | 2012-03-02 | 122d? | start no earlier than 2011-09-16 | C1 | 976h | 976h | BBAI_BBIII-CT | PCG-27 | new TR 24.820 | Huawei | qiaoweihua@huawei.com | Rel-11 | CP-53 | Frederic | HNB, WLAN |  | PCG-28 | CP-55 |
| 1332 | 318.11.2 | Deleted - CT1 part of Stage 3 BB III: BBF convergence and network based mobility | 122d? | 2011-09-16 A | 2012-03-02 A | 100% | 2011-09-16 | 2012-03-02 | 122d? | start no earlier than 2011-09-16 | C1 | 976h | 976h | BBAI_BBIII-CT | PCG-27 | TBD | Huawei | qiaoweihua@huawei.com | Rel-11 | CP-53 | Frederic | HNB, WLAN |  | PCG-28 | CP-55 |
| 1333 | 318.11.3 | Deleted - CT3 part of Stage 3 BB III: BBF convergence and network based mobility | 122d? | 2011-09-16 A | 2012-03-02 A | 100% | 2011-09-16 | 2012-03-02 | 122d? | start no earlier than 2011-09-16 | C3 | 976h | 976h | BBAI_BBIII-CT | PCG-27 | 29.212, 29.213, 29.215 | Huawei | qiaoweihua@huawei.com | Rel-11 | CP-53 | Adrian | HNB, WLAN |  | PCG-28 | CP-55 |
| 1334 | 318.11.4 | Deleted - CT4 part of Stage 3 BB III: BBF convergence and network based mobility | 122d? | 2011-09-16 A | 2012-03-02 A | 100% | 2011-09-16 | 2012-03-02 | 122d? | start no earlier than 2011-09-16 | C4 | 976h | 976h | BBAI_BBIII-CT | PCG-27 | 23.008, 29.273 | Huawei | qiaoweihua@huawei.com | Rel-11 | CP-53 | Kimmo | HNB, WLAN |  | PCG-28 | CP-55 |
| 1335 | 319 | **Single Radio Voice Call Continuity (SRVCC) aspect of enhancements for Multimedia Priority Service** | 398d? | 2010-06-10 A | 2011-12-14 A | 100% | 2010-06-10 | 2011-12-14 | 398d? |  | S2 | 8432h | 8432h | eMPS_SRVCC | PCG-25 | Stage 2 | NTT DoCoMo | Atsushi Minokuchi (minokuchi@nttdocomo.co.jp) | Rel-11 | SP-48 | Maurice | Public Safety (I-A) | eMPS_SRVCC |  |  |
| 1336 | 319.1 | TR on SRVCC for eMPS | 260d? | 2010-06-10 A | 2011-06-08 A | 100% | 2010-06-10 | 2011-06-08 | 260d? | finish no earlier than 2011-06-08 | S2 | 2080h | 2080h | eMPS_SRVCC | PCG-25 | new TR 23.854 | NTT DoCoMo | Atsushi Minokuchi (minokuchi@nttdocomo.co.jp) | Rel-11 | SP-48 | Maurice | Public Safety (I-A) |  |  |  |
| 1337 | 319.2 | Stage 2 on SRVCC for eMPS | 398d? | 2010-06-10 A | 2011-12-14 A | 100% | 2010-06-10 | 2011-12-14 | 398d? | finish no earlier than 2011-12-14 | S2 | 3168h | 3168h | eMPS_SRVCC | PCG-25 | 23.216, 23.237 | NTT DoCoMo | Atsushi Minokuchi (minokuchi@nttdocomo.co.jp) | Rel-11 | SP-48 | Maurice | Public Safety (I-A) |  |  |  |
| 1338 | 320 | **Single Radio Video Call Continuity for 3G-CS** | 440d? | 2010-10-15 A | 2012-06-15 A | 100% | 2010-10-15 | 2012-06-15 | 440d? |  | S2; C1; C3; C4 | 26572.4h | 26572.4h | vSRVCC | PCG-26 |  | Samsung | xiaowan.ke@samsung.com | Rel-11 | SP-50 | Maurice |  | vSRVCC |  |  |
| 1339 | 320.1 | Stage 2 for Single Radio Video Call Continuity for 3G-CS | 199.85d? | 2010-10-15 A | 2011-09-21 A | 100% | 2010-10-15 | 2011-09-21 | 199.85d? | finish no earlier than 2011-12-07 | S2 | 1580.41h | 1580.41h | vSRVCC | PCG-26 | 23.203, 23.216, 23.237 | Samsung | xiaowan.ke@samsung.com | Rel-11 | SP-50 | Maurice |  |  |  |  |
| 1340 | 320.2 | **CN aspects of Single Radio Video Call Continuity for 3G-CS** | 275d? | 2011-06-03 A | 2012-06-15 A | 100% | 2011-06-03 | 2012-06-15 | 275d? |  | C1; C3; C4 | 10912h | 10912h | vSRVCC-CT | PCG-27 |  | NEC | gottfried.punz@neclab.eu | Rel-11 | CP-52 | Frederic |  | vSRVCC-CT |  |  |
| 1341 | 320.2.1 | CT1 aspects of Single Radio Video Call Continuity for 3G-CS | 275d? | 2011-06-03 A | 2012-06-15 A | 100% | 2011-06-03 | 2012-06-15 | 275d? | finish no earlier than 2012-06-15 | C1 | 2184h | 2184h | vSRVCC-CT | PCG-27 | 24.008, 24.237, 24.301 | NEC | gottfried.punz@neclab.eu | Rel-11 | CP-52 | Frederic |  |  |  |  |
| 1342 | 320.2.2 | CT3 aspects of Single Radio Video Call Continuity for 3G-CS | 134d? | 2011-06-03 A | 2011-12-02 A | 100% | 2011-06-03 | 2011-12-02 | 134d? | finish no earlier than 2011-12-02 | C3 | 1064h | 1064h | vSRVCC-CT | PCG-27 | 29.211, 29.212, 29.213, 29.215 | NEC | gottfried.punz@neclab.eu | Rel-11 | CP-52 | Adrian |  |  |  |  |
| 1343 | 320.2.3 | CT4 aspects of Single Radio Video Call Continuity for 3G-CS | 134d? | 2011-06-03 A | 2011-12-02 A | 100% | 2011-06-03 | 2011-12-02 | 134d? | finish no earlier than 2011-12-02 | C4 | 1064h | 1064h | vSRVCC-CT | PCG-27 | 29.280 | NEC | gottfried.punz@neclab.eu | Rel-11 | CP-52 | Kimmo |  |  |  |  |
| 1344 | 321 | **Network-provided Location information for IMS (NETLOC)** | 720d? | 2010-06-10 A | 2013-03-01 A | 100% | 2010-06-10 | 2013-03-01 | 720d? |  | S2; S1; S5; C3; C4; C1 | 57274.7h | 57274.7h | NWK-PL2IMS | PCG-25 |  | T-Mobile | michele.zarri@t-mobile.co.uk | Rel-11 | SP-48 | Maurice |  | NWK-PL2IMS |  |  |
| 1345 | 321.1 | Stage 1 for Network-provided Location information for IMS | 203d? | 2010-12-15 A | 2011-09-21 A | 100% | 2010-12-15 | 2011-09-21 | 203d? | finish no earlier than 2011-09-21 | S1 | 1608h | 1608h | NWK-PL2IMS | PCG-26 | 22.115 | n/a | n/a | Rel-11 | SP-50 | Alain |  |  |  |  |
| 1346 | 321.2 | TR on Stage 2 for Network-provided Location information for IMS | 395d? | 2010-06-10 A | 2011-12-14 A | 100% | 2010-06-10 | 2011-12-14 | 395d? | finish no earlier than 2011-12-06 | S2 | 3160h | 3160h | NWK-PL2IMS | PCG-25 | new TR 23.842 | T-Mobile | michele.zarri@t-mobile.co.uk | Rel-11 | SP-48 | Maurice |  |  |  |  |
| 1347 | 321.3 | Stage 2 for Network-provided Location information for IMS | 455d? | 2010-06-15 A | 2012-03-07 A | 100% | 2010-06-15 | 2012-03-07 | 455d? | finish no earlier than 2012-03-07 | S2 | 3640h | 3640h | NWK-PL2IMS | PCG-25 | 23.060, 23.203, 23.228, 23.401 | T-Mobile | michele.zarri@t-mobile.co.uk | Rel-11 | SP-48 | Maurice |  |  |  |  |
| 1348 | 321.4 | Charging for Network-provided Location information for IMS | 515d? | 2010-09-23 A | 2012-09-12 A | 100% | 2010-09-23 | 2012-09-12 | 515d? | finish no earlier than 2012-09-12 | S5 | 4120h | 4120h | NWK-PL2IMS_CH | PCG-25 | Stage 2 (32.240, 32.260), Stage 3 (32.298, 32.299) | Nokia Siemens Networks | Gerald.Goermer@nsn.com | Rel-11 | SP-49 | Mirko |  | NWK-PL2IMS_CH |  |  |

Notes:
- 1323: CP#57 completed
- 1324: CP#56 completed
- 1325: CP#57 completed
- 1326: CP#57 completed
- 1327: CP#55 completed
- 1328: SP#57 stopped. Updated WID SP-120419=>SP-120539 (removed BB3 objectives not implemented in Stage 2). SP#53 completed
- 1329: SP#57 updated WID SP-120419=>SP-120539 (removed BB3 objectives not implemented in Stage 2). SP#55 stopped
- 1330: CP#55 stopped
- 1331: CP#55 stopped
- 1332: CP#55 stopped
- 1333: CP#55 stopped
- 1334: CP#55 stopped
- 1335: SP#54 completed. Analyze and if needed specify mechanisms for the priority handling of SRVCC with regard to LTE/EPC
- 1336: SP#52 completed
- 1337: SP#54 completed
- 1338: CP#56 completed. Provide Single Radio VIDEO Call Continuity from E-UTRAN to UTRAN-CS based on the agreed architecture alternative in TR 23.886
- 1339: SP#53 completed. Triggered by Feasibility Study on video call handover capability in TR 23.886 UID_470048 Study on Single Radio Video Call Continuity for 3G-CS (FS_vSRVCC)
- 1340: Stage 3. CP#56 completed
- 1341: CP#56 completed
- 1342: CP#54 completed
- 1343: CP#54 completed
- 1344: Covers the case where UE is served by a 3GPP RAN. Architecture making Cell/PLMN ID (UE is camped on) available to IMS nodes when the operator needs to record this information either to fulfil legal obligations or for charging.
- 1345: SP#53 completed
- 1346: SP#54 completed
- 1347: SP#55 completed
- 1348: SP#57 completed

| ID | WBS | Task | Type | Duration | Start | Finish | Complete | Remaining | Baseline start | Baseline finish | Baseline duration | Total slack | Constraint | Resources | Work | Actual work | Acronym | PCG approved | WI rapporteur name | WI rapporteur e-mail | Release | TSG approved | MCC resp | Acronym_3GU_Export | Special Focus Doc | PCG stopped | TSG stopped |
| --- | --- | --- | --- | --- | --- | --- | --- | --- | --- | --- | --- | --- | --- | --- | --- | --- | --- | --- | --- | --- | --- | --- | --- | --- | --- | --- | --- |
| 1349 | 321.5 | **CT aspects of Network-provided Location information for IMS (Stage 3)** |  | 266d? | 2012-03-02 A | 2013-03-01 A | 100% |  | 2012-03-02 | 2013-03-01 | 266d? |  |  | C3; C4; C1 | 10186.7h | 10186.7h | NWK-PL2IMS_CT | PCG-28 | Huawei | Qiao Weihua (qiaoweihua@huawei.com) | Rel-11 | CP-55 | Adrian | NWK-PL2IMS_CT |  |  |  |
| 1350 | 321.5.1 | CT3 part of CT aspects of Network-provided Location information for IMS |  | 138d? | 2012-03-02 A | 2012-09-07 A | 100% |  | 2012-03-02 | 2012-09-07 | 138d? |  | finish no earlier than 2012-09-07 | C3 | 1088h | 1088h | NWK-PL2IMS_CT | PCG-28 | Huawei | Qiao Weihua (qiaoweihua@huawei.com) | Rel-11 | CP-55 | Adrian |  |  |  |  |
| 1351 | 321.5.2 | CT4 part of CT aspects of Network-provided Location information for IMS |  | 77d? | 2012-03-02 A | 2012-06-15 A | 100% |  | 2012-03-02 | 2012-06-15 | 77d? |  | finish no earlier than 2012-06-01 | C4 | 608h | 608h | NWK-PL2IMS_CT | PCG-28 | Huawei | Qiao Weihua (qiaoweihua@huawei.com) | Rel-11 | CP-55 | Kimmo |  |  |  |  |
| 1352 | 321.5.3 | CT1 part of CT aspects of Network-provided Location information for IMS |  | 266d? | 2012-03-02 A | 2013-03-01 A | 100% |  | 2012-03-02 | 2013-03-01 | 266d? |  | finish no earlier than 2013-06-14 | C1 | 2106.67h | 2106.67h | NWK-PL2IMS_CT | PCG-28 | Huawei | Qiao Weihua (qiaoweihua@huawei.com) | Rel-11 | CP-55 | Frederic |  |  |  |  |
| 1353 | 322 | **Service Awareness and Privacy Policies** |  | 301.15d? | 2010-10-12 A | 2011-12-02 A | 100% |  | 2010-10-12 | 2011-12-02 | 301.15d? |  |  | S2; S1; C3 | 10667.6h | 10667.6h | SAPP | PCG-26 | Allot | Alla Goldner (agoldner@allot.com) | Rel-11 | SP-50 | Maurice | SAPP |  |  |  |
| 1354 | 322.1 | Stage 1 for Service Awareness and Privacy Policies |  | 46.15d? | 2010-10-12 A | 2010-12-15 A | 100% |  | 2010-10-12 | 2010-12-15 | 46.15d? |  | finish no earlier than 2010-12-15 | S1 | 369.2h | 369.2h | SAPP | PCG-26 | Allot | Alla Goldner (agoldner@allot.com) | Rel-11 | SP-50 | Maurice |  |  |  |  |
| 1355 | 322.2 | Stage 2 for Service Awareness and Privacy Policies |  | 199.85d? | 2010-10-15 A | 2011-09-21 A | 100% |  | 2010-10-15 | 2011-09-21 | 199.85d? |  | finish no earlier than 2011-09-21 | S2 | 1582.8h | 1582.8h | SAPP | PCG-26 | Allot | Alla Goldner (agoldner@allot.com) | Rel-11 | SP-50 | Maurice |  |  |  |  |
| 1356 | 322.3 | CT3 part of Service Awareness and Privacy Policies |  | 187d? | 2011-03-18 A | 2011-12-02 A | 100% |  | 2011-03-18 | 2011-12-02 | 187d? |  | finish no earlier than 2011-12-02 | C3 | 1488h | 1488h | SAPP-CT3 | PCG-26 | Allot | Alla Goldner (agoldner@allot.com) | Rel-11 | CP-51 | Adrian | SAPP-CT3 |  |  |  |
| 1357 | 323 | **VPLMN Autonomous CSG Roaming** |  | 307d? | 2010-10-15 A | 2011-12-14 A | 100% |  | 2010-10-15 | 2011-12-14 | 307d? |  |  | S2; C4 | 6974.61h | 6974.61h | VCSG | PCG-26 | Qualcomm | AC Mahendran (ac@qualcomm.com) | Rel-11 | SP-50 | Maurice | VCSG |  |  |  |
| 1358 | 323.1 | Stage 2 for VPLMN Autonomous CSG Roaming |  | 260.85d? | 2010-10-15 A | 2011-12-14 A | 100% |  | 2010-10-15 | 2011-12-14 | 260.85d? |  | finish no earlier than 2011-12-07 | S2 | 2062.61h | 2062.61h | VCSG | PCG-26 | Qualcomm | AC Mahendran (ac@qualcomm.com) | Rel-11 | SP-50 | Maurice |  |  |  |  |
| 1359 | 323.2 | CT aspects of VPLMN Autonomous CSG Roaming | milestone | 0d? | 2011-12-07 A | 2011-12-07 A | 100% |  | 2011-12-07 | 2011-12-07 | 0d? |  | finish no earlier than 2012-09-07 | C4 |  |  | VCSG-St3 | PCG-27 | ZTE | Fei Lu (lu.fei1@zte.com.cn) | Rel-11 | CP-53 | Kimmo | VCSG-St3 |  |  |  |
| 1360 | 324 | **Data Identification in Access Network Discovery and Selection Function (ANDSF)** |  | 455d? | 2011-03-23 A | 2012-12-07 A | 100% |  | 2011-03-23 | 2012-12-07 | 455d? |  |  | S2; C1 | 12488h | 12488h | DIDA | PCG-26 | Qualcomm | Gerardo Giaretta (gerardo@qualcomm.com) | Rel-11 | SP-51 | Maurice | DIDA |  |  |  |
| 1361 | 324.1 | TR on Stage 2 for Data Identification in ANDSF |  | 193d? | 2011-03-23 A | 2011-12-14 A | 100% |  | 2011-03-23 | 2011-12-14 | 193d? |  | finish no earlier than 2011-12-07 | S2 | 1544h | 1544h | DIDA | PCG-26 | Qualcomm | Gerardo Giaretta (gerardo@qualcomm.com) | Rel-11 | SP-51 | Maurice |  |  |  |  |
| 1362 | 324.2 | Stage 2 for Data Identification in ANDSF |  | 253d? | 2011-03-24 A | 2012-03-07 A | 100% |  | 2011-03-24 | 2012-03-07 | 253d? |  | finish no earlier than 2012-03-07 | S2 | 2024h | 2024h | DIDA | PCG-26 | Qualcomm | Gerardo Giaretta (gerardo@qualcomm.com) | Rel-11 | SP-51 | Maurice |  |  |  |  |
| 1363 | 324.3 | CT aspects of Data Identification in Access Network Discovery and Selection Function (ANDSF) Stage 3 |  | 205d? | 2012-03-02 A | 2012-12-07 A | 100% |  | 2012-03-02 | 2012-12-07 | 205d? |  | finish no earlier than 2012-12-07 | C1 | 1640h | 1640h | DIDA-CT | PCG-28 | Qualcomm | Patrick Stupar (pstupar@qualcomm.com) | Rel-11 | CP-55 | Frederic | DIDA-CT |  |  |  |
| 1364 | 325 | **LOcation-Based Selection of gaTEways foR WLAN** |  | 327d? | 2011-03-23 A | 2012-06-15 A | 100% |  | 2011-03-23 | 2012-06-15 | 327d? |  |  | S2; C4 | 10170.5h | 10170.5h | LOBSTER | PCG-26 | ZTE | zhu.chunhui@zte.com.cn | Rel-11 | SP-51 | Maurice | LOBSTER | WLAN |  |  |
| 1365 | 325.1 | Stage 2 for LOcation-Based Selection of gaTEways foR WLAN |  | 194d? | 2011-03-23 A | 2011-12-14 A | 100% |  | 2011-03-23 | 2011-12-14 | 194d? |  | finish no earlier than 2011-12-07 | S2 | 1546.52h | 1546.52h | LOBSTER | PCG-26 | ZTE | zhu.chunhui@zte.com.cn | Rel-11 | SP-51 | Maurice |  | WLAN |  |  |
| 1366 | 325.2 | **CT aspects of LOcation-Based Selection of gaTEways foR WLAN** |  | 142d? | 2011-12-02 A | 2012-06-15 A | 100% |  | 2011-12-02 | 2012-06-15 | 142d? |  |  | C4 | 3392h | 3392h | LOBSTER-CT | PCG-28 | ZTE | zhou.xingyue@zte.com.cn | Rel-11 | CP-54 | Kimmo | LOBSTER-CT | WLAN |  |  |
| 1367 | 325.2.1 | CT4 part of CT aspects of LOcation-Based Selection of gaTEways foR WLAN |  | 142d? | 2011-12-02 A | 2012-06-15 A | 100% |  | 2011-12-02 | 2012-06-15 | 142d? |  | finish no earlier than 2012-06-15 | C4 | 1128h | 1128h | LOBSTER-CT | PCG-28 | ZTE | zhou.xingyue@zte.com.cn | Rel-11 | CP-54 | Kimmo |  | WLAN |  |  |
| 1368 | 325.2.2 | Deleted - CT1 part of CT aspects of LOcation-Based Selection of gaTEways foR WLAN |  | 142d? | 2011-12-02 A | 2012-06-15 A | 100% |  | 2011-12-02 | 2012-06-15 | 142d? |  | finish no earlier than 2012-06-15 | C1 | 1128h | 1128h | LOBSTER-CT | PCG-28 | ZTE | zhou.xingyue@zte.com.cn | Rel-11 | CP-54 | Frederic |  | WLAN | PCG-29 | CP-56 |
| 1369 | 326 | **Single Radio Voice Call Continuity from UTRAN/GERAN to E-UTRAN/HSPA** |  | 929d? | 2011-09-12 A | 2015-03-15 | 94% | 55.56d? | 2011-09-12 | 2014-12-05 | 856d? | 589d |  | S2; C1; C3; C4; G2; R2; R3; R5 | 83776.8h | 53649.7h | rSRVCC | PCG-27 | Orange | antoine.mouquet@orange-ftgroup.com | Rel-11 | SP-53 | Maurice | rSRVCC |  |  |  |
| 1370 | 326.1 | Stage 2 for Single Radio Voice Call Continuity from UTRAN/GERAN to E-UTRAN/HSPA |  | 197d? | 2011-09-22 A | 2012-06-20 A | 100% |  | 2011-09-22 | 2012-06-20 | 197d? |  | finish no earlier than 2012-06-20 | S2 | 1568h | 1568h | rSRVCC | PCG-27 | Orange | antoine.mouquet@orange-ftgroup.com | Rel-11 | SP-53 | Maurice |  |  |  |  |
| 1371 | 326.2 | **CT aspects for Single Radio Voice Call Continuity from UTRAN/GERAN to E-UTRAN/HSPA (Stage 3)** |  | 259d? | 2011-09-16 A | 2012-09-07 A | 100% |  | 2011-09-16 | 2012-09-07 | 259d? |  |  | C1; C3; C4 | 12360h | 12360h | rSRVCC-CT | PCG-27 | Ericsson | ivo.sedlacek@ericsson.com | Rel-11 | CP-53 | Frederic | rSRVCC-CT |  |  |  |
| 1372 | 326.2.1 | CT1 part for Single Radio Voice Call Continuity from UTRAN/GERAN to E-UTRAN/HSPA |  | 258d? | 2011-09-16 A | 2012-09-07 A | 100% |  | 2011-09-16 | 2012-09-07 | 258d? |  | finish no earlier than 2012-09-07 | C1 | 2048h | 2048h | rSRVCC-CT | PCG-27 | Ericsson | ivo.sedlacek@ericsson.com | Rel-11 | CP-53 | Frederic |  |  |  |  |
| 1373 | 326.2.2 | CT3 part for Single Radio Voice Call Continuity from UTRAN/GERAN to E-UTRAN/HSPA |  | 257d? | 2011-09-19 A | 2012-09-07 A | 100% |  | 2011-09-19 | 2012-09-07 | 257d? |  | finish no earlier than 2012-09-07 | C3 | 2048h | 2048h | rSRVCC-CT | PCG-27 | Ericsson | ivo.sedlacek@ericsson.com | Rel-11 | CP-53 | Adrian |  |  |  |  |
| 1374 | 326.2.3 | CT4 part for Single Radio Voice Call Continuity from UTRAN/GERAN to E-UTRAN/HSPA |  | 257d? | 2011-09-19 A | 2012-09-07 A | 100% |  | 2011-09-19 | 2012-09-07 | 257d? |  | finish no earlier than 2012-09-07 | C4 | 2048h | 2048h | rSRVCC-CT | PCG-27 | Ericsson | ivo.sedlacek@ericsson.com | Rel-11 | CP-53 | Kimmo |  |  |  |  |
| 1375 | 326.3 | GERAN aspects of Single Radio Voice Call Continuity from UTRAN/GERAN to E-UTRAN/HSPA (Stage 3) |  | 476.1d? | 2011-09-12 A | 2013-06-28 A | 100% |  | 2011-09-12 | 2013-06-28 | 476.1d? |  | finish no earlier than 2013-11-22 | G2 | 2048h | 2048h | rSRVCC-GERAN | PCG-27 | ZTE | li.jing4@zte.com.cn | Rel-11 | GP-51 | Gert | rSRVCC-GERAN |  |  |  |

Notes:
- 1349: Stage 3
- 1350: CP#57 completed / Impacted TSs and TRs: 29.212, 29.214, 29.215
- 1351: CP#56 completed / Impacted TSs and TRs: 23.008, 29.002, 29.060, 29.230, 29.272, 29.274, 29.305, 29.328, 29.329
- 1352: CP#59 completed / Impacted TSs and TRs: 24.229, 24.292
- 1353: CP#54 completed. Triggered by the SA1,SA2 Rel-10 TR 23.813 Study on Policy solutions and enhancements (FS_PP) UID_440047
- 1354: For deep packet inspection (i.e. Traffic Detection Functionality) SA1 indicated that no new requirements are needed (see Objective of FS_PP SA1,SA2 Rel-10 Study on Policy solutions and enhancements UID_440047 TR 23.813)
- 1355: SP#53 completed / Impacted TSs and TRs: 23.203
- 1356: CP#54 completed. Stage 3 to support Application Detection and Control Functionality. Update Gx / introduce Sd reference points and procedures. Update S9 reference point in roaming scenarios / Impacted TSs and TRs: 29.212, 29.213, 29.214, 29.215
- 1357: CP#56 completed. Linked to Rel-10 UID_450053 Enhanced Home NodeB / eNodeB (EHNB). Implements Rel-9 requirements for CSG support in SA1 TS 22.220
- 1358: SP#54 completed / Impacted TSs and TRs: 23.002, 23.060, 23.401
- 1359: CP#57 completed / Impacted TSs and TRs: 23.003, 23.007, 23.008, 23.012, 29.002, 29.230, 29.272
- 1360: SP#58 completed. Linked to Rel-10 IFOM (IP Flow Mobility and seamless WLAN offload) UID_450041. Defines IP flow mobility, seamless and non seamless WLAN offload and respective ANDSF extensions / Impacted TSs and TRs: Stage 2/3
- 1361: SP#54 completed / Impacted TSs and TRs: New TR 23.855
- 1362: SP#55 completed / Impacted TSs and TRs: 23.402
- 1363: CP#58 completed / Impacted TSs and TRs: 24.302, 24.312
- 1364: CP#56 completed. Related to UID_350027 SAE for support for non-3GPP accesses (SAES-SA-FP_n3GPP). Enhancements to ePDG and PDN GW selection functions for S2b and S2c based on UE location
- 1365: SP#54 completed / Impacted TSs and TRs: 23.402
- 1366: Stage 3. CP#56 completed / Impacted TSs and TRs: Stage 3
- 1367: CP#56 completed / Impacted TSs and TRs: 29.273
- 1368: CP#56 stopped / Impacted TSs and TRs: 24.302
- 1369: Stage 1 in Rel-8 TS 22.278 clause 7.1.4.2. Triggered by Rel-11 TR 23.885 Study on Single Radio Voice Call Continuity from UTRAN/GERAN to E-UTRAN/HSPA (FS_rSRVCC) UID_460030
- 1370: SP#56 completed / Impacted TSs and TRs: 23.216, 23.237
- 1371: CP#57 completed / Impacted TSs and TRs: Stage 3
- 1372: CP#57 completed / Impacted TSs and TRs: 23.009, 24.008, 24.229, 24.237, 24.292, 24.301
- 1373: CP#57 completed / Impacted TSs and TRs: 29.165, 29.292
- 1374: CP#57 completed / Impacted TSs and TRs: 23.003, 23.008, 29.002, 29.230, 29.272, 29.280, 29.303, 29.305, 29.328
- 1375: GP#60 completed. GP#51 approved WID / Impacted TSs and TRs: 44.018, 48.008

| ID | WBS | Task | Duration | Start | Finish | Complete | Remaining | Baseline start | Baseline finish | Baseline duration | Total slack | Constraint | Resources | Work | Actual work | Acronym | PCG approved | Impacted TSs and TRs | WI rapporteur name | Release | TSG approved | MCC resp | Acronym_3GU_Export | Status Report | Special Focus Doc | PCG stopped | TSG stopped |
| --- | --- | --- | --- | --- | --- | --- | --- | --- | --- | --- | --- | --- | --- | --- | --- | --- | --- | --- | --- | --- | --- | --- | --- | --- | --- | --- | --- |
| 1376 | 326.4 | **UTRAN aspects of Single Radio Voice Call Continuity from UTRAN/GERAN to E-UTRAN/HSPA** | 325d? | 2011-09-19 A | 2012-12-07 A | 100% |  | 2011-09-19 | 2012-12-07 | 325d? |  |  | R3; R2 | 10400h | 10400h | rSRVCC-RAN_UTRA | PCG-27 | UTRA | Huawei | Rel-11 | RP-53 | Juha | rSRVCC-RAN_UTRA |  |  |  |  |
| 1377 | 326.4.1 | Core part: UTRAN aspects of Single Radio Voice Call Continuity from UTRAN/GERAN to E-UTRAN/HSPA | 325d? | 2011-09-19 A | 2012-12-07 A | 100% |  | 2011-09-19 | 2012-12-07 | 325d? |  | finish no earlier than 2012-12-07 | R3; R2 | 5200h | 5200h | rSRVCC-RAN_UTRA-Core | PCG-27 | 25.331, 25.401, 25.413 | Huawei | Rel-11 | RP-53 | Juha | rSRVCC-RAN_UTRA-Core | RP-121553 |  |  |  |
| 1378 | 326.5 | Test part: Single Radio Voice Call Continuity from UTRAN/GERAN to E-UTRAN/HSPA | 196d? | 2014-06-15 A | 2015-03-15 | 40% | 117.6d? | 2014-06-13 | 2014-12-05 | 126d? | 589d | finish no earlier than 2015-03-15 | R5 | 1568h | 627.2h | rSRVCC-UEConTest | PCG-33 | 36.508, 36.523-1, 36.523-2, 36.523-3 | Ericsson | Rel-11 | RP-64 |  | rSRVCC-UEConTest | RP-141167 |  |  |  |
| 1379 | 327 | **S2a Mobility based On GTP and WLAN access to EPC** | 651d? | 2011-09-22 A | 2014-03-05 A | 100% |  | 2011-09-22 | 2014-03-05 | 651d? |  |  | S2; C4; C1; C3; IETF | 54000h | 54000h | SaMOG_WLAN | PCG-27 | Stage 2/3 | ZTE | Rel-11 | SP-53 | Maurice | SaMOG_WLAN |  | WLAN |  |  |
| 1380 | 327.1 | Stage 2 for S2a Mobility based On GTP and WLAN access to EPC | 121d? | 2011-09-22 A | 2012-03-07 A | 100% |  | 2011-09-22 | 2012-03-07 | 121d? |  | finish no earlier than 2012-03-07 | S2 | 968h | 968h | SaMOG_WLAN | PCG-27 | 23.002, 23.203, 23.402 | ZTE | Rel-11 | SP-53 | Maurice |  |  | WLAN |  |  |
| 1381 | 327.2 | **CN aspects of Mobility based On GTP & PMIPv6 for WLAN access to EPC** | 599d? | 2011-12-02 A | 2014-03-05 A | 100% |  | 2011-12-02 | 2014-03-05 | 599d? |  |  | C4; C1; C3; IETF | 26992h | 26992h | SaMOG_WLAN-CN | PCG-28 | Stage 3 | Alcatel-Lucent | Rel-11 | CP-54 | Kimmo | SaMOG_WLAN-CN |  | WLAN |  |  |
| 1382 | 327.2.1 | CT4 part of CN aspects of Mobility based On GTP & PMIPv6 for WLAN access to EPC | 203d? | 2011-12-02 A | 2012-09-07 A | 100% |  | 2011-12-02 | 2012-09-07 | 203d? |  | finish no earlier than 2012-09-07 | C4 | 1608h | 1608h | SaMOG_WLAN-CN | PCG-28 | 23.003, 23.007, 23.008, 29.273, 29.274, 29.281, 29.303 | Alcatel-Lucent | Rel-11 | CP-54 | Kimmo |  |  | WLAN |  |  |
| 1383 | 327.2.2 | Deleted - (IETF) CT4 part of CN aspects of Mobility based On GTP & PMIPv6 for WLAN access to EPC | 498d? | 2012-04-23 A | 2014-03-05 A | 100% |  | 2012-04-23 | 2014-03-05 | 498d? |  | finish no earlier than 2014-03-05 | C4-IETF | 3960h | 3960h | SaMOG_WLAN-CN | PCG-29 | draft-ietf-radext-ieee802ext | Lionel Morand | Rel-11 | CP-56 | Kimmo |  |  | WLAN | PCG-32 | CP-53 |
| 1384 | 327.2.3 | Deleted - CT1 part of CN aspects of Mobility based On GTP & PMIPv6 for WLAN access to EPC | 142d? | 2011-12-02 A | 2012-06-15 A | 100% |  | 2011-12-02 | 2012-06-15 | 142d? |  | finish no earlier than 2012-06-15 | C1 | 1128h | 1128h | SaMOG_WLAN-CN | PCG-28 | 24.302 | Alcatel-Lucent | Rel-11 | CP-54 | Frederic |  |  | WLAN | PCG-29 | CP-56 |
| 1385 | 327.2.4 | CT3 part of CN aspects of Mobility based On GTP & PMIPv6 for WLAN access to EPC | 142d? | 2011-12-02 A | 2012-06-15 A | 100% |  | 2011-12-02 | 2012-06-15 | 142d? |  | finish no earlier than 2012-09-07 | C3 | 1128h | 1128h | SaMOG_WLAN-CN | PCG-28 | 29.212, 29.213, 29.215 | Alcatel-Lucent | Rel-11 | CP-54 | Adrian |  |  | WLAN |  |  |
| 1386 | 328 | **Roaming Architecture for Voice over IMS with Local Breakout** | 273d? | 2011-11-28 A | 2012-12-07 A | 100% |  | 2011-11-28 | 2012-12-07 | 273d? |  |  | S2; S5; C1; C3 | 16904h | 16904h | RAVEL | PCG-28 | Stage 2/3 | Deutsche Telekom | Rel-11 | SP-54 | Maurice | RAVEL |  |  |  |  |
| 1387 | 328.1 | Stage 2 for Roaming Architecture for Voice over IMS with Local Breakout | 12d? | 2011-11-28 A | 2011-12-14 A | 100% |  | 2011-11-28 | 2011-12-14 | 12d? |  | finish no earlier than 2012-03-07 | S2 | 96h | 96h | RAVEL | PCG-28 | 23.002, 23.228 | Deutsche Telekom | Rel-11 | SP-54 | Maurice |  |  |  |  |  |
| 1388 | 328.2 | Charging for Roaming Architecture for Voice over IMS with Local Breakout | 196d? | 2011-12-14 A | 2012-09-12 A | 100% |  | 2011-12-14 | 2012-09-12 | 196d? |  | finish no earlier than 2012-09-12 | S5 | 1568h | 1568h | RAVEL-CH | PCG-28 | 32.240, 32.260, 32.298, 32.299 | Nokia Siemens Networks | Rel-11 | SP-54 | Mirko | RAVEL-CH |  |  |  |  |
| 1389 | 328.3 | **CT aspects of Roaming Architecture for Voice over IMS with Local Breakout (Stage 3)** | 205d? | 2012-03-02 A | 2012-12-07 A | 100% |  | 2012-03-02 | 2012-12-07 | 205d? |  |  | C1; C3 | 6504h | 6504h | RAVEL-CT | PCG-28 | Stage 3 | Deutsche Telekom | Rel-11 | CP-55 | Frederic | RAVEL-CT |  |  |  |  |
| 1390 | 328.3.1 | CT1 part of CT aspects of Roaming Architecture for Voice over IMS with Local Breakout | 204d? | 2012-03-02 A | 2012-12-07 A | 100% |  | 2012-03-02 | 2012-12-07 | 204d? |  | finish no earlier than 2012-12-07 | C1 | 1608h | 1608h | RAVEL-CT | PCG-28 | 24.229, 24.292, 24.237 | Deutsche Telekom | Rel-11 | CP-55 | Frederic |  |  |  |  |  |
| 1391 | 328.3.2 | CT3 part of CT aspects of Roaming Architecture for Voice over IMS with Local Breakout | 204d? | 2012-03-02 A | 2012-12-07 A | 100% |  | 2012-03-02 | 2012-12-07 | 204d? |  | finish no earlier than 2012-12-07 | C3 | 1616h | 1616h | RAVEL-CT | PCG-28 | 29.165, 29.162, 29.079 | Deutsche Telekom | Rel-11 | CP-55 | Adrian |  |  |  |  |  |
| 1392 | 329 | **IMS Overload Control** | 659d? | 2012-06-18 A | 2014-12-09 | 97% | 20.5d? | 2012-06-18 | 2014-12-05 | 654d? | 657d |  | S2; C1; C3; IETF | 52408h | 18342.4h | IOC | PCG-29 | Stage 2/3 | Orange, China Mobile | Rel-11 | SP-56 | Maurice | IOC |  |  |  |  |
| 1393 | 329.1 | Stage 2 for IMS Overload Control | 64d? | 2012-06-18 A | 2012-09-12 A | 100% |  | 2012-06-18 | 2012-09-12 | 64d? |  | finish no earlier than 2012-09-12 | S2 | 504h | 504h | IOC | PCG-29 | 23.228 | Orange, China Mobile | Rel-11 | SP-56 | Maurice |  |  |  |  |  |
| 1394 | 329.2 | **Stage 3 for IMS Overload Control** | 601d? | 2012-09-05 A | 2014-12-09 | 97% | 19.79d? | 2012-09-05 | 2014-12-05 | 596d? | 657d |  | C1; C3; IETF | 30816h | 15886.4h | IOC | PCG-29 |  | Alcatel-Lucent | Rel-11 | CP-57 | Frederic |  |  |  |  |  |
| 1395 | 329.2.1 | CT1 part of Stage 3 for IMS Overload Control | 70d? | 2012-09-05 A | 2012-12-07 A | 100% |  | 2012-09-05 | 2012-12-07 | 70d? |  | finish no earlier than 2012-12-07 | C1 | 544h | 544h | IOC | PCG-29 | 24.229 | Alcatel-Lucent | Rel-11 | CP-57 | Frederic |  |  |  |  |  |
| 1396 | 329.2.2 | CT3 part of Stage 3 for IMS Overload Control | 70d? | 2012-09-05 A | 2012-12-07 A | 100% |  | 2012-09-05 | 2012-12-07 | 70d? |  | finish no earlier than 2012-12-07 | C3 | 552h | 552h | IOC | PCG-29 | 29.165 | Alcatel-Lucent | Rel-11 | CP-57 | Adrian |  |  |  |  |  |
| 1397 | 329.2.3 | (IETF) CT part of Stage 3 for IMS Overload Control (soc-overload-control) | 361d? | 2013-07-29 A | 2014-12-09 A | 100% |  | 2013-07-29 | 2014-12-05 | 359d? |  | finish no earlier than 2014-12-09 | C1-IETF; C3-IETF | 5776h | 5776h | IOC | PCG-29 | draft-ietf-soc-overload-control | Keith Drage | Rel-11 | CP-57 | Frederic |  |  |  |  |  |
| 1398 | 329.2.4 | (IETF) CT part of Stage 3 for IMS Overload Control (soc-overload-rate-control) | 361d? | 2013-07-29 A | 2014-12-09 | 90% | 36.1d? | 2013-07-29 | 2014-12-05 | 359d? | 657d | finish no earlier than 2014-12-09 | C1-IETF; C3-IETF | 5776h | 5198.4h | IOC | PCG-29 | draft-ietf-soc-overload-rate-control | Keith Drage | Rel-11 | CP-57 | Frederic |  |  |  |  |  |
| 1399 | 329.2.5 | (IETF) CT part of Stage 3 for IMS Overload Control (RFC 7200) | 234d? | 2013-07-29 A | 2014-06-13 A | 100% |  | 2013-07-29 | 2014-06-13 | 234d? |  | finish no earlier than 2014-06-13 | C1-IETF; C3-IETF | 3744h | 3744h | IOC | PCG-29 | RFC 7200 (was draft-ietf-soc-load-control-event-package) | Keith Drage | Rel-11 | CP-57 | Frederic |  |  |  |  |  |
| 1400 | 330 | Rel-11 Security small Enhancements | 336d? | 2011-06-08 A | 2012-09-12 A | 100% |  | 2011-06-08 | 2012-09-12 | 336d? |  | finish no earlier than 2012-09-12 | S3 | 2680h | 2680h | SEC11 | PCG-27 |  |  | Rel-11 | SP-52 | Mirko | SEC11 |  |  |  |  |
| 1401 | 331 | Lawful Interception in the 3GPP Rel-11 | 272d? | 2011-06-10 A | 2012-06-20 A | 100% |  | 2011-06-10 | 2012-06-20 | 272d? |  | finish no earlier than 2012-06-20 | S3 | 2176h | 2176h | LI11 | PCG-27 | 33.106, 33.107, 33.108 | PIDS, Alcatel-Lucent | Rel-11 | SP-52 | Mirko | LI11 |  |  |  |  |

Notes:
- 1376: RP#58 completed / WI rapporteur e-mail: liwei.qiu@huawei.com
- 1377: RP#58 completed / WI rapporteur e-mail: liwei.qiu@huawei.com
- 1378: Prev CD:Thu 11/12/14; Prev %:5%, WID: RP-140960->RP-141786 / WI rapporteur e-mail: calle.hagenfeldt@ericsson.com
- 1379: Triggered by Rel-11 TR 23.852 FS_SaMOG UID_510061, Rel-8 UID_350027 SAE for support for non-3GPP accesses (defines PMIP-S2a) / WI rapporteur e-mail: Chunhui Zhu (zhu.chunhui@zte.com.cn)
- 1380: SP#55 completed / WI rapporteur e-mail: zhu.chunhui@zte.com.cn
- 1381: - / WI rapporteur e-mail: bruno.landais@alcatel-lucent.com
- 1382: CP#57 completed / WI rapporteur e-mail: bruno.landais@alcatel-lucent.com
- 1383: CP#63 Draft removed from 3GPP documentation
- 1384: CP#56 stopped (no CT1 impact) / WI rapporteur e-mail: bruno.landais@alcatel-lucent.com
- 1385: CP#56 completed / WI rapporteur e-mail: bruno.landais@alcatel-lucent.com
- 1386: CP#58 completed. Triggered by Rel-11 TR 23.850 Study on Roaming Architecture for Voice over IMS with Local Breakout (FS_RAVEL). GSMA CPWP LS_in S5-102806 asked 3GPP SA5 to check if CS voice charging principles also apply to voice over IMS / WI rapporteur e-mail: michele.zarri@telekom.com
- 1387: SP#54 completed / WI rapporteur e-mail: michele.zarri@telekom.com
- 1388: Stage 2/3. SP#57 completed / WI rapporteur e-mail: Gerald.Goermer@nsn.com
- 1389: CP#58 completed / WI rapporteur e-mail: reinhard.lauster@)t-mobile.at
- 1390: CP#58 completed / WI rapporteur e-mail: reinhard.lauster@)t-mobile.at
- 1391: CP#58 completed / WI rapporteur e-mail: reinhard.lauster@)t-mobile.at
- 1392: SP#57 Stage 2 completed. Moved Rel-12=>Rel-11 as CT finished Stage 3. Linked to UID_410041 Study on IMS Evolution (TR 23.812). Solutions from IETF SOC WG and existing 3GPP procedures to be re-used if possible & backward compatibility ensured / WI rapporteur e-mail: Antoine MOUQUET, YU Qing
- 1393: SP#57 completed. Moved Rel-12=>Rel-11 as CT finished Stage 3. / WI rapporteur e-mail: antoine.mouquet@orange-ftgroup.com, YU Qing
- 1394: - / WI rapporteur e-mail: Keith Drage
- 1395: CP#58 completed / WI rapporteur e-mail: Keith Drage
- 1396: CP#58 completed / WI rapporteur e-mail: Keith Drage
- 1397: in RFC Ed-queue. LM: 75->100 / WI rapporteur e-mail: Keith Drage
- 1398: Submitted to IESG for publication. LM; 50->90% / WI rapporteur e-mail: Keith Drage
- 1399: CP#64 completed / WI rapporteur e-mail: Keith Drage
- 1400: SEC11 is an umbrella Feature for Security related TEI11 type of changes that are not part of any other dedicated feature
- 1401: Stage 1/2/3. SP#56 completed / WI rapporteur e-mail: Koen Jaspers (k.b.jaspers@minjus.nl), terry.jacobson@alcatel-lucent.com

| ID | WBS | Task | Duration | Start | Finish | Complete | Baseline start | Baseline finish | Baseline duration | Constraint | Resources | Work | Actual work | Acronym | PCG approved | WI rapporteur name | Release | TSG approved | MCC resp | Acronym_3GU_Export | Status Report | Special Focus Doc |
| --- | --- | --- | --- | --- | --- | --- | --- | --- | --- | --- | --- | --- | --- | --- | --- | --- | --- | --- | --- | --- | --- | --- |
| 1402 | 332 | **ZUC EEA3 and EIA3 (new Encryption & Integrity EPS security Algorithms)** | 857d? | 2009-06-04 A | 2012-09-07 A | 100% | 2009-06-04 | 2012-09-07 | 857d? |  | S3; R5 | 19488h | 19488h | EEA3_EIA3 | PCG-23 | CATR | Rel-11 | SP-44 | Mirko | EEA3_EIA3 |  |  |
| 1403 | 332.1 | ZUC EEA3 and EIA3 | 663d? | 2009-06-04 A | 2011-12-14 A | 100% | 2009-06-04 | 2011-12-14 | 663d? | finish no earlier than 2011-09-21 | S3 | 5288h | 5288h | EEA3_EIA3 | PCG-23 | CATR | Rel-11 | SP-44 | Mirko |  |  |  |
| 1404 | 332.2 | Conformance Test Aspects – ZUC (EEA3 and EIA3 Encryption & Integrity EPS security Algorithms) | 61d? | 2012-06-18 A | 2012-09-07 A | 100% | 2012-06-18 | 2012-09-07 | 61d? | finish no earlier than 2013-03-01 | R5 | 488h | 488h | EEA3_EIA3_UEConTest | PCG-29 | CATR | Rel-11 | RP-56 | Ingbert | EEA3_EIA3_UEConTest | RP-120968 |  |
| 1405 | 333 | Specification of Protection against Unsolicited Communication for IMS (produced TR-only) | 456d? | 2010-06-10 A | 2012-03-07 A | 100% | 2010-06-10 | 2012-03-07 | 456d? | finish no earlier than 2012-03-07 | S3 | 3640h | 3640h | SPUCI | PCG-25 | NEC | Rel-11 | SP-48 | Mirko | SPUCI |  |  |
| 1406 | 334 | H(e)NB security features for UE mobility scenarios (Stage 2) | 252d? | 2011-03-23 A | 2012-03-07 A | 100% | 2011-03-23 | 2012-03-07 | 252d? | finish no earlier than 2012-03-07 | S3 | 2008h | 2008h | HNB_mob_Sec | PCG-26 | Huawei | Rel-11 | SP-51 | Mirko | HNB_mob_Sec |  | HNB |
| 1407 | 335 | **Generic Bootstrapping Architecture (GBA) extensions for re-use of SIP Digest credentials** | 203d? | 2011-12-02 A | 2012-09-07 A | 100% | 2011-12-02 | 2012-09-07 | 203d? |  | S3; C4; C1 | 11824h | 11824h | GBA-ext | PCG-28 | Nokia | Rel-11 | SP-54 | Mirko | GBA-ext |  |  |
| 1408 | 335.1 | Stage 2 for GBA extensions for re-use of SIP Digest credentials | 61d? | 2011-12-14 A | 2012-03-07 A | 100% | 2011-12-14 | 2012-03-07 | 61d? | finish no earlier than 2012-02-28 | S3 | 488h | 488h | GBA-ext | PCG-28 | Nokia | Rel-11 | SP-54 | Mirko |  |  |  |
| 1409 | 335.2 | **Stage 3 for GBA extensions for re-use of SIP Digest credentials** | 203d? | 2011-12-02 A | 2012-09-07 A | 100% | 2011-12-02 | 2012-09-07 | 203d? |  | C4; C1 | 6464h | 6464h | GBA-ext-St3 | PCG-28 | Alcatel-Lucent | Rel-11 | CP-54 | Kimmo | GBA-ext-St3 |  |  |
| 1410 | 335.2.1 | CT4 part of Stage 3 for GBA extensions for re-use of SIP Digest credentials | 203d? | 2011-12-02 A | 2012-09-07 A | 100% | 2011-12-02 | 2012-09-07 | 203d? | finish no earlier than 2012-09-07 | C4 | 1608h | 1608h | GBA-ext-St3 | PCG-28 | Alcatel-Lucent | Rel-11 | CP-54 | Kimmo |  |  |  |
| 1411 | 335.2.2 | CT1 part of Stage 3 for GBA extensions for re-use of SIP Digest credentials | 202d? | 2011-12-05 A | 2012-09-07 A | 100% | 2011-12-05 | 2012-09-07 | 202d? | finish no earlier than 2012-09-07 | C1 | 1608h | 1608h | GBA-ext-St3 | PCG-28 | Alcatel-Lucent | Rel-11 | CP-54 | Frederic |  |  |  |
| 1412 | 336 | Extensions of Acoustic Test Specifications in TS 26.131 and TS 26.132 | 332d? | 2011-06-08 A | 2012-09-12 A | 100% | 2011-06-08 | 2012-09-12 | 332d? | finish no earlier than 2012-09-12 | S4 | 2648h | 2648h | Ext_ATS | PCG-27 | Orange, Qualcomm | Rel-11 | SP-52 | Paolo | Ext_ATS |  |  |
| 1413 | 337 | **Enhancements to Multimedia: PSS, MMS, and MBMS Enhancements and Performance Improvements** | 397d? | 2011-09-07 A | 2013-03-06 A | 100% | 2011-09-07 | 2013-03-06 | 397d? |  | S4 | 10928.6h | 10928.6h | EMM | PCG-27 | Qualcomm | Rel-11 | SP-53 | Paolo | EMM |  |  |
| 1414 | 337.1 | Enhancement to FEC for MBMS | 386d? | 2011-09-21 A | 2013-03-06 A | 100% | 2011-09-21 | 2013-03-06 | 386d? | finish no earlier than 2013-03-06 | S4 | 3048h | 3048h | EMM-EFEC | PCG-27 | Qualcomm | Rel-11 | SP-53 | Paolo | EMM-EFEC |  |  |
| 1415 | 337.2 | Download Delivery Enhancements for MBMS | 325d? | 2011-09-21 A | 2012-12-12 A | 100% | 2011-09-21 | 2012-12-12 | 325d? | finish no earlier than 2012-12-12 | S4 | 2576.59h | 2576.59h | EMM-DDE | PCG-27 | Qualcomm | Rel-11 | SP-53 | Paolo | EMM-DDE |  |  |
| 1416 | 337.3 | IMS-based PSS and MBMS Streaming Synchronization Enhancements | 268d? | 2011-09-07 A | 2012-09-12 A | 100% | 2011-09-07 | 2012-09-12 | 268d? | finish no earlier than 2012-09-12 | S4 | 2128h | 2128h | EMM-IPME | PCG-27 | InterDigital Communications | Rel-11 | SP-53 | Paolo | EMM-IPME |  |  |
| 1417 | 338 | Mobile 3D Video Coding | 71d? | 2012-06-07 A | 2012-09-12 A | 100% | 2012-06-07 | 2012-09-12 | 71d? | finish no earlier than 2012-09-12 | S4 | 560h | 560h | M3DV | PCG-29 | Orange | Rel-11 | SP-56 | Paolo | M3DV |  |  |
| 1418 | 339 | **Rel-11 Operations, Administration, Maintenance and Provisioning (OAM&P)** | 519d? | 2011-03-23 A | 2013-03-07 A | 100% | 2011-03-23 | 2013-03-06 | 519d? |  | S5 | 39394.5h | 39394.5h | OAM11 | PCG-26 |  | Rel-11 | SP-51 | Mirko | OAM11 |  |  |
| 1419 | 339.1 | **Rel-11 Network Infrastructure Management** | 519d? | 2011-03-23 A | 2013-03-07 A | 100% | 2011-03-23 | 2013-03-06 | 519d? |  | S5 | 8256h | 8256h | OAM11-NIM | PCG-26 |  | Rel-11 | SP-51 | Mirko | OAM11-NIM |  |  |
| 1420 | 339.1.1 | IRP framework enhancements to support Management of Converged Networks | 515d? | 2011-03-23 A | 2013-03-07 A | 100% | 2011-03-23 | 2013-03-06 | 515d? | finish no earlier than 2013-03-06 | S5 | 4104h | 4104h | OAM-FMC-IRP | PCG-26 | Nokia Siemens Networks, Ericsson | Rel-11 | SP-51 | Mirko | OAM-FMC-IRP |  |  |
| 1421 | 339.2 | **Rel-11 Performance Management** | 458d? | 2011-03-23 A | 2012-12-12 A | 100% | 2011-03-23 | 2012-12-12 | 458d? |  | S5 | 14530.5h | 14530.5h | OAM11-PM | PCG-26 |  | Rel-11 | SP-51 | Mirko | OAM11-PM |  |  |
| 1422 | 339.2.1 | IMS Performance Management enhancements | 252d? | 2011-03-23 A | 2012-03-07 A | 100% | 2011-03-23 | 2012-03-07 | 252d? | finish no earlier than 2012-09-12 | S5 | 2010.52h | 2010.52h | OAM-ePM-IMS | PCG-26 | ZTE | Rel-11 | SP-51 | Mirko | OAM-ePM-IMS |  |  |
| 1423 | 339.2.2 | Enhanced Management of UE based network performance measurements | 455d? | 2011-03-23 A | 2012-12-12 A | 100% | 2011-03-23 | 2012-12-12 | 455d? | finish no earlier than 2012-12-12 | S5 | 3624h | 3624h | OAM-ePM-UE | PCG-26 | Huawei, Ericsson, Nokia Siemens Networks | Rel-11 | SP-51 | Mirko | OAM-ePM-UE |  |  |
| 1424 | 339.2.3 | CN performance measurements enhancement | 334d? | 2011-06-08 A | 2012-09-12 A | 100% | 2011-06-08 | 2012-09-12 | 334d? | finish no earlier than 2012-09-12 | S5 | 2648h | 2648h | OAM-ePM-CN | PCG-27 | China Mobile | Rel-11 | SP-52 | Mirko | OAM-ePM-CN |  |  |
| 1425 | 339.2.4 | Management of Carrier Aggregation for LTE | 325d? | 2011-09-21 A | 2012-12-12 A | 100% | 2011-09-21 | 2012-12-12 | 325d? | finish no earlier than 2012-12-12 | S5 | 2584h | 2584h | OAM-CA | PCG-27 | Nokia Siemens Networks, Ericsson | Rel-11 | SP-53 | Mirko | OAM-CA |  | CA |

Notes:
- 1402: RP#57 completed testing / WI rapporteur e-mail: Yuan Qi (yuanqi@catr.cn)
- 1403: SP#53 completed new EPS algorithms e.g. for China / Impacted TSs and TRs: 33.401, New (35.221, 35.222, 35.223, 35.924) / WI rapporteur e-mail: Yuan Qi (yuanqi@catr.cn)
- 1404: RP#57 completed. Testing for SA3 TSs 33.401, new (35.221, 35.222, 35.223) / Impacted TSs and TRs: 36.523-1, 36.523-2, 36.523-3 / WI rapporteur e-mail: Ms Jun Chen (chenjun@catr.cn)
- 1405: SP#55 completed (No normative work). TR 33.838v200 for Approval & abandoned new TS 33.237. Continuation of Rel-9 UID_410027/410029. Builds on TR 33.937 Study of Mechanisms for PUCI / Impacted TSs and TRs: New TR 33.838, abandoned New TS 33.237 / WI rapporteur e-mail: Anand R. Prasad (anand@bq.jp.nec.com)
- 1406: SP#55 completed. Add HeNB Security extensions to Extended H(e)NB Features (EHNBF) UID_450053 / Impacted TSs and TRs: 33.320 / WI rapporteur e-mail: Marcus Wong (mwong@huawei.com)
- 1407: Stage 2/3. CP#57 completed / WI rapporteur e-mail: Silke.Holtmanns@nokia.com
- 1408: SP#55 completed / Impacted TSs and TRs: 33.220 / WI rapporteur e-mail: Silke.Holtmanns@nokia.com
- 1409: CP#57 completed / Impacted TSs and TRs: Stage 3 / WI rapporteur e-mail: jean-jacques.trottin@alcatel-lucent.com
- 1410: CP#57 completed / Impacted TSs and TRs: 29.109 / WI rapporteur e-mail: jean-jacques.trottin@alcatel-lucent.com
- 1411: CP#57 completed / Impacted TSs and TRs: 24.109 / WI rapporteur e-mail: jean-jacques.trottin@alcatel-lucent.com
- 1412: SP#57 completed / Impacted TSs and TRs: 26.131, 26.132 / WI rapporteur e-mail: stephane.ragot@orange-ftgroup.com, Andre Schevciw (aschevci@qualcomm.com)
- 1413: Stage 3. SP#59 completed / Impacted TSs and TRs: 26.140, 26.234, 26.247, New TR 26.951=>26.851 / WI rapporteur e-mail: Nikolai Leung (nleung@qualcomm.com)
- 1414: SP#59 completed / Impacted TSs and TRs: 26.346, new TR 26.947 / WI rapporteur e-mail: Thomas Stockhammer (c_tstock@qualcomm.com)
- 1415: SP#58 completed / Impacted TSs and TRs: 26.346, new TR 26.951=>26.851 / WI rapporteur e-mail: Nikolai Leung (nleung@qualcomm.com)
- 1416: SP#58 completed / Impacted TSs and TRs: 26.237, new TR 26.951=>26.851 / WI rapporteur e-mail: hang.liu@interdigital.com
- 1417: SP#57 completed. Triggered by UID_520036 Rel-11 Study on Mobile 3D Video Coding (FS_M3DVC) TR 26.905. / Impacted TSs and TRs: 26.140, 26.234, 26.244, 26.245, 26.247, 26.346, 26.430, 26.905 / WI rapporteur e-mail: gilles.teniou@orange.com
- 1418: OAM11 is an umbrella Feature also for OAM&P related TEI11 type of changes that are not part of any other dedicated feature/WI
- 1419: -
- 1420: SP#59 completed. Triggered by SA5 Studies TR 32.833, 32.828, 32.831 / Impacted TSs and TRs: 32.101/103/150, new (28.620/621/622/623/624/625/626/627/628/629/631/632/633/651/652/653/654/655/656/657/658/659/661/662/663/671/672/673/674/675/676/701/702/703/704/705/706/707/708/709/731/732/733/734/735/736/751/752/753, 32.107/156/157/853/854 / WI rapporteur e-mail: thomas.tovinger@ericsson.com, olaf.pollakowski@nsn.com
- 1421: -
- 1422: SP#55 completed / Impacted TSs and TRs: 32.409 / WI rapporteur e-mail: guo.wenjie1@zte.com.cn
- 1423: SP#58 completed / Impacted TSs and TRs: 32.421, 32.422, 32.423, 32.441, 32.442, 32.446 / WI rapporteur e-mail: Zou Lan (zlan@huawei.com), ulf.hubinette@ericsson.com, gyula.bodog@nsn.com
- 1424: SP#57 completed / Impacted TSs and TRs: 32.406, 32.407, 32.426 / WI rapporteur e-mail: Liang Shuangchun (liangshuangchun@cmdi.chinamobile.com), Li Jian (lijian@chinamobile.com)
- 1425: SP#58 completed. Updated WID SP-110636=>SP-120776. Stage 2 in Rel-10 RAN Feature UID_460007 Carrier Aggregation for LTE (LTE_CA) / Impacted TSs and TRs: 32.425 / WI rapporteur e-mail: yizhi.yao@nsn.com, per.elmdahl@ericsson.com

| ID | WBS | Task | Type | Duration | Start | Finish | Complete | Baseline start | Baseline finish | Baseline duration | Constraint | Resources | Work | Actual work | Acronym | PCG approved | Release | TSG approved | MCC resp | Special Focus Doc | Acronym_3GU_Export | WI rapporteur name | WI rapporteur e-mail |
| --- | --- | --- | --- | --- | --- | --- | --- | --- | --- | --- | --- | --- | --- | --- | --- | --- | --- | --- | --- | --- | --- | --- | --- |
| 1426 | 339.3 | **Rel-11 Self-Organizing Networks (SON) - OAM aspects** |  | 519d? | 2011-03-23 A | 2013-03-06 A | 100% | 2011-03-23 | 2013-03-06 | 519d? |  | S5 | 12456h | 12456h | OAM11-SON | PCG-26 | Rel-11 | SP-51 | Mirko | SON | OAM11-SON |  |  |
| 1427 | 339.3.1 | UTRAN Self-Organizing Networks (SON) management |  | 388d? | 2011-03-23 A | 2012-09-12 A | 100% | 2011-03-23 | 2012-09-12 | 388d? | finish no earlier than 2012-09-12 | S5 | 3088h | 3088h | OAM-SON-UTRAN | PCG-26 | Rel-11 | SP-51 | Mirko | SON | OAM-SON-UTRAN | Huawei | kai.zhangkai@huawei.com |
| 1428 | 339.3.2 | LTE Self-Organizing Networks (SON) coordination management |  | 387d? | 2011-09-21 A | 2013-03-06 A | 100% | 2011-09-21 | 2013-03-06 | 387d? | finish no earlier than 2013-03-06 | S5 | 3072h | 3072h | OAM-SON-LTE_COORD | PCG-27 | Rel-11 | SP-53 | Mirko | SON | OAM-SON-LTE_COORD | Huawei, Nokia Siemens Networks | kai.zhangkai@huawei.com, clemens.suerbaum@nsn.com |
| 1429 | 339.3.3 | Inter-RAT Energy Saving Management |  | 269d? | 2011-12-07 A | 2012-12-12 A | 100% | 2011-12-07 | 2012-12-12 | 269d? | finish no earlier than 2012-12-12 | S5 | 2144h | 2144h | OAM-IRAT-ESM | PCG-28 | Rel-11 | SP-54 | Mirko | SON | OAM-IRAT-ESM | Nokia Siemens Networks, Huawei | clemens.suerbaum@nsn.com, xiahaitao@huawei.com |
| 1430 | 340 | **Rel-11 Charging Management small Enhancements** |  | 717d? | 2010-03-25 A | 2012-12-12 A | 100% | 2010-03-25 | 2012-12-12 | 717d? |  | S5 | 11528h | 11528h | CH11 | PCG-26 | Rel-11 | SP-51 | Mirko |  | CH11 |  |  |
| 1431 | 340.1 | Add solutions for Rc - reference point within the Online Charging System (OCS) |  | 392d? | 2010-03-25 A | 2011-09-21 A | 100% | 2010-03-25 | 2011-09-21 | 392d? | finish no earlier than 2011-08-26 | S5 | 3120h | 3120h | CH-Rc | PCG-24 | Rel-11 | SP-47 | Mirko |  | CH-Rc | Huawei | shan.mingjun@huawei.com |
| 1432 | 340.2 | Charging for Policy Enhancements for Sponsored Connectivity and Coherent Access to Policy related Data Bases |  | 135d? | 2011-03-21 A | 2011-09-21 A | 100% | 2011-03-21 | 2011-09-21 | 135d? | finish no earlier than 2011-09-21 | S5 | 1064h | 1064h | PEST-CH | PCG-26 | Rel-11 | SP-51 | Mirko |  | PEST-CH | Ericsson | patrik.teppo@@ericsson.com |
| 1433 | 340.3 | Unification of Charging session from SIP AS and SRVCC functions in IMS |  | 203d? | 2012-03-07 A | 2012-12-12 A | 100% | 2012-03-07 | 2012-12-12 | 203d? | finish no earlier than 2012-12-12 | S5 | 1608h | 1608h | UCHIMS_AS-SRVCC | PCG-28 | Rel-11 | SP-55 | Mirko |  | UCHIMS_AS-SRVCC | Alcatel-Lucent | maryse.gardella@alcatel-lucent.com |
| 1434 | 341 | **Transit Inter Operator Identifier for IMS Interconnection Charging in multi operator environment** |  | 432d? | 2010-10-27 A | 2012-06-15 A | 100% | 2010-10-27 | 2012-06-15 | 432d? |  | S5; S1; C1 | 15921.1h | 15921.1h | IOI_IMS_CH | PCG-26 | Rel-11 | SP-51 | Mirko |  | IOI_IMS_CH | Deutsche Telekom | matthias.seibel@telekom.de |
| 1435 | 341.1 | Stage 1 for Transit Inter Operator Identifier for IMS Interconnection Charging in multi operator environment |  | 237d? | 2010-10-27 A | 2011-09-21 A | 100% | 2010-10-27 | 2011-09-21 | 237d? |  | S1 | 1896h | 1896h | IOI_IMS_CH | PCG-26 | Rel-11 | SP-51 | Dionisio |  |  | Deutsche Telekom | matthias.seibel@telekom.de |
| 1436 | 341.2 | Stage 2/3 SA5 part of Transit Inter Operator Identifier for IMS Interconnection Charging in multi operator environment |  | 187d? | 2010-10-27 A | 2011-12-07 A | 100% | 2010-10-27 | 2011-12-07 | 187d? | finish no earlier than 2012-03-21 | S5 | 1488h | 1488h | IOI_IMS_CH | PCG-26 | Rel-11 | SP-51 | Mirko |  |  | Deutsche Telekom | matthias.seibel@telekom.de |
| 1437 | 341.3 | Stage 3 for Transit Inter Operator Identifier for IMS Interconnection Charging in multi operator environment |  | 273d? | 2011-06-07 A | 2012-06-15 A | 100% | 2011-06-07 | 2012-06-15 | 273d? | finish no earlier than 2012-06-01 | C1 | 2169.09h | 2169.09h | IOI_IMS_CH | PCG-27 | Rel-11 | CP-52 | Frederic |  |  | Deutsche Telekom | martin.huelsemann@telekom.de] |
| 1438 | 342 | **User Data Convergence - Data Model** |  | 647d? | 2010-03-25 A | 2012-09-07 A | 100% | 2010-03-25 | 2012-09-07 | 647d? |  | C4; S1 | 22984h | 22984h | UDC_DM | PCG-25 | Rel-11 | CP-48 | Kimmo |  | UDC_DM | Telecom Italia | mauro.ficaccio@telecomitalia.it |
| 1439 | 342.1 | Stage 1 for UDC Data Model |  | 392d? | 2010-03-25 A | 2011-09-21 A | 100% | 2010-03-25 | 2011-09-21 | 392d? | finish no earlier than 2010-06-10 | S1 | 3136h | 3136h | UDC_DM | PCG-25 | Rel-11 | CP-48 | Alain |  |  | Telecom Italia | mauro.ficaccio@telecomitalia.it |
| 1440 | 342.2 | TR on User Data Convergence (UDC) Data Model |  | 593d? | 2010-06-04 A | 2012-09-07 A | 100% | 2010-06-04 | 2012-09-07 | 593d? | finish no earlier than 2012-09-07 | C4 | 4736h | 4736h | UDC_DM | PCG-25 | Rel-11 | CP-48 | Kimmo |  |  | Telecom Italia | mauro.ficaccio@telecomitalia.it |
| 1441 | 342.3 | User Data Convergence (UDC) Data Model |  | 596d? | 2010-06-04 A | 2012-09-07 A | 100% | 2010-06-04 | 2012-09-07 | 596d? | finish no earlier than 2012-09-07 | C4 | 4760h | 4760h | UDC_DM | PCG-25 | Rel-11 | CP-48 | Kimmo |  |  | Telecom Italia | mauro.ficaccio@telecomitalia.it |
| 1442 | 343 | Definition of the UICC Application for Hosting Party Module |  | 327d? | 2011-03-18 A | 2012-06-15 A | 100% | 2011-03-18 | 2012-06-15 | 327d? | finish no earlier than 2012-06-15 | C6 | 2608h | 2608h | HPM_UICC | PCG-26 | Rel-11 | CP-51 | Xavier |  | HPM_UICC | Gemalto | Denis.Lheriteau@gemalto.com |
| 1443 | 344 | Usability improvement of Inter-IMS Network to Network Interface (II-NNI) specification for inter-connection by means of Option Item list |  | 273d? | 2011-06-07 A | 2012-06-15 A | 100% | 2011-06-07 | 2012-06-15 | 273d? | finish no earlier than 2012-06-01 | C3 | 2169.56h | 2169.56h | NNI_OI | PCG-27 | Rel-11 | CP-52 | Adrian |  | NNI_OI | NTT | arai.kenjiro@lab.ntt.co.jp |
| 1444 | 345 | **enhanced Nodes Restoration for EPC (Stage 2/3)** |  | 668d? | 2011-06-03 A | 2013-12-06 A | 100% | 2011-06-03 | 2013-12-06 | 668d? |  | C4; C1; C3; IETF | 27728h | 27728h | eNR_EPC | PCG-27 | Rel-11 | CP-52 | Kimmo |  | eNR_EPC | ZTE | lu.fei1@zte.com.cn |
| 1445 | 345.1 | CT4 part of enhanced Nodes Restoration for EPC |  | 402d? | 2011-06-03 A | 2012-12-07 A | 100% | 2011-06-03 | 2012-12-07 | 402d? | finish no earlier than 2012-12-07 | C4 | 3192h | 3192h | eNR_EPC | PCG-27 | Rel-11 | CP-52 | Kimmo |  |  | ZTE | lu.fei1@zte.com.cn |
| 1446 | 345.2 | (IETF) CT4 part of enhanced Nodes Restoration for EPC (RFC 7077) |  | 266d? | 2012-12-07 A | 2013-12-06 A | 100% | 2012-12-07 | 2013-12-06 | 266d? | finish no earlier than 2013-12-06 | C4-IETF | 2104h | 2104h | eNR_EPC | PCG-30 | Rel-11 | CP-58 | Kimmo |  |  | Lionel Morand | Lionel Morand |
| 1447 | 345.3 | CT1 part of enhanced Nodes Restoration for EPC |  | 66d? | 2011-12-02 A | 2012-03-02 A | 100% | 2011-12-02 | 2012-03-02 | 66d? | finish no earlier than 2012-06-15 | C1 | 528h | 528h | eNR_EPC | PCG-28 | Rel-11 | CP-54 | Frederic |  |  | ZTE | lu.fei1@zte.com.cn |
| 1448 | 345.4 | CT3 part of enhanced Nodes Restoration for EPC |  | 67d? | 2012-09-10 A | 2012-12-07 A | 100% | 2012-09-10 | 2012-12-07 | 67d? | finish no earlier than 2012-12-07 | C3 | 528h | 528h | eNR_EPC | PCG-29 | Rel-11 | CP-57 | Adrian |  |  | ZTE | lu.fei1@zte.com.cn |
| 1449 | 346 | **Reference Location Information (Stage 3)** |  | 78d? | 2011-06-03 A | 2011-09-16 A | 100% | 2011-06-03 | 2011-09-16 | 78d? |  | C4; C1 | 1860.74h | 1860.74h | RLI | PCG-27 | Rel-11 | CP-52 | Kimmo |  | RLI | Huawei | susan.shishufeng@Huawei.com |
| 1450 | 346.1 | CT4 part of Reference Location Information (Stage 3) | milestone | 0d? | 2011-06-03 A | 2011-06-03 A | 100% | 2011-06-03 | 2011-06-03 | 0d? | finish no earlier than 2011-06-03 | C4 |  |  | RLI | PCG-27 | Rel-11 | CP-52 | Kimmo |  |  | Huawei | susan.shishufeng@Huawei.com |
| 1451 | 346.2 | CT1 part of Reference Location Information (Stage 3) |  | 78d? | 2011-06-03 A | 2011-09-16 A | 100% | 2011-06-03 | 2011-09-16 | 78d? | finish no earlier than 2011-08-30 | C1 | 612.74h | 612.74h | RLI | PCG-27 | Rel-11 | CP-52 | Frederic |  |  | Huawei | susan.shishufeng@Huawei.com |

Notes:
- 1426: -
- 1427: SP#57 completed. Updated WID SP-110518=>SP-120552 / Impacted TSs and TRs: UTRA 32.405, 32.500, 32.511, 32.521, 32.522, 32.526, 32.642, 32.646
- 1428: SP#59 completed / Impacted TSs and TRs: LTE 32.425, 32.500, 32.521, 32.522, 32.526, 32.762, 32.766
- 1429: SP#58 completed. Triggered by Rel-11 TR 32.834 (Study on OAM aspects of inter-RAT Energy Saving) UID_510045. Needs coordination with RAN WGs / Impacted TSs and TRs: 32.405, 32.551, 32.522, 32.526, 32.642, 32.646, 32.762, 32.766
- 1430: CH11 is an umbrella Feature also for OAM&P related TEI11 type of changes that are not part of any other dedicated feature/WI / Impacted TSs and TRs: TR 30.821
- 1431: SP#53 completed. Stage 3 (Stage 1 in 22.115). Triggered by Rel-10 TR 32.825 SA5 Study on Rc Reference Point Functionalities and Message Flows (UID_410044) / Impacted TSs and TRs: 32.296, 32.299
- 1432: SP#53 completed. Stage 3 / Impacted TSs and TRs: 32.251, 32.298, 32.299
- 1433: Stage 2/3. SP#58 completed / Impacted TSs and TRs: 32.260, 32.275, 32.298, 32.299
- 1434: Stage 2/3. CP#56 completed. Stage 1 in SA1 22.115
- 1435: SP#53 completed under IPXS / Impacted TSs and TRs: 22.115
- 1436: SP#54 completed / Impacted TSs and TRs: 32.240, 32.260, 32.298, 32.299
- 1437: CP#56 completed / Impacted TSs and TRs: 24.229
- 1438: CP#57 completed. SP#48 Stage 1 completed as Rel-10
- 1439: SP#53 completed under Rel-10 UDC / Impacted TSs and TRs: 22.101
- 1440: CP#57 completed / Impacted TSs and TRs: new TR 29.935
- 1441: CP#57 completed / Impacted TSs and TRs: 29.335
- 1442: CP#56 completed / Impacted TSs and TRs: 31.102, New TS 31.104
- 1443: CP#56 completed. Stage 3 (No architectural change, specify the list of selectable items related to control plane signalling directly for the same architecture) / Impacted TSs and TRs: 29.165
- 1444: Triggered by DRAFT TR 23.857 Study on EPC Nodes Restoration UID_490014
- 1445: CP#58 completed / Impacted TSs and TRs: 23.007, 23.008, 23.018, 29.274, 29.275
- 1446: CP#62 completed / Impacted TSs and TRs: RFC 7077 (was draft-ietf-netext-update-notifications)
- 1447: CP#55 completed / Impacted TSs and TRs: 29.118
- 1448: CP#58 completed / Impacted TSs and TRs: 29.212
- 1449: CP#53 completed. Stage 2 clause C.1.1 of SA2 TS 23.167 CR#0182 (WI code: TEI11)
- 1450: CP#52 completed / Impacted TSs and TRs: 23.008, 29.228, 29.328, 29.329
- 1451: CP#53 completed / Impacted TSs and TRs: 24.229

| ID | WBS | Task | Duration | Start | Finish | Complete | Baseline start | Baseline finish | Baseline duration | Constraint | Resources | Work | Actual work | Acronym | PCG approved | WI rapporteur name | WI rapporteur e-mail | Release | TSG approved | MCC resp | Acronym_3GU_Export | PCG stopped | TSG stopped | Special Focus Doc |
| --- | --- | --- | --- | --- | --- | --- | --- | --- | --- | --- | --- | --- | --- | --- | --- | --- | --- | --- | --- | --- | --- | --- | --- | --- |
| 1452 | 347 | **IMS Stage 3 IETF Protocol Alignment - phase 5** | 868d? | 2011-06-07 A | 2014-09-12 A | 100% | 2011-06-07 | 2014-12-05 | 927d? |  | C1; C3; IETF | 34260h | 34260h | IMSProtoc5 | PCG-27 | Alcatel-Lucent | keith.drage@alcatel-lucent.com | Rel-11 | CP-52 | Frederic | IMSProtoc5 |  |  |  |
| 1453 | 347.1 | CT1 part of IMS Stage 3 IETF Protocol Alignment - phase 5 | 333d? | 2011-06-07 A | 2012-09-07 A | 100% | 2011-06-07 | 2012-09-07 | 333d? | finish no earlier than 2012-09-07 | C1 | 2648h | 2648h | IMSProtoc5 | PCG-27 | Alcatel-Lucent | keith.drage@alcatel-lucent.com | Rel-11 | CP-52 | Frederic |  |  |  |  |
| 1454 | 347.2 | (IETF) CT1 part of IMS Stage 3 IETF Protocol Alignment - phase 5 (RFC 7315) | 356.5d? | 2013-03-01 A | 2014-09-12 A | 100% | 2013-03-01 | 2014-12-05 | 416.5d? | finish no earlier than 2014-09-12 | C1-IETF | 2812h | 2812h | IMSProtoc5 | PCG-30 | Roland Jesske | Roland Jesske | Rel-11 | CP-59 | Frederic |  |  |  |  |
| 1455 | 347.3 | (IETF) CT1 part of IMS Stage 3 IETF Protocol Alignment - phase 5 (RFC 7135) | 203d? | 2013-09-06 A | 2014-06-13 A | 100% | 2013-09-06 | 2014-06-13 | 203d? | finish no earlier than 2014-06-13 | C1-IETF | 1608h | 1608h | IMSProtoc5 | PCG-31 | Roland Jesske | Roland Jesske | Rel-11 | CP-61 |  |  |  |  |  |
| 1456 | 347.4 | CT3 part of IMS Stage 3 IETF Protocol Alignment - phase 5 | 333d? | 2011-06-07 A | 2012-09-07 A | 100% | 2011-06-07 | 2012-09-07 | 333d? | finish no earlier than 2012-09-07 | C3 | 2648h | 2648h | IMSProtoc5 | PCG-27 | Alcatel-Lucent | keith.drage@alcatel-lucent.com | Rel-11 | CP-52 | Adrian |  |  |  |  |
| 1457 | 347.5 | Deleted - (IETF) CT3 part of IMS Stage 3 IETF Protocol Alignment - phase 5 (avasarala-dispatch-comm-div-notification) | 466d? | 2012-12-07 A | 2014-09-12 A | 100% | 2012-12-07 | 2014-12-05 | 526d? | finish no earlier than 2014-09-12 | C3-IETF | 3712h | 3712h | IMSProtoc5 | PCG-30 | Andrew Allen | Andrew Allen | Rel-11 | CP-58 | Adrian |  | PCG-33 | CP-65 |  |
| 1458 | 348 | **Service Identification for RRC Improvements in GERAN (Stage 2/3)** | 258d? | 2011-09-19 A | 2012-09-07 A | 100% | 2011-09-19 | 2012-09-07 | 258d? |  | S2; C4; C3; G2 | 16216h | 16216h | SIRIG | PCG-27 | China Mobile | zhanghao@chinamobile.com | Rel-11 | GP-51 | Maurice | SIRIG |  |  |  |
| 1459 | 348.1 | Stage 2 for Service Identification for RRC Improvements in GERAN | 61d? | 2012-06-18 A | 2012-09-07 A | 100% | 2012-06-18 | 2012-09-07 | 61d? | finish no earlier than 2012-09-07 | S2 | 480h | 480h | SIRIG | PCG-29 |  |  | Rel-11 | SP-56 | Maurice |  |  |  |  |
| 1460 | 348.2 | **CN aspects of Service Identification for RRC Improvements in GERAN** | 203d? | 2011-12-02 A | 2012-09-07 A | 100% | 2011-12-02 | 2012-09-07 | 203d? |  | C4; C3 | 5464h | 5464h | SIRIG | PCG-28 | China Mobile | zhanghao@chinamobile.com | Rel-11 | CP-54 | Kimmo |  |  |  |  |
| 1461 | 348.2.1 | CT4 part of CN aspects of Service Identification for RRC Improvements in GERAN | 203d? | 2011-12-02 A | 2012-09-07 A | 100% | 2011-12-02 | 2012-09-07 | 203d? | finish no earlier than 2012-09-07 | C4 | 1608h | 1608h | SIRIG | PCG-28 | China Mobile | zhanghao@chinamobile.com | Rel-11 | CP-54 | Kimmo |  |  |  |  |
| 1462 | 348.2.2 | Deleted - CT3 part of CN aspects of Service Identification for RRC Improvements in GERAN | 77d? | 2012-03-02 A | 2012-06-15 A | 100% | 2012-03-02 | 2012-06-15 | 77d? | finish no earlier than 2012-06-01 | C3 | 608h | 608h | SIRIG | PCG-28 | China Mobile | zhanghao@chinamobile.com | Rel-11 | CP-55 | Adrian |  | PCG-29 | CP-56 |  |
| 1463 | 348.3 | GERAN2 part of Service Identification for RRC Improvements in GERAN | 252d? | 2011-09-19 A | 2012-08-31 A | 100% | 2011-09-19 | 2012-08-31 | 252d? | finish no earlier than 2012-08-31 | G2 | 2016h | 2016h | SIRIG | PCG-27 | China Mobile, Huawei | Juan Deng, Yang Zhao | Rel-11 | GP-51 | Gert |  |  |  |  |
| 1464 | 349 | **SAE Protocol Development - Phase 2** | 259d? | 2011-09-16 A | 2012-09-07 A | 100% | 2011-09-16 | 2012-09-07 | 259d? |  | C1 | 6168h | 6168h | SAES2 | PCG-27 | Nokia Siemens Networks | robert.zaus@nsn.com | Rel-11 | CP-53 | Frederic | SAES2 |  |  |  |
| 1465 | 349.1 | SAE Protocol Development (Stage 3) - Phase 2 | 259d? | 2011-09-16 A | 2012-09-07 A | 100% | 2011-09-16 | 2012-09-07 | 259d? | finish no earlier than 2012-09-07 | C1 | 2048h | 2048h | SAES2 | PCG-27 | Nokia Siemens Networks | robert.zaus@nsn.com | Rel-11 | CP-53 | Frederic |  |  |  |  |
| 1466 | 349.2 | CS Fallback in EPS - Phase 2 | 259d? | 2011-09-16 A | 2012-09-07 A | 100% | 2011-09-16 | 2012-09-07 | 259d? | finish no earlier than 2012-09-07 | C1 | 2048h | 2048h | SAES2-CSFB | PCG-27 | Nokia Siemens Networks | robert.zaus@nsn.com | Rel-11 | CP-53 | Frederic | SAES2-CSFB |  |  |  |
| 1467 | 350 | **GCSMSC and GCR Redundancy for VGCS/VBS (Stage 2/3)** | 258d? | 2011-09-19 A | 2012-09-07 A | 100% | 2011-09-19 | 2012-09-07 | 258d? |  | C1 | 5680h | 5680h | RT_VGCS_Red | PCG-27 | Nokia Siemens Networks | robert.zaus@nsn.com | Rel-11 | CP-53 | Frederic | RT_VGCS_Red |  |  |  |
| 1468 | 350.1 | CT1 part of GCSMSC and GCR Redundancy for VGCS/VBS | 258d? | 2011-09-19 A | 2012-09-07 A | 100% | 2011-09-19 | 2012-09-07 | 258d? | finish no earlier than 2012-09-07 | C1 | 2048h | 2048h | RT_VGCS_Red | PCG-27 | Nokia Siemens Networks | robert.zaus@nsn.com | Rel-11 | CP-53 | Frederic |  |  |  |  |
| 1469 | 350.2 | Deleted - CT4 part of GCSMSC and GCR Redundancy for VGCS/VBS | 197d? | 2011-09-19 A | 2012-06-15 A | 100% | 2011-09-19 | 2012-06-15 | 197d? | finish no earlier than 2012-06-15 | C4 | 1568h | 1568h | RT_VGCS_Red | PCG-27 | Nokia Siemens Networks | robert.zaus@nsn.com | Rel-11 | CP-53 | Kimmo |  | PCG-29 | CP-56 |  |
| 1470 | 351 | Support of RFC 6140 in IMS | 203d? | 2011-12-02 A | 2012-09-07 A | 100% | 2011-12-02 | 2012-09-07 | 203d? | finish no earlier than 2012-09-07 | C1 | 1608h | 1608h | GINI | PCG-28 | Deutsche Telekom | martin.huelsemann@telekom.de | Rel-11 | CP-54 | Frederic | GINI |  |  |  |
| 1471 | 352 | **Enhancements for Multimedia Priority Service (MPS) – Gateway Control Priority** | 203d? | 2011-12-02 A | 2012-09-07 A | 100% | 2011-12-02 | 2012-09-07 | 203d? |  | C4; C3 | 6464h | 6464h | eMPS_Gateway | PCG-28 | Telcordia | Viqar Shaikh | Rel-11 | CP-54 | Kimmo | eMPS_Gateway |  |  | Public Safety (I-A) |
| 1472 | 352.1 | CT4 part of Enhancements for Multimedia Priority Service (MPS) – Gateway Control Priority | 202d? | 2011-12-02 A | 2012-09-07 A | 100% | 2011-12-02 | 2012-09-07 | 202d? | finish no earlier than 2012-09-07 | C4 | 1608h | 1608h | eMPS_Gateway | PCG-28 | Telcordia | Viqar Shaikh | Rel-11 | CP-54 | Kimmo |  |  |  | Public Safety (I-A) |
| 1473 | 352.2 | CT3 part of Enhancements for Multimedia Priority Service (MPS) – Gateway Control Priority | 202d? | 2011-12-02 A | 2012-09-07 A | 100% | 2011-12-02 | 2012-09-07 | 202d? | finish no earlier than 2012-09-07 | C3 | 1608h | 1608h | eMPS_Gateway | PCG-28 | Telcordia | Viqar Shaikh | Rel-11 | CP-54 | Adrian |  |  |  | Public Safety (I-A) |
| 1474 | 353 | Inter-IMS Network to Network Interface (II-NNI) enhancements: SIP timers applicability (Stage 3) | 138d? | 2012-03-02 A | 2012-09-07 A | 100% | 2012-03-02 | 2012-09-07 | 138d? | start no earlier than 2012-03-02 | C3 | 1088h | 1088h | NNI_timers | PCG-28 | Telecom Italia | antonio.ascolese@telecomitalia.it | Rel-11 | CP-55 | Adrian | NNI_timers |  |  |  |
| 1475 | 354 | AT commands for Universal Resource Identifier (URI) support | 188d? | 2012-06-15 A | 2013-03-01 A | 100% | 2012-06-15 | 2013-03-01 | 188d? | finish no earlier than 2013-03-01 | C1 | 1496h | 1496h | ATURI | PCG-29 | Intel | frank.kowalewski@intel.com | Rel-11 | CP-56 | Frederic | ATURI |  |  |  |
| 1476 | 355 | PS Additional Number (Stage 3) | 62d? | 2012-06-15 A | 2012-09-07 A | 100% | 2012-06-15 | 2012-09-07 | 62d? | finish no earlier than 2012-09-07 | C4 | 488h | 488h | PSAN | PCG-29 | Deutsche Telekom | Yvette.koza@t-mobile.at | Rel-11 | CP-56 | Kimmo | PSAN |  |  |  |
| 1477 | 356 | Generic IMS User Group Over Sh | 62d? | 2012-06-15 A | 2012-09-07 A | 100% | 2012-06-15 | 2012-09-07 | 62d? | finish no earlier than 2012-09-07 | C4 | 488h | 488h | GenUG_Sh | PCG-29 | Alcatel-Lucent | jean-jacques.trottin@alcatel-lucent.com | Rel-11 | CP-56 | Kimmo | GenUG_Sh |  |  |  |

Notes:
- 1452: CP#57 completed
- 1453: CP#57 completed / Impacted TSs and TRs: 23.218, 24.229, 24.930
- 1454: CP#65 completed / Impacted TSs and TRs: RFC 7315 (was draft-drage-sipping-rfc3455bis)
- 1455: CP#64 completed / Impacted TSs and TRs: RFC 7135 (was draft-polk-local-emergency-rph-namespace)
- 1456: CP#57 completed / Impacted TSs and TRs: 29.163, 29.165
- 1457: CP#64 Draft removed from 3GPP documentation / Impacted TSs and TRs: draft-avasarala-dispatch-comm-div-notification
- 1458: TSG#57, GP#55 completed. CT defined a generic solution (not only for GERAN) / Impacted TSs and TRs: GERAN
- 1459: SP#57 completed / Impacted TSs and TRs: 23.060, 23.251
- 1460: CP#57 completed
- 1461: CP#57 completed / Impacted TSs and TRs: 29.281
- 1462: CP#56 stopped (SA2 decided NO CT3 impact) / Impacted TSs and TRs: 29.212
- 1463: GP#55 completed. GP#51 approved WID / Impacted TSs and TRs: 48.018
- 1464: CP#57 completed. Stage 3 continuation of Rel-8 Feature SAES (3GPP System Architecture Evolution Specification - Evolved Packet System) UID_320005
- 1465: CP#57 completed / Impacted TSs and TRs: 23.122, 24.008, 24.167, 24.229, 24.301, 24.302, 24.303, 24.304, 24.305, 24.312, 29.018, 29.118
- 1466: CP#57 completed / Impacted TSs and TRs: 23.122, 24.008, 24.167, 24.229, 24.301, 24.302, 24.303, 24.304, 24.305, 24.312, 29.018, 29.118
- 1467: CP#57 completed. Stage 2/3 adding a CN internal functionality, not affecting Voice Group Call Service (VGCS)/VBS as perceived by service subscriber. Hence, no Stage 1 impact for VGCS/VBS (42.068, 42.069) / Impacted TSs and TRs: Stage 2/3
- 1468: CP#57 completed / Impacted TSs and TRs: 43.068, 43.069
- 1469: CP#56 stopped (no CT4 impact) / Impacted TSs and TRs: 29.002
- 1470: CP#57 completed. Stage 3. Support procedures and protocol extensions in RFC6140 "Registration for Multiple Phone Numbers in SIP" to IMS for complex UEs. Ensure co-existence with NGCN IP-PBX registration procedures already defined in IMS. / Impacted TSs and TRs: 24.229
- 1471: CP#57 completed. Stage 3. Stage 1 for MPS in 22.153. Details of any MGW actions for priority needs to be further studied within the scope of this WI. / Impacted TSs and TRs: Stage 3
- 1472: CP#57 completed / Impacted TSs and TRs: 23.333, 23.334, 29.232, 29.238, 29.332, 29.333, 29.334
- 1473: CP#57 completed / Impacted TSs and TRs: 29.162, 29.163, 29.292
- 1474: CP#57 completed / Impacted TSs and TRs: 29.165
- 1475: CP#59 completed. Define new AT cmd for URI addresses for IMS services (eg VoLTE). 27.007(AT cmd to control MT functions and GSM/UMTS/LTE network services from TE), 27.005(AT commands for SMS). Currently address types for AT cmd based on dialling# / Impacted TSs and TRs: 27.005, 27.007
- 1476: CP#57 completed. Stage 1 in Rel-11 SA1 TS 22.101 clause 17.7.3 (No Stage 2 needed since no architecture impact) / Impacted TSs and TRs: 23.003, 23.008, 29.002, 29.272, 29.230
- 1477: CP#57 completed / Impacted TSs and TRs: 29.364

| ID | WBS | Task | Duration | Start | Finish | Complete | Baseline start | Baseline finish | Baseline duration | Constraint | Resources | Work | Actual work | Acronym | PCG approved | WI rapporteur name | WI rapporteur e-mail | Release | TSG approved | MCC resp | Acronym_3GU_Export | PCG stopped | TSG stopped | Status Report |
| --- | --- | --- | --- | --- | --- | --- | --- | --- | --- | --- | --- | --- | --- | --- | --- | --- | --- | --- | --- | --- | --- | --- | --- | --- |
| 1478 | 357 | **IMS Operator Determined Call Barring** | 205d? | 2012-09-07 A | 2013-06-14 A | 100% | 2012-09-07 | 2013-06-14 | 205d? |  | C1; C4 | 5411.54h | 5411.54h | IODB | PCG-29 | Orange | Youssef.Chadli@Orange.com | Rel-11 | CP-57 | Frederic | IODB |  |  |  |
| 1479 | 357.1 | CT1 part of IMS Operator Determined Call Barring | 203d? | 2012-09-10 A | 2013-06-14 A | 100% | 2012-09-10 | 2013-06-14 | 203d? | finish no earlier than 2013-06-14 | C1 | 1616h | 1616h | IODB | PCG-29 | Orange | Youssef.Chadli@Orange.com | Rel-11 | CP-57 | Frederic |  |  |  |  |
| 1480 | 357.2 | CT4 part of IMS Operator Determined Call Barring | 69d? | 2012-09-07 A | 2013-03-12 A | 100% | 2012-09-07 | 2013-03-12 | 69d? | finish no earlier than 2012-12-07 | C4 | 515.54h | 515.54h | IODB | PCG-29 | Orange | Youssef.Chadli@Orange.com | Rel-11 | CP-57 | Kimmo |  |  |  |  |
| 1481 | 358 | **Enhanced T.38 FAX support (Stage 3)** | 69d? | 2012-09-06 A | 2012-12-07 A | 100% | 2012-09-06 | 2012-12-07 | 69d? |  | C3; C1; C4 | 2728h | 2728h | MMTel_T.38_FAX | PCG-29 | NEC | Naoaki Suzuki (n-suzuki@en.jp.nec.com) | Rel-11 | CP-57 | Adrian | MMTel_T.38_FAX |  |  |  |
| 1482 | 358.1 | CT3 part of Enhanced T.38 FAX support | 68d? | 2012-09-07 A | 2012-12-07 A | 100% | 2012-09-07 | 2012-12-07 | 68d? | finish no earlier than 2012-12-07 | C3 | 528h | 528h | MMTel_T.38_FAX | PCG-29 | NEC | Naoaki Suzuki (n-suzuki@en.jp.nec.com) | Rel-11 | CP-57 | Adrian |  |  |  |  |
| 1483 | 358.2 | CT1 part of Enhanced T.38 FAX support | 67d? | 2012-09-07 A | 2012-12-07 A | 100% | 2012-09-07 | 2012-12-07 | 67d? | finish no earlier than 2012-12-07 | C1 | 528h | 528h | MMTel_T.38_FAX | PCG-29 | NEC | Naoaki Suzuki (n-suzuki@en.jp.nec.com) | Rel-11 | CP-57 | Frederic |  |  |  |  |
| 1484 | 358.3 | CT4 part of Enhanced T.38 FAX support | 2d? | 2012-09-06 A | 2012-09-07 A | 100% | 2012-09-06 | 2012-09-07 | 2d? | finish no earlier than 2012-12-07 | C4 | 16h | 16h | MMTel_T.38_FAX | PCG-29 | NEC | Naoaki Suzuki (n-suzuki@en.jp.nec.com) | Rel-11 | CP-57 | Kimmo |  |  |  |  |
| 1485 | 359 | **Deleted - Enhancement of the Protocols for SMS over SGs (Stage 3)** | 142d? | 2011-12-02 A | 2012-06-15 A | 100% | 2011-12-02 | 2012-06-15 | 142d? |  | C4; C1 | 5664h | 5664h | PROTOC_SMS_SGs | PCG-28 | Alcatel-Lucent | jean-jacques.trottin@alcatel-lucent.com | Rel-11 | CP-54 | Kimmo | PROTOC_SMS_SGs | PCG-29 | CP-56 |  |
| 1486 | 359.1 | Deleted - TR Study on enhancement of protocols for SMS service over SGs | 142d? | 2011-12-02 A | 2012-06-15 A | 100% | 2011-12-02 | 2012-06-15 | 142d? | finish no earlier than 2012-06-15 | C4 | 1128h | 1128h | PROTOC_SMS_SGs | PCG-28 | Alcatel-Lucent | jean-jacques.trottin@alcatel-lucent.com | Rel-11 | CP-54 | Kimmo |  | PCG-29 | CP-56 |  |
| 1487 | 359.2 | Deleted - CT4 part of Enhancement of the Protocols for SMS over SGs | 142d? | 2011-12-02 A | 2012-06-15 A | 100% | 2011-12-02 | 2012-06-15 | 142d? | finish no earlier than 2012-06-15 | C4 | 1128h | 1128h | PROTOC_SMS_SGs | PCG-28 | Alcatel-Lucent | jean-jacques.trottin@alcatel-lucent.com | Rel-11 | CP-54 | Kimmo |  | PCG-29 | CP-56 |  |
| 1488 | 359.3 | Deleted - CT1 part of Enhancement of the Protocols for SMS over SGs | 142d? | 2011-12-02 A | 2012-06-15 A | 100% | 2011-12-02 | 2012-06-15 | 142d? | finish no earlier than 2012-06-15 | C1 | 1136h | 1136h | PROTOC_SMS_SGs | PCG-28 | Alcatel-Lucent | jean-jacques.trottin@alcatel-lucent.com | Rel-11 | CP-54 | Frederic |  | PCG-29 | CP-56 |  |
| 1489 | 360 | **Full Support of Multi-Operator Core Network by GERAN** | 584d? | 2011-03-04 A | 2013-05-17 A | 100% | 2011-03-04 | 2013-05-17 | 584d? |  | G2; S2; C1 | 31293.3h | 31293.3h | Full_MOCN-GERAN | PCG-26 | Alcatel-Lucent | michel.robert@alcatel-lucent.com | Rel-11 | GP-49 | Paolo | Full_MOCN-GERAN |  |  |  |
| 1490 | 360.1 | GERAN part of Full Support of Multi-Operator Core Network by GERAN | 584d? | 2011-03-04 A | 2013-05-17 A | 100% | 2011-03-04 | 2013-05-17 | 584d? | finish no earlier than 2013-06-07 | G2 | 4656.4h | 4656.4h | Full_MOCN-GERAN | PCG-26 | Alcatel-Lucent | michel.robert@alcatel-lucent.com | Rel-11 | GP-49 | Gert |  |  |  |  |
| 1491 | 360.2 | Stage 2 for Full Support of Multi-Operator Core Network by GERAN | 160.8d? | 2011-06-08 A | 2012-03-07 A | 100% | 2011-06-08 | 2012-03-07 | 160.8d? | finish no earlier than 2012-03-07 | S2 | 1278.4h | 1278.4h | Full_MOCN-GERAN | PCG-26 | Alcatel-Lucent | nicolas.drevon@alcatel-lucent.com | Rel-11 | GP-49 | Maurice |  |  |  |  |
| 1492 | 360.3 | **CN Stage 3 for Full Support of Multi-Operator Core Network by GERAN** | 403d? | 2011-06-03 A | 2012-12-07 A | 100% | 2011-06-03 | 2012-12-07 | 403d? |  | C1; C4 | 9838.51h | 9838.51h | Full_MOCN-GERAN | PCG-26 | Alcatel-Lucent | jennifer.liu@alcatel-lucent.com | Rel-11 | GP-49 | Frederic |  |  |  |  |
| 1493 | 360.3.1 | CT1 part of CN Stage 3 for Full Support of Multi-Operator Core Network by GERAN | 362.8d? | 2011-06-03 A | 2012-12-07 A | 100% | 2011-06-03 | 2012-12-07 | 362.8d? | finish no earlier than 2012-12-07 | C1 | 2886.51h | 2886.51h | Full_MOCN-GERAN | PCG-26 | Alcatel-Lucent | jennifer.liu@alcatel-lucent.com | Rel-11 | GP-49 | Frederic |  |  |  |  |
| 1494 | 360.3.2 | CT4 part of CN Stage 3 for Full Support of Multi-Operator Core Network by GERAN | 64d? | 2012-06-13 A | 2012-09-07 A | 100% | 2012-06-13 | 2012-09-07 | 64d? | finish no earlier than 2012-09-07 | C4 | 504h | 504h | Full_MOCN-GERAN | PCG-29 | Alcatel-Lucent | michel.robert@alcatel-lucent.com | Rel-11 | GP-54 | Kimmo |  |  |  |  |
| 1495 | 360.4 | Stage 2 for Gateway Core Network Sharing for GERAN | 192d? | 2012-06-18 A | 2013-03-06 A | 100% | 2012-06-18 | 2013-03-06 | 192d? | finish no earlier than 2013-03-06 | S2 | 1504h | 1504h | Full_MOCN-GERAN-GWCN | PCG-29 | Vodafone | chris.pudney@vodafone.com | Rel-11 | SP-56 | Maurice | Full_MOCN-GERAN-GWCN |  |  |  |
| 1496 | 361 | **Medium range/local area requirements for multicarrier BTS** | 264d? | 2011-11-25 A | 2012-11-23 A | 100% | 2011-11-25 | 2012-11-23 | 264d? |  | G1 | 6296h | 6296h | MRLA | PCG-28 | Ericsson | Eric Nordström | Rel-11 | GP-52 | Paolo | MRLA |  |  |  |
| 1497 | 361.1 | Core part: Medium range/local area requirements for multicarrier BTS | 263d? | 2011-11-25 A | 2012-11-23 A | 100% | 2011-11-25 | 2012-11-23 | 263d? | finish no earlier than 2012-11-23 | G1 | 2096h | 2096h | MRLA-Core | PCG-28 | Ericsson | Eric Nordström | Rel-11 | GP-52 | Paolo | MRLA-Core |  |  |  |
| 1498 | 361.2 | Perf. part: Medium range/local area requirements for multicarrier BTS | 262d? | 2011-11-28 A | 2012-11-23 A | 100% | 2011-11-28 | 2012-11-23 | 262d? | finish no earlier than 2012-11-23 | G1 | 2088h | 2088h | MRLA-Perf | PCG-28 | Ericsson | Eric Nordström | Rel-11 | GP-52 | Paolo | MRLA-Perf |  |  |  |
| 1499 | 362 | Domain Specific Access Control in GERAN | 131d? | 2012-03-05 A | 2012-08-31 A | 100% | 2012-03-05 | 2012-08-31 | 131d? | finish no earlier than 2012-08-31 | G2 | 1048h | 1048h | GDSAC | PCG-28 | Vodafone | chris.pudney@vodafone.com | Rel-11 | GP-53 | Gert | GDSAC |  |  |  |
| 1500 | 363 | **Extending 850 MHz Upper Band (814 – 849 MHz)** | 589d? | 2010-12-10 A | 2013-03-01 A | 100% | 2010-12-10 | 2013-03-01 | 589d? |  | R4; R2; R3; R5 | 33352h | 33352h | e850_UB | PCG-26 | Sprint | John.J.Humbert@Sprint.com | Rel-11 | RP-50 | Issam | e850_UB |  |  |  |
| 1501 | 363.1 | Core part: Extending 850 MHz Upper Band (814 – 849 MHz) | 324d? | 2010-12-10 A | 2012-03-02 A | 100% | 2010-12-10 | 2012-03-02 | 324d? | finish no earlier than 2012-03-02 | R4; R2; R3 | 7776h | 7776h | e850_UB-Core | PCG-26 | Sprint | John.J.Humbert@Sprint.com | Rel-11 | RP-50 | Issam | e850_UB-Core |  |  | RP-120075 |
| 1502 | 363.2 | Perf. part: Extending 850 MHz Upper Band (814 – 849 MHz) | 324d? | 2010-12-10 A | 2012-03-02 A | 100% | 2010-12-10 | 2012-03-02 | 324d? | finish no earlier than 2012-03-02 | R4 | 2592h | 2592h | e850_UB-Perf | PCG-26 | Sprint | John.J.Humbert@Sprint.com | Rel-11 | RP-50 | Issam | e850_UB-Perf |  |  | RP-120076 |
| 1503 | 363.3 | Test part: Extending 850 MHz Upper Band (814 – 849 MHz) | 517d? | 2011-03-18 A | 2013-03-01 A | 100% | 2011-03-18 | 2013-03-01 | 517d? | finish no earlier than 2013-03-01 | R5 | 4136h | 4136h | e850_UB-UEConTest | PCG-26 | Sprint | John.J.Humbert@Sprint.com | Rel-11 | RP-51 | Ingbert | e850_UB-UEConTest |  |  | RP-130043 |

Notes:
- 1478: LS_in C4-121615 GSMA IREG RILTE concluded that TS 22.041 clause 5.4 Stage 1 requirements are not covered by stage 3 specifications
- 1479: CP#60 completed. Handling of premium rate numbers remained OPEN in Rel-11 (shifted to Rel-12). CP-130384 LS_out sent to SA1 / GSMA informing this TSG CT decision. / Impacted TSs and TRs: New TS 24.315
- 1480: CP#58 completed / Impacted TSs and TRs: 23.008 , 23.015 , 29.328 , 29.329 , 29.364
- 1481: CP#58 completed. Linked to Rel-8 Feature: IMS Multimedia Telephony Service (IMS-MMTel) UID_7038. SA1 added FAX stage 1 requirement only in Rel-10 under TEI10 to TS 22.173 (CR#0064)
- 1482: CP#58 completed / Impacted TSs and TRs: 29.163
- 1483: CP#58 completed / Impacted TSs and TRs: 24.229
- 1484: CP#57 completed / Impacted TSs and TRs: 29.332
- 1485: CP#56 stopped. Reason: Protocols for SMS over SGs is replaced by the SIMTC SMS in MME solution (as solution not only for MTC user but for general subscribers) / Impacted TSs and TRs: Stage 3
- 1486: CP#56 stopped (abandonned new TR 29.818) / Impacted TSs and TRs: new TR 29.818
- 1487: CP#56 stopped (abandonned new TS 29.218 Diameter based protocols for SMS service over SGs) / Impacted TSs and TRs: 29.305, new TS 29.218
- 1488: CP#56 stopped / Impacted TSs and TRs: 23.040, 24.011, 43.068
- 1489: GP#58 completed. GP#49 approved WID. Standardization of management of MOCN supporting MSs/UEs in GERAN. Continuation of Rel-10 MOCN-GERAN UID_490001 / Impacted TSs and TRs: GERAN
- 1490: GP#58 completed. GP#49 approved WID / Impacted TSs and TRs: 44.018, 44.060, 45.002, 45.008, 48.008, 48.018
- 1491: SP#55 completed / Impacted TSs and TRs: 23.251, 23.272
- 1492: CP#58 completed
- 1493: CP#58 completed / Impacted TSs and TRs: 24.008
- 1494: CP#57 completed / Impacted TSs and TRs: 23.003
- 1495: SP#59 completed. (23.251CR0062R2 as TEI11. TS 23.251 specifies both MOCN and GWCN for E-UTRAN and UTRAN, but GWCN is not yet supported on GERAN. Extend Full_MOCN-GERAN to also cover GWCN GERAN / Impacted TSs and TRs: 23.251
- 1496: GP#56 completed. GP#52 approved WID / Impacted TSs and TRs: GERAN
- 1497: Stage 3. GP#56 completed. GP#52 approved WID / Impacted TSs and TRs: 45.005
- 1498: Test spec. GP#56 completed. GP#52 approved WID / Impacted TSs and TRs: 51.021
- 1499: GP#55 completed. GP#53 approved WID. Work is dependent upon Full_MOCN-GERAN (UID_510001) / Impacted TSs and TRs: GERAN 44.018
- 1500: Stage 3. Triggered by R4 Rel-10 LTE TR 37.806 Study on Extending 850 MHz (UID_440016) / Impacted TSs and TRs: UTRA, LTE
- 1501: RP#55 completed / Impacted TSs and TRs: 25.101, 25.104, 25.113, 25.133, 25.141, 25.461, 25.466, 36.101, 36.104, 36.113, 36.124, 36.133, 36.141, 36.307, 36.331, 37.104, 37.113, 37.141
- 1502: RP#55 completed / Impacted TSs and TRs: 25.101, 25.104, 25.113, 25.133, 25.141, 25.461, 25.466, 36.101, 36.104, 36.124, 36.133, 36.141, 36.307, 36.331, 37.104, 37.113, 37.141
- 1503: RP#59 completed / Impacted TSs and TRs: 34.108, 34.121-1, 34.121-2, 34.123-1, 34.123-2, 34.123-3, 36.508, 36.521-1, 36.521-2, 36.521-3, 36.523-1, 36.523-2, 36.523-3

| ID | WBS | Task | Duration | Start | Finish | Complete | Baseline start | Baseline finish | Baseline duration | Constraint | Resources | Work | Actual work | Acronym | PCG approved | WI rapporteur name | WI rapporteur e-mail | Release | TSG approved | MCC resp | Special Focus Doc | Acronym_3GU_Export | Status Report |
| --- | --- | --- | --- | --- | --- | --- | --- | --- | --- | --- | --- | --- | --- | --- | --- | --- | --- | --- | --- | --- | --- | --- | --- |
| 1504 | 364 | **Further Self Optimizing Networks (SON) enhancements** | 325d? | 2011-09-19 A | 2012-12-07 A | 100% | 2011-09-19 | 2012-12-07 | 325d? |  | R3; R2 | 10400h | 10400h | SONenh2_LTE_UTRA | PCG-27 | Nokia Siemens Networks | krzysztof.kordybach@nsn.com | Rel-11 | RP-53 | Juha | SON | SONenh2_LTE_UTRA |  |
| 1505 | 364.1 | Core part: Further Self Optimizing Networks (SON) enhancements | 325d? | 2011-09-19 A | 2012-12-07 A | 100% | 2011-09-19 | 2012-12-07 | 325d? | finish no earlier than 2012-12-07 | R3; R2 | 5200h | 5200h | SONenh2_LTE_UTRA-Core | PCG-27 | Nokia Siemens Networks | krzysztof.kordybach@nsn.com | Rel-11 | RP-53 | Juha | SON | SONenh2_LTE_UTRA-Core | RP-121557 |
| 1506 | 365 | **Enhancement of Minimization of Drive Tests for E-UTRAN and UTRAN** | 590d? | 2011-09-19 A | 2013-12-06 A | 100% | 2011-09-19 | 2013-12-06 | 590d? |  | R2; R1; R3; R4; R5 | 35608h | 35608h | eMDT_UMTSLTE | PCG-27 | MediaTek | Johan Johansson | Rel-11 | RP-53 | Yong-Jun |  | eMDT_UMTSLTE |  |
| 1507 | 365.1 | Core part: Enhancement of Minimization of Drive Tests for E-UTRAN and UTRAN | 325d? | 2011-09-19 A | 2012-12-07 A | 100% | 2011-09-19 | 2012-12-07 | 325d? | finish no earlier than 2012-12-07 | R2; R1; R3; R4 | 10400h | 10400h | eMDT_UMTSLTE-Core | PCG-27 | MediaTek | Johan Johansson | Rel-11 | RP-53 | Yong-Jun |  | eMDT_UMTSLTE-Core | RP-121556 |
| 1508 | 365.2 | Test part: Enhancement of Minimization of Drive Tests for E-UTRAN and UTRAN | 202d? | 2013-03-04 A | 2013-12-06 A | 100% | 2013-03-04 | 2013-12-06 | 202d? | finish no earlier than 2013-12-06 | R5 | 1608h | 1608h | eMDT_UMTSLTE-UEConTest | PCG-30 | NTT DoCoMo | masahiro.tamaoki.eu@nttdocomo.com | Rel-11 | RP-59 | Ingbert |  | eMDT_UMTSLTE-UEConTest | RP-131447 |
| 1509 | 366 | **Network Energy Saving for E-UTRAN** | 258d? | 2011-09-19 A | 2012-09-07 A | 100% | 2011-09-19 | 2012-09-07 | 258d? |  | R3; GP | 6224h | 6224h | Netw_Energy_LTE | PCG-27 | China Mobile | yangning@chinamobile.com | Rel-11 | RP-53 | Juha |  | Netw_Energy_LTE |  |
| 1510 | 366.1 | Core part: Network Energy Saving for E-UTRAN | 257d? | 2011-09-19 A | 2012-09-07 A | 100% | 2011-09-19 | 2012-09-07 | 257d? | finish no earlier than 2012-09-07 | R3 | 2056h | 2056h | Netw_Energy_LTE-Core | PCG-27 | China Mobile | yangning@chinamobile.com | Rel-11 | RP-53 | Juha |  | Netw_Energy_LTE-Core | RP-121016 |
| 1511 | 366.2 | GERAN part: Network Energy Saving for E-UTRAN | 5d? | 2012-08-27 A | 2012-08-31 A | 100% | 2012-08-27 | 2012-08-31 | 5d? | finish no earlier than 2012-08-31 | GP | 40h | 40h |  | PCG-29 | Alcatel-Lucent | marguerite.woch@alcatel-lucent.com | Rel-11 | GP-55 | Paolo |  |  |  |
| 1512 | 367 | **E-UTRA medium range and MSR medium range/local area BS class requirements** | 325d? | 2011-09-19 A | 2012-12-07 A | 100% | 2011-09-19 | 2012-12-07 | 325d? |  | R4; G1 | 12432h | 12432h | medBS_class_LTE_MSR | PCG-27 | Ericsson | johan.skold@ericsson.com | Rel-11 | RP-53 | Issam |  | medBS_class_LTE_MSR |  |
| 1513 | 367.1 | Core part: E-UTRA medium range and MSR medium range/local area BS class requirements | 323d? | 2011-09-19 A | 2012-12-07 A | 100% | 2011-09-19 | 2012-12-07 | 323d? | finish no earlier than 2012-12-07 | R4 | 2576h | 2576h | medBS_class_LTE_MSR-Core | PCG-27 | Ericsson | johan.skold@ericsson.com | Rel-11 | RP-53 | Issam |  | medBS_class_LTE_MSR-Core | RP-121558 |
| 1514 | 367.2 | Perf. part: E-UTRA medium range and MSR medium range/local area BS class requirements | 321d? | 2011-09-23 A | 2012-12-07 A | 100% | 2011-09-23 | 2012-12-07 | 321d? | finish no earlier than 2012-12-07 | R4 | 2568h | 2568h | medBS_class_LTE_MSR-Perf | PCG-27 | Ericsson | johan.skold@ericsson.com | Rel-11 | RP-53 | Issam |  | medBS_class_LTE_MSR-Perf | RP-121559 |
| 1515 | 367.3 | GERAN part: E-UTRA medium range and MSR medium range/local area BS class requirements | 261d? | 2011-11-28 A | 2012-11-23 A | 100% | 2011-11-28 | 2012-11-23 | 261d? | finish no earlier than 2012-11-23 | G1 | 2088h | 2088h | medBS_class_LTE_MSR-GERAN | PCG-28 | Ericsson | Eric Nordström | Rel-11 | GP-52 | Paolo |  | medBS_class_LTE_MSR-GERAN |  |
| 1516 | 368 | **RF Requirements for Multi-Band and Multi-Standard Radio (MB-MSR) Base Station** | 553.1d? | 2012-02-06 A | 2014-03-06 A | 100% | 2012-02-06 | 2014-03-06 | 553.1d? |  | R4; G1 | 20915.2h | 20915.2h | MB_MSR_RF | PCG-28 | Huawei | Liu Ye (leo.liuye@huawei.com) | Rel-11 | RP-55 | Issam |  | MB_MSR_RF |  |
| 1517 | 368.1 | Core part: RF Requirements for Multi-Band and Multi-Standard Radio (MB-MSR) Base Station | 223.1d? | 2012-02-06 A | 2012-12-07 A | 100% | 2012-02-06 | 2012-12-07 | 223.1d? | finish no earlier than 2012-12-07 | R4; G1 | 3569.6h | 3569.6h | MB_MSR_RF-Core | PCG-28 | Huawei | Liu Ye (leo.liuye@huawei.com) | Rel-11 | RP-55 | Issam |  | MB_MSR_RF-Core | RP-121985 |
| 1518 | 368.2 | Perf. part: RF Requirements for Multi-Band and Multi-Standard Radio (MB-MSR) Base Station | 531d? | 2012-03-08 A | 2014-03-06 A | 100% | 2012-03-08 | 2014-03-06 | 531d? | finish no earlier than 2014-03-06 | R4; G1 | 8496h | 8496h | MB_MSR_RF-Perf | PCG-28 | Huawei | Liu Ye (leo.liuye@huawei.com) | Rel-11 | RP-55 | Issam |  | MB_MSR_RF-Perf | RP-140064 |
| 1519 | 369 | **Further enhancements to H(e)NB mobility - Part 1** | 129d? | 2012-06-15 A | 2012-12-07 A | 100% | 2012-06-15 | 2012-12-07 | 129d? |  | R3; R2 | 4128h | 4128h | EHNB_enh1 | PCG-29 | Alcatel-Lucent | Martin.Warner@alcatel-lucent.com | Rel-11 | RP-56 | Juha | HNB | EHNB_enh1 |  |
| 1520 | 369.1 | Core part: Further enhancements to H(e)NB mobility - Part 1 | 129d? | 2012-06-15 A | 2012-12-07 A | 100% | 2012-06-15 | 2012-12-07 | 129d? | finish no earlier than 2012-12-07 | R3; R2 | 2064h | 2064h | EHNB_enh1-Core | PCG-29 | Alcatel-Lucent | Martin.Warner@alcatel-lucent.com | Rel-11 | RP-56 | Juha | HNB | EHNB_enh1-Core | RP-121563 |
| 1521 | 370 | **Further enhancements to H(e)NB mobility - Part 2** | 127d? | 2012-06-19 A | 2012-12-07 A | 100% | 2012-06-19 | 2012-12-07 | 127d? |  | R3; R2 | 4064h | 4064h | EHNB_enh2 | PCG-29 | Alcatel-Lucent | Martin.Warner@alcatel-lucent.com | Rel-11 | RP-56 | Juha | HNB | EHNB_enh2 |  |
| 1522 | 370.1 | Core part: Further enhancements to H(e)NB mobility - Part 2 | 127d? | 2012-06-19 A | 2012-12-07 A | 100% | 2012-06-19 | 2012-12-07 | 127d? | finish no earlier than 2012-12-07 | R3; R2 | 2032h | 2032h | EHNB_enh2-Core | PCG-29 | Alcatel-Lucent | Martin.Warner@alcatel-lucent.com | Rel-11 | RP-56 | Juha | HNB | EHNB_enh2-Core | RP-121564 |
| 1523 | 371 | **Network-Based Positioning Support for LTE** | 1391d? | 2009-03-05 A | 2014-06-13 A | 100% | 2009-03-05 | 2014-06-13 | 1391d? |  | R2; R1; R3; R4 | 91464h | 91464h | LCS_LTE-NBPS | PCG-22 | TruePosition | terri.brooks@trueposition.com | Rel-11 | RP-43 | Yong-Jun |  | LCS_LTE-NBPS |  |
| 1524 | 371.1 | Core part: Network-Based Positioning Support for LTE | 1125d? | 2009-03-05 A | 2013-06-12 A | 100% | 2009-03-05 | 2013-06-12 | 1125d? | finish no earlier than 2013-06-12 | R2; R1; R3; R4 | 36000h | 36000h | LCS_LTE-NBPS-Core | PCG-22 | TruePosition | terri.brooks@trueposition.com | Rel-11 | RP-43 | Yong-Jun |  | LCS_LTE-NBPS-Core | RP-130483 |
| 1525 | 371.2 | Perf. part: Network-Based Positioning Support for LTE | 1377d? | 2009-03-24 A | 2014-06-13 A | 100% | 2009-03-24 | 2014-06-13 | 1377d? | finish no earlier than 2014-06-13 | R4 | 11016h | 11016h | LCS_LTE-NBPS-Perf | PCG-22 | TruePosition | terri.brooks@trueposition.com | Rel-11 | RP-43 | Yong-Jun |  | LCS_LTE-NBPS-Perf | RP-140626 |
| 1526 | 372 | **Service continuity improvements for MBMS for LTE** | 993d? | 2010-06-04 A | 2014-03-06 A | 100% | 2010-06-04 | 2014-03-06 | 993d? |  | R2; R3; R5 | 35496h | 35496h | MBMS_LTE_SC | PCG-25 | Huawei | David.Lecompte@huawei.com | Rel-11 | RP-48 | Yong-Jun |  | MBMS_LTE_SC |  |
| 1527 | 372.1 | Core part: Service continuity improvements for MBMS for LTE | 596d? | 2010-06-04 A | 2012-09-07 A | 100% | 2010-06-04 | 2012-09-07 | 596d? | finish no earlier than 2012-09-07 | R2; R3 | 9536h | 9536h | MBMS_LTE_SC-Core | PCG-25 | Huawei | David.Lecompte@huawei.com | Rel-11 | RP-48 | Yong-Jun |  | MBMS_LTE_SC-Core | RP-121001 |
| 1528 | 372.2 | Test part: Service continuity improvements for MBMS for LTE | 266d? | 2013-03-04 A | 2014-03-06 A | 100% | 2013-03-04 | 2014-03-06 | 266d? | finish no earlier than 2014-03-06 | R5 | 2128h | 2128h | MBMS_LTE_SC-UEConTest | PCG-30 | Ericsson | leif.mattisson@ericsson.com | Rel-11 | RP-59 | Ingbert |  | MBMS_LTE_SC-UEConTest | RP-140074 |

Notes:
- 1504: Stage 1/2/3 / Impacted TSs and TRs: UTRA, LTE
- 1505: RP#58 completed / Impacted TSs and TRs: 25.331, 25.401, 25.410, 25.413, 25.423, 25.433, 36.300, 36.331, 36.413, 36.423
- 1506: Stage 2/3 / Impacted TSs and TRs: UTRA, LTE
- 1507: RP#58 completed / Impacted TSs and TRs: 25.133, 25.123, 25.304, 25.331, 25.413, 25.423, 36.133, 36.304, 36.306, 36.331, 36.413, 36.423, 37.320, 36.300
- 1508: RP#62 completed / Impacted TSs and TRs: 34.108, 34.109, 34.123-1, 34.123-2, 34.123-3, 36.508, 36.509, 36.523-1, 36.523-2, 36.523-3
- 1509: Stage 2/3 / Impacted TSs and TRs: LTE, GERAN
- 1510: RP#57 completed. Inter-RAT aspect can affect UTRA and GERAN as well / Impacted TSs and TRs: 25.413, 36.300, 36.413, 36.423
- 1511: GP#55 approved WID and completed. Stage 3. Changes in RIM protocol and in SON Transfer RIM application to provide support for Energy Savings Indication feature / Impacted TSs and TRs: 48.018 [Serving GPRS Support Node (SGSN); BSS GPRS protocol (BSSGP)]
- 1512: Stage 3. GERAN BS RF requirements specs need aligned with RAN4 ongoing Rel-11 Feature UID_530037 E-UTRA medium range and MSR medium range/local area BS class requirements (medBS_class_LTE_MSR) / Impacted TSs and TRs: UTRA, LTE, GERAN
- 1513: RP#58 completed. TR 37.809 v200 for Approval / Impacted TSs and TRs: 25.104, 36.104, 37.104, new TR 37.809
- 1514: RP#58 completed / Impacted TSs and TRs: 25.141, 36.141, 37.141
- 1515: GP#56 completed. GP#52 approved WID / Impacted TSs and TRs: 45.005, 51.021
- 1516: - / Impacted TSs and TRs: UTRA, LTE, GERAN
- 1517: RP#58 completed / Impacted TSs and TRs: 25.104, 25.105, 36.104, 37.104, new TR 37.812
- 1518: RP#63 completed / Impacted TSs and TRs: 25.141, 25.142, 36.141, 37.141
- 1519: Stage 2/3. Triggered by FS_EHNB_enh (UTRA, LTE TR 37.803 under AI 12.3.2). Compare also Rel-10 WI HNB_HENB_mob_enh RP-110183 / Impacted TSs and TRs: UTRA, LTE
- 1520: RP#58 completed / Impacted TSs and TRs: 25.413, 25.467, 25.469, 36.300, 36.413, 36.423
- 1521: Stage 2/3. Legacy UE Handling (X2-GW, 20% complete, moved to Rel-12 UID_580030). Triggered by FS_EHNB_enh (UTRA, LTE TR 37.803 under AI 12.3.2) / Impacted TSs and TRs: UTRA, LTE
- 1522: RP#58 completed Legacy UE Handling (X2-GW, 20% complete, moved to Rel-12 UID_580030). Updated WID RP-121147=>RP-121712 / Impacted TSs and TRs: 25.413, 25.467, 25.469, 25.471
- 1523: - / Impacted TSs and TRs: LTE
- 1524: RP#60 completed / Impacted TSs and TRs: 36.214, 36.300, 36.305, 36.401, 36.413, 36.455, new TS (36.111, 36.456, 36.457, 36.458, 36.459)
- 1525: RP#64 completed. TS 36.112v100 for 1-step Approval / Impacted TSs and TRs: 36.111, new TS 36.112
- 1526: - / Impacted TSs and TRs: LTE
- 1527: RP#57 completed / Impacted TSs and TRs: 25.446, 36.300, 36.304, 36.321, 36.322, 36.323, 36.331, 36.440, 36.441, 36.442, 36.443, 36.444, 36.445
- 1528: RP#63 completed / Impacted TSs and TRs: 36.508, 36.523-1, 36.523-2, 36.523-3

| ID | WBS | Task | Duration | Start | Finish | Complete | Baseline start | Baseline finish | Baseline duration | Constraint | Resources | Work | Actual work | Acronym | PCG approved | WI rapporteur name | WI rapporteur e-mail | Release | TSG approved | MCC resp | Acronym_3GU_Export | Status Report | Special Focus Doc |
| --- | --- | --- | --- | --- | --- | --- | --- | --- | --- | --- | --- | --- | --- | --- | --- | --- | --- | --- | --- | --- | --- | --- | --- |
| 1529 | 373 | **Further Enhanced Non CA-based ICIC for LTE** | 990d? | 2011-03-22 A | 2014-12-15 A | 100% | 2011-03-22 | 2014-09-12 | 922d? |  | R1; R2; R3; R4; R5 | 63064h | 63064h | eICIC_enh_LTE | PCG-26 | China Mobile | ShenXiaodong@chinamobile.com | Rel-11 | RP-51 | Patrick | eICIC_enh_LTE |  |  |
| 1530 | 373.1 | Core part: Further Enhanced Non CA-based ICIC for LTE | 456d? | 2011-03-22 A | 2012-12-07 A | 100% | 2011-03-22 | 2012-12-07 | 456d? | finish no earlier than 2012-12-07 | R1; R2; R3; R4 | 14592h | 14592h | eICIC_enh_LTE-Core | PCG-26 | China Mobile | ShenXiaodong@chinamobile.com | Rel-11 | RP-51 | Patrick | eICIC_enh_LTE-Core | RP-121986 |  |
| 1531 | 373.2 | Perf. part: Further Enhanced Non CA-based ICIC for LTE | 715d? | 2011-03-23 A | 2013-12-06 A | 100% | 2011-03-23 | 2013-12-06 | 715d? | finish no earlier than 2013-12-06 | R4 | 5720h | 5720h | eICIC_enh_LTE-Perf | PCG-26 | China Mobile | ShenXiaodong@chinamobile.com | Rel-11 | RP-51 | Issam | eICIC_enh_LTE-Perf | RP-131463 |  |
| 1532 | 373.3 | Test part: Further Enhanced Non CA-based ICIC for LTE | 394d? | 2013-06-15 A | 2014-12-15 A | 100% | 2013-06-18 | 2014-09-12 | 326d? | finish no earlier than 2014-12-15 | R5 | 3152h | 3152h | eICIC_enh_LTE-UEConTest | PCG-31 | ZTE | Carolyn Taylor (carolyn.tayl@zte.com.cn) | Rel-11 | RP-60 | Ingbert | eICIC_enh_LTE-UEConTest | RP-141131 |  |
| 1533 | 374 | **New Band LTE Downlink FDD 716-728 MHz (Band 29, Carrier Aggregation of Band 2 and Band 29 and of Band 4 and Band 29)** | 456d? | 2011-03-22 A | 2012-12-07 A | 100% | 2011-03-22 | 2012-12-07 | 456d? |  | R4 | 10880h | 10880h | LTE_DL_FDD700 | PCG-26 | AT&T | marc.grant@att.com | Rel-11 | RP-51 | Issam | LTE_DL_FDD700 |  | CA |
| 1534 | 374.1 | Core part: New Band LTE Downlink FDD 716-728 MHz (Band 29), Carrier Aggregation of Band 2 and Band 29 and of Band 4 and Band 29 | 453d? | 2011-03-22 A | 2012-12-07 A | 100% | 2011-03-22 | 2012-12-07 | 453d? | finish no earlier than 2012-12-07 | R4 | 3624h | 3624h | LTE_DL_FDD700-Core | PCG-26 | AT&T | marc.grant@att.com | Rel-11 | RP-51 | Issam | LTE_DL_FDD700-Core | RP-121604 |  |
| 1535 | 374.2 | Perf. part: New Band LTE Downlink FDD 716-728 MHz (Band 29), Carrier Aggregation of Band 2 and Band 29 and of Band 4 and Band 29 | 451d? | 2011-03-29 A | 2012-12-07 A | 100% | 2011-03-29 | 2012-12-07 | 451d? | finish no earlier than 2012-12-07 | R4 | 3608h | 3608h | LTE_DL_FDD700-Perf | PCG-26 | AT&T | marc.grant@att.com | Rel-11 | RP-51 | Issam | LTE_DL_FDD700-Perf | RP-121605 |  |
| 1536 | 375 | **LTE RAN Enhancements for Diverse Data Applications** | 657d? | 2011-03-18 A | 2013-09-06 A | 100% | 2011-03-18 | 2013-09-06 | 657d? |  | R2; R5 | 15248h | 15248h | LTE_eDDA | PCG-26 | BlackBerry | Gordon Young (gyoung@rim.com) | Rel-11 | RP-51 | Yong-Jun | LTE_eDDA |  |  |
| 1537 | 375.1 | Core part: LTE RAN Enhancements for Diverse Data Applications | 456d? | 2011-03-18 A | 2012-12-07 A | 100% | 2011-03-18 | 2012-12-07 | 456d? | finish no earlier than 2012-12-07 | R2 | 3648h | 3648h | LTE_eDDA-Core | PCG-26 | BlackBerry | Gordon Young (gyoung@rim.com) | Rel-11 | RP-51 | Yong-Jun | LTE_eDDA-Core | RP-121571 |  |
| 1538 | 375.2 | Test part: LTE RAN Enhancements for Diverse Data Applications | 136d? | 2013-03-04 A | 2013-09-06 A | 100% | 2013-03-04 | 2013-09-06 | 136d? | finish no earlier than 2013-09-06 | R5 | 1088h | 1088h | LTE_eDDA-UEConTest | PCG-30 | BlackBerry | Enikő Sokondár (esokondar@rim.com) | Rel-11 | RP-59 | Ingbert | LTE_eDDA-UEConTest | RP-130946 |  |
| 1539 | 376 | **LTE E850 - Lower Band for Region 2 (non-US), Band 27** | 516d? | 2011-03-23 A | 2013-03-01 A | 100% | 2011-03-23 | 2013-03-01 | 516d? |  | R1; R2; R4; R5 | 28496h | 28496h | LTE_e850_LB | PCG-26 | NII Holdings | bill.shvodian@nii.com | Rel-11 | RP-51 | Patrick | LTE_e850_LB |  |  |
| 1540 | 376.1 | Core part: LTE E850 - Lower Band for Region 2 (non-US), Band 27 | 328d? | 2011-06-15 A | 2012-09-07 A | 100% | 2011-06-15 | 2012-09-07 | 328d? | finish no earlier than 2012-09-07 | R1; R2; R4 | 7872h | 7872h | LTE_e850_LB-Core | PCG-26 | NII Holdings | bill.shvodian@nii.com | Rel-11 | RP-51 | Patrick | LTE_e850_LB-Core | RP-120570 |  |
| 1541 | 376.2 | Perf. part: LTE E850 - Lower Band for Region 2 (non-US), Band 27 | 326d? | 2011-03-23 A | 2012-06-15 A | 100% | 2011-03-23 | 2012-06-15 | 326d? | finish no earlier than 2012-12-07 | R4 | 2608h | 2608h | LTE_e850_LB-Perf | PCG-26 | NII Holdings | bill.shvodian@nii.com | Rel-11 | RP-51 | Issam | LTE_e850_LB-Perf | RP-120571 |  |
| 1542 | 376.3 | Test part: LTE E850 - Lower Band for Region 2 (non-US), Band 27 | 189d? | 2012-06-18 A | 2013-03-01 A | 100% | 2012-06-18 | 2013-03-01 | 189d? | finish no earlier than 2013-03-01 | R5 | 1504h | 1504h | LTE_e850_LB-UEConTest | PCG-29 | NII Holdings | bill.shvodian@nii.com | Rel-11 | RP-56 | Ingbert | LTE_e850_LB-UEConTest | RP-130045 |  |
| 1543 | 377 | **LTE for 700 MHz Digital Dividend** | 538d? | 2011-06-07 A | 2013-06-14 A | 100% | 2011-06-07 | 2013-06-14 | 538d? |  | R4; R2; R3; R5 | 28032h | 28032h | LTE_APAC700 | PCG-27 | Ericsson | olav.queseth@ericsson.com | Rel-11 | RP-52 | Issam | LTE_APAC700 |  |  |
| 1544 | 377.1 | Core part: LTE for 700 MHz Digital Dividend | 273d? | 2011-06-07 A | 2012-06-15 A | 100% | 2011-06-07 | 2012-06-15 | 273d? | finish no earlier than 2012-06-15 | R4; R2; R3 | 6552h | 6552h | LTE_APAC700-Core | PCG-27 | Ericsson | olav.queseth@ericsson.com | Rel-11 | RP-52 | Issam | LTE_APAC700-Core | RP-120572 |  |
| 1545 | 377.2 | Perf. part: LTE for 700 MHz Digital Dividend | 271d? | 2011-06-09 A | 2012-06-15 A | 100% | 2011-06-09 | 2012-06-15 | 271d? | finish no earlier than 2012-06-15 | R4 | 2168h | 2168h | LTE_APAC700-Perf | PCG-27 | Ericsson | olav.queseth@ericsson.com | Rel-11 | RP-52 | Issam | LTE_APAC700-Perf | RP-120573 |  |
| 1546 | 377.3 | Test part: LTE for 700 MHz Digital Dividend | 262d? | 2012-06-18 A | 2013-06-14 A | 100% | 2012-06-18 | 2013-06-14 | 262d? | finish no earlier than 2013-06-14 | R5 | 2096h | 2096h | LTE_APAC700-UEConTest | PCG-29 | Ericsson | fredrik.sundstrom@ericsson.com | Rel-11 | RP-56 | Ingbert | LTE_APAC700-UEConTest | RP-130467 |  |
| 1547 | 378 | **Relays for LTE (part 2)** | 930d? | 2009-12-04 A | 2013-06-14 A | 100% | 2009-12-04 | 2013-06-14 | 930d? |  | R4 | 17496.4h | 17496.4h | LTE_Relay2 | PCG-24 | Ericsson | christian.hoymann@ericsson.com | Rel-11 | RP-46 | Patrick | LTE_Relay2 |  |  |
| 1548 | 378.1 | Core part: Relays for LTE (part 2) | 333d? | 2011-06-07 A | 2012-09-07 A | 100% | 2011-06-07 | 2012-09-07 | 333d? | finish no earlier than 2012-09-07 | R4 | 2656.39h | 2656.39h | LTE_Relay2-Core | PCG-27 | Ericsson | christian.hoymann@ericsson.com | Rel-11 | RP-52 | Issam | LTE_Relay2-Core | RP-121008 |  |
| 1549 | 378.2 | Perf. part: Relays for LTE (part 2) | 925d? | 2009-12-04 A | 2013-06-14 A | 100% | 2009-12-04 | 2013-06-14 | 925d? | finish no earlier than 2013-06-14 | R4 | 7400h | 7400h | LTE_Relay2-Perf | PCG-24 | Ericsson | christian.hoymann@ericsson.com | Rel-11 | RP-46 | Issam | LTE_Relay2-Perf | RP-130487 |  |
| 1550 | 379 | **Signalling and Procedure for Interference Avoidance for in-device coexistence** | 325d? | 2011-09-19 A | 2012-12-07 A | 100% | 2011-09-19 | 2012-12-07 | 325d? |  | R2; R4 | 12976h | 12976h | SPIA_IDC_LTE | PCG-27 | China Mobile | Zhenping HU | Rel-11 | RP-53 | Yong-Jun | SPIA_IDC_LTE |  |  |
| 1551 | 379.1 | Core part: Signalling and Procedure for Interference Avoidance for in-device coexistence | 325d? | 2011-09-19 A | 2012-12-07 A | 100% | 2011-09-19 | 2012-12-07 | 325d? | finish no earlier than 2012-12-07 | R2; R4 | 5200h | 5200h | SPIA_IDC_LTE-Core | PCG-27 | China Mobile | Zhenping HU | Rel-11 | RP-53 | Yong-Jun | SPIA_IDC_LTE-Core | RP-121573 |  |
| 1552 | 379.2 | Perf. part: Signalling and Procedure for Interference Avoidance for in-device coexistence | 322d? | 2011-09-20 A | 2012-12-07 A | 100% | 2011-09-20 | 2012-12-07 | 322d? | finish no earlier than 2012-12-07 | R4 | 2576h | 2576h | SPIA_IDC_LTE-Perf | PCG-27 | China Mobile | Zhenping HU | Rel-11 | RP-53 | Issam | SPIA_IDC_LTE-Perf | RP-121574 |  |

Notes:
- 1529: - / Impacted TSs and TRs: LTE
- 1530: RP#58 completed / Impacted TSs and TRs: 36.101, 36.133, 36.201, 36.211, 36.212, 36.213, 36.214, 36.300, 36.304, 36.321, 36.331, 36.413, 36.423
- 1531: RP#62 completed / Impacted TSs and TRs: 36.101, 36.104, 36.133, 36.141
- 1532: Prev CD:Thu 11/12/14; Prev %:98% / Impacted TSs and TRs: 36.508, 36.521-1, 36.521-2, 36.521-3, 36.523-1, 36.523-2, 36.523-3
- 1533: Stage 3 / Impacted TSs and TRs: LTE
- 1534: RP#58 completed / Impacted TSs and TRs: 36.101, 36.104, 36.141, 36.307
- 1535: RP#58 completed / Impacted TSs and TRs: 36.101, 36.104, 36.133, 36.141, 36.307
- 1536: Stage 2/3 / Impacted TSs and TRs: LTE
- 1537: RP#58 completed / Impacted TSs and TRs: 36.300, 36.321, 36.331, new TR 36.822
- 1538: RP#61 completed / Impacted TSs and TRs: 36.523-1, 36.523-2, 36.523-3
- 1539: Stage 3 / Impacted TSs and TRs: LTE
- 1540: RP#56 completed / Impacted TSs and TRs: 25.101, 25.104, 25.461, 25.466, 36.101, 36.104, 36.113, 36.124, 36.307, 37.104, 37.113
- 1541: RP#56 completed / Impacted TSs and TRs: 25.123, 25.133, 25.141, 36.133, 36.141, 37.141
- 1542: RP#59 completed / Impacted TSs and TRs: 36.508, 36.521-1, 36.521-2, 36.521-3, 36.523-2, 36.523-3, 37.571-1
- 1543: Stage 3. Asian Pacific American Caucus (APAC) Asia-Pacific Telecommunity (APT) Wireless Forum / Impacted TSs and TRs: LTE
- 1544: RP#56 completed. TR 36.820 v100 for Information and Approval / Impacted TSs and TRs: 25.461, 25.466, 36.101, 36.104, 36.113, 36.124, 36.133, 36.307, 37.104, 37.113, new TR 36.820
- 1545: RP#56 completed / Impacted TSs and TRs: 36.133, 36.141, 37.141
- 1546: RP#60 completed / Impacted TSs and TRs: 36.508, 36.521-1, 36.521-2, 36.521-3, 36.523-2, 36.523-3, 37.571-1
- 1547: Continuation of Rel-10 (open RAN4 Core & Perf parts) / Impacted TSs and TRs: LTE
- 1548: RP#57 completed. TS 36.116, TR 36.826 v100 for Information & Approval. RP#52 Core part not completed in Rel-10 / Impacted TSs and TRs: 36.133, new RAN4 (36.116, 36.826)
- 1549: RP#60 completed. New TS 36.117 v100 for 1-step Approval. RP#52 transferred completely from Rel-10 UID_460213 / Impacted TSs and TRs: 36.133, new TS 36.117 (E-UTRA Relay conformance testing)
- 1550: Stage 2/3 / Impacted TSs and TRs: LTE
- 1551: RP#58 completed / Impacted TSs and TRs: 36.133, 36.300, 36.306, 36.321, 36.331
- 1552: RP#58 completed / Impacted TSs and TRs: 36.133

| ID | WBS | Task | Duration | Start | Finish | Complete | Remaining | Baseline start | Baseline finish | Baseline duration | Total slack | Constraint | Resources | Work | Actual work | Acronym | PCG approved | WI rapporteur name | Release | TSG approved | MCC resp | Acronym_3GU_Export | Status Report | Special Focus Doc |
| --- | --- | --- | --- | --- | --- | --- | --- | --- | --- | --- | --- | --- | --- | --- | --- | --- | --- | --- | --- | --- | --- | --- | --- | --- |
| 1553 | 380 | **Coordinated Multi-Point Operation for LTE** | 866d? | 2011-09-19 A | 2014-12-23 A | 100% |  | 2011-09-19 | 2014-09-12 | 791d? |  |  | R1; R2; R3; R4; R5 | 66416h | 66416h | COMP_LTE | PCG-27 | Huawei, Samsung | Rel-11 | RP-53 | Patrick | COMP_LTE |  |  |
| 1554 | 380.1 | Core part: Coordinated Multi-Point Operation for LTE – Uplink | 325d? | 2011-09-19 A | 2012-12-07 A | 100% |  | 2011-09-19 | 2012-12-07 | 325d? |  | finish no earlier than 2012-12-07 | R1; R2; R3; R4 | 10400h | 10400h | COMP_LTE_UL-Core | PCG-27 | Huawei | Rel-11 | RP-53 | Patrick | COMP_LTE_UL-Core | RP-121575 |  |
| 1555 | 380.2 | Perf. part: Coordinated Multi-Point Operation for LTE – Uplink | 321d? | 2011-09-23 A | 2012-12-07 A | 100% |  | 2011-09-23 | 2012-12-07 | 321d? |  | finish no earlier than 2012-12-07 | R4 | 2568h | 2568h | COMP_LTE_UL-Perf | PCG-27 | Huawei | Rel-11 | RP-53 | Issam | COMP_LTE_UL-Perf | RP-121576 |  |
| 1556 | 380.3 | Core part: Coordinated Multi-Point Operation for LTE – Downlink | 325d? | 2011-09-19 A | 2012-12-07 A | 100% |  | 2011-09-19 | 2012-12-07 | 325d? |  | finish no earlier than 2012-12-07 | R1; R2; R3; R4 | 10400h | 10400h | COMP_LTE_DL-Core | PCG-27 | Samsung | Rel-11 | RP-53 | Patrick | COMP_LTE_DL-Core | RP-121577 |  |
| 1557 | 380.4 | Perf. part: Coordinated Multi-Point Operation for LTE – Downlink | 582d? | 2011-09-23 A | 2013-12-06 A | 100% |  | 2011-09-23 | 2013-12-06 | 582d? |  | finish no earlier than 2013-12-06 | R4 | 4656h | 4656h | COMP_LTE_DL-Perf | PCG-27 | Samsung | Rel-11 | RP-53 | Issam | COMP_LTE_DL-Perf | RP-131465 |  |
| 1558 | 380.5 | Test part: Coordinated Multi-Point Operation for LTE | 469d? | 2013-03-15 A | 2014-12-23 A | 100% |  | 2013-03-04 | 2014-09-12 | 404d? |  | finish no earlier than 2014-12-15 | R5 | 3752h | 3752h | COMP_LTE-UEConTest | PCG-30 | Samsung | Rel-11 | RP-59 | Ingbert | COMP_LTE-UEConTest | RP-141159 |  |
| 1559 | 381 | **Enhanced downlink control channel(s) for LTE Advanced** | 732d? | 2011-12-09 A | 2014-09-12 A | 100% |  | 2011-12-09 | 2014-09-12 | 731d? |  |  | R1; R2; R4; R5 | 38272h | 38272h | LTE_enh_dl_ctrl | PCG-28 | Alcatel-Lucent | Rel-11 | RP-54 | Patrick | LTE_enh_dl_ctrl |  |  |
| 1560 | 381.1 | Core part: Enhanced downlink control channel(s) for LTE Advanced | 265d? | 2011-12-09 A | 2012-12-07 A | 100% |  | 2011-12-09 | 2012-12-07 | 265d? |  | finish no earlier than 2012-12-07 | R1; R2; R4 | 6360h | 6360h | LTE_enh_dl_ctrl-Core | PCG-28 | Alcatel-Lucent | Rel-11 | RP-54 | Patrick | LTE_enh_dl_ctrl-Core | RP-121579 |  |
| 1561 | 381.2 | Perf. part: Enhanced downlink control channel(s) for LTE Advanced | 659d? | 2011-12-16 A | 2014-06-13 A | 100% |  | 2011-12-16 | 2014-06-13 | 659d? |  | finish no earlier than 2014-06-13 | R4 | 5272h | 5272h | LTE_enh_dl_ctrl-Perf | PCG-28 | Alcatel-Lucent | Rel-11 | RP-54 | Issam | LTE_enh_dl_ctrl-Perf | RP-140651 |  |
| 1562 | 381.3 | Test part: Enhanced downlink control channel(s) for LTE Advanced | 402d? | 2013-03-04 A | 2014-09-12 A | 100% |  | 2013-03-04 | 2014-09-12 | 402d? |  | finish no earlier than 2014-09-12 | R5 | 3216h | 3216h | LTE_enh_dl_ctrl-UEConTest | PCG-30 | Huawei | Rel-11 | RP-59 | Ingbert | LTE_enh_dl_ctrl-UEConTest | RP-141256 |  |
| 1563 | 382 | **Public Safety Broadband High Power UE for Band 14 for Region 2** | 403d? | 2012-03-05 A | 2013-09-06 A | 100% |  | 2012-03-05 | 2013-09-06 | 403d? |  |  | R4; R5 | 9144h | 9144h | LTE_B14_PSBB_HPUE | PCG-28 | Motorola Solutions | Rel-11 | RP-55 | Issam | LTE_B14_PSBB_HPUE |  | Public Safety (A-A) |
| 1564 | 382.1 | Core part: Public Safety Broadband High Power UE for Band 14 for Region 2 | 201d? | 2012-03-05 A | 2012-12-07 A | 100% |  | 2012-03-05 | 2012-12-07 | 201d? |  | finish no earlier than 2012-12-07 | R4 | 1608h | 1608h | LTE_B14_PSBB_HPUE-Core | PCG-28 | Motorola Solutions | Rel-11 | RP-55 | Issam | LTE_B14_PSBB_HPUE-Core | RP-121581 | Public Safety (A-A) |
| 1565 | 382.2 | Test part: Public Safety Broadband High Power UE for Band 14 for Region 2 | 138d? | 2013-03-04 A | 2013-09-06 A | 100% |  | 2013-03-04 | 2013-09-06 | 138d? |  | finish no earlier than 2013-09-06 | R5 | 1088h | 1088h | LTE_B14_PSBB_HPUE-UEConTest | PCG-30 | Motorola Solutions | Rel-11 | RP-59 | Ingbert | LTE_B14_PSBB_HPUE-UEConTest | RP-130949 | Public Safety (A-A) |
| 1566 | 383 | **Improved Minimum Performance Requirements for E-UTRA: Interference Rejection** | 671d? | 2012-03-05 A | 2014-09-12 A | 100% |  | 2012-03-05 | 2014-09-12 | 670d? |  |  | R4; R5 | 14952h | 14952h | LTE_Interf_Rej | PCG-28 | Renesas Mobile | Rel-11 | RP-55 | Issam | LTE_Interf_Rej |  |  |
| 1567 | 383.1 | Perf. part: Improved Minimum Performance Requirements for E-UTRA: Interference Rejection | 201d? | 2012-03-05 A | 2012-12-07 A | 100% |  | 2012-03-05 | 2012-12-07 | 201d? |  | finish no earlier than 2012-12-07 | R4 | 1608h | 1608h | LTE_Interf_Rej-Perf | PCG-28 | Renesas Mobile | Rel-11 | RP-55 | Issam | LTE_Interf_Rej-Perf | RP-121582 |  |
| 1568 | 383.2 | Test part: Improved Minimum Performance Requirements for E-UTRA: Interference Rejection | 327d? | 2013-06-18 A | 2014-09-12 A | 100% |  | 2013-06-18 | 2014-09-12 | 327d? |  | finish no earlier than 2014-09-12 | R5 | 2608h | 2608h | LTE_Interf_Rej-UEConTest | PCG-31 | Broadcom | Rel-11 | RP-60 | Ingbert | LTE_Interf_Rej-UEConTest | RP-141602 |  |
| 1569 | 384 | **Additional special subframe configuration for LTE TDD** | 341d? | 2012-03-05 A | 2013-06-14 A | 100% |  | 2012-03-05 | 2013-06-14 | 341d? |  |  | R4; R2; R3; R5 | 14808h | 14808h | LTE_TDD_add_subframe | PCG-28 | China Mobile | Rel-11 | RP-55 | Issam | LTE_TDD_add_subframe |  |  |
| 1570 | 384.1 | Core part: Additional special subframe configuration for LTE TDD | 137d? | 2012-03-05 A | 2012-09-07 A | 100% |  | 2012-03-05 | 2012-09-07 | 137d? |  | finish no earlier than 2012-09-07 | R4; R2; R3 | 3288h | 3288h | LTE_TDD_add_subframe-Core | PCG-28 | China Mobile | Rel-11 | RP-55 | Issam | LTE_TDD_add_subframe-Core | RP-121019 |  |
| 1571 | 384.2 | Test part: Additional special subframe configuration for LTE TDD | 76d? | 2013-03-04 A | 2013-06-14 A | 100% |  | 2013-03-04 | 2013-06-14 | 76d? |  | finish no earlier than 2013-09-13 | R5 | 608h | 608h | LTE_TDD_add_subframe-UEConTest | PCG-30 | Huawei | Rel-11 | RP-59 | Ingbert | LTE_TDD_add_subframe-UEConTest | RP-130475 |  |
| 1572 | 385 | **Rel-11 LTE Carrier Aggregation** | 1062d? | 2010-12-10 A | 2014-12-15 | 99% | 8.37d? | 2010-12-10 | 2014-12-05 | 1054d? | 654d |  | R1; R2; R3; R4; R5 | 315760h | 263184h | LTE_CA_Rel-11 | PCG-30 |  | Rel-11 | RP-58 | Patrick | LTE_CA_Rel-11 |  | CA |
| 1573 | 385.1 | **LTE Carrier Aggregation Enhancements** | 995d? | 2011-03-15 A | 2014-12-15 | 93% | 65.41d? | 2011-03-22 | 2014-12-05 | 982d? | 654d |  | R1; R2; R3; R4; R5 | 70824h | 47768h | LTE_CA_enh | PCG-26 | Nokia | Rel-11 | RP-51 | Patrick | LTE_CA_enh |  | CA |
| 1574 | 385.1.1 | Core part: LTE Carrier Aggregation Enhancements | 646.25d? | 2011-03-22 A | 2013-08-27 | 80% | 129.25d? | 2011-03-22 | 2013-03-01 | 517d? | 997.75d | finish no earlier than 2013-03-01 | R1; R2; R4; R3 | 20680h | 16544h | LTE_CA_enh-Core | PCG-26 | Nokia | Rel-11 | RP-51 | Patrick | LTE_CA_enh-Core | RP-130059 | CA |
| 1575 | 385.1.2 | Perf. part: LTE Carrier Aggregation Enhancements | 994d? | 2011-03-15 A | 2014-12-15 A | 100% |  | 2011-03-29 | 2014-12-05 | 977d? |  | finish no earlier than 2014-12-15 | R4 | 7936h | 7936h | LTE_CA_enh-Perf | PCG-26 | Nokia | Rel-11 | RP-51 | Issam | LTE_CA_enh-Perf | RP-141377 | CA |
| 1576 | 385.1.3 | Test part: LTE Carrier Aggregation Enhancements | 326d? | 2013-06-18 A | 2014-09-12 A | 100% |  | 2013-06-18 | 2014-09-12 | 326d? |  | finish no earlier than 2014-09-12 | R5 | 2608h | 2608h | LTE_CA_enh-UEConTest | PCG-31 | Microsoft | Rel-11 | RP-60 | Ingbert | LTE_CA_enh-UEConTest | RP-141443 | CA |
| 1577 | 385.2 | UE Conformance Test Aspects – LTE Advanced Carrier Aggregation of Intra-band contiguous and Inter-band configurations | 329d? | 2012-09-11 A | 2013-12-06 A | 100% |  | 2012-09-11 | 2013-12-06 | 329d? |  | finish no earlier than 2013-12-06 | R5 | 2624h | 2624h | LTE_CA_intraC_inter_UEConTest | PCG-29 | Nokia | Rel-11 | RP-57 | Ingbert | LTE_CA_intraC_inter_UEConTest | RP-131446 | CA |

Notes:
- 1553: Stage 3. Triggered by Rel-11 TR 36.819 Study on Coordinated Multi-Point Operation for LTE (FS_CoMP_LTE) / Impacted TSs and TRs: LTE / WI rapporteur e-mail: Juho Lee (juho95.lee@samsung.com), david.mazzarese@huawei.com
- 1554: RP#58 completed / Impacted TSs and TRs: 36.101, 36.104, 36.133, 36.201, 36.211, 36.212, 36.213, 36.214, 36.300, 36.306, 36.321, 36.331, 36.423 / WI rapporteur e-mail: david.mazzarese@huawei.com
- 1555: RP#58 completed / Impacted TSs and TRs: 36.101, 36.104, 36.133, 36.141 / WI rapporteur e-mail: Xinwei Zhi (zhixinwei@huawei.com)
- 1556: RP#58 completed / Impacted TSs and TRs: 36.101, 36.104, 36.133, 36.201, 36.211, 36.212, 36.213, 36.214, 36.300, 36.306, 36.321, 36.331, 36.423 / WI rapporteur e-mail: Juho Lee (juho95.lee@samsung.com)
- 1557: RP#62 completed / Impacted TSs and TRs: 36.101, 36.104, 36.133, 36.141, 36.307 / WI rapporteur e-mail: xutao.zhou@samsung.com
- 1558: Prev CD:Thu 11/12/14; Prev %:85% / Impacted TSs and TRs: 36.508, 36.521-1, 36.521-2, 36.523-1, 36.523-2, 36.523-3 / WI rapporteur e-mail: Stoyan.Baev@partner.samsung.com
- 1559: Stage 3. RP#58 Core completed. Triggered by UID_510037 Rel-11 TR 36.871 Study on further Downlink MIMO enhancements for LTE-Advanced (FS_LTE_eDL_MIMO_enh) / Impacted TSs and TRs: LTE / WI rapporteur e-mail: sigen.ye@alcatel-lucent.com
- 1560: RP#58 completed / Impacted TSs and TRs: 36.101, 36.211, 36.212, 36.213, 36.331 / WI rapporteur e-mail: sigen.ye@alcatel-lucent.com
- 1561: RP#64 completed / Impacted TSs and TRs: 36.101, 36.104, 36.133, 36.141 / WI rapporteur e-mail: teck.hu@alcatel-lucent.com
- 1562: RP#65 completed / Impacted TSs and TRs: 36.508, 36.521-1, 36.521-2, 36.523-1, 36.523-2, 36.523-3 / WI rapporteur e-mail: Xu Kai (xk.xukai@huawei.com)
- 1563: Stage 3 / Impacted TSs and TRs: LTE / WI rapporteur e-mail: xiaowei.jin@motorolasolutions.com
- 1564: RP#58 completed. TR 36.837 v100 for Information and Approval / Impacted TSs and TRs: 36.101, new TR 36.837 / WI rapporteur e-mail: xiaowei.jin@motorolasolutions.com
- 1565: RP#61 completed / Impacted TSs and TRs: 36.521-1, 36.521-2 / WI rapporteur e-mail: xiaowei.jin@motorolasolutions.com
- 1566: RP#58 completed. Triggered by FS_enh_perf_UE_LTE. Adds Perf. requirements for demodulation of the already specified PDSCH with the transmission modes defined in Rel-8 to Rel-10 / Impacted TSs and TRs: LTE / WI rapporteur e-mail: Timo Roman
- 1567: RP#58 completed / Impacted TSs and TRs: 36.101 / WI rapporteur e-mail: Timo Roman
- 1568: RP#65 completed. TR 36.904 for 1-step Approval. Testing for 36.101 / Impacted TSs and TRs: 36.508, 36.521-1, 36.521-2, New TR 36.904 / WI rapporteur e-mail: jarkko.hellsten@kolumbus.fi
- 1569: Stage 3. Exists already for 1UL a WI LTE_CA_B3_B5 / Impacted TSs and TRs: LTE / WI rapporteur e-mail: Xiaodong Shen
- 1570: RP#57 completed / Impacted TSs and TRs: 36.211, 36.213, 36.331, 36.423 / WI rapporteur e-mail: Xiaodong Shen
- 1571: RP#60 completed / Impacted TSs and TRs: 36.508, 36.523-1, 36.523-2, 36.523-3 / WI rapporteur e-mail: Li Xiang (tricia.li@huawei.com)
- 1572: LTE_CA_Rel-11 / Impacted TSs and TRs: LTE
- 1573: Stage 3 / Impacted TSs and TRs: LTE / WI rapporteur e-mail: lars.e.lindh@nokia.com
- 1574: RP#59 completed. New TR 36.823 v100 for Information and Approval / Impacted TSs and TRs: 36.101, 36.104, 36.133, 36.201, 36.211, 36.212, 36.213, 36.300, 36.302, 36.306, 36.321, 36.331, 36.413, 36.423, new TR 36.823 / WI rapporteur e-mail: lars.e.lindh@nokia.com
- 1575: Prev CD:Thu 11/12/14; Prev %:98% / Impacted TSs and TRs: 36.101, 36.104, 36.133, 36.141 / WI rapporteur e-mail: lars.e.lindh@nokia.com
- 1576: SP#65 completed / Impacted TSs and TRs: 36.508, 36.521-1, 36.521-2, 36.521-3, 36.523-1, 36.523-2, 36.523-3 / WI rapporteur e-mail: jussi.kuusisto@microsoft.com
- 1577: RP#62 completed / Impacted TSs and TRs: 36.508, 36.521-1, 36.521-2, 36.521-3, 36.523-1, 36.523-2, 36.523-3, 37.571-1 / WI rapporteur e-mail: jussi.kuusisto@nokia.com

| ID | WBS | Task | Duration | Start | Finish | Complete | Baseline start | Baseline finish | Baseline duration | Constraint | Resources | Work | Actual work | PCG approved | Release | TSG approved | MCC resp | Special Focus Doc | Acronym | WI rapporteur name | WI rapporteur e-mail | Acronym_3GU_Export | Status Report |
| --- | --- | --- | --- | --- | --- | --- | --- | --- | --- | --- | --- | --- | --- | --- | --- | --- | --- | --- | --- | --- | --- | --- | --- |
| 1578 | 385.3 | **Rel-11 inter-band Carrier Aggregation** | 528d? | 2010-12-10 A | 2012-12-07 A | 100% | 2010-12-10 | 2012-12-07 | 528d? |  | R4 | 180968h | 180968h | PCG-30 | Rel-11 | RP-58 | Issam | CA |  |  |  |  |  |
| 1579 | 385.3.1 | **LTE Advanced Carrier Aggregation of Band 3 and Band 7** | 528d? | 2010-12-10 A | 2012-12-07 A | 100% | 2010-12-10 | 2012-12-07 | 528d? |  | R4 | 12040h | 12040h | PCG-25 | Rel-11 | RP-48 | Issam | CA | LTE_CA_B3_B7 | TeliaSonera | Ralf.Schuh@TeliaSonera.com | LTE_CA_B3_B7 |  |
| 1580 | 385.3.1.1 | Core part: LTE Advanced Carrier Aggregation of Band 3 and Band 7 | 456d? | 2010-12-10 A | 2012-09-07 A | 100% | 2010-12-10 | 2012-09-07 | 456d? | finish no earlier than 2012-09-07 | R4 | 3648h | 3648h | PCG-25 | Rel-11 | RP-48 | Issam | CA | LTE_CA_B3_B7-Core | TeliaSonera | Ralf.Schuh@TeliaSonera.com | LTE_CA_B3_B7-Core | RP-121022 |
| 1581 | 385.3.1.2 | Perf. part: LTE Advanced Carrier Aggregation of Band 3 and Band 7 | 523d? | 2010-12-17 A | 2012-12-07 A | 100% | 2010-12-17 | 2012-12-07 | 523d? | finish no earlier than 2012-12-07 | R4 | 4168h | 4168h | PCG-25 | Rel-11 | RP-48 | Issam | CA | LTE_CA_B3_B7-Perf | TeliaSonera | Ralf.Schuh@TeliaSonera.com | LTE_CA_B3_B7-Perf | RP-121023 |
| 1582 | 385.3.2 | **LTE Advanced Carrier Aggregation of Band 4 and Band 17** | 528d? | 2010-12-10 A | 2012-12-07 A | 100% | 2010-12-10 | 2012-12-07 | 528d? |  | R4 | 12064h | 12064h | PCG-26 | Rel-11 | RP-50 | Issam | CA | LTE_CA_B4_B17 | AT&T | marc.grant@att.com | LTE_CA_B4_B17 |  |
| 1583 | 385.3.2.1 | Core part: LTE Advanced Carrier Aggregation of Band 4 and Band 17 | 459d? | 2010-12-10 A | 2012-09-07 A | 100% | 2010-12-10 | 2012-09-07 | 459d? | finish no earlier than 2012-09-07 | R4 | 3672h | 3672h | PCG-26 | Rel-11 | RP-50 | Issam | CA | LTE_CA_B4_B17-Core | AT&T | marc.grant@att.com | LTE_CA_B4_B17-Core | RP-121024 |
| 1584 | 385.3.2.2 | Perf. part: LTE Advanced Carrier Aggregation of Band 4 and Band 17 | 521d? | 2010-12-17 A | 2012-12-07 A | 100% | 2010-12-17 | 2012-12-07 | 521d? | finish no earlier than 2012-12-07 | R4 | 4168h | 4168h | PCG-26 | Rel-11 | RP-50 | Issam | CA | LTE_CA_B4_B17-Perf | AT&T | marc.grant@att.com | LTE_CA_B4_B17-Perf | RP-121595 |
| 1585 | 385.3.3 | **LTE Advanced Carrier Aggregation of Band 4 and Band 13** | 528d? | 2010-12-10 A | 2012-12-07 A | 100% | 2010-12-10 | 2012-12-07 | 528d? |  | R4 | 12040h | 12040h | PCG-26 | Rel-11 | RP-50 | Issam | CA | LTE_CA_B4_B13 | Ericsson | christian.bergljung@ericsson.com | LTE_CA_B4_B13 |  |
| 1586 | 385.3.3.1 | Core part: LTE Advanced Carrier Aggregation of Band 4 and Band 13 | 456d? | 2010-12-10 A | 2012-09-07 A | 100% | 2010-12-10 | 2012-09-07 | 456d? | finish no earlier than 2012-09-07 | R4 | 3648h | 3648h | PCG-26 | Rel-11 | RP-50 | Issam | CA | LTE_CA_B4_B13-Core | Ericsson | christian.bergljung@ericsson.com | LTE_CA_B4_B13-Core | RP-121026 |
| 1587 | 385.3.3.2 | Perf. part: LTE Advanced Carrier Aggregation of Band 4 and Band 13 | 521d? | 2010-12-21 A | 2012-12-07 A | 100% | 2010-12-21 | 2012-12-07 | 521d? | finish no earlier than 2012-12-07 | R4 | 4168h | 4168h | PCG-26 | Rel-11 | RP-50 | Issam | CA | LTE_CA_B4_B13-Perf | Ericsson | christian.bergljung@ericsson.com | LTE_CA_B4_B13-Perf | RP-121594 |
| 1588 | 385.3.4 | **LTE Advanced Carrier Aggregation of Band 4 and Band 12** | 456d? | 2011-03-22 A | 2012-12-07 A | 100% | 2011-03-22 | 2012-12-07 | 456d? |  | R4; R2 | 18200h | 18200h | PCG-26 | Rel-11 | RP-51 | Issam | CA | LTE_CA_B4_B12 | Leap Wireless | Bill Chandler (bchandler@cricketcommunications.com) | LTE_CA_B4_B12 |  |
| 1589 | 385.3.4.1 | Core part: LTE Advanced Carrier Aggregation of Band 4 and Band 12 | 456d? | 2011-03-22 A | 2012-12-07 A | 100% | 2011-03-22 | 2012-12-07 | 456d? | finish no earlier than 2012-12-07 | R4; R2 | 7296h | 7296h | PCG-26 | Rel-11 | RP-51 | Issam | CA | LTE_CA_B4_B12-Core | Leap Wireless | Bill Chandler (bchandler@cricketcommunications.com) | LTE_CA_B4_B12-Core | RP-121592 |
| 1590 | 385.3.4.2 | Perf. part: LTE Advanced Carrier Aggregation of Band 4 and Band 12 | 451d? | 2011-03-29 A | 2012-12-07 A | 100% | 2011-03-29 | 2012-12-07 | 451d? | finish no earlier than 2012-12-07 | R4 | 3608h | 3608h | PCG-26 | Rel-11 | RP-51 | Issam | CA | LTE_CA_B4_B12-Perf | Leap Wireless | Bill Chandler (bchandler@cricketcommunications.com) | LTE_CA_B4_B12-Perf | RP-121593 |
| 1591 | 385.3.5 | **LTE Advanced Carrier Aggregation of Band 5 and Band 12** | 456d? | 2011-03-22 A | 2012-12-07 A | 100% | 2011-03-22 | 2012-12-07 | 456d? |  | R4; R2 | 18200h | 18200h | PCG-26 | Rel-11 | RP-51 | Issam | CA | LTE_CA_B5_B12 | US Cellular | sebastian.thalanany@uscellular.com | LTE_CA_B5_B12 |  |
| 1592 | 385.3.5.1 | Core part: LTE Advanced Carrier Aggregation of Band 5 and Band 12 | 456d? | 2011-03-22 A | 2012-12-07 A | 100% | 2011-03-22 | 2012-12-07 | 456d? | finish no earlier than 2012-12-07 | R4; R2 | 7296h | 7296h | PCG-26 | Rel-11 | RP-51 | Issam | CA | LTE_CA_B5_B12-Core | US Cellular | sebastian.thalanany@uscellular.com | LTE_CA_B5_B12-Core | RP-121596 |
| 1593 | 385.3.5.2 | Perf. part: LTE Advanced Carrier Aggregation of Band 5 and Band 12 | 451d? | 2011-03-25 A | 2012-12-07 A | 100% | 2011-03-25 | 2012-12-07 | 451d? | finish no earlier than 2012-12-07 | R4 | 3608h | 3608h | PCG-26 | Rel-11 | RP-51 | Issam | CA | LTE_CA_B5_B12-Perf | US Cellular | sebastian.thalanany@uscellular.com | LTE_CA_B5_B12-Perf | RP-121597 |
| 1594 | 385.3.6 | **LTE Advanced Carrier Aggregation of Band 7 and Band 20** | 389d? | 2011-03-22 A | 2012-09-07 A | 100% | 2011-03-22 | 2012-09-07 | 389d? |  | R4 | 9288h | 9288h | PCG-26 | Rel-11 | RP-51 | Issam | CA | LTE_CA_B7_B20 | Huawei | Steven Chen | LTE_CA_B7_B20 |  |
| 1595 | 385.3.6.1 | Core part: LTE Advanced Carrier Aggregation of Band 7 and Band 20 | 386d? | 2011-03-22 A | 2012-09-07 A | 100% | 2011-03-22 | 2012-09-07 | 386d? | finish no earlier than 2012-09-07 | R4 | 3088h | 3088h | PCG-26 | Rel-11 | RP-51 | Issam | CA | LTE_CA_B7_B20-Core | Huawei | Steven Chen | LTE_CA_B7_B20-Core | RP-121032 |
| 1596 | 385.3.6.2 | Perf. part: LTE Advanced Carrier Aggregation of Band 7 and Band 20 | 386d? | 2011-03-25 A | 2012-09-07 A | 100% | 2011-03-25 | 2012-09-07 | 386d? | finish no earlier than 2012-09-07 | R4 | 3088h | 3088h | PCG-26 | Rel-11 | RP-51 | Issam | CA | LTE_CA_B7_B20-Perf | Huawei | Steven Chen | LTE_CA_B7_B20-Perf | RP-121033 |
| 1597 | 385.3.7 | **LTE Advanced Carrier Aggregation of Band 2 and Band 17** | 455d? | 2011-03-23 A | 2012-12-07 A | 100% | 2011-03-23 | 2012-12-07 | 455d? |  | R4 | 10336h | 10336h | PCG-26 | Rel-11 | RP-51 | Issam | CA | LTE_CA_B2_B17 | AT&T | marc.grant@att.com | LTE_CA_B2_B17 |  |
| 1598 | 385.3.7.1 | Core part: LTE Advanced Carrier Aggregation of Band 2 and Band 17 | 386d? | 2011-03-23 A | 2012-09-07 A | 100% | 2011-03-23 | 2012-09-07 | 386d? | finish no earlier than 2012-09-07 | R4 | 3088h | 3088h | PCG-26 | Rel-11 | RP-51 | Issam | CA | LTE_CA_B2_B17-Core | AT&T | marc.grant@att.com | LTE_CA_B2_B17-Core | RP-121034 |
| 1599 | 385.3.7.2 | Perf. part: LTE Advanced Carrier Aggregation of Band 2 and Band 17 | 451d? | 2011-03-25 A | 2012-12-07 A | 100% | 2011-03-25 | 2012-12-07 | 451d? | finish no earlier than 2012-12-07 | R4 | 3608h | 3608h | PCG-26 | Rel-11 | RP-51 | Issam | CA | LTE_CA_B2_B17-Perf | AT&T | marc.grant@att.com | LTE_CA_B2_B17-Perf | RP-121585 |
| 1600 | 385.3.8 | **LTE Advanced Carrier Aggregation of Band 4 and Band 5** | 455d? | 2011-03-23 A | 2012-12-07 A | 100% | 2011-03-23 | 2012-12-07 | 455d? |  | R4 | 10856h | 10856h | PCG-26 | Rel-11 | RP-51 | Issam | CA | LTE_CA_B4_B5 | AT&T | marc.grant@att.com | LTE_CA_B4_B5 |  |
| 1601 | 385.3.8.1 | Core part: LTE Advanced Carrier Aggregation of Band 4 and Band 5 | 451d? | 2011-03-23 A | 2012-12-07 A | 100% | 2011-03-23 | 2012-12-07 | 451d? | finish no earlier than 2012-12-07 | R4 | 3608h | 3608h | PCG-26 | Rel-11 | RP-51 | Issam | CA | LTE_CA_B4_B5-Core | AT&T | marc.grant@att.com | LTE_CA_B4_B5-Core | RP-121757 |
| 1602 | 385.3.8.2 | Perf. part: LTE Advanced Carrier Aggregation of Band 4 and Band 5 | 451d? | 2011-03-25 A | 2012-12-07 A | 100% | 2011-03-25 | 2012-12-07 | 451d? | finish no earlier than 2012-12-07 | R4 | 3608h | 3608h | PCG-26 | Rel-11 | RP-51 | Issam | CA | LTE_CA_B4_B5-Perf | AT&T | marc.grant@att.com | LTE_CA_B4_B5-Perf | RP-121589 |

Notes:
- 1578: LTE_CA_Rel-11 / Impacted TSs and TRs: LTE
- 1579: RP#57 completed. In Europe Band 3,7,20 are interesting for LTE and LTE-Advanced deployment. Different CA combinations for these bands are of high priority for Region 1 / Impacted TSs and TRs: LTE
- 1580: RP#57 completed. RP#59 new generic TR 36.850v100 for Information and Approval / Impacted TSs and TRs: 36.101, 36.104, 36.307, new generic TR 36.850
- 1581: RP#57 completed / Impacted TSs and TRs: 36.133, 36.141
- 1582: Stage 3. RP#57 Core completed. RP#58 Perf completed / Impacted TSs and TRs: LTE
- 1583: RP#57 completed. RP#59 new generic TR 36.850v100 for Information and Approval / Impacted TSs and TRs: 36.101, 36.104, 36.133, 36.141, 36.307, new generic TR 36.850
- 1584: RP#58 completed / Impacted TSs and TRs: 36.101, 36.104, 36.133, 36.307
- 1585: Stage 3. RP#57 Core completed. RP#58 Perf completed / Impacted TSs and TRs: LTE
- 1586: RP#57 completed / Impacted TSs and TRs: 36.101, 36.104, 36.133, 36.307, new generic TR 36.850
- 1587: RP#58 completed / Impacted TSs and TRs: 36.101, 36.133, 36.141
- 1588: Stage 3. RP#58 completed / Impacted TSs and TRs: LTE
- 1589: RP#58 completed. RP#59 new generic TR 36.850v100 for Information and Approval / Impacted TSs and TRs: 36.101, 36.104, 36.307, new generic TR 36.850
- 1590: RP#58 completed / Impacted TSs and TRs: 36.133, 36.141
- 1591: Stage 3. RP#58 completed / Impacted TSs and TRs: LTE
- 1592: RP#58 completed. RP#59 new generic TR 36.850v100 for Information and Approval / Impacted TSs and TRs: 36.101, 36.104, 36.133, 36.141, 36.307, new generic TR 36.850
- 1593: RP#58 completed / Impacted TSs and TRs: 36.101, 36.104, 36.133, 36.307
- 1594: Stage 3. RP#57 completed / Impacted TSs and TRs: LTE
- 1595: RP#57 completed. RP#59 new generic TR 36.850v100 for Information and Approval / Impacted TSs and TRs: 36.101, 36.104, 36.307, new generic TR 36.850
- 1596: RP#57 completed / Impacted TSs and TRs: 36.133, 36.141
- 1597: Stage 3. RP#57 Core completed. RP#58 Perf completed / Impacted TSs and TRs: LTE
- 1598: RP#57 completed. RP#59 new generic TR 36.850v100 for Information and Approval / Impacted TSs and TRs: 36.101, 36.104, 36.133, 36.141, 36.307, new generic TR 36.850
- 1599: RP#58 completed / Impacted TSs and TRs: 36.101, 36.104, 36.133, 36.307
- 1600: Stage 3. RP#58 completed / Impacted TSs and TRs: LTE
- 1601: RP#58 completed. RP#59 new generic TR 36.850v100 for Information and Approval / Impacted TSs and TRs: 36.101, 36.104, 36.133, 36.141, 36.307, new generic TR 36.850
- 1602: RP#58 completed / Impacted TSs and TRs: 36.101, 36.104, 36.133, 36.307

| ID | WBS | Task | Duration | Start | Finish | Complete | Baseline start | Baseline finish | Baseline duration | Constraint | Resources | Work | Actual work | Acronym | PCG approved | WI rapporteur name | WI rapporteur e-mail | Release | TSG approved | MCC resp | Special Focus Doc | Acronym_3GU_Export | Status Report |
| --- | --- | --- | --- | --- | --- | --- | --- | --- | --- | --- | --- | --- | --- | --- | --- | --- | --- | --- | --- | --- | --- | --- | --- |
| 1603 | 385.3.9 | **LTE Advanced Carrier Aggregation of Band 5 and Band 17** | 455d? | 2011-03-23 A | 2012-12-07 A | 100% | 2011-03-23 | 2012-12-07 | 455d? |  | R4 | 10856h | 10856h | LTE_CA_B5_B17 | PCG-26 | AT&T | marc.grant@att.com | Rel-11 | RP-51 | Issam | CA | LTE_CA_B5_B17 |  |
| 1604 | 385.3.9.1 | Core part: LTE Advanced Carrier Aggregation of Band 5 and Band 17 | 451d? | 2011-03-23 A | 2012-12-07 A | 100% | 2011-03-23 | 2012-12-07 | 451d? | finish no earlier than 2012-12-07 | R4 | 3608h | 3608h | LTE_CA_B5_B17-Core | PCG-26 | AT&T | marc.grant@att.com | Rel-11 | RP-51 | Issam | CA | LTE_CA_B5_B17-Core | RP-121598 |
| 1605 | 385.3.9.2 | Perf. part: LTE Advanced Carrier Aggregation of Band 5 and Band 17 | 451d? | 2011-03-25 A | 2012-12-07 A | 100% | 2011-03-25 | 2012-12-07 | 451d? | finish no earlier than 2012-12-07 | R4 | 3608h | 3608h | LTE_CA_B5_B17-Perf | PCG-26 | AT&T | marc.grant@att.com | Rel-11 | RP-51 | Issam | CA | LTE_CA_B5_B17-Perf | RP-121599 |
| 1606 | 385.3.10 | **LTE Advanced Carrier Aggregation of Band 3 and Band 20** | 258d? | 2011-09-19 A | 2012-09-07 A | 100% | 2011-09-19 | 2012-09-07 | 258d? |  | R4 | 6168h | 6168h | LTE_CA_B3_B20 | PCG-27 | Vodafone | tim.frost@vodafone.com | Rel-11 | RP-53 | Issam | CA | LTE_CA_B3_B20 |  |
| 1607 | 385.3.10.1 | Core part: LTE Advanced Carrier Aggregation of Band 3 and Band 20 | 256d? | 2011-09-19 A | 2012-09-07 A | 100% | 2011-09-19 | 2012-09-07 | 256d? | finish no earlier than 2012-09-07 | R4 | 2048h | 2048h | LTE_CA_B3_B20-Core | PCG-27 | Vodafone | tim.frost@vodafone.com | Rel-11 | RP-53 | Issam | CA | LTE_CA_B3_B20-Core | RP-121046 |
| 1608 | 385.3.10.2 | Perf. part: LTE Advanced Carrier Aggregation of Band 3 and Band 20 | 257d? | 2011-09-20 A | 2012-09-07 A | 100% | 2011-09-20 | 2012-09-07 | 257d? | finish no earlier than 2012-09-07 | R4 | 2056h | 2056h | LTE_CA_B3_B20-Perf | PCG-27 | Vodafone | tim.frost@vodafone.com | Rel-11 | RP-53 | Issam | CA | LTE_CA_B3_B20-Perf | RP-121047 |
| 1609 | 385.3.11 | **LTE Advanced Carrier Aggregation of Band 8 and Band 20** | 325d? | 2011-09-19 A | 2012-12-07 A | 100% | 2011-09-19 | 2012-12-07 | 325d? |  | R4 | 7752h | 7752h | LTE_CA_B8_B20 | PCG-27 | Vodafone | Luis.Anaya@vodafone.com | Rel-11 | RP-53 | Issam | CA | LTE_CA_B8_B20 |  |
| 1610 | 385.3.11.1 | Core part: LTE Advanced Carrier Aggregation of Band 8 and Band 20 | 323d? | 2011-09-19 A | 2012-12-07 A | 100% | 2011-09-19 | 2012-12-07 | 323d? | finish no earlier than 2012-12-07 | R4 | 2584h | 2584h | LTE_CA_B8_B20-Core | PCG-27 | Vodafone | Luis.Anaya@vodafone.com | Rel-11 | RP-53 | Issam | CA | LTE_CA_B8_B20-Core | RP-121600 |
| 1611 | 385.3.11.2 | Perf. part: LTE Advanced Carrier Aggregation of Band 8 and Band 20 | 321d? | 2011-09-23 A | 2012-12-07 A | 100% | 2011-09-23 | 2012-12-07 | 321d? | finish no earlier than 2012-12-07 | R4 | 2568h | 2568h | LTE_CA_B8_B20-Perf | PCG-27 | Vodafone | Luis.Anaya@vodafone.com | Rel-11 | RP-53 | Issam | CA | LTE_CA_B8_B20-Perf | RP-121601 |
| 1612 | 385.3.12 | **LTE Advanced Carrier Aggregation of Band 3 and Band 5** | 258d? | 2011-09-19 A | 2012-09-07 A | 100% | 2011-09-19 | 2012-09-07 | 258d? |  | R4 | 6160h | 6160h | LTE_CA_B3_B5 | PCG-27 | SK Telecom | Haesung Park | Rel-11 | RP-53 | Issam | CA | LTE_CA_B3_B5 |  |
| 1613 | 385.3.12.1 | Core part: LTE Advanced Carrier Aggregation of Band 3 and Band 5 | 256d? | 2011-09-19 A | 2012-09-07 A | 100% | 2011-09-19 | 2012-09-07 | 256d? | finish no earlier than 2012-09-07 | R4 | 2048h | 2048h | LTE_CA_B3_B5-Core | PCG-27 | SK Telecom | Haesung Park | Rel-11 | RP-53 | Issam | CA | LTE_CA_B3_B5-Core | RP-121042 |
| 1614 | 385.3.12.2 | Perf. part: LTE Advanced Carrier Aggregation of Band 3 and Band 5 | 256d? | 2011-09-21 A | 2012-09-07 A | 100% | 2011-09-21 | 2012-09-07 | 256d? | finish no earlier than 2012-09-07 | R4 | 2048h | 2048h | LTE_CA_B3_B5-Perf | PCG-27 | SK Telecom | Haesung Park | Rel-11 | RP-53 | Issam | CA | LTE_CA_B3_B5-Perf | RP-121043 |
| 1615 | 385.3.13 | **LTE Advanced Carrier Aggregation of Band 4 and Band 7** | 325d? | 2011-09-19 A | 2012-12-07 A | 100% | 2011-09-19 | 2012-12-07 | 325d? |  | R4 | 7744h | 7744h | LTE_CA_B4_B7 | PCG-27 | Rogers Wireless | takwing.wan@rci.rogers.com | Rel-11 | RP-53 | Issam | CA | LTE_CA_B4_B7 |  |
| 1616 | 385.3.13.1 | Core part: LTE Advanced Carrier Aggregation of Band 4 and Band 7 | 322d? | 2011-09-19 A | 2012-12-07 A | 100% | 2011-09-19 | 2012-12-07 | 322d? | finish no earlier than 2012-12-07 | R4 | 2576h | 2576h | LTE_CA_B4_B7-Core | PCG-27 | Rogers Wireless | takwing.wan@rci.rogers.com | Rel-11 | RP-53 | Issam | CA | LTE_CA_B4_B7-Core | RP-121590 |
| 1617 | 385.3.13.2 | Perf. part: LTE Advanced Carrier Aggregation of Band 4 and Band 7 | 321d? | 2011-09-23 A | 2012-12-07 A | 100% | 2011-09-23 | 2012-12-07 | 321d? | finish no earlier than 2012-12-07 | R4 | 2568h | 2568h | LTE_CA_B4_B7-Perf | PCG-27 | Rogers Wireless | takwing.wan@rci.rogers.com | Rel-11 | RP-53 | Issam | CA | LTE_CA_B4_B7-Perf | RP-121591 |
| 1618 | 385.3.14 | **LTE Advanced Carrier Aggregation of Band 11 and Band 18** | 265d? | 2011-12-09 A | 2012-12-07 A | 100% | 2011-12-09 | 2012-12-07 | 265d? |  | R4; R2 | 10568h | 10568h | LTE_CA_B11_B18 | PCG-28 | KDDI | Masaaki Obara (ms-obara@kddi.com) | Rel-11 | RP-54 | Issam | CA | LTE_CA_B11_B18 |  |
| 1619 | 385.3.14.1 | Core part: LTE Advanced Carrier Aggregation of Band 11 and Band 18 | 265d? | 2011-12-09 A | 2012-12-07 A | 100% | 2011-12-09 | 2012-12-07 | 265d? | finish no earlier than 2012-12-07 | R4; R2 | 4240h | 4240h | LTE_CA_B11_B18-Core | PCG-28 | KDDI | Masaaki Obara (ms-obara@kddi.com) | Rel-11 | RP-54 | Issam | CA | LTE_CA_B11_B18-Core | RP-121602 |
| 1620 | 385.3.14.2 | Perf. part: LTE Advanced Carrier Aggregation of Band 11 and Band 18 | 261d? | 2011-12-15 A | 2012-12-07 A | 100% | 2011-12-15 | 2012-12-07 | 261d? | finish no earlier than 2012-12-07 | R4 | 2088h | 2088h | LTE_CA_B11_B18-Perf | PCG-28 | KDDI | Masaaki Obara (ms-obara@kddi.com) | Rel-11 | RP-54 | Issam | CA | LTE_CA_B11_B18-Perf | RP-121603 |
| 1621 | 385.3.15 | **LTE Advanced Carrier Aggregation of Band 1 and Band 18** | 198d? | 2011-12-09 A | 2012-09-07 A | 100% | 2011-12-09 | 2012-09-07 | 198d? |  | R4; R2 | 7904h | 7904h | LTE_CA_B1_B18 | PCG-28 | KDDI | Masaaki Obara (ms-obara@kddi.com) | Rel-11 | RP-54 | Issam | CA | LTE_CA_B1_B18 |  |
| 1622 | 385.3.15.1 | Core part: LTE Advanced Carrier Aggregation of Band 1 and Band 18 | 198d? | 2011-12-09 A | 2012-09-07 A | 100% | 2011-12-09 | 2012-09-07 | 198d? | finish no earlier than 2012-09-07 | R4; R2 | 3168h | 3168h | LTE_CA_B1_B18-Core | PCG-28 | KDDI | Masaaki Obara (ms-obara@kddi.com) | Rel-11 | RP-54 | Issam | CA | LTE_CA_B1_B18-Core | RP-121052 |
| 1623 | 385.3.15.2 | Perf. part: LTE Advanced Carrier Aggregation of Band 1 and Band 18 | 196d? | 2011-12-13 A | 2012-09-07 A | 100% | 2011-12-13 | 2012-09-07 | 196d? | finish no earlier than 2012-12-07 | R4 | 1568h | 1568h | LTE_CA_B1_B18-Perf | PCG-28 | KDDI | Masaaki Obara (ms-obara@kddi.com) | Rel-11 | RP-54 | Issam | CA | LTE_CA_B1_B18-Perf | RP-121053 |
| 1624 | 385.3.16 | **LTE Advanced Carrier Aggregation of Band 1 and Band 19** | 197d? | 2011-12-12 A | 2012-09-07 A | 100% | 2011-12-12 | 2012-09-07 | 197d? |  | R4; R2 | 6432h | 6432h | LTE_CA_B1_B19 | PCG-28 | NTT DoCoMo | Hiromasa Umeda (umedah@nttdocomo.co.jp) | Rel-11 | RP-54 | Issam | CA | LTE_CA_B1_B19 |  |
| 1625 | 385.3.16.1 | Core part: LTE Advanced Carrier Aggregation of Band 1 and Band 19 | 137d? | 2012-03-05 A | 2012-09-07 A | 100% | 2012-03-05 | 2012-09-07 | 137d? | finish no earlier than 2012-09-07 | R4; R2 | 2192h | 2192h | LTE_CA_B1_B19-Core | PCG-28 | NTT DoCoMo | Hiromasa Umeda (umedah@nttdocomo.co.jp) | Rel-11 | RP-54 | Issam | CA | LTE_CA_B1_B19-Core | RP-120552 |
| 1626 | 385.3.16.2 | Perf. part: LTE Advanced Carrier Aggregation of Band 1 and Band 19 | 136d? | 2011-12-12 A | 2012-06-15 A | 100% | 2011-12-12 | 2012-06-15 | 136d? | finish no earlier than 2012-12-07 | R4 | 1088h | 1088h | LTE_CA_B1_B19-Perf | PCG-28 | NTT DoCoMo | Hiromasa Umeda (umedah@nttdocomo.co.jp) | Rel-11 | RP-54 | Issam | CA | LTE_CA_B1_B19-Perf | RP-120553 |

Notes:
- 1603: Stage 3. RP#58 completed / Impacted TSs and TRs: LTE
- 1604: RP#58 completed. RP#59 new generic TR 36.850v100 for Information and Approval / Impacted TSs and TRs: 36.101, 36.104, 36.133, 36.141, 36.307, new generic TR 36.850
- 1605: RP#58 completed / Impacted TSs and TRs: 36.101, 36.104, 36.133, 36.141, 36.307
- 1606: Stage 3. RP#57 completed / Impacted TSs and TRs: LTE
- 1607: RP#57 completed. RP#59 new generic TR 36.850v100 for Information and Approval / Impacted TSs and TRs: 36.101, 36.104, 36.133, 36.307, new generic TR 36.850
- 1608: RP#57 completed / Impacted TSs and TRs: 36.101, 36.104, 36.133, 36.141, 36.307
- 1609: Stage 3. RP#58 completed / Impacted TSs and TRs: LTE
- 1610: RP#58 completed. RP#59 new generic TR 36.850v100 for Information and Approval / Impacted TSs and TRs: 36.101, 36.104, 36.307, new generic TR 36.850
- 1611: RP#58 completed / Impacted TSs and TRs: 36.101, 36.104, 36.133, 36.141
- 1612: Stage 3. RP#57 completed / Impacted TSs and TRs: LTE
- 1613: RP#57 completed. RP#59 new generic TR 36.850v100 for Information and Approval / Impacted TSs and TRs: 36.101, 36.104, 36.133, 36.307, new generic TR 36.850
- 1614: RP#57 completed / Impacted TSs and TRs: 36.133, 36.141
- 1615: Stage 3. RP#58 completed / Impacted TSs and TRs: LTE
- 1616: RP#58 completed. RP#59 new generic TR 36.850v100 for Information and Approval / Impacted TSs and TRs: 36.101, 36.104, 36.133, 36.141, 36.307, 37.104, new generic TR 36.850
- 1617: RP#58 completed / Impacted TSs and TRs: 36.101, 36.104, 36.133, 36.141, 36.307
- 1618: Stage 3. RP#58 completed / Impacted TSs and TRs: LTE
- 1619: RP#58 completed. RP#59 new generic TR 36.850v100 for Information and Approval / Impacted TSs and TRs: 36.101, 36.104, 36.307, new generic TR 36.850
- 1620: RP#58 completed / Impacted TSs and TRs: 36.133
- 1621: Stage 3. RP#57 completed / Impacted TSs and TRs: LTE
- 1622: RP#57 completed. RP#59 new generic TR 36.850v100 for Information and Approval / Impacted TSs and TRs: 36.101, 36.104, 36.307, new generic TR 36.850
- 1623: RP#57 completed / Impacted TSs and TRs: 36.133, 36.141
- 1624: Stage 3. RP#56 completed. Updated WID RP-111765=>RP-120866 / Impacted TSs and TRs: LTE
- 1625: RP#56 completed. RP#59 new generic TR 36.850v100 for Information and Approval / Impacted TSs and TRs: 36.101, 36.104, 36.133, 36.307, new generic TR 36.850
- 1626: RP#56 completed / Impacted TSs and TRs: 36.133, 36.141

| ID | WBS | Task | Duration | Start | Finish | Complete | Remaining | Baseline start | Baseline finish | Baseline duration | Total slack | Constraint | Resources | Work | Actual work | Acronym | PCG approved | WI rapporteur name | Release | TSG approved | MCC resp | Special Focus Doc | Acronym_3GU_Export | Status Report |
| --- | --- | --- | --- | --- | --- | --- | --- | --- | --- | --- | --- | --- | --- | --- | --- | --- | --- | --- | --- | --- | --- | --- | --- | --- |
| 1627 | 385.3.17 | **LTE Advanced Carrier Aggregation of Band 1 and Band 21** | 265d? | 2011-12-09 A | 2012-12-07 A | 100% |  | 2011-12-09 | 2012-12-07 | 265d? |  |  | R4; R2 | 9496h | 9496h | LTE_CA_B1_B21 | PCG-28 | NTT DoCoMo | Rel-11 | RP-54 | Issam | CA | LTE_CA_B1_B21 |  |
| 1628 | 385.3.17.1 | Core part: LTE Advanced Carrier Aggregation of Band 1 and Band 21 | 198d? | 2011-12-09 A | 2012-09-07 A | 100% |  | 2011-12-09 | 2012-09-07 | 198d? |  | finish no earlier than 2012-09-07 | R4; R2 | 3168h | 3168h | LTE_CA_B1_B21-Core | PCG-28 | NTT DoCoMo | Rel-11 | RP-54 | Issam | CA | LTE_CA_B1_B21-Core | RP-121054 |
| 1629 | 385.3.17.2 | Perf. part: LTE Advanced Carrier Aggregation of Band 1 and Band 21 | 263d? | 2011-12-13 A | 2012-12-07 A | 100% |  | 2011-12-13 | 2012-12-07 | 263d? |  | finish no earlier than 2012-12-07 | R4 | 2088h | 2088h | LTE_CA_B1_B21-Perf | PCG-28 | NTT DoCoMo | Rel-11 | RP-54 | Issam | CA | LTE_CA_B1_B21-Perf | RP-121055 |
| 1630 | 385.3.18 | **LTE Advanced Carrier Aggregation of Band 3 and Band 8** | 204d? | 2012-03-05 A | 2012-12-07 A | 100% |  | 2012-03-05 | 2012-12-07 | 204d? |  |  | R4 | 4864h | 4864h | LTE_CA_B3_B8 | PCG-28 | KT | Rel-11 | RP-55 | Issam | CA | LTE_CA_B3_B8 |  |
| 1631 | 385.3.18.1 | Core part: LTE Advanced Carrier Aggregation of Band 3 and Band 8 | 201d? | 2012-03-05 A | 2012-12-07 A | 100% |  | 2012-03-05 | 2012-12-07 | 201d? |  | finish no earlier than 2012-12-07 | R4 | 1608h | 1608h | LTE_CA_B3_B8-Core | PCG-28 | KT | Rel-11 | RP-55 | Issam | CA | LTE_CA_B3_B8-Core | RP-121586 |
| 1632 | 385.3.18.2 | Perf. part: LTE Advanced Carrier Aggregation of Band 3 and Band 8 | 203d? | 2012-03-06 A | 2012-12-07 A | 100% |  | 2012-03-06 | 2012-12-07 | 203d? |  | finish no earlier than 2012-12-07 | R4 | 1624h | 1624h | LTE_CA_B3_B8-Perf | PCG-28 | KT | Rel-11 | RP-55 | Issam | CA | LTE_CA_B3_B8-Perf | RP-121587 |
| 1633 | 385.4 | **Rel-11 intra-band Carrier Aggregation** | 334d? | 2011-06-07 A | 2012-09-07 A | 100% |  | 2011-06-07 | 2012-09-07 | 334d? |  |  | RP | 18864h | 18864h |  | PCG-30 |  | Rel-11 | RP-58 |  | CA |  |  |
| 1634 | 385.4.1 | **LTE Advanced Carrier Aggregation in Band 38** | 334d? | 2011-06-07 A | 2012-09-07 A | 100% |  | 2011-06-07 | 2012-09-07 | 334d? |  |  | R4 | 7976h | 7976h | LTE_CA_B38 | PCG-27 | Huawei | Rel-11 | RP-52 | Issam | CA | LTE_CA_B38 |  |
| 1635 | 385.4.1.1 | Core part: LTE Advanced Carrier Aggregation in Band 38 | 331d? | 2011-06-07 A | 2012-09-07 A | 100% |  | 2011-06-07 | 2012-09-07 | 331d? |  | finish no earlier than 2012-09-07 | R4 | 2648h | 2648h | LTE_CA_B38-Core | PCG-27 | Huawei | Rel-11 | RP-52 | Issam | CA | LTE_CA_B38-Core | RP-121060 |
| 1636 | 385.4.1.2 | Perf. part: LTE Advanced Carrier Aggregation in Band 38 | 333d? | 2011-06-08 A | 2012-09-07 A | 100% |  | 2011-06-08 | 2012-09-07 | 333d? |  | finish no earlier than 2012-09-07 | R4 | 2656h | 2656h | LTE_CA_B38-Perf | PCG-27 | Huawei | Rel-11 | RP-52 | Issam | CA | LTE_CA_B38-Perf | RP-121061 |
| 1637 | 385.4.2 | **LTE Advanced Carrier Aggregation in Band 41** | 197d? | 2011-06-07 A | 2012-03-02 A | 100% |  | 2011-06-07 | 2012-03-02 | 197d? |  |  | R4 | 4720h | 4720h | LTE_CA_B41 | PCG-27 | Clearwire | Rel-11 | RP-52 | Issam | CA | LTE_CA_B41 |  |
| 1638 | 385.4.2.1 | Core part: LTE Advanced Carrier Aggregation in Band 41 | 196d? | 2011-06-07 A | 2012-03-02 A | 100% |  | 2011-06-07 | 2012-03-02 | 196d? |  | finish no earlier than 2012-02-23 | R4 | 1568h | 1568h | LTE_CA_B41-Core | PCG-27 | Clearwire | Rel-11 | RP-52 | Issam | CA | LTE_CA_B41-Core | RP-120126 |
| 1639 | 385.4.2.2 | Perf. part: LTE Advanced Carrier Aggregation in Band 41 | 197d? | 2011-06-07 A | 2012-03-02 A | 100% |  | 2011-06-07 | 2012-03-02 | 197d? |  | finish no earlier than 2012-03-02 | R4 | 1576h | 1576h | LTE_CA_B41-Perf | PCG-27 | Clearwire | Rel-11 | RP-52 | Issam | CA | LTE_CA_B41-Perf | RP-120127 |
| 1640 | 385.4.3 | **LTE Advanced Carrier Aggregation in Band 7** | 258d? | 2011-09-19 A | 2012-09-07 A | 100% |  | 2011-09-19 | 2012-09-07 | 258d? |  |  | R4 | 6168h | 6168h | LTE_CA_B7 | PCG-27 | China Unicom | Rel-11 | RP-53 | Issam | CA | LTE_CA_B7 |  |
| 1641 | 385.4.3.1 | Core part: LTE Advanced Carrier Aggregation in Band 7 | 256d? | 2011-09-19 A | 2012-09-07 A | 100% |  | 2011-09-19 | 2012-09-07 | 256d? |  | finish no earlier than 2012-09-07 | R4 | 2048h | 2048h | LTE_CA_B7-Core | PCG-27 | China Unicom | Rel-11 | RP-53 | Issam | CA | LTE_CA_B7-Core | RP-121062 |
| 1642 | 385.4.3.2 | Perf. part: LTE Advanced Carrier Aggregation in Band 7 | 257d? | 2011-09-20 A | 2012-09-07 A | 100% |  | 2011-09-20 | 2012-09-07 | 257d? |  | finish no earlier than 2012-09-07 | R4 | 2056h | 2056h | LTE_CA_B7-Perf | PCG-27 | China Unicom | Rel-11 | RP-53 | Issam | CA | LTE_CA_B7-Perf | RP-121063 |
| 1643 | 386 | **UE Over The Air (Antenna) conformance testing methodology - Laptop mounted equipment Free Space test** | 1515d? | 2009-09-18 A | 2015-06-17 | 97% | 48.88d? | 2009-09-18 | 2014-12-05 | 1374d? | 521d |  | R4; R5 | 37344h | 22023.6h | UEAnt_FSTest | PCG-23 | CATR | Rel-11 | RP-45 | Issam |  | UEAnt_FSTest |  |
| 1644 | 386.1 | Core part: UE Over The Air (Antenna) conformance testing methodology - Laptop mounted equipment Free Space test | 583d? | 2009-09-18 A | 2011-12-09 A | 100% |  | 2009-09-18 | 2011-12-09 | 583d? |  | finish no earlier than 2011-12-09 | R4 | 4664h | 4664h | UEAnt_FSTest-Core | PCG-23 | CATR | Rel-11 | RP-45 | Issam |  | UEAnt_FSTest-Core | RP-111456 |
| 1645 | 386.2 | Test part: UE Over The Air (Antenna) conformance testing methodology - Laptop mounted equipment Free Space test | 1061d? | 2011-06-15 A | 2015-06-17 | 95% | 53.05d? | 2011-06-07 | 2014-12-05 | 926d? | 521d | finish no earlier than 2015-06-15 | R5 | 8440h | 8015.6h | UEAnt_FSTest-UEConTest | PCG-27 | ZTE | Rel-11 | RP-52 | Ingbert |  | UEAnt_FSTest-UEConTest | RP-141130 |
| 1646 | 387 | **Eight carrier HSDPA** | 589d? | 2010-09-15 A | 2012-12-07 A | 100% |  | 2010-09-15 | 2012-12-07 | 589d? |  |  | R1; R2; R3; R4 | 37768h | 37768h | 8C_HSDPA | PCG-26 | Ericsson | Rel-11 | RP-50 | Patrick |  | 8C_HSDPA |  |
| 1647 | 387.1 | Core part: Eight carrier HSDPA | 461d? | 2010-09-15 A | 2012-06-15 A | 100% |  | 2010-09-15 | 2012-06-15 | 461d? |  | finish no earlier than 2012-06-15 | R1; R2; R3; R4 | 14752h | 14752h | 8C_HSDPA-Core | PCG-26 | Ericsson | Rel-11 | RP-50 | Patrick |  | 8C_HSDPA-Core | RP-120971 |
| 1648 | 387.2 | Perf. part: Eight carrier HSDPA | 523d? | 2010-12-15 A | 2012-12-07 A | 100% |  | 2010-12-15 | 2012-12-07 | 523d? |  | finish no earlier than 2012-12-07 | R4 | 4168h | 4168h | 8C_HSDPA-Perf | PCG-26 | Ericsson | Rel-11 | RP-50 | Issam |  | 8C_HSDPA-Perf | RP-120972 |
| 1649 | 388 | **UE demodulation performance requirements under multiple-cell scenario for 1.28Mcps TDD** | 324d? | 2010-12-10 A | 2012-03-02 A | 100% |  | 2010-12-10 | 2012-03-02 | 324d? |  |  | R4; R5 | 7760h | 7760h | LCR_TDD_UE_demod_mc | PCG-26 | China Mobile | Rel-11 | RP-50 | Issam |  | LCR_TDD_UE_demod_mc |  |
| 1650 | 388.1 | Perf. part: UE demodulation performance requirements under multiple-cell scenario for 1.28Mcps TDD | 201d? | 2010-12-10 A | 2011-09-16 A | 100% |  | 2010-12-10 | 2011-09-16 | 201d? |  | finish no earlier than 2011-09-16 | R4 | 1608h | 1608h | LCR_TDD_UE_demod_mc-Perf | PCG-26 | China Mobile | Rel-11 | RP-50 | Issam |  | LCR_TDD_UE_demod_mc-Perf | RP-110996 |
| 1651 | 388.2 | Test part: UE demodulation performance requirements under multiple-cell scenario for 1.28Mcps TDD | 121d? | 2011-09-19 A | 2012-03-02 A | 100% |  | 2011-09-19 | 2012-03-02 | 121d? |  | finish no earlier than 2012-02-23 | R5 | 968h | 968h | LCR_TDD_UE_demod_mc-UEConTest | PCG-27 | China Mobile | Rel-11 | RP-53 | Ingbert |  | LCR_TDD_UE_demod_mc-UEConTest | RP-120052 |

Notes:
- 1627: Stage 3. RP#57 completed. Updated WID RP-111764=>RP-121173 / Impacted TSs and TRs: LTE / WI rapporteur e-mail: Hiromasa Umeda (umedah@nttdocomo.co.jp)
- 1628: RP#57 completed. RP#59 new generic TR 36.850v100 for Information and Approval / Impacted TSs and TRs: 36.101, 36.104, 36.133, 36.307, new generic TR 36.850 / WI rapporteur e-mail: Hiromasa Umeda (umedah@nttdocomo.co.jp)
- 1629: RP#57 completed / Impacted TSs and TRs: 36.133, 36.141 / WI rapporteur e-mail: Hiromasa Umeda (umedah@nttdocomo.co.jp)
- 1630: Stage 3. RP#58 completed / Impacted TSs and TRs: LTE / WI rapporteur e-mail: Chungwoo HWANG (cwhwang@kt.com)
- 1631: RP#58 completed. RP#59 new generic TR 36.850v100 for Information and Approval / Impacted TSs and TRs: 36.101, 36.104, 36.133, 36.307, new generic TR 36.850 / WI rapporteur e-mail: Chungwoo HWANG (cwhwang@kt.com)
- 1632: RP#58 completed / Impacted TSs and TRs: 36.133, 36.141 / WI rapporteur e-mail: Chungwoo HWANG (cwhwang@kt.com)
- 1633: LTE_CA_Rel-11 / Impacted TSs and TRs: LTE
- 1634: Stage 3. RP#57 completed. WI only covers intra-band contiguous and not non-contiguous aspects / Impacted TSs and TRs: LTE / WI rapporteur e-mail: ronnie.zhang@huawei.com
- 1635: RP#57 completed. TR 36.830 v100 for Information & Approval / Impacted TSs and TRs: 36.101, 36.104, 36.133, 36.141, 36.307, 37.104, 37.141, new TR 36.833-1-38 [instead of 36.830] / WI rapporteur e-mail: ronnie.zhang@huawei.com
- 1636: RP#57 completed / Impacted TSs and TRs: 36.101, 36.104, 36.133, 36.141, 36.307, 37.104, 37.141 / WI rapporteur e-mail: ronnie.zhang@huawei.com
- 1637: RP#55 completed. WI only covers intra-band contiguous and not non-contiguous aspects. / Impacted TSs and TRs: LTE / WI rapporteur e-mail: michael.hart@clearwire.com
- 1638: RP#55 completed. Updated WID RP-110673=>RP-120249. TR 36.827 v100 for Information + Approval / Impacted TSs and TRs: 36.101, 36.104, 36.133, 36.141, 36.307, 37.104, new TR 36.833-1-41 [instead of 36.827] / WI rapporteur e-mail: michael.hart@clearwire.com
- 1639: RP#55 completed / Impacted TSs and TRs: 36.101, 36.104, 36.133, 36.141, 36.307 / WI rapporteur e-mail: michael.hart@clearwire.com
- 1640: Stage 3. RP#57 completed. Updated WID RP-111356=>RP-121193. WI only covers intra-band contiguous and not non-contiguous aspects / Impacted TSs and TRs: LTE / WI rapporteur e-mail: Zhangchao Ma (mazc@chinaunicom.cn), Zhonghao Zhang (zhangzh306@chinaunicom.cn)
- 1641: RP#57 completed. TR 36.831 v100 for Information & Approval / Impacted TSs and TRs: 36.101, 36.104, 36.133, 36.141, 36.307, 37.104, 37.141, new TR 36.833-1-07 [instead of 36.831] / WI rapporteur e-mail: Zhangchao Ma (mazc@chinaunicom.cn), Zhonghao Zhang (zhangzh306@chinaunicom.cn)
- 1642: RP#57 completed / Impacted TSs and TRs: 36.101, 36.104, 36.133, 36.141, 36.307, 37.104, 37.141 / WI rapporteur e-mail: Zhangchao Ma (mazc@chinaunicom.cn), Zhonghao Zhang (zhangzh306@chinaunicom.cn)
- 1643: - / Impacted TSs and TRs: UTRA / WI rapporteur e-mail: Guo Lin (guolin@emcite.com)
- 1644: RP#54 completed / Impacted TSs and TRs: 25.144, 25.914, 34.114 / WI rapporteur e-mail: Guo Lin (guolin@emcite.com)
- 1645: Prev CD:Thu 11/12/14; Prev %:95% / Impacted TSs and TRs: 34.114 / WI rapporteur e-mail: carolyn.tayl@zte.com.cn
- 1646: Stage 3 / Impacted TSs and TRs: UTRA / WI rapporteur e-mail: johan.hultell@ericsson.com
- 1647: RP#57 completed / Impacted TSs and TRs: 25.101, 25.104, 25.133, 25.211, 25.212, 25.213, 25.214, 25.215, 25.308, 25.331, 25.423, 25.433, 26.306 / WI rapporteur e-mail: johan.hultell@ericsson.com
- 1648: RP#57 completed / Impacted TSs and TRs: 25.101, 25.104, 25.133, 25.141 / WI rapporteur e-mail: johan.hultell@ericsson.com
- 1649: Stage 3 / Impacted TSs and TRs: UTRA / WI rapporteur e-mail: Li Nan (linan@chinamobile.com)
- 1650: RP#53 completed. TR 25.873v100 for Approval / Impacted TSs and TRs: 25.102, new TR 25.873 / WI rapporteur e-mail: Li Nan (linan@chinamobile.com)
- 1651: RP#55 completed / Impacted TSs and TRs: 34.108, 34.122 / WI rapporteur e-mail: Ma Shuai (mashuai@chinamobile.com)

| ID | WBS | Task | Duration | Start | Finish | Complete | Remaining | Baseline start | Baseline finish | Baseline duration | Total slack | Constraint | Resources | Work | Actual work | Acronym | PCG approved | WI rapporteur name | WI rapporteur e-mail | Release | TSG approved | MCC resp | Acronym_3GU_Export | Status Report |
| --- | --- | --- | --- | --- | --- | --- | --- | --- | --- | --- | --- | --- | --- | --- | --- | --- | --- | --- | --- | --- | --- | --- | --- | --- |
| 1652 | 389 | **Uplink Transmit Diversity for HSPA** | 929d? | 2010-12-10 A | 2014-06-13 A | 100% |  | 2010-12-10 | 2014-06-13 | 929d? |  |  | R1; R4; R2; R3; R5 | 83568.3h | 83568.3h | HSPA_UL_TxDiv | PCG-26 | Huawei | zongjie.wang@huawei.com | Rel-11 | RP-50 | Patrick | HSPA_UL_TxDiv |  |
| 1653 | 389.1 | Core part: Uplink Transmit Diversity for HSPA - Closed Loop | 528d? | 2010-12-10 A | 2012-12-07 A | 100% |  | 2010-12-10 | 2012-12-07 | 528d? |  | finish no earlier than 2012-12-07 | R1; R4; R2; R3 | 16896h | 16896h | HSPA_UL_TxDiv-CL-Core | PCG-26 | Huawei | zongjie.wang@huawei.com | Rel-11 | RP-50 | Patrick | HSPA_UL_TxDiv-CL-Core | RP-121542 |
| 1654 | 389.2 | Perf. part: Uplink Transmit Diversity for HSPA - Closed Loop | 721d? | 2010-12-14 A | 2013-09-06 A | 100% |  | 2010-12-14 | 2013-09-06 | 721d? |  | finish no earlier than 2013-09-06 | R4 | 5760.31h | 5760.31h | HSPA_UL_TxDiv-CL-Perf | PCG-26 | Huawei | zongjie.wang@huawei.com | Rel-11 | RP-50 | Issam | HSPA_UL_TxDiv-CL-Perf | RP-130477 |
| 1655 | 389.3 | Core part: Uplink Transmit Diversity for HSPA - Open Loop | 528d? | 2010-12-10 A | 2012-12-07 A | 100% |  | 2010-12-10 | 2012-12-07 | 528d? |  | finish no earlier than 2012-12-07 | R4; R1; R2; R3 | 16896h | 16896h | HSPA_UL_TxDiv-OL-Core | PCG-26 | Huawei | zongjie.wang@huawei.com | Rel-11 | RP-50 | Patrick | HSPA_UL_TxDiv-OL-Core | RP-121544 |
| 1656 | 389.4 | Perf. part: Uplink Transmit Diversity for HSPA - Open Loop | 521d? | 2010-12-14 A | 2012-12-07 A | 100% |  | 2010-12-14 | 2012-12-07 | 521d? |  | finish no earlier than 2012-12-07 | R4 | 4168h | 4168h | HSPA_UL_TxDiv-OL-Perf | PCG-26 | Huawei | zongjie.wang@huawei.com | Rel-11 | RP-50 | Issam | HSPA_UL_TxDiv-OL-Perf | RP-121545 |
| 1657 | 389.5 | Test part: Uplink Transmit Diversity for HSPA | 336d? | 2013-03-04 A | 2014-06-13 A | 100% |  | 2013-03-04 | 2014-06-13 | 336d? |  | finish no earlier than 2014-06-13 | R5 | 2688h | 2688h | HSPA_UL_TxDiv-UEConTest | PCG-30 | Qualcomm | Shubhang Vora (svora@qti.qualcomm.com) | Rel-11 | RP-59 | Ingbert | HSPA_UL_TxDiv-UEConTest | RP-140767 |
| 1658 | 390 | **Introduction of New Configuration for 4C-HSDPA** | 328d? | 2011-03-22 A | 2012-06-15 A | 100% |  | 2011-03-22 | 2012-06-15 | 328d? |  |  | R4; R2 | 10928h | 10928h | 4C_HSDPA_Config | PCG-26 | Telus Communications | jorge.delrio@telus.com | Rel-11 | RP-51 | Issam | 4C_HSDPA_Config |  |
| 1659 | 390.1 | Core part: Introduction of New Configuration for 4C-HSDPA | 192d? | 2011-03-22 A | 2011-12-09 A | 100% |  | 2011-03-22 | 2011-12-09 | 192d? |  | finish no earlier than 2011-12-09 | R4; R2 | 3072h | 3072h | 4C_HSDPA_Config-Core | PCG-26 | Telus Communications | jorge.delrio@telus.com | Rel-11 | RP-51 | Issam | 4C_HSDPA_Config-Core | RP-111463 |
| 1660 | 390.2 | Perf. part: Introduction of New Configuration for 4C-HSDPA | 326d? | 2011-03-24 A | 2012-06-15 A | 100% |  | 2011-03-24 | 2012-06-15 | 326d? |  | finish no earlier than 2012-06-15 | R4 | 2608h | 2608h | 4C_HSDPA_Config-Perf | PCG-26 | Telus Communications | jorge.delrio@telus.com | Rel-11 | RP-51 | Issam | 4C_HSDPA_Config-Perf | RP-120475 |
| 1661 | 391 | **Non-contiguous 4C-HSDPA operation** | 516d? | 2011-03-23 A | 2013-03-01 A | 100% |  | 2011-03-23 | 2013-03-01 | 516d? |  |  | R4; R2; R3 | 24360h | 24360h | NC_4C_HSDPA | PCG-26 | Ericsson | muhammad.kazmi@ericsson.com | Rel-11 | RP-51 | Issam | NC_4C_HSDPA |  |
| 1662 | 391.1 | Core part: Non-contiguous 4C-HSDPA operation | 328d? | 2011-06-15 A | 2012-09-07 A | 100% |  | 2011-06-15 | 2012-09-07 | 328d? |  | finish no earlier than 2012-09-07 | R4; R2; R3 | 7872h | 7872h | NC_4C_HSDPA-Core | PCG-26 | Ericsson | muhammad.kazmi@ericsson.com | Rel-11 | RP-51 | Issam | NC_4C_HSDPA-Core | RP-120842 |
| 1663 | 391.2 | Perf. part: Non-contiguous 4C-HSDPA operation | 513d? | 2011-03-23 A | 2013-03-01 A | 100% |  | 2011-03-23 | 2013-03-01 | 513d? |  | finish no earlier than 2013-03-01 | R4 | 4104h | 4104h | NC_4C_HSDPA-Perf | PCG-26 | Ericsson | muhammad.kazmi@ericsson.com | Rel-11 | RP-51 | Issam | NC_4C_HSDPA-Perf | RP-130049 |
| 1664 | 392 | **Further Enhancements to CELL_FACH** | 1057d? | 2011-03-18 A | 2015-03-15 | 98% | 23.67d? | 2011-03-18 | 2014-09-12 | 924d? | 589d |  | R1; R2; R3; R4; R5 | 66320h | 42067.5h | Cell_FACH_enh | PCG-26 | Qualcomm | Ravi Agarwal | Rel-11 | RP-51 | Patrick | Cell_FACH_enh |  |
| 1665 | 392.1 | Core part: Further Enhancements to CELL_FACH | 458d? | 2011-03-18 A | 2012-12-07 A | 100% |  | 2011-03-18 | 2012-12-07 | 458d? |  | finish no earlier than 2012-12-07 | R2; R1; R3; R4 | 14656h | 14656h | Cell_FACH_enh-Core | PCG-26 | Qualcomm | Ravi Agarwal | Rel-11 | RP-51 | Yong-Jun | Cell_FACH_enh-Core | RP-121547 |
| 1666 | 392.2 | Perf. part: Further Enhancements to CELL_FACH | 717d? | 2011-03-24 A | 2013-12-06 A | 100% |  | 2011-03-24 | 2013-12-06 | 717d? |  | finish no earlier than 2013-12-06 | R4 | 5728h | 5728h | Cell_FACH_enh-Perf | PCG-26 | Qualcomm | Heechoon Lee (heechoon@qti.qualcomm.com) | Rel-11 | RP-51 | Issam | Cell_FACH_enh-Perf | RP-131459 |
| 1667 | 392.3 | Test part: Further Enhancements to CELL_FACH | 457d? | 2013-06-15 A | 2015-03-15 | 92% | 36.56d? | 2013-06-18 | 2014-09-12 | 327d? | 589d | finish no earlier than 2015-03-15 | R5 | 3656h | 3363.52h | Cell_FACH_enh-UEConTest | PCG-31 | Ericsson | leif.mattisson@ericsson.com | Rel-11 | RP-60 | Ingbert | Cell_FACH_enh-UEConTest | RP-141164 |
| 1668 | 393 | **HSDPA Multiflow Data Transmission** | 928d? | 2011-09-19 A | 2015-03-19 | 97% | 26.19d? | 2011-09-19 | 2014-12-05 | 851d? | 585d |  | R2; R1; R3; R4; R5 | 54328h | 29942.4h | HSDPA_MFTX | PCG-27 | Nokia Siemens Networks | Alexander Sayenko | Rel-11 | RP-53 | Yong-Jun | HSDPA_MFTX |  |
| 1669 | 393.1 | Core part: HSDPA Multiflow Data Transmission | 325d? | 2011-09-19 A | 2012-12-07 A | 100% |  | 2011-09-19 | 2012-12-07 | 325d? |  | finish no earlier than 2012-12-07 | R2; R1; R3; R4 | 10400h | 10400h | HSDPA_MFTX-Core | PCG-27 | Nokia Siemens Networks | Alexander Sayenko | Rel-11 | RP-53 | Yong-Jun | HSDPA_MFTX-Core | RP-121551 |
| 1670 | 393.2 | Perf. part: HSDPA Multiflow Data Transmission | 519d? | 2011-09-20 A | 2013-09-06 A | 100% |  | 2011-09-20 | 2013-09-06 | 519d? |  | finish no earlier than 2013-09-06 | R4 | 4152h | 4152h | HSDPA_MFTX-Perf | PCG-27 | Nokia Siemens Networks | kamil.bechta@nsn.com | Rel-11 | RP-53 | Issam | HSDPA_MFTX-Perf | RP-130959 |
| 1671 | 393.3 | Test part: HSDPA Multiflow Data Transmission | 332d? | 2013-12-15 A | 2015-03-19 | 90% | 33.2d? | 2013-12-06 | 2014-12-05 | 262d? | 585d | finish no earlier than 2015-03-15 | R5 | 2656h | 2390.4h | HSDPA_MFTX-UEConTest | PCG-32 | Qualcomm | Shubhang Vora (svora@qti.qualcomm.com) | Rel-11 | RP-62 | Ingbert | HSDPA_MFTX-UEConTest | RP-141136 |
| 1672 | 394 | **Four Branch MIMO transmission for HSDPA** | 590d? | 2011-09-19 A | 2013-12-06 A | 100% |  | 2011-09-19 | 2013-12-06 | 590d? |  |  | R1; R2; R3; R4 | 33968h | 33968h | 4Tx_HSDPA | PCG-27 | Ericsson | johan.hultell@ericsson.com | Rel-11 | RP-53 | Patrick | 4Tx_HSDPA |  |
| 1673 | 394.1 | Core part: Four Branch MIMO transmission for HSDPA | 325d? | 2011-09-19 A | 2012-12-07 A | 100% |  | 2011-09-19 | 2012-12-07 | 325d? |  | finish no earlier than 2012-12-07 | R1; R2; R3; R4 | 10400h | 10400h | 4Tx_HSDPA-Core | PCG-27 | Ericsson | johan.hultell@ericsson.com | Rel-11 | RP-53 | Patrick | 4Tx_HSDPA-Core | RP-121549 |
| 1674 | 394.2 | Perf. part: Four Branch MIMO transmission for HSDPA | 586d? | 2011-09-21 A | 2013-12-06 A | 100% |  | 2011-09-21 | 2013-12-06 | 586d? |  | finish no earlier than 2013-12-06 | R4 | 4688h | 4688h | 4Tx_HSDPA-Perf | PCG-27 | Ericsson | johan.hultell@ericsson.com | Rel-11 | RP-53 | Issam | 4Tx_HSDPA-Perf | RP-131460 |
| 1675 | 395 | **MIMO with 64QAM for HSUPA** | 464d? | 2011-12-09 A | 2013-09-06 A | 100% |  | 2011-12-09 | 2013-09-06 | 464d? |  |  | R1; R2; R3; R4 | 26984h | 26984h | MIMO_64QAM_HSUPA | PCG-28 | Nokia Siemens Networks | Karri Ranta-aho | Rel-11 | RP-54 | Patrick | MIMO_64QAM_HSUPA |  |
| 1676 | 395.1 | Core part: MIMO with 64QAM for HSUPA | 265d? | 2011-12-09 A | 2012-12-07 A | 100% |  | 2011-12-09 | 2012-12-07 | 265d? |  | finish no earlier than 2012-12-07 | R1; R2; R3; R4 | 8480h | 8480h | MIMO_64QAM_HSUPA-Core | PCG-28 | Nokia Siemens Networks | Karri Ranta-aho | Rel-11 | RP-54 | Patrick | MIMO_64QAM_HSUPA-Core | RP-121554 |
| 1677 | 395.2 | Perf. part: MIMO with 64QAM for HSUPA | 457d? | 2011-12-13 A | 2013-09-06 A | 100% |  | 2011-12-13 | 2013-09-06 | 457d? |  | finish no earlier than 2013-09-06 | R4 | 3656h | 3656h | MIMO_64QAM_HSUPA-Perf | PCG-28 | Nokia Siemens Networks | kamil.bechta@nsn.com | Rel-11 | RP-54 | Issam | MIMO_64QAM_HSUPA-Perf | RP-130960 |

Notes:
- 1652: Stage 2/3 / Impacted TSs and TRs: UTRA
- 1653: RP#58 completed / Impacted TSs and TRs: 25.101, 25.104, 25.133, 25.211, 25.212, 25.213, 25.214, 25.215, 25.306, 25.319, 25.321, 25.331, 25.423, 25.433
- 1654: RP#61 completed / Impacted TSs and TRs: 25.101, 25.104, 25.133, 25.141
- 1655: RP#58 completed / Impacted TSs and TRs: 25.101, 25.133, 25.306, 25.319, 25.321, 25.331, 25.423, 25.433
- 1656: RP#58 completed / Impacted TSs and TRs: 25.101, 25.133
- 1657: RP#64 completed / Impacted TSs and TRs: 34.121-1, 34.121-2, 34.123-1, 34.123-2, 34.123-3
- 1658: - / Impacted TSs and TRs: UTRA
- 1659: RP#54 completed. RP#62 existing TS 25.317 replaced by new TS 25.327 / Impacted TSs and TRs: 25.101, 25.104, 25.141, 25.317 replaced by new TS 25.327
- 1660: RP#56 completed. RP#62 existing TS 25.317 replaced by new TS 25.327 / Impacted TSs and TRs: 25.101, 25.104, 25.141, 25.317 replaced by new TS 25.327
- 1661: - / Impacted TSs and TRs: UTRA
- 1662: RP#56 completed / Impacted TSs and TRs: 25.101, 25.104, 25.133, 25.331, 25.423, 25.433
- 1663: RP#59 completed / Impacted TSs and TRs: 25.101, 25.104, 25.133, 25.141
- 1664: - / Impacted TSs and TRs: UTRA
- 1665: RP#58 completed / Impacted TSs and TRs: 25.101, 25.104, 25.133, 25.211, 25.212, 25.213, 25.214, 25.306, 25.308, 25.319, 25.321, 25.331, 25.423, 25.433
- 1666: RP#62 completed / Impacted TSs and TRs: 25.101, 25.104, 25.133, 25.141
- 1667: Prev CD:Thu 11/12/14; Prev %:90% / Impacted TSs and TRs: 34.108, 34.121-1, 34.121-2, 34.123-1, 34.123-2, 34.123-3, 36.508, 36.523-1, 36.523-2, 36.523-3
- 1668: Stage 2,3 / Impacted TSs and TRs: UTRA
- 1669: RP#58 completed / Impacted TSs and TRs: 25.101, 25.104, 25.133, 25.211, 25.212, 25.214, 25.306, 25.308, 25.321, 25.331, 25.423, 25.433
- 1670: RP#61 completed / Impacted TSs and TRs: 25.101, 25.104, 25.133, 25.141
- 1671: Prev CD:Thu 11/12/14; Prev %:55% / Impacted TSs and TRs: 34.108, 34.121-1, 34.121-2, 34.123-1, 34.123-2, 34.123-3
- 1672: Stage 3 / Impacted TSs and TRs: UTRA
- 1673: RP#58 completed / Impacted TSs and TRs: 25.101, 25.104, 25.133, 25.211, 25.212, 25.213, 25.214, 25.215, 25.308, 25.331, 25.423, 25.433, 26.306
- 1674: RP#62 completed / Impacted TSs and TRs: 25.101, 25.104, 25.133, 25.141
- 1675: Specified UE and BS performance requirements for uplink MIMO together with QPSK and 16QAM modulations for E-DCH/HSUPA. 64QAM is for future releases / Impacted TSs and TRs: UTRA
- 1676: RP#58 completed / Impacted TSs and TRs: 25.101, 25.104, 25.133, 25.211, 25.212, 25.213, 25.214, 25.215, 25.308, 25.321, 25.331, 25.423, 25.433, 26.306
- 1677: RP#61 completed / Impacted TSs and TRs: 25.101, 25.104, 25.133, 25.141

| ID | WBS | Task | Type | Duration | Start | Finish | Complete | Baseline start | Baseline finish | Baseline duration | Constraint | Resources | Work | Actual work | Acronym | PCG approved | Impacted TSs and TRs | WI rapporteur name | Release | TSG approved | MCC resp | Acronym_3GU_Export | Status Report | Special Focus Doc | PCG stopped | TSG stopped |
| --- | --- | --- | --- | --- | --- | --- | --- | --- | --- | --- | --- | --- | --- | --- | --- | --- | --- | --- | --- | --- | --- | --- | --- | --- | --- | --- |
| 1678 | 396 | **HSDPA Dual-Band Multi-Carrier combinations** |  | 198d? | 2011-12-09 A | 2012-09-07 A | 100% | 2011-12-09 | 2012-09-07 | 198d? |  | R4; R2 | 7920h | 7920h | HSDPA_DB_MC | PCG-28 | UTRA | Ericsson | Rel-11 | RP-54 | Issam | HSDPA_DB_MC |  |  |  |  |
| 1679 | 396.1 | Core part: HSDPA Dual-Band Multi-Carrier combinations |  | 198d? | 2011-12-09 A | 2012-09-07 A | 100% | 2011-12-09 | 2012-09-07 | 198d? | finish no earlier than 2012-09-07 | R4; R2 | 3168h | 3168h | HSDPA_DB_MC-Core | PCG-28 | 25.101, 25.104, 25.141, 25.317 replaced by new TS 25.327 | Ericsson | Rel-11 | RP-54 | Issam | HSDPA_DB_MC-Core | RP-120987 |  |  |  |
| 1680 | 396.2 | Perf. part: HSDPA Dual-Band Multi-Carrier combinations |  | 198d? | 2011-12-09 A | 2012-09-07 A | 100% | 2011-12-09 | 2012-09-07 | 198d? | finish no earlier than 2012-09-07 | R4 | 1584h | 1584h | HSDPA_DB_MC-Perf | PCG-28 | 25.101, 25.104, 25.141 | Ericsson | Rel-11 | RP-54 | Issam | HSDPA_DB_MC-Perf | RP-120988 |  |  |  |
| 1681 | 397 | Split TTCN Test Models for IMS testing in TS 34.229-3 |  | 201d? | 2013-12-09 A | 2014-09-12 A | 100% | 2013-12-09 | 2014-09-12 | 201d? | finish no earlier than 2014-09-12 | R5 | 1608h | 1608h | IMS-CCR_Test2 | PCG-32 | 34.229-3, New TS 34.229-4 | Spirent | Rel-11 | RP-62 | Ingbert | IMS-CCR_Test2 | RP-141155 |  |  |  |
| 1682 | 398 | (Small) Technical Enhancements and Improvements for Rel-11 |  | 595d? | 2010-06-18 A | 2012-09-20 A | 100% | 2010-06-18 | 2012-09-20 | 595d? | finish no earlier than 2012-09-20 | SP; CP; RP; GP | 19040h | 19040h | TEI11 | PCG-25 |  |  | Rel-11 | SP-48 | All | TEI11 |  |  |  |  |
| 1683 | 399 | Test - (Small) Technical Enhancements and Improvements for Rel-11 |  | 397d? | 2012-06-15 A | 2013-12-11 A | 100% | 2012-06-15 | 2013-12-11 | 397d? | finish no earlier than 2013-12-11 | R5; G3new | 6352h | 6352h | TEI11_Test | PCG-29 |  |  | Rel-11 | RP-56 | Ingbert | TEI11_Test |  |  |  |  |
| 1684 | 400 | (IETF) (Small) Technical Enhancements and Improvements for Rel-11 (RFC 7077) |  | 333d? | 2012-09-07 A | 2013-12-06 A | 100% | 2012-09-07 | 2013-12-06 | 333d? | finish no earlier than 2013-11-28 | C4-IETF | 2632.95h | 2632.95h | TEI11_IETF | PCG-29 | RFC 7077 (was draft-ietf-netext-update-notifications) | Lionel Morand | Rel-11 | CP-57 | Kimmo | TEI11_IETF |  |  |  |  |
| 1685 | 401 | Release 11 Studies | milestone | 0d? | 2009-12-10 A | 2009-12-10 A | 100% | 2009-12-10 | 2012-09-14 | 727d? | finish no earlier than 2012-12-07 | SP; CP; GP; RP |  |  |  |  |  |  | Rel-11 |  | All |  |  |  |  |  |
| 1686 | 402 | Study on IMS based Peer-to-Peer Content Distribution Services |  | 284d? | 2009-05-12 A | 2010-06-10 A | 100% | 2009-05-12 | 2010-06-10 | 284d? | finish no earlier than 2010-06-10 | S1; S2 | 4544h | 4544h | FS_IMS_P2P | PCG-23 | 22.906 | China Mobile | Rel-11 | SP-45 | Alain | FS_IMS_P2P |  |  |  |  |
| 1687 | 403 | Study on Non Voice Emergency Services |  | 467d? | 2009-12-10 A | 2011-09-21 A | 100% | 2009-12-10 | 2011-09-21 | 467d? | finish no earlier than 2011-09-21 | S1 | 3720h | 3720h | FS_NOVES | PCG-24 | 22.871 | Qualcomm | Rel-11 | SP-46 | Alain | FS_NOVES |  |  |  |  |
| 1688 | 404 | Study on Support for 3GPP Voice Interworking with Enterprise IP-PBX |  | 130d? | 2010-09-23 A | 2011-03-23 A | 100% | 2010-09-23 | 2011-03-23 | 130d? | finish no earlier than 2011-02-21 | S1; S2 | 2080h | 2080h | FS_VINE | PCG-25 | 22.809 | Tatara Systems | Rel-11 | SP-48 | Alain | FS_VINE |  |  |  |  |
| 1689 | 405 | Study on IMS Network-Independent Public User Identities |  | 185d? | 2010-09-23 A | 2011-06-08 A | 100% | 2010-09-23 | 2011-06-08 | 185d? | finish no earlier than 2011-06-08 | S1 | 1480h | 1480h | FS_INIPUI | PCG-25 | 22.894 | Vodafone | Rel-11 | SP-49 | Alain | FS_INIPUI |  |  |  |  |
| 1690 | 406 | Study on IMS Evolution |  | 849d? | 2008-09-18 A | 2011-12-14 A | 100% | 2008-09-18 | 2011-12-14 | 849d? | finish no earlier than 2011-12-07 | S2 | 6784h | 6784h | FS_eIMS | PCG-21 | 23.812 | China Mobile | Rel-11 | SP-41 | Maurice | FS_eIMS |  |  |  |  |
| 1691 | 407 | Study on Policy solutions and enhancements |  | 525d? | 2000-01-03 A | 2002-01-03 A | 100% | 2000-01-03 | 2002-01-03 | 525d? |  | S2; S1 | 8400h | 8400h | FS_PP | PCG-23 | 23.813 | AT&T | Rel-11 | SP-44 | Maurice | FS_PP |  |  |  |  |
| 1692 | 408 | Study on IPv6 Migration |  | 525d? | 2009-06-04 A | 2011-06-08 A | 100% | 2009-06-04 | 2011-06-08 | 525d? | finish no earlier than 2011-06-08 | S2 | 4200h | 4200h | FS_IP6M | PCG-23 | 23.975 | China Mobile | Rel-11 | SP-44 | Maurice | FS_IP6M |  |  |  |  |
| 1693 | 409 | Study on Single Radio Voice Call Continuity from UTRAN/GERAN to E-UTRAN/HSPA |  | 528d? | 2009-12-10 A | 2011-12-14 A | 100% | 2009-12-10 | 2011-12-14 | 528d? | finish no earlier than 2011-09-21 | S2 | 4208h | 4208h | FS_rSRVCC | PCG-24 | 23.885 | Orange | Rel-11 | SP-46 | Maurice | FS_rSRVCC |  |  |  |  |
| 1694 | 410 | Study on Roaming Architecture for Voice over IMS with Local Breakout |  | 194d? | 2011-03-23 A | 2011-12-14 A | 100% | 2011-03-23 | 2011-12-14 | 194d? | finish no earlier than 2011-12-07 | S2 | 1535.79h | 1535.79h | FS_RAVEL | PCG-26 | 23.850 | Deutsche Telekom | Rel-11 | SP-51 | Maurice | FS_RAVEL |  |  |  |  |
| 1695 | 411 | Study on UTRAN key management enhancements |  | 1102d? | 2007-12-20 A | 2012-03-07 A | 100% | 2007-12-20 | 2012-03-07 | 1102d? | finish no earlier than 2012-02-20 | S3 | 8808.12h | 8808.12h | FS_UKM | PCG-21 | 33.859 | Ericsson | Rel-11 | SP-38 | Mirko | FS_UKM |  |  |  |  |
| 1696 | 412 | Study on Single Sign On (SSO) Application Security for IMS - based on SIP Digest |  | 532d? | 2010-06-10 A | 2012-06-20 A | 100% | 2010-06-10 | 2012-06-20 | 532d? | finish no earlier than 2012-06-20 | S3 | 4247.09h | 4247.09h | FS_SSO_APS | PCG-25 | 33.914 converted to 33.804 | Nokia | Rel-11 | SP-48 | Mirko | FS_SSO_APS |  |  |  |  |
| 1697 | 413 | Study on Mobile 3D Video Coding |  | 273d? | 2011-06-08 A | 2012-06-20 A | 100% | 2011-06-08 | 2012-06-20 | 273d? | finish no earlier than 2012-06-20 | S4 | 2168h | 2168h | FS_M3DVC | PCG-27 | 26.905 | Orange | Rel-11 | SP-52 | Paolo | FS_M3DVC |  |  |  |  |
| 1698 | 414 | Study on Management of Converged Networks |  | 591d? | 2010-06-10 A | 2012-09-12 A | 100% | 2010-06-10 | 2012-09-12 | 591d? | finish no earlier than 2012-09-12 | S5 | 4720h | 4720h | FS_ManCon | PCG-25 | 32.833 | Nokia Siemens Networks | Rel-11 | SP-48 | Mirko | FS_ManCon |  |  |  |  |
| 1699 | 415 | Study on User Data Convergence (UDC) information model handling and provisioning: Example Use Cases |  | 321d? | 2010-09-23 A | 2011-12-14 A | 100% | 2010-09-23 | 2011-12-14 | 321d? | finish no earlier than 2011-12-14 | S5 | 2560h | 2560h | FS_UDC_AppUseCase | PCG-25 | 32.901 | Alcatel-Lucent | Rel-11 | SP-49 | Mirko | FS_UDC_AppUseCase |  |  |  |  |
| 1700 | 416 | Study on OAM aspects of inter-RAT Energy Saving |  | 194d? | 2011-03-23 A | 2011-12-14 A | 100% | 2011-03-23 | 2011-12-14 | 194d? | start no earlier than 2011-03-23 | S5 | 1528h | 1528h | FS_OAM_ES_iRAT | PCG-26 | 32.834 | Nokia Siemens Networks | Rel-11 | SP-51 | Mirko | FS_OAM_ES_iRAT |  | SON |  |  |
| 1701 | 417 | Study on impacts on UE-Core Network signalling from Energy Saving |  | 261d? | 2010-06-04 A | 2011-06-03 A | 100% | 2010-06-04 | 2011-06-03 | 261d? | finish no earlier than 2011-06-03 | C1 | 2088h | 2088h | FS_UE-CN_ES | PCG-25 | 24.826 | NEC | Rel-11 | CP-48 | Frederic | FS_UE-CN_ES |  |  |  |  |
| 1702 | 418 | Study on EPC Nodes Restoration |  | 588d? | 2010-09-17 A | 2012-12-07 A | 100% | 2010-09-17 | 2012-12-07 | 588d? | finish no earlier than 2012-12-07 | C4 | 4664h | 4664h | FS_EPC_NR | PCG-25 | 23.857 | ZTE | Rel-11 | CP-49 | Kimmo | FS_EPC_NR |  |  |  |  |
| 1703 | 419 | Study on Signal Precoding enhancements for EGPRS2 DL |  | 394d? | 2010-09-03 A | 2012-03-02 A | 100% | 2010-09-03 | 2012-03-02 | 394d? | finish no earlier than 2012-03-02 | G1; G2 | 6304h | 6304h | FS_SPEED | PCG-25 | GERAN 45.860 | Ericsson | Rel-11 | GP-46 | Paolo | FS_SPEED |  |  |  |  |
| 1704 | 420 | Study on Coordinated Multi-Point operation for LTE |  | 203d? | 2010-12-10 A | 2011-09-16 A | 100% | 2010-12-10 | 2011-09-16 | 203d? | finish no earlier than 2011-09-16 | R1; R2; R3 | 4872h | 4872h | FS_CoMP_LTE | PCG-24 | LTE 36.819 | Samsung | Rel-11 | RP-47 | Patrick | FS_CoMP_LTE | RP-111343 |  |  |  |
| 1705 | 421 | Study on Signalling and procedure for interference avoidance for in-device coexistence |  | 338d? | 2010-06-04 A | 2011-09-16 A | 100% | 2010-06-04 | 2011-09-16 | 338d? | finish no earlier than 2011-09-16 | R2; R4 | 5408h | 5408h | FS_SPIA_IDC | PCG-25 | LTE 36.816 | China Mobile | Rel-11 | RP-48 | Yong-Jun | FS_SPIA_IDC | RP-111057 |  |  |  |
| 1706 | 422 | Study on HetNet mobility enhancements for LTE |  | 391d? | 2011-03-18 A | 2012-09-07 A | 100% | 2011-03-18 | 2012-09-07 | 391d? | finish no earlier than 2012-09-07 | R2; R1; R3; R4 | 12512h | 12512h | FS_HetNet_eMOB_LTE | PCG-26 | LTE 36.839 | Alcatel-Lucent | Rel-11 | RP-51 | Yong-Jun | FS_HetNet_eMOB_LTE | RP-121085 |  |  |  |
| 1707 | 423 | Study on further Downlink MIMO enhancements for LTE-Advanced |  | 193d? | 2011-03-18 A | 2011-12-09 A | 100% | 2011-03-18 | 2011-12-09 | 193d? | finish no earlier than 2011-12-09 | R1 | 1544h | 1544h | FS_LTE_eDL_MIMO_enh | PCG-26 | LTE 36.871 | Alcatel-Lucent | Rel-11 | RP-51 | Patrick | FS_LTE_eDL_MIMO_enh | RP-111550 |  |  |  |
| 1708 | 424 | Study on Further Enhancements to LTE TDD for DL-UL Interference Management and Traffic Adaptation |  | 328d? | 2011-03-22 A | 2012-06-15 A | 100% | 2011-03-22 | 2012-06-15 | 328d? | finish no earlier than 2012-06-15 | R1; R4 | 5248h | 5248h | FS_LTE_TDD_eIMTA | PCG-26 | LTE 36.828 | CATT | Rel-11 | RP-51 | Patrick | FS_LTE_TDD_eIMTA | RP-120587 | Small cell |  |  |
| 1709 | 425 | Study on LTE Coverage Enhancements |  | 197d? | 2011-09-19 A | 2012-06-15 A | 100% | 2011-09-19 | 2012-06-15 | 197d? | finish no earlier than 2012-06-15 | R1; R2 | 3152h | 3152h | FS_Cov_Enh_LTE | PCG-27 | LTE 36.824 | China Telecom | Rel-11 | RP-53 | Patrick | FS_Cov_Enh_LTE | RP-120589 |  |  |  |
| 1710 | 426 | Study on Enhanced performance requirement for LTE UE |  | 121d? | 2011-09-19 A | 2012-03-02 A | 100% | 2011-09-19 | 2012-03-02 | 121d? | finish no earlier than 2012-03-02 | R4; R1 | 1936h | 1936h | FS_enh_perf_UE_LTE | PCG-27 | LTE 36.829 | NTT DoCoMo | Rel-11 | RP-53 | Issam | FS_enh_perf_UE_LTE | RP-120167 |  |  |  |
| 1711 | 427 | Study on Measurements of radio performances for LTE terminals - Total Radiated Power (TRP) and Total Radiated Sensitivity (TRS) test methodology |  | 136d? | 2012-03-05 A | 2012-09-07 A | 100% | 2012-03-05 | 2012-09-07 | 136d? | finish no earlier than 2012-09-07 | R4 | 1088h | 1088h | FS_LTE_OTA | PCG-28 | LTE 25.914, New TR 37.902 | CATR | Rel-11 | RP-55 | Issam | FS_LTE_OTA | RP-121083 |  |  |  |
| 1712 | 428 | Study on Measurement of Radiated Performance for MIMO and multi-antenna reception for HSPA and LTE terminals |  | 712.8d? | 2009-03-06 A | 2012-03-02 A | 100% | 2009-03-06 | 2012-03-02 | 712.8d? | finish no earlier than 2012-03-02 | R4 | 5702.4h | 5702.4h | FS_HSPA_LTE_measRP_MIMO_multi-antenna | PCG-22 | UTRA, LTE 37.976 | Vodafone | Rel-11 | RP-43 | Issam | FS_HSPA_LTE_measRP_MIMO_multi-antenna | RP-120154 |  |  |  |
| 1713 | 429 | Study on Extending 850 MHz |  | 860d? | 2009-05-30 A | 2012-09-07 A | 100% | 2009-05-30 | 2012-09-07 | 860d? | finish no earlier than 2012-09-07 | R4 | 6880h | 6880h | FS_e850 | PCG-23 | UTRA, LTE 37.806 | Ericsson | Rel-11 | RP-44 | Issam | FS_e850 | RP-121080 |  |  |  |
| 1714 | 430 | Study on RAN improvements for Machine-Type Communications |  | 523d? | 2009-09-18 A | 2011-09-16 A | 100% | 2009-09-18 | 2011-09-16 | 523d? | finish no earlier than 2011-09-16 | R2; R1; R3; R4 | 16736h | 16736h | FS_NIMTC_RAN | PCG-23 | UTRA, LTE 37.868 | Huawei | Rel-11 | RP-45 | Yong-Jun | FS_NIMTC_RAN | RP-111052 | MTC, M2M |  |  |
| 1715 | 431 | Study on UE Application Layer Data Throughput Performance |  | 264d? | 2010-09-16 A | 2011-09-16 A | 100% | 2010-09-16 | 2011-09-16 | 264d? | finish no earlier than 2011-09-16 | R5; R4 | 4224h | 4224h | FS_UE_App_Data_Perf | PCG-26 | UTRA, LTE 37.901 | Spirent | Rel-11 | RP-50 | Ingbert | FS_UE_App_Data_Perf | RP-111543 |  |  |  |
| 1716 | 432 | Study on further enhancements for HNB and HeNB |  | 330d? | 2011-03-18 A | 2012-06-15 A | 100% | 2011-03-18 | 2012-06-15 | 330d? | finish no earlier than 2012-06-15 | R3; R2 | 5280h | 5280h | FS_EHNB_enh | PCG-26 | UTRA, LTE 37.803 | Alcatel-Lucent | Rel-11 | RP-51 | Juha | FS_EHNB_enh | RP-120579 | HNB |  |  |
| 1717 | 433 | Study on Interference analysis between 800~900 MHz bands |  | 326d? | 2011-03-23 A | 2012-06-15 A | 100% | 2011-03-23 | 2012-06-15 | 326d? | finish no earlier than 2012-06-15 | R4 | 2608h | 2608h | FS_B800_B900_Interf_LTE | PCG-26 | UTRA, LTE impacts TR 37.804 | LG Uplus | Rel-11 | RP-51 | Issam | FS_B800_B900_Interf_LTE | RP-120586 |  |  |  |
| 1718 | 434 | Study on UMTS/LTE in 900 MHz band (Japan, Korea) |  | 272d? | 2011-06-07 A | 2012-06-15 A | 100% | 2011-06-07 | 2012-06-15 | 272d? | finish no earlier than 2012-06-15 | R4 | 2176h | 2176h | FS_UTRA_LTE_900MHz | PCG-27 | UTRA, LTE 37.804 | NTT DoCoMo | Rel-11 | SP-52 | Issam | FS_UTRA_LTE_900MHz | RP-120580 |  |  |  |
| 1719 | 435 | Study on Uplink MIMO |  | 203d? | 2010-12-10 A | 2011-09-16 A | 100% | 2010-12-10 | 2011-09-16 | 203d? | finish no earlier than 2011-09-16 | R1 | 1624h | 1624h | FS_UTRA_UL_MIMO | PCG-26 | UTRA 25.871 | Qualcomm | Rel-11 | RP-50 | Patrick | FS_UTRA_UL_MIMO | RP-111048 |  |  |  |
| 1720 | 436 | Study on HSDPA Multipoint Transmission |  | 203d? | 2010-12-10 A | 2011-09-16 A | 100% | 2010-12-10 | 2011-09-16 | 203d? | finish no earlier than 2011-09-16 | R1; R2; R3 | 4872h | 4872h | FS_HSDPA_MP_TX | PCG-26 | UTRA 25.872 | Nokia Siemens Networks | Rel-11 | RP-50 | Patrick | FS_HSDPA_MP_TX | RP-111049 |  |  |  |
| 1721 | 437 | Study on UE Over The Air (OTA) test method with Head and Hand Phantoms |  | 258d? | 2011-09-19 A | 2012-09-07 A | 100% | 2011-09-19 | 2012-09-07 | 258d? | finish no earlier than 2012-09-07 | R4; R5 | 4128h | 4128h | FS_OTA_phantoms_UTRA | PCG-27 | UTRA 25.914 | Nokia | Rel-11 | RP-53 | Issam | FS_OTA_phantoms_UTRA | RP-121078 |  |  |  |
| 1722 | 438 | Study on HSPA feedback and signalling efficiency enhancements for LCR TDD |  | 199d? | 2011-12-07 A | 2012-09-07 A | 100% | 2011-12-07 | 2012-09-07 | 199d? | finish no earlier than 2012-09-07 | R1 | 1584h | 1584h | FS_LCRTDD_HSPAenh | PCG-28 | UTRA 25.874 | TD Tech | Rel-11 | RP-54 | Patrick | FS_LCRTDD_HSPAenh | RP-121079 |  |  |  |
| 1723 | 439 | Deleted - Study on Enhanced Uplink Transmission for LTE |  | 328d? | 2011-03-22 A | 2012-06-15 A | 100% | 2011-03-22 | 2012-06-15 | 328d? | finish no earlier than 2012-06-15 | R1 | 2624h | 2624h | FS_eUL_TX_LTE | PCG-26 | LTE 36.8xy | Huawei | Rel-11 | RP-51 | Patrick | FS_eUL_TX_LTE | RP-120585 |  | PCG-29 | RP-56 |
| 1724 | 440 | Release 10 Features |  | 728d? | 2008-12-11 A | 2011-09-21 A | 100% | 2008-12-11 | 2011-09-21 | 728d? | finish no earlier than 2011-09-21 | CP; GP; RP; SP | 23296h | 23296h |  |  |  |  | Rel-10 |  |  |  |  |  |  |  |

Notes:
- 1678: Stage 3 / WI rapporteur e-mail: muhammad.kazmi@ericsson.com
- 1679: RP#57 completed. RP#62 existing TS 25.317 replaced by new TS 25.327 / WI rapporteur e-mail: muhammad.kazmi@ericsson.com
- 1680: RP#57 completed / WI rapporteur e-mail: muhammad.kazmi@ericsson.com
- 1681: SP#65 completed. TS 34.229-4 for Approval. Split out of old TS 34.229-3 a new TS 34.229-4 / WI rapporteur e-mail: richard.catmur@spirent.com
- 1682: SP#50 EU-Alert is introduced under Public Warning System in parallel with the already existing ETWS and CMAS. SA1 22.268 CR#9r1 adds EU-ALERT specific requirements & CT1 23.041 CRs#
- 1683: -
- 1684: CP#62 completed / WI rapporteur e-mail: Lionel Morand
- 1685: -
- 1686: SP#48 completed / WI rapporteur e-mail: Li Gang (ligangyf@chinamobile.com)
- 1687: SP#53 completed. Spin-off Feature UID_500030 Non Voice Emergency Services (NOVES) / WI rapporteur e-mail: dwilliams@qualcomm.com
- 1688: SP#51 completed. Support Interworking between 3GPP networks and Enterprise environments to provide enterprise voice services via 3GPP mobile devices / WI rapporteur e-mail: Phillip Brown (pbrown@tatarasystems.com)
- 1689: SP#52 completed / WI rapporteur e-mail: mona.mustapha@vodafone.com
- 1690: SP#54 completed / WI rapporteur e-mail: Li Gang (ligangyf@chinamobile.com), Yu Qing (yuqing@chinamobile.com)
- 1691: SP#52 completed / WI rapporteur e-mail: farooq.bari@att.com
- 1692: SP#52 completed / WI rapporteur e-mail: Li Lianyuan (lilianyuan@chinamobile.com), Liu Hong (liuhongyfw@chinamobile.com)
- 1693: SP#54 completed. Study on "reverse direction" from UTRAN/GERAN to E-UTRAN/HSPA (Rel-8 SRVCC was in the other direction E-UTRAN/HSPA to GERAN/UTRAN) / WI rapporteur e-mail: delphin.barankanira@orange-ftgroup.com
- 1694: SP#54 completed. Linked to Rel-11 OSCAR (Optimized Service Charging and Allocation of Resources in IMS whilst Roaming) UID_490032. Related to LBO/home routing decision / WI rapporteur e-mail: michele.zarri@telekom.com
- 1695: SP#55 completed / WI rapporteur e-mail: karl.norrman@ericsson.com
- 1696: SP#56 completed. SP#55 TR 33.914v200 approved (converted 33.804). Study reuse of non-UICC credentials (in particular SIP Digest) to provide security for access to applications. Provide reference material for IMS based non-UICC based SSO to applications / WI rapporteur e-mail: Silke.Holtmanns@nokia.com
- 1697: SP#56 completed. Extends Rel-10 work on 3D video formats UID_480044 Improved Video Coding Support for PSS and MBMS / WI rapporteur e-mail: gilles.teniou@orange-ftgroup.com
- 1698: SP#57 completed. TR 32.833v200 for Approval / WI rapporteur e-mail: Jörg Schmidt (J.Schmidt@nsn.com)
- 1699: SP#54 completed / WI rapporteur e-mail: Nick Mazzarella (njmazzarella@alcatel-lucent.com)
- 1700: SP#54 completed. Triggered by Rel-10 UID_430044 TR 32.826 Study on Energy Savings Management (FS_OAM_ESM) and UID_470037 OAM aspects of Energy Saving in Radio Networks (OAM-ES) / WI rapporteur e-mail: clemens.suerbaum@nsn.com
- 1701: CP#52 completed. Linked to SA5 UID_430044 (FS_OAM-ESM) & UID_470037 (OAM-ES), RAN3 UID_470015 (FS_Energy_LTE), RAN1 UID_460016 (FS_Energy_UMTS) / WI rapporteur e-mail: gottfried.punz@nw.neclab.eu
- 1702: CP#58 completed. Continue work in Rel-11 especially to cover handling of Idle mode Signalling Reduction (ISR). Linked to SA2 UID_490036 Study on Core Network Overload solutions / WI rapporteur e-mail: lu.fei1@zte.com.cn
- 1703: GP#53 completed (03/12). GP#46 approved WID. / WI rapporteur e-mail: marten.sundberg@ericsson.com
- 1704: RP#53 completed / WI rapporteur e-mail: bruno.clerckx@samsung.com
- 1705: RP#53 completed. Studied coexistence scenario of LTE and Industrial, Scientific and Medical (ISM) Radio within the same device working in adjacent frequencies / WI rapporteur e-mail: Zhenping Hu (huzhenping@chinamobile.com)
- 1706: RP#57 completed. TR 36.839 v100 for Information & Approval / WI rapporteur e-mail: sudeep.palat@alcatel-lucent.com
- 1707: RP#54 completed / WI rapporteur e-mail: federico.boccardi@alcatel-lucent.com
- 1708: RP#56 completed. TR 36.828 for Information and Approval / WI rapporteur e-mail: Zukang Shen (shenzukang@catt.cn)
- 1709: RP#56 completed. TR 36.824 v200 for Approval / WI rapporteur e-mail: Peng Chen (chenpeng@ctbri.com.cn)
- 1710: RP#55 completed. TR 36.829 v100 for Information + Approval / WI rapporteur e-mail: Yuta Sagae
- 1711: RP#57 completed / WI rapporteur e-mail: Xudong An (anxudong@emcite.com)
- 1712: RP#55 completed. TR 37.976 v200 for Approval / WI rapporteur e-mail: Tim.frost@vodafone.com
- 1713: RP#57 completed. TR 37.806 v200 for Approval / WI rapporteur e-mail: christian.bergljung@ericsson.com
- 1714: RP#53 completed. TR 37.868v100 for Approval (No WID change: RAN overload only). Triggered by TR 22.868 Study on Facilitating Machine to Machine Communication in GSM and UMTS (M2M) UID_7027 and Rel-10 NIMTC UID_410030 / WI rapporteur e-mail: Jeff Gao (gaoyq@huawei.com)
- 1715: RP#54 completed / WI rapporteur e-mail: ron.borsato@spirent.com
- 1716: RP#56 completed. TR 37.803 v200 for Approval / WI rapporteur e-mail: Martin.Warner@alcatel-lucent.com
- 1717: RP#56 completed. Impacts TR 37.804 Study on UMTS/LTE in 900 MHz band (Japan, Korea) UID_520018 / WI rapporteur e-mail: Koo Yeon Sang (yskoo@lguplus.co.kr)
- 1718: RP#56 completed. Updated WID RP-111751=>RP-120617. TR 37.804 v100 for Information and Approval. Linked to Study on Interference analysis between 800~900 MHz bands UID_510038 / WI rapporteur e-mail: Masahiro Fujii (fujiima@nttdocomo.co.jp)
- 1719: RP#53 completed (1-step Approval) / WI rapporteur e-mail: Sharad Sambhwani
- 1720: RP#53 completed / WI rapporteur e-mail: karri.ranta-aho@nsn.com
- 1721: RP#57 completed / WI rapporteur e-mail: petri.j.vasenkari@nokia.com
- 1722: RP#57 completed. TR 25.874 v100 for Information & Approval / WI rapporteur e-mail: limei.wei@td-tech.com
- 1723: RP#56 stopped. RP-120856 discussion: most content moved to Rel-11 Coordinated Multi-Point Operation for LTE Uplink (COMP_LTE_UL) and RAN1 has no time to look at it / WI rapporteur e-mail: Yongxing Zhou
- 1724: -

| ID | WBS | Task | Duration | Start | Finish | Complete | Baseline start | Baseline finish | Baseline duration | Constraint | Resources | Work | Actual work | Acronym | PCG approved | WI rapporteur name | WI rapporteur e-mail | Release | TSG approved | MCC resp | Special Focus Doc | Acronym_3GU_Export | PCG stopped | TSG stopped | Status Report |
| --- | --- | --- | --- | --- | --- | --- | --- | --- | --- | --- | --- | --- | --- | --- | --- | --- | --- | --- | --- | --- | --- | --- | --- | --- | --- |
| 1725 | 441 | **Enhancements for Multimedia Priority Service** | 1311d? | 2006-03-13 A | 2011-03-18 A | 100% | 2006-03-13 | 2011-03-18 | 1311d? |  | S1; S2; C4; C3; C1 | 72120h | 72120h | eMPS | PCG-21 | Telcordia | jgarraha@telcordia.com | Rel-10 | SP-39 | Alain | Public Safety (I-A) | eMPS |  |  |  |
| 1726 | 441.1 | Stage 1 on enhancements for Multimedia Priority Service | 584d? | 2006-03-13 A | 2008-06-05 A | 100% | 2006-03-13 | 2008-06-05 | 584d? | start no earlier than 2006-03-12 | S1 | 4672h | 4672h | ePRIOR | PCG-21 | Telcordia | jgarraha@telcordia.com | Rel-10 | SP-39 | Alain | Public Safety (I-A) | ePRIOR |  |  |  |
| 1727 | 441.2 | **Stage 2 on enhancements for Multimedia Priority Service** | 206d? | 2009-12-10 A | 2010-09-23 A | 100% | 2009-12-10 | 2010-09-23 | 206d? |  | S2 | 6592h | 6592h | ePRIOR | PCG-24 | Telcordia, NTT DoCoMo | Vijay Varma, Katsutoshi Nishida | Rel-10 | SP-46 | Maurice | Public Safety (I-A) |  |  |  |  |
| 1728 | 441.2.1 | Stage 2 on eMPS for CSFB | 206d? | 2009-12-10 A | 2010-09-23 A | 100% | 2009-12-10 | 2010-09-23 | 206d? | finish no earlier than 2010-09-24 | S2 | 1648h | 1648h | ePRIOR | PCG-24 | Telcordia, NTT DoCoMo | Vijay Varma, Katsutoshi Nishida | Rel-10 | SP-46 | Maurice | Public Safety (I-A) |  |  |  |  |
| 1729 | 441.2.2 | Stage 2 on eMPS for EPS Bearer Service | 206d? | 2009-12-10 A | 2010-09-23 A | 100% | 2009-12-10 | 2010-09-23 | 206d? | finish no earlier than 2010-12-09 | S2 | 1648h | 1648h | ePRIOR | PCG-24 | Telcordia, NTT DoCoMo | Vijay Varma, Katsutoshi Nishida | Rel-10 | SP-46 | Maurice | Public Safety (I-A) |  |  |  |  |
| 1730 | 441.2.3 | Stage 2 on eMPS for IMS Aspects | 206d? | 2009-12-10 A | 2010-09-23 A | 100% | 2009-12-10 | 2010-09-23 | 206d? | finish no earlier than 2010-12-09 | S2 | 1648h | 1648h | ePRIOR | PCG-24 | Telcordia, NTT DoCoMo | Vijay Varma, Katsutoshi Nishida | Rel-10 | SP-46 | Maurice | Public Safety (I-A) |  |  |  |  |
| 1731 | 441.3 | Deleted - TR 23.854 on Stage 2 on enhancements for Multimedia Priority Service | 266d? | 2009-12-10 A | 2010-12-16 A | 100% | 2009-12-10 | 2010-12-16 | 266d? | finish no earlier than 2011-03-17 | S2 | 2128h | 2128h | ePRIOR | PCG-24 | Telcordia, NTT DoCoMo | Vijay Varma, Katsutoshi Nishida | Rel-10 | SP-46 | Maurice | Public Safety (I-A) |  | PCG-27 | SP-50 |  |
| 1732 | 441.4 | **Stage 3 on enhancements for Multimedia Priority Service** | 131d? | 2010-09-17 A | 2011-03-18 A | 100% | 2010-09-17 | 2011-03-18 | 131d? |  | C4; C3; C1 | 6288h | 6288h | eMPS-CN | PCG-25 | Ericsson | Philip.hodges@ericsson.com | Rel-10 | CP-49 | Kimmo | Public Safety (I-A) | eMPS-CN |  |  |  |
| 1733 | 441.4.1 | CT4 part on Stage 3 on enhancements for Multimedia Priority Service | 131d? | 2010-09-17 A | 2011-03-18 A | 100% | 2010-09-17 | 2011-03-18 | 131d? | start no earlier than 2010-09-17 | C4 | 1048h | 1048h | eMPS-CN | PCG-25 | Ericsson | Philip.hodges@ericsson.com | Rel-10 | CP-49 | Kimmo | Public Safety (I-A) |  |  |  |  |
| 1734 | 441.4.2 | CT3 part on Stage 3 on enhancements for Multimedia Priority Service | 131d? | 2010-09-17 A | 2011-03-18 A | 100% | 2010-09-17 | 2011-03-18 | 131d? | start no earlier than 2010-09-17 | C3 | 1048h | 1048h | eMPS-CN | PCG-25 | Ericsson | Philip.hodges@ericsson.com | Rel-10 | CP-49 | Adrian | Public Safety (I-A) |  |  |  |  |
| 1735 | 441.4.3 | CT1 part on Stage 3 on enhancements for Multimedia Priority Service | 131d? | 2010-09-17 A | 2011-03-18 A | 100% | 2010-09-17 | 2011-03-18 | 131d? | start no earlier than 2010-09-17 | C1 | 1048h | 1048h | eMPS-CN | PCG-25 | Ericsson | Philip.hodges@ericsson.com | Rel-10 | CP-49 | Frederic | Public Safety (I-A) |  |  |  |  |
| 1736 | 442 | **Network Improvements for Machine-Type Communications** | 1365d? | 2008-09-18 A | 2013-11-22 A | 100% | 2008-09-18 | 2013-11-22 | 1365d? |  | S1; S2; S5; C1; C4; C6; G2; R2; R3; R5; G3new | 149017h | 149017h | NIMTC | PCG-21 | KPN | toon.norp@tno.nl | Rel-10 | SP-41 | Alain | MTC, M2M | NIMTC |  |  |  |
| 1737 | 442.1 | Stage 1 for Network Improvements for Machine-Type Communications | 397d? | 2008-09-18 A | 2010-03-25 A | 100% | 2008-09-18 | 2010-03-25 | 397d? | finish no earlier than 2009-12-10 | S1 | 3176h | 3176h | NIMTC | PCG-21 | KPN | toon.norp@tno.nl | Rel-10 | SP-41 | Alain | MTC, M2M |  |  |  |  |
| 1738 | 442.2 | Deleted - TR on Stage 2 for Network Improvements for Machine-Type Communications | 321d? | 2009-09-24 A | 2010-12-16 A | 100% | 2009-09-24 | 2010-12-16 | 321d? | finish no earlier than 2010-11-30 | S2 | 2568h | 2568h | NIMTC | PCG-23 | Samsung | erik.guttman@partner.samsung.com | Rel-10 | SP-45 | Maurice | MTC, M2M |  | PCG-26 | SP-50 |  |
| 1739 | 442.3 | Stage 2 for Network Improvements for Machine-Type Communications | 19d? | 2010-08-30 A | 2010-09-23 A | 100% | 2010-08-30 | 2010-09-23 | 19d? | finish no earlier than 2010-09-17 | S2 | 152h | 152h | NIMTC | PCG-23 | Samsung | erik.guttman@partner.samsung.com | Rel-10 | SP-45 | Maurice | MTC, M2M |  |  |  |  |
| 1740 | 442.4 | Deleted - Security for Network Improvements for Machine-Type Communications | 193.15d? | 2009-12-10 A | 2010-09-23 A | 100% | 2009-12-10 | 2010-09-23 | 193.15d? | finish no earlier than 2010-09-23 | S3 | 1545.2h | 1545.2h | NIMTC | PCG-24 | Samsung | Rajavelsamy R (rajvel@samsung.com) | Rel-10 | SP-46 | Mirko | MTC, M2M |  | PCG-25 | SP-49 |  |
| 1741 | 442.5 | Charging for Network Improvements for Machine-Type Communication | 3d? | 2011-03-21 A | 2011-03-23 A | 100% | 2011-03-21 | 2011-03-23 | 3d? | start no earlier than 2011-03-21 | S5 | 24h | 24h | NIMTC-CH | PCG-26 | Ericsson | patrik.teppo@@ericsson.com | Rel-10 | SP-51 | Mirko | MTC, M2M | NIMTC-CH |  |  |  |
| 1742 | 442.6 | **CN part of Stage 3 for Network Improvements for Machine-Type Communications** | 261d? | 2010-06-04 A | 2011-06-03 A | 100% | 2010-06-04 | 2011-06-03 | 261d? |  | C1; C4; C6 | 12976h | 12976h | NIMTC-CN | PCG-25 | Ericsson | mikael.wass@ericsson.com | Rel-10 | CP-48 | Frederic | MTC, M2M | NIMTC-CN |  |  |  |
| 1743 | 442.6.1 | CT1 part of Stage 3 for Network Improvements for Machine-Type Communications | 261d? | 2010-06-04 A | 2011-06-03 A | 100% | 2010-06-04 | 2011-06-03 | 261d? | finish no earlier than 2011-06-03 | C1 | 2088h | 2088h | NIMTC-CN | PCG-25 | Ericsson | mikael.wass@ericsson.com | Rel-10 | CP-48 | Frederic | MTC, M2M |  |  |  |  |
| 1744 | 442.6.2 | Deleted - CT3 part of Stage 3 for Network Improvements for Machine-Type Communications | 261d? | 2010-06-04 A | 2011-06-03 A | 100% | 2010-06-04 | 2011-06-03 | 261d? | finish no earlier than 2010-12-10 | C3 | 2088h | 2088h | NIMTC-CN | PCG-25 | Ericsson | mikael.wass@ericsson.com | Rel-10 | CP-48 | Adrian | MTC, M2M |  | PCG-27 | CP-52 |  |
| 1745 | 442.6.3 | CT4 part of Stage 3 for Network Improvements for Machine-Type Communications | 261d? | 2010-06-04 A | 2011-06-03 A | 100% | 2010-06-04 | 2011-06-03 | 261d? | finish no earlier than 2011-03-18 | C4 | 2088h | 2088h | NIMTC-CN | PCG-25 | Ericsson | mikael.wass@ericsson.com | Rel-10 | CP-48 | Kimmo | MTC, M2M |  |  |  |  |
| 1746 | 442.6.4 | CT6 part of Stage 3 for Network Improvements for Machine-Type Communications | 56d? | 2011-03-18 A | 2011-06-03 A | 100% | 2011-03-18 | 2011-06-03 | 56d? | finish no earlier than 2011-06-03 | C6 | 448h | 448h | NIMTC-CN | PCG-26 | Sagem-Orga | heiko.kruse@sagem-orga.com | Rel-10 | CP-51 | Xavier | MTC, M2M |  |  |  |  |
| 1747 | 442.7 | GERAN part of Network Improvements for Machine-Type Communications (Stage 3) | 261d? | 2010-09-03 A | 2011-09-02 A | 100% | 2010-09-03 | 2011-09-02 | 261d? | finish no earlier than 2011-09-02 | G2 | 2088h | 2088h | NIMTC | PCG-25 | Vodafone, Ericsson | leo.patanapongpibul@vodafone.com, john.diachina@ericsson.com | Rel-10 | GP-47 | Gert | MTC, M2M |  |  |  |  |
| 1748 | 442.8 | MS Conformance Test Aspects for GERAN - Network Improvements for Machine-Type Communications | 333d? | 2012-08-27 A | 2013-11-22 A | 100% | 2012-08-27 | 2013-11-22 | 333d? | finish no earlier than 2013-11-22 | G3new | 2656h | 2656h | NIMTC_GERAN-MSTest | PCG-29 | ST-Ericsson | hakan.e.grunditz@stericsson.com | Rel-10 | GP-55 | Ingbert | MTC, M2M | NIMTC_GERAN-MSTest |  |  |  |
| 1749 | 442.9 | RAN mechanisms to avoid CN overload due to Machine-Type Communications | 131d? | 2010-09-17 A | 2011-03-18 A | 100% | 2010-09-17 | 2011-03-18 | 131d? | finish no earlier than 2011-03-18 | R2; R3 | 2096h | 2096h | NIMTC-RAN_overload | PCG-25 | Huawei | Jeff Gao (gaoyq@huawei.com) | Rel-10 | RP-49 | Yong-Jun | MTC, M2M | NIMTC-RAN_overload |  |  | RP-110063 |
| 1750 | 442.10 | UE Conformance Test Aspects - Network Improvements for Machine-Type Communications | 202d? | 2012-09-11 A | 2013-06-14 A | 100% | 2012-09-11 | 2013-06-14 | 202d? | finish no earlier than 2013-06-14 | R5 | 1616h | 1616h | NIMTC-UEConTest | PCG-29 | Ericsson | calle.hagenfeldt@ericsson.com | Rel-10 | RP-57 | Ingbert | MTC, M2M | NIMTC-UEConTest |  |  | RP-130465 |

Notes:
- 1725: CP#51 completed. SP#49 moved Stage 1 from Rel-9 & Completed Stage 2. SP#40 Stage 1 completed. Continuation of Rel-8 Feature PRIOR (UID_340044)
- 1726: ePRIOR started Mar 2006 as a Rel-8 Feature. It was delayed to Rel-9 (completed at SP#40), then moved to Rel-10 at SP#49 and demoted to Building Block level. / Impacted TSs and TRs: 22.153, 22.278
- 1727: SP#49 completed. Updated WID SP-100166=>SP-100647
- 1728: SP#49 completed / Impacted TSs and TRs: 23.002, 23.203, 23.221, 23.228, 23.272, 23.401
- 1729: SP#49 completed / Impacted TSs and TRs: 23.002, 23.203, 23.221, 23.228, 23.272, 23.401
- 1730: SP#49 completed / Impacted TSs and TRs: 23.002, 23.203, 23.221, 23.228, 23.272, 23.401
- 1731: SP#49 TR 23.854 v100 for Information. SP#50 moved to Rel-11 SRVCC aspect of enhancements for Multimedia Priority Service UID_480135 (place holder for solution alternatives and agreed functions to be reflected in affected existing TS) / Impacted TSs and TRs: new TR 23.854
- 1732: CP#51 completed / Impacted TSs and TRs: Stage 3
- 1733: CP#51 completed / Impacted TSs and TRs: 23.008, 29.002, 29.228, 29.229, 29.272, 29.274, 29.277, 29.328, 29.329
- 1734: CP#51 completed / Impacted TSs and TRs: 29.212, 29.213, 29.214
- 1735: CP#51 completed / Impacted TSs and TRs: 24.008, 24.229, 24.301
- 1736: Triggered by Rel-8 UID_7027 Study on Facilitating Machine to Machine Communication in GSM and UMTS (FS_M2M) TR 22.868
- 1737: SP#47 completed / Impacted TSs and TRs: 22.011, New 22.368
- 1738: SP#50 updated WID SP-090832=>SP-100863 (TR 23.888 not submitted for approval to conclude Rel-10 NIMTC as it will continue to serve as basis for Rel-11 SIMTC work item) / Impacted TSs and TRs: New TR 23.888
- 1739: SP#49 completed / Impacted TSs and TRs: 23.060, 23.236, 23.401
- 1740: SP#49 stopped (activity transferred to Rel-11 Feature SIMTC under UID_490028 "TR on Security aspects of Machine-Type Communications". / Impacted TSs and TRs: New TR 33.868
- 1741: SP#51 completed / Impacted TSs and TRs: 32.251, 32.298, 32.299
- 1742: CP#52 completed / Impacted TSs and TRs: Stage 3
- 1743: CP#52 completed / Impacted TSs and TRs: 23.122, 24.008, 24.301, New 24.368
- 1744: CP#52 stopped (SA2 decided to move impact from CT3 to CT4). Updated WID CP-110147=>CP-110442 (no CT3 impact) / Impacted TSs and TRs: 29.212, 29.213, 29.215
- 1745: CP#52 completed / Impacted TSs and TRs: 23.003, 23.008, 29.002, 29.060, 29.230, 29.272, 29.274, 29.275, 29.282
- 1746: CP#52 completed / Impacted TSs and TRs: 31.102
- 1747: GP#51 completed. GP#47 approved WID / Impacted TSs and TRs: 44.018, 44.060
- 1748: GP#60 completed. GP#55 approved WID. Testing for CT1 part of Stage 3 for NIMTC UID_480105, GERAN part of NIMTC (Stage 3) UID_490003 / Impacted TSs and TRs: 51.010-1, 51.010-2
- 1749: RP#51 completed / Impacted TSs and TRs: UTRA, LTE 25.331, 25.413, 36.331, 36.413
- 1750: RP#60 completed. Testing for CT1 part of Stage 3 UID_480105, RAN mechanisms to avoid CN overload due to MTC UID_490024 / Impacted TSs and TRs: 34.123-1, 34.123-2, 34.123-3, 36.523-1, 36.523-2, 36.523-3

| ID | WBS | Task | Duration | Start | Finish | Complete | Baseline start | Baseline finish | Baseline duration | Constraint | Resources | Work | Actual work | Acronym | PCG approved | WI rapporteur name | Release | TSG approved | MCC resp | Acronym_3GU_Export | Special Focus Doc |
| --- | --- | --- | --- | --- | --- | --- | --- | --- | --- | --- | --- | --- | --- | --- | --- | --- | --- | --- | --- | --- | --- |
| 1751 | 443 | **Multi Access PDN Connectivity** | 527d? | 2009-03-13 A | 2011-03-18 A | 100% | 2009-03-13 | 2011-03-18 | 527d? |  | S2; C4; C1; C3 | 23680h | 23680h | MAPCON | PCG-22 | Telecom Italia | Rel-10 | SP-43 | Maurice | MAPCON |  |
| 1752 | 443.1 | Stage 2 for Multi Access PDN Connectivity | 401d? | 2009-03-13 A | 2010-09-23 A | 100% | 2009-03-13 | 2010-09-23 | 401d? |  | S2 | 3208h | 3208h | MAPCON |  | Telecom Italia | Rel-10 |  | Maurice |  |  |
| 1753 | 443.2 | **CT aspects of Multi Access PDN Connectivity** | 90d? | 2010-11-15 A | 2011-03-18 A | 100% | 2010-11-15 | 2011-03-18 | 90d? |  | C4; C1; C3 | 3608h | 3608h | MAPCON-St3 | PCG-26 | ZTE | Rel-10 | CP-50 | Kimmo | MAPCON-St3 |  |
| 1754 | 443.2.1 | CT4 aspects of Multi Access PDN Connectivity | 20d? | 2010-11-15 A | 2010-12-10 A | 100% | 2010-11-15 | 2010-12-10 | 20d? | start no earlier than 2010-12-10 | C4 | 160h | 160h | MAPCON-St3 | PCG-26 | ZTE | Rel-10 | CP-50 | Kimmo |  |  |
| 1755 | 443.2.2 | CT1 aspects of Multi Access PDN Connectivity | 71d? | 2010-12-10 A | 2011-03-18 A | 100% | 2010-12-10 | 2011-03-18 | 71d? | start no earlier than 2010-12-10 | C1 | 568h | 568h | MAPCON-St3 | PCG-26 | ZTE | Rel-10 | CP-50 | Frederic |  |  |
| 1756 | 443.2.3 | CT3 aspects of Multi Access PDN Connectivity | 90d? | 2010-11-15 A | 2011-03-18 A | 100% | 2010-11-15 | 2011-03-18 | 90d? | finish no earlier than 2011-03-18 | C3 | 720h | 720h | MAPCON-St3 | PCG-26 | ZTE | Rel-10 | CP-50 | Adrian |  |  |
| 1757 | 444 | **IMS Service Continuity – Inter Device Transfer enhancements** | 924d? | 2009-06-04 A | 2012-12-07 A | 100% | 2009-06-04 | 2012-12-07 | 924d? |  | S1; S2; C1; IETF | 41168h | 41168h | IMS_SC_eIDT | PCG-23 | Huawei | Rel-10 | SP-44 | Alain | IMS_SC_eIDT |  |
| 1758 | 444.1 | Stage 1 - IMS Service Continuity – Inter Device Transfer enhancements | 211d? | 2009-06-04 A | 2010-03-25 A | 100% | 2009-06-04 | 2010-03-25 | 211d? | finish no earlier than 2010-03-25 | S1 | 1688h | 1688h | IMS_SC_eIDT | PCG-23 | Huawei | Rel-10 | SP-44 | Alain |  |  |
| 1759 | 444.2 | Stage 2 - IMS Inter-UE Transfer enhancements | 261d? | 2009-09-24 A | 2010-09-23 A | 100% | 2009-09-24 | 2010-09-23 | 261d? | finish no earlier than 2010-09-23 | S2 | 2088h | 2088h | IMS_SC_eIDT | PCG-23 | Huawei | Rel-10 | SP-45 | Maurice |  |  |
| 1760 | 444.3 | Stage 3 - IMS Inter-UE Transfer enhancements | 261d? | 2010-03-19 A | 2011-03-18 A | 100% | 2010-03-19 | 2011-03-18 | 261d? | start no earlier than 2010-03-19 | C1 | 2088h | 2088h | IMS_SC_eIDT | PCG-24 | Huawei | Rel-10 | CP-47 | Frederic |  |  |
| 1761 | 444.4 | (IETF) Stage 3 - IMS Inter-UE Transfer enhancements | 717d? | 2010-03-19 A | 2012-12-07 A | 100% | 2010-03-19 | 2012-12-07 | 717d? | finish no earlier than 2012-12-04 | C1-IETF | 5736h | 5736h | IMS_SC_eIDT | PCG-27 | christer.holmberg@ericsson.com | Rel-10 | CP-52 | Frederic |  |  |
| 1762 | 445 | **IP-Short-Message-Gateway enhancements for CPM-SMS Interworking** | 257d? | 2009-09-24 A | 2010-09-17 A | 100% | 2009-09-24 | 2010-09-17 | 257d? |  | S1; S2; C3 | 9904.8h | 9904.8h | CPM-SMS | PCG-23 | China Mobile | Rel-10 | SP-45 | Alain | CPM-SMS |  |
| 1763 | 445.1 | Stage 1 for CPM-SMS | 131d? | 2009-09-24 A | 2010-03-25 A | 100% | 2009-09-24 | 2010-03-25 | 131d? | finish no earlier than 2010-03-25 | S1 | 1048h | 1048h | CPM-SMS | PCG-23 | China Mobile | Rel-10 | SP-45 | Alain |  |  |
| 1764 | 445.2 | Stage 2 for CPM-SMS | 130.1d? | 2009-09-24 A | 2010-03-25 A | 100% | 2009-09-24 | 2010-03-25 | 130.1d? | finish no earlier than 2010-03-25 | S2 | 1040.8h | 1040.8h | CPM-SMS | PCG-23 | Orange | Rel-10 | SP-45 | Maurice |  |  |
| 1765 | 445.3 | Stage 3 for IP-Short-Message-Gateway enhancements for CPM-SMS Interworking | 206d? | 2009-12-04 A | 2010-09-17 A | 100% | 2009-12-04 | 2010-09-17 | 206d? | finish no earlier than 2010-09-17 | C3 | 1648h | 1648h | CPM-SMS | PCG-24 | Ericsson | Rel-10 | CP-46 | Adrian |  |  |
| 1766 | 446 | **Completion of Communications on Not Logged-in** | 387d? | 2009-09-24 A | 2011-03-18 A | 100% | 2009-09-24 | 2011-03-18 | 387d? |  | S1; C1; C3 | 11992h | 11992h | CCNL | PCG-23 | Deutsche Telekom | Rel-10 | SP-45 | Alain | CCNL |  |
| 1767 | 446.1 | Stage 1 for Completion of Communications on Not Logged-in | 1d? | 2009-09-24 A | 2009-09-24 A | 100% | 2009-09-24 | 2009-09-24 | 1d? | start no earlier than 2009-09-24 | S1 | 8h | 8h | CCNL | PCG-23 | Deutsche Telekom | Rel-10 | SP-45 | Alain |  |  |
| 1768 | 446.2 | CT1 part of Stage 3 for Completion of Communications on Not Logged-in | 261d? | 2010-03-19 A | 2011-03-18 A | 100% | 2010-03-19 | 2011-03-18 | 261d? | finish no earlier than 2011-03-18 | C1 | 2088h | 2088h | CCNL | PCG-24 | Deutsche Telekom | Rel-10 | CP-47 | Frederic |  |  |
| 1769 | 446.3 | CT3 part of Stage 3 for Completion of Communications on Not Logged-in | 76d? | 2010-06-04 A | 2010-09-17 A | 100% | 2010-06-04 | 2010-09-17 | 76d? | finish no earlier than 2010-09-17 | C3 | 608h | 608h | CCNL | PCG-25 | Deutsche Telekom | Rel-10 | CP-48 | Adrian |  |  |
| 1770 | 447 | **Local IP Access and Selected Internet IP Traffic Offload** | 390d? | 2009-09-24 A | 2011-03-23 A | 100% | 2009-09-24 | 2011-03-23 | 390d? |  | S2; S1; S3; S5; C4; C1 | 66128h | 66128h | LIPA_SIPTO | PCG-23 | Huawei, China Mobile | Rel-10 | SP-45 | Maurice | LIPA_SIPTO | HNB |
| 1771 | 447.1 | Stage 1 for Local IP Access and Selected Internet IP Traffic Offload | 131d? | 2009-09-24 A | 2010-03-25 A | 100% | 2009-09-24 | 2010-03-25 | 131d? | finish no earlier than 2010-03-25 | S1 | 1048h | 1048h | LIPA_SIPTO | PCG-23 | Huawei, China Mobile | Rel-10 | SP-45 | Alain |  | HNB |
| 1772 | 447.2 | TR on Local IP Access and Selected Internet IP Traffic Offload | 387d? | 2009-09-24 A | 2011-03-18 A | 100% | 2009-09-24 | 2011-03-18 | 387d? | finish no earlier than 2011-03-18 | S2 | 3096h | 3096h | LIPA_SIPTO | PCG-23 | Huawei, China Mobile | Rel-10 | SP-45 | Maurice |  | HNB |
| 1773 | 447.3 | Security for Local IP Access and Selected Internet IP Traffic Offload | 261d? | 2009-09-24 A | 2010-09-23 A | 100% | 2009-09-24 | 2010-09-23 | 261d? | finish no earlier than 2010-09-23 | S3 | 2088h | 2088h | LIPA_SIPTO | PCG-23 | Huawei, Qualcomm | Rel-10 | SP-45 | Mirko |  | HNB |
| 1774 | 447.4 | OAM&P for Local IP Access and Selected Internet IP Traffic Offload | 390d? | 2009-09-24 A | 2011-03-23 A | 100% | 2009-09-24 | 2011-03-23 | 390d? | finish no earlier than 2011-03-23 | S5 | 3120h | 3120h | LIPA_SIPTO | PCG-23 | Huawei, China Mobile | Rel-10 | SP-45 | Mirko |  | HNB |
| 1775 | 447.5 | Charging for Local IP Access and Selected Internet IP Traffic Offload | 335d? | 2009-12-10 A | 2011-03-23 A | 100% | 2009-12-10 | 2011-03-23 | 335d? | finish no earlier than 2011-03-23 | S5 | 2680h | 2680h | LIPA_SIPTO | PCG-24 | Huawei, China Mobile | Rel-10 | SP-46 | Mirko |  | HNB |

Notes:
- 1751: CP#51 completed. SP#49 Stage 2 completed. Triggered by TR 23.861 UID_410043 FS_MAPIM. Stage 1 in Rel-9 22.278 (6.2 - IP session control) / WI rapporteur e-mail: ivano.guardini@telecomitalia.it
- 1752: SP#49 completed. Triggered by TR 23.861 UID_410043 FS_MAPIM. Stage 1 in Rel-9 22.278 (6.2 - IP session control) / Impacted TSs and TRs: 23.237, 23.401, 23.402 / WI rapporteur e-mail: ivano.guardini@telecomitalia.it
- 1753: CP#51 completed / WI rapporteur e-mail: Xingyue (Joy) Zhou (zhou.xingyue@zte.com.cn)
- 1754: CP#50 completed / Impacted TSs and TRs: 29.273, 29.272, 29.002, 23.008 / WI rapporteur e-mail: Xingyue (Joy) Zhou (zhou.xingyue@zte.com.cn)
- 1755: CP#51 completed / Impacted TSs and TRs: 24.302, 24.312 / WI rapporteur e-mail: Xingyue (Joy) Zhou (zhou.xingyue@zte.com.cn)
- 1756: CP#51 completed / Impacted TSs and TRs: 29.215 / WI rapporteur e-mail: Xingyue (Joy) Zhou (zhou.xingyue@zte.com.cn)
- 1757: CP#51 completed. SP#47 Stage 1 completed. Rel-9 set Inter-Device Transfer requirements UID_410033 (IMS_SCC-IDT). Adds IDT scenarios and requirements / WI rapporteur e-mail: Amar Deol (adeol@huawei.com)
- 1758: SP#47 completed / Impacted TSs and TRs: 22.228 / WI rapporteur e-mail: Amar Deol (adeol@huawei.com)
- 1759: SP#49 completed / Impacted TSs and TRs: 23.237, 23.292, new 23.831 / WI rapporteur e-mail: Lee Valerius (lvalerius@huawei.com)
- 1760: CP#51 completed. WID updated CP-100334=>CP-110285 / Impacted TSs and TRs: 24.216, 24.229, 24.237, new (24.837, 24.337) / WI rapporteur e-mail: georg.mayer@huawei.com
- 1761: CP#58 completed / Impacted TSs and TRs: RFC 6809 (was draft-ietf-sipcore-proxy-feature) / WI rapporteur e-mail: christer.holmberg@ericsson.com
- 1762: CP#49 completed. SP#47 Stage 1 completed. IP-SM-GW enhancements for interworking with OMA CPM / WI rapporteur e-mail: Qing Huang (huangqing@chinamobile.com)
- 1763: SP#47 completed. External requirements (Stage 1 in OMA-RD-CPM-V1_0-20090310-C) / Impacted TSs and TRs: 22.340 / WI rapporteur e-mail: Qing Huang
- 1764: SP#47 completed / Impacted TSs and TRs: 23.204, new TR 23.824 / WI rapporteur e-mail: antoine.mouquet@orange-ftgroup.com
- 1765: CP#49 completed. Linked to Rel-8 UID_340031 Service-Level Interworking for Messaging Services (MESSIW) 23.204 / Impacted TSs and TRs: 29.311 / WI rapporteur e-mail: Jan Holm
- 1766: CP#51 completed. SP#45 Stage 1 completed / WI rapporteur e-mail: Kurt Bischinger
- 1767: SP#45 completed / Impacted TSs and TRs: 22.173 CR#0056r1 / WI rapporteur e-mail: Kurt Bischinger
- 1768: CP#51 completed / Impacted TSs and TRs: 24.173, 24.642 / WI rapporteur e-mail: martin.huelsemann@telekom.de
- 1769: CP#49 completed / Impacted TSs and TRs: 29.165 / WI rapporteur e-mail: martin.huelsemann@telekom.de
- 1770: TSG#51 completed. Updated WID SP-100696=>SP-110131. SP#49 Stage 2 & Security completed. UID_400035 Enhanced Home NodeB/eNodeB (EHNB) formerly covered Local IP Access to Internet and Local access to Home Network from the Home NodeB/eNodeB / WI rapporteur e-mail: patrice.hede@huawei.com, Tao Sun (suntao@chinamobile.com)
- 1771: SP#47 completed / Impacted TSs and TRs: 22.101, 22.220 / WI rapporteur e-mail: Amar Deol (adeolf@huawei.com), Gang Li (ligangyf@chinamobile.com)
- 1772: SP#51 completed. TR 23.829 for Approval / Impacted TSs and TRs: New TR 23.829 / WI rapporteur e-mail: patrice.hede@huawei.com, Tao Sun (suntao@chinamobile.com)
- 1773: SP#49 completed / Impacted TSs and TRs: 33.102, 33.107, 33.108, 33.320, 33.401 / WI rapporteur e-mail: Marcus Wong (mwong@huawei.com), Brian Rosenberg (bmr@qualcomm.com)
- 1774: SP#51 completed. Updated WID SP-100696=>SP-110131 / Impacted TSs and TRs: 32.581, 32.582, 32.584, 32.591, 32.592, 32.642, 32.646, 32.772, 32.782 / WI rapporteur e-mail: Zou Lan (zlan@huawei.com), Chen Gang (chengang@chinamobile.com)
- 1775: SP#51 completed. Updated WID SP-100696=>SP-110131 / Impacted TSs and TRs: 32.251 / WI rapporteur e-mail: shan.mingjun@huawei.com, Ai Chen (chenai@chinamobile.com)

| ID | WBS | Task | Duration | Start | Finish | Complete | Baseline start | Baseline finish | Baseline duration | Constraint | Resources | Work | Actual work | Acronym | PCG approved | WI rapporteur name | WI rapporteur e-mail | Release | TSG approved | MCC resp | Special Focus Doc | Acronym_3GU_Export |
| --- | --- | --- | --- | --- | --- | --- | --- | --- | --- | --- | --- | --- | --- | --- | --- | --- | --- | --- | --- | --- | --- | --- |
| 1776 | 447.6 | **Stage 2/3 for Local IP Access** | 387d? | 2009-09-24 A | 2011-03-18 A | 100% | 2009-09-24 | 2011-03-18 | 387d? |  | S2; C4; C1 | 17968h | 17968h | LIPA | PCG-23 | Huawei, China Mobile | patrice.hede@huawei.com, Tao Sun (suntao@chinamobile.com) | Rel-10 | SP-45 | Maurice | HNB | LIPA |
| 1777 | 447.6.1 | Stage 2 for Local IP Access | 261d? | 2009-09-24 A | 2010-09-23 A | 100% | 2009-09-24 | 2010-09-23 | 261d? | finish no earlier than 2010-08-10 | S2 | 2088h | 2088h | LIPA | PCG-23 | Huawei, China Mobile | patrice.hede@huawei.com, Tao Sun (suntao@chinamobile.com) | Rel-10 | SP-45 | Maurice | HNB |  |
| 1778 | 447.6.2 | **Stage 3 for Local IP Access** | 206d? | 2010-06-04 A | 2011-03-18 A | 100% | 2010-06-04 | 2011-03-18 | 206d? |  | C4; C1 | 6592h | 6592h | LIPA | PCG-25 | China Mobile | Zhang Hao (zhanghao@chinamobile.com) | Rel-10 | CP-48 | Kimmo | HNB |  |
| 1779 | 447.6.2.1 | CT4 part of Stage 3 for Local IP Access | 206d? | 2010-06-04 A | 2011-03-18 A | 100% | 2010-06-04 | 2011-03-18 | 206d? | finish no earlier than 2011-03-18 | C4 | 1648h | 1648h | LIPA | PCG-25 | China Mobile | Zhang Hao (zhanghao@chinamobile.com) | Rel-10 | CP-48 | Kimmo | HNB |  |
| 1780 | 447.6.2.2 | CT1 part of Stage 3 for Local IP Access | 206d? | 2010-06-04 A | 2011-03-18 A | 100% | 2010-06-04 | 2011-03-18 | 206d? | finish no earlier than 2011-03-18 | C1 | 1648h | 1648h | LIPA | PCG-25 | China Mobile | Zhang Hao (zhanghao@chinamobile.com) | Rel-10 | CP-48 | Frederic | HNB |  |
| 1781 | 447.7 | **Stage 2/3 for SIPTO for macro networks** | 387d? | 2009-09-24 A | 2011-03-18 A | 100% | 2009-09-24 | 2011-03-18 | 387d? |  | S2; C4; C1 | 17408h | 17408h | SIPTO | PCG-23 | Huawei, China Mobile | patrice.hede@huawei.com, Tao Sun (suntao@chinamobile.com) | Rel-10 | SP-45 | Maurice | HNB | SIPTO |
| 1782 | 447.7.1 | Stage 2 for SIPTO for macro networks | 261d? | 2009-09-24 A | 2010-09-23 A | 100% | 2009-09-24 | 2010-09-23 | 261d? | finish no earlier than 2010-09-23 | S2 | 2088h | 2088h | SIPTO | PCG-23 | Huawei, China Mobile | patrice.hede@huawei.com, Tao Sun (suntao@chinamobile.com) | Rel-10 | SP-45 | Maurice | HNB |  |
| 1783 | 447.7.2 | **Stage 3 for SIPTO for macro networks** | 206d? | 2010-06-04 A | 2011-03-18 A | 100% | 2010-06-04 | 2011-03-18 | 206d? |  | C4; C1 | 6032h | 6032h | SIPTO | PCG-25 | Huawei | Caixia Qi (qcxmay@huawei.com) | Rel-10 | CP-48 | Kimmo | HNB |  |
| 1784 | 447.7.2.1 | CT4 part of Stage 3 for SIPTO for macro networks | 206d? | 2010-06-04 A | 2011-03-18 A | 100% | 2010-06-04 | 2011-03-18 | 206d? | finish no earlier than 2011-03-18 | C4 | 1648h | 1648h | SIPTO | PCG-25 | Huawei | Caixia Qi (qcxmay@huawei.com) | Rel-10 | CP-48 | Kimmo | HNB |  |
| 1785 | 447.7.2.2 | CT1 part of Stage 3 for SIPTO for macro networks | 136d? | 2010-06-04 A | 2010-12-10 A | 100% | 2010-06-04 | 2010-12-10 | 136d? | finish no earlier than 2011-03-18 | C1 | 1088h | 1088h | SIPTO | PCG-25 | Huawei | Caixia Qi (qcxmay@huawei.com) | Rel-10 | CP-48 | Frederic | HNB |  |
| 1786 | 448 | **IP Flow Mobility and seamless WLAN offload** | 390d? | 2009-09-24 A | 2011-03-23 A | 100% | 2009-09-24 | 2011-03-23 | 390d? |  | S2; S1; S5; C1; C3 | 26808h | 26808h | IFOM | PCG-23 | Qualcomm | Gerardo Giaretta (gerardo@qualcomm.com) | Rel-10 | SP-45 | Maurice | WLAN | IFOM |
| 1787 | 448.1 | Stage 1 for IP Flow Mobility and seamless WLAN offload | 56d? | 2009-09-24 A | 2009-12-10 A | 100% | 2009-09-24 | 2009-12-10 | 56d? | finish no earlier than 2009-12-10 | S1 | 448h | 448h | IFOM | PCG-23 | Qualcomm | David Williams (dwilliam@qualcomm.com) | Rel-10 | SP-45 | Alain | WLAN |  |
| 1788 | 448.2 | Stage 2 for IP Flow Mobility and seamless WLAN offload | 261d? | 2009-09-24 A | 2010-09-23 A | 100% | 2009-09-24 | 2010-09-23 | 261d? | finish no earlier than 2010-09-23 | S2 | 2088h | 2088h | IFOM | PCG-23 | Qualcomm | Gerardo Giaretta (gerardo@qualcomm.com) | Rel-10 | SP-45 | Maurice | WLAN |  |
| 1789 | 448.3 | Charging for IP Flow Mobility and seamless WLAN offload | 260d? | 2010-03-25 A | 2011-03-23 A | 100% | 2010-03-25 | 2011-03-23 | 260d? | finish no earlier than 2011-03-23 | S5 | 2080h | 2080h | IFOM | PCG-24 | Alcatel-Lucent | maryse.gardella@alcatel-lucent.com | Rel-10 | SP-47 | Mirko | WLAN |  |
| 1790 | 448.4 | **Stage 3 for IP Flow Mobility and seamless WLAN offload** | 206d? | 2010-06-04 A | 2011-03-18 A | 100% | 2010-06-04 | 2011-03-18 | 206d? |  | C1; C3 | 6592h | 6592h | IFOM-CT | PCG-25 | Qualcomm | Patrick Stupar (pstupar@qualcomm.com) | Rel-10 | CP-48 | Frederic | WLAN | IFOM-CT |
| 1791 | 448.4.1 | CT1 part of Stage 3 for IP Flow Mobility and seamless WLAN offload | 206d? | 2010-06-04 A | 2011-03-18 A | 100% | 2010-06-04 | 2011-03-18 | 206d? | finish no earlier than 2011-03-18 | C1 | 1648h | 1648h | IFOM-CT | PCG-25 | Qualcomm | Patrick Stupar (pstupar@qualcomm.com) | Rel-10 | CP-48 | Frederic | WLAN |  |
| 1792 | 448.4.2 | CT3 part of Stage 3 for IP Flow Mobility and seamless WLAN offload | 206d? | 2010-06-04 A | 2011-03-18 A | 100% | 2010-06-04 | 2011-03-18 | 206d? | finish no earlier than 2011-03-18 | C3 | 1648h | 1648h | IFOM-CT | PCG-25 | Qualcomm | Patrick Stupar (pstupar@qualcomm.com) | Rel-10 | CP-48 | Adrian | WLAN |  |
| 1793 | 449 | **Enabling Coder Selection and Rate Adaptation for UTRAN and E-UTRAN for Load Adaptive Applications** | 827.4d? | 2009-07-15 A | 2012-09-07 A | 100% | 2009-07-15 | 2012-09-07 | 827.4d? |  | S2; S4; C4; C3; C1; IETF | 85939.2h | 85939.2h | ECSRA_LAA | PCG-23 | Qualcomm | AC Mahendran (ac@qualcomm.com) | Rel-10 | SP-45 | Maurice |  | ECSRA_LAA |
| 1794 | 449.1 | TR on Enabling Coder Selection and Rate Adaptation for UTRAN and E-UTRAN for Load Adaptive Applications | 186d? | 2010-01-07 A | 2010-09-23 A | 100% | 2010-01-07 | 2010-09-23 | 186d? | finish no earlier than 2010-09-23 | S2; S4 | 2976h | 2976h | ECSRA_LAA | PCG-23 | Qualcomm | AC Mahendran (ac@qualcomm.com) | Rel-10 | SP-45 | Maurice |  |  |
| 1795 | 449.2 | SA4 review of TR on Enabling Coder Selection and Rate Adaptation for UTRAN and E-UTRAN for Load Adaptive Applications | 320d? | 2009-09-24 A | 2010-12-15 A | 100% | 2009-09-24 | 2010-12-15 | 320d? | finish no earlier than 2010-12-15 | S4 | 2560h | 2560h | ECSRA_LAA | PCG-23 | Qualcomm | AC Mahendran (ac@qualcomm.com) | Rel-10 | SP-45 | Paolo |  |  |
| 1796 | 449.3 | Stage 2 for Enabling Coder Selection and Rate Adaptation for UTRAN and E-UTRAN for Load Adaptive Applications | 261d? | 2009-09-24 A | 2010-09-23 A | 100% | 2009-09-24 | 2010-09-23 | 261d? | finish no earlier than 2010-09-23 | S2 | 2088h | 2088h | ECSRA_LAA | PCG-23 | Qualcomm | AC Mahendran (ac@qualcomm.com) | Rel-10 | SP-45 | Maurice |  |  |
| 1797 | 449.4 | SA4 aspects of Enabling Coder Selection and Rate Adaptation for UTRAN and E-UTRAN for Load Adaptive Applications | 130d? | 2010-09-23 A | 2011-03-23 A | 100% | 2010-09-23 | 2011-03-23 | 130d? | finish no earlier than 2011-03-23 | S4 | 1040h | 1040h | ECSRA_LAA | PCG-25 | Qualcomm | AC Mahendran (ac@qualcomm.com) | Rel-10 | SP-49 | Paolo |  |  |
| 1798 | 449.5 | **CN aspects of Enabling Coder Selection and Rate Adaptation for UTRAN and E-UTRAN for Load Adaptive Applications** | 827.4d? | 2009-07-15 A | 2012-09-07 A | 100% | 2009-07-15 | 2012-09-07 | 827.4d? |  | C4; C3; C1 | 37560h | 37560h | ECSRA_LAA-CN | PCG-25 | Ericsson | philip.hodges@ericsson.com | Rel-10 | CP-49 | Kimmo |  | ECSRA_LAA-CN |
| 1799 | 449.5.1 | CT4 part of CN aspects of Enabling Coder Selection and Rate Adaptation for UTRAN and E-UTRAN for Load Adaptive Applications | 186d? | 2010-09-17 A | 2011-06-03 A | 100% | 2010-09-17 | 2011-06-03 | 186d? | start no earlier than 2010-09-17 | C4 | 1488h | 1488h | ECSRA_LAA-CN | PCG-25 | Ericsson | philip.hodges@ericsson.com | Rel-10 | CP-49 | Kimmo |  |  |
| 1800 | 449.5.2 | (IETF) CT3, CT4 part of CN aspects of Enabling Coder Selection and Rate Adaptation for UTRAN and E-UTRAN for Load Adaptive Applications | 827.4d? | 2009-07-15 A | 2012-09-07 A | 100% | 2009-07-15 | 2012-09-07 | 827.4d? | finish no earlier than 2012-09-07 | C3-IETF; C4-IETF | 13238.4h | 13238.4h | ECSRA_LAA-CN | PCG-27 | Lionel Morand |  | Rel-10 | CP-53 | Adrian |  |  |
| 1801 | 449.5.3 | CT3 part of CN aspects of Enabling Coder Selection and Rate Adaptation for UTRAN and E-UTRAN for Load Adaptive Applications | 186d? | 2010-09-17 A | 2011-06-03 A | 100% | 2010-09-17 | 2011-06-03 | 186d? | finish no earlier than 2011-06-03 | C3 | 1488h | 1488h | ECSRA_LAA-CN | PCG-25 | Ericsson | philip.hodges@ericsson.com | Rel-10 | CP-49 | Adrian |  |  |
| 1802 | 449.5.4 | CT1 part of CN aspects of Enabling Coder Selection and Rate Adaptation for UTRAN and E-UTRAN for Load Adaptive Applications | 186d? | 2010-09-17 A | 2011-06-03 A | 100% | 2010-09-17 | 2011-06-03 | 186d? | start no earlier than 2010-09-17 | C1 | 1488h | 1488h | ECSRA_LAA-CN | PCG-25 | Ericsson | philip.hodges@ericsson.com | Rel-10 | CP-49 | Frederic |  |  |

Notes:
- 1776: -
- 1777: SP#49 completed (has impacts to RAN) / Impacted TSs and TRs: 23.060, 23.401
- 1778: CP#51 completed
- 1779: CP#51 completed / Impacted TSs and TRs: 23.008, 23.015, 29.002, 29.060, 29.272, 29.274, 29.281, 29.303
- 1780: CP#51 completed / Impacted TSs and TRs: 24.008, 24.301
- 1781: -
- 1782: SP#49 completed (SIPTO GW selection for wild card APN and for GERAN. Serving-GW selection for SIPTO. Corrections and Clarifications of the SIPTO procedure) / Impacted TSs and TRs: 23.060, 23.401
- 1783: CP#51 completed. Updated WID CP-100419=>CP-110091
- 1784: CP#51 completed. Updated WID CP-100419=>CP-110091 / Impacted TSs and TRs: 23.003, 23.008, 29.002, 29.272, 29.303
- 1785: CP#50 completed / Impacted TSs and TRs: 24.008, 24.301
- 1786: SP#51 completed. Triggered by Rel-10 TR 23.861 (UID_410043 Study on Multi Access PDN connectivity and IP flow mobility - MAPIM)
- 1787: SP#46 completed / Impacted TSs and TRs: 22.278
- 1788: SP#49 completed / Impacted TSs and TRs: 23.203, 23.402, new 23.261
- 1789: SP#51 completed / Impacted TSs and TRs: 32.240, 32.251, 32.252, 32.298, 32.299
- 1790: CP#51 completed / Impacted TSs and TRs: Stage 3
- 1791: CP#51 completed / Impacted TSs and TRs: 24.008, 24.301, 24.302, 24.303, 24.312, 24.327
- 1792: CP#51 completed / Impacted TSs and TRs: 29.212, 29.213, 29.214, 29.215
- 1793: CP#52 completed. Triggered by Rel-9 UID_440013 Vocoder rate adaptation for LTE / Impacted TSs and TRs: UTRA, LTE
- 1794: SP#48 completed / Impacted TSs and TRs: new 23.860
- 1795: SP#50 completed / Impacted TSs and TRs: new 23.860
- 1796: SP#49 completed / Impacted TSs and TRs: 23.060, 23.203, 23.228, 23.401
- 1797: SP#51 completed / Impacted TSs and TRs: 26.114
- 1798: CP#52 completed / Impacted TSs and TRs: Stage 2/3
- 1799: CP#52 completed / Impacted TSs and TRs: 23.334, 29.334, 29.238, 23.333, 29.333, 29.232, 29.332
- 1800: CP#57 completed / Impacted TSs and TRs: RFC 6679 (was draft-ietf-avtcore-ecn-for-rtp)
- 1801: CP#52 completed / Impacted TSs and TRs: 29.162, 29.163, 29.213, 29.235, 29.292
- 1802: CP#52 completed / Impacted TSs and TRs: 24.229

| ID | WBS | Task | Type | Duration | Start | Finish | Complete | Baseline start | Baseline finish | Baseline duration | Constraint | Resources | Work | Actual work | Acronym | PCG approved | Impacted TSs and TRs | WI rapporteur name | WI rapporteur e-mail | Release | TSG approved | MCC resp | Special Focus Doc | Acronym_3GU_Export | PCG stopped | TSG stopped |
| --- | --- | --- | --- | --- | --- | --- | --- | --- | --- | --- | --- | --- | --- | --- | --- | --- | --- | --- | --- | --- | --- | --- | --- | --- | --- | --- |
| 1803 | 450 | **Extended H(e)NB features** |  | 467d? | 2008-12-11 A | 2010-09-23 A | 100% | 2008-12-11 | 2010-09-23 | 467d? |  | S1; S2; S3 | 15552h | 15552h | EHNBF | PCG-23 | UTRA, LTE | NEC | joerg.swetina@neclab.eu | Rel-10 | SP-45 | Alain | HNB | EHNBF |  |  |
| 1804 | 450.1 | Stage 1 of Extended H(e)NB features |  | 131d? | 2009-09-24 A | 2010-03-25 A | 100% | 2009-09-24 | 2010-03-25 | 131d? | finish no earlier than 2010-03-25 | S1 | 1048h | 1048h | EHNBF | PCG-23 | 22.220 | NEC | joerg.swetina@neclab.eu | Rel-10 | SP-45 | Alain | HNB |  |  |  |
| 1805 | 450.2 | IMS aspects of Architecture for Home NodeB |  | 336d? | 2008-12-11 A | 2010-03-25 A | 100% | 2008-12-11 | 2010-03-25 | 336d? | finish no earlier than 2010-03-25 | S2 | 2688h | 2688h | EHNB-IMS | PCG-22 | New 23.832 | Alcatel-Lucent | Nicolas Drevon | Rel-10 | SP-42 | Maurice | HNB | EHNB-IMS |  |  |
| 1806 | 450.3 | Extended H(e)NB Security features (Stage 2) |  | 76d? | 2010-06-10 A | 2010-09-23 A | 100% | 2010-06-10 | 2010-09-23 | 76d? | finish no earlier than 2010-09-23 | S3 | 608h | 608h | EHNBF-Sec | PCG-25 | 33.320 | Huawei | Marcus Wong (mwong@huawei.com) | Rel-10 | SP-48 | Mirko | HNB | EHNBF-Sec |  |  |
| 1807 | 451 | **Optimal Media Routing** |  | 314d? | 2010-03-25 A | 2011-06-08 A | 100% | 2010-03-25 | 2011-06-08 | 314d? |  | S2; S5; C3; C1 | 22696h | 22696h | OMR | PCG-24 |  | Alcatel-Lucent | andy.bennett@alcatel-lucent.com | Rel-10 | SP-46 | Maurice |  | OMR |  |  |
| 1808 | 451.1 | Stage 2 for Optimal Media Routing | milestone | 0d? | 2010-03-25 A | 2010-03-25 A | 100% | 2010-03-25 | 2010-03-25 | 0d? |  | S2 |  |  | OMR | PCG-24 | 23.228 | Alcatel-Lucent | andy.bennett@alcatel-lucent.com | Rel-10 | SP-46 | Maurice |  |  |  |  |
| 1809 | 451.2 | **Stage 3 for Optimal Media Routing** |  | 261d? | 2010-06-04 A | 2011-06-03 A | 100% | 2010-06-04 | 2011-06-03 | 261d? |  | C3; C1; C4 | 11648h | 11648h | OMR | PCG-25 |  | Alcatel-Lucent | jim.calme@alcatel-lucent.com | Rel-10 | CP-48 | Adrian |  |  |  |  |
| 1810 | 451.2.1 | CT3 part of Stage 3 for Optimal Media Routeing |  | 261d? | 2010-06-04 A | 2011-06-03 A | 100% | 2010-06-04 | 2011-06-03 | 261d? | finish no earlier than 2011-06-03 | C3 | 2088h | 2088h | OMR | PCG-25 | 29.162, 29.163, 29.165, 29.235, new TS 29.079 | Alcatel-Lucent | jim.calme@alcatel-lucent.com | Rel-10 | CP-48 | Adrian |  |  |  |  |
| 1811 | 451.2.2 | CT1 part of Stage 3 for Optimal Media Routeing |  | 206d? | 2010-06-04 A | 2011-03-18 A | 100% | 2010-06-04 | 2011-03-18 | 206d? | finish no earlier than 2011-03-18 | C1 | 1648h | 1648h | OMR | PCG-25 | 24.229 | Alcatel-Lucent | jim.calme@alcatel-lucent.com | Rel-10 | CP-48 | Frederic |  |  |  |  |
| 1812 | 451.2.3 | Deleted - CT4 part of Stage 3 for Optimal Media Routeing |  | 206d? | 2010-06-04 A | 2011-03-18 A | 100% | 2010-06-04 | 2011-03-18 | 206d? | finish no earlier than 2011-03-18 | C4 | 1648h | 1648h | OMR | PCG-25 |  | Alcatel-Lucent | jim.calme@alcatel-lucent.com | Rel-10 | CP-48 | Kimmo |  |  | PCG-26 | CP-51 |
| 1813 | 451.3 | Charging for Optimal Media Routing |  | 125d? | 2010-12-16 A | 2011-06-08 A | 100% | 2010-12-16 | 2011-06-08 | 125d? | finish no earlier than 2011-06-08 | S5 | 1000h | 1000h | OMR | PCG-26 | 32.260, 32.298, 32.299 | Alcatel-Lucent | maryse.gardella@alcatel-lucent.com | Rel-10 | SP-50 | Mirko |  |  |  |  |
| 1814 | 452 | **IMS Emergency Session Enhancements** |  | 312d? | 2010-03-25 A | 2011-06-03 A | 100% | 2010-03-25 | 2011-06-03 | 312d? |  | S1; S2; C1 | 9552h | 9552h | IESE | PCG-24 |  | Deutsche Telekom, T-Mobile | michele.zarri@t-mobile.co.uk | Rel-10 | SP-47 | Maurice | Public Safety (I-A) | IESE |  |  |
| 1815 | 452.1 | Stage 1 for IMS Emergency Session Enhancements |  | 1d? | 2010-03-25 A | 2010-03-25 A | 100% | 2010-03-25 | 2010-03-25 | 1d? | start no earlier than 2010-03-25 | S1 | 8h | 8h | IESE | PCG-24 | 22.101 CR#0343 | Deutsche Telekom, T-Mobile | Kurt Bischinger | Rel-10 | SP-47 | Alain | Public Safety (I-A) |  |  |  |
| 1816 | 452.2 | Stage 2 for IMS Emergency Session Enhancements |  | 131d? | 2010-03-25 A | 2010-09-23 A | 100% | 2010-03-25 | 2010-09-23 | 131d? | finish no earlier than 2010-09-23 | S2 | 1048h | 1048h | IESE | PCG-24 | 23.167 | Deutsche Telekom, T-Mobile | michele.zarri@t-mobile.co.uk | Rel-10 | SP-47 | Maurice | Public Safety (I-A) |  |  |  |
| 1817 | 452.3 | Stage 3 for IMS Emergency Session Enhancements |  | 126d? | 2010-12-10 A | 2011-06-03 A | 100% | 2010-12-10 | 2011-06-03 | 126d? | finish no earlier than 2011-06-03 | C1 | 1008h | 1008h | IESE | PCG-26 | 24.229 | Deutsche Telekom | reinhard.lauster@t-mobile.at | Rel-10 | CP-50 | Frederic | Public Safety (I-A) |  |  |  |
| 1818 | 453 | **S2b Mobility based on GTP** |  | 202d? | 2010-06-10 A | 2011-03-18 A | 100% | 2010-06-10 | 2011-03-18 | 202d? |  | S2; C4; C3; C1 | 12800h | 12800h | SMOG | PCG-25 |  | Alcatel-Lucent | bruno.landais@alcatel-lucent.com | Rel-10 | SP-48 | Maurice | WLAN | SMOG |  |  |
| 1819 | 453.1 | Stage 2 for S2b Mobility based on GTP |  | 76d? | 2010-06-10 A | 2010-09-23 A | 100% | 2010-06-10 | 2010-09-23 | 76d? | finish no earlier than 2010-09-23 | S2 | 608h | 608h | SMOG | PCG-25 | 23.002, 23.203, 23.402 | Alcatel-Lucent | bruno.landais@alcatel-lucent.com | Rel-10 | SP-48 | Maurice | WLAN |  |  |  |
| 1820 | 453.2 | **Stage 3 for S2b Mobility based on GTP** |  | 131d? | 2010-09-17 A | 2011-03-18 A | 100% | 2010-09-17 | 2011-03-18 | 131d? |  | C4; C3; C1 | 5728h | 5728h | SMOG-St3 | PCG-25 |  | Alcatel-Lucent | bruno.landais@alcatel-lucent.com | Rel-10 | CP-49 | Kimmo | WLAN | SMOG-St3 |  |  |
| 1821 | 453.2.1 | CT4 part of Stage 3 for S2b Mobility based on GTP |  | 131d? | 2010-09-17 A | 2011-03-18 A | 100% | 2010-09-17 | 2011-03-18 | 131d? | finish no earlier than 2011-03-18 | C4 | 1048h | 1048h | SMOG-St3 | PCG-25 | 23.003, 23.007, 23.008, 29.273, 29.274, 29.281, 29.303 | Alcatel-Lucent | bruno.landais@alcatel-lucent.com | Rel-10 | CP-49 | Kimmo | WLAN |  |  |  |
| 1822 | 453.2.2 | CT3 part of Stage 3 for S2b Mobility based on GTP |  | 131d? | 2010-09-17 A | 2011-03-18 A | 100% | 2010-09-17 | 2011-03-18 | 131d? | finish no earlier than 2011-03-18 | C3 | 1048h | 1048h | SMOG-St3 | PCG-25 | 29.212, 29.213, 29.215 | Alcatel-Lucent | bruno.landais@alcatel-lucent.com | Rel-10 | CP-49 | Adrian | WLAN |  |  |  |
| 1823 | 453.2.3 | CT1 part of Stage 3 for S2b Mobility based on GTP |  | 61d? | 2010-09-17 A | 2010-12-10 A | 100% | 2010-09-17 | 2010-12-10 | 61d? | finish no earlier than 2010-12-10 | C1 | 488h | 488h | SMOG-St3 | PCG-25 | 24.302 | Alcatel-Lucent | bruno.landais@alcatel-lucent.com | Rel-10 | CP-49 | Frederic | WLAN |  |  |  |
| 1824 | 454 | **Policy Enhancements for Sponsored Connectivity and Coherent Access to Policy related Databases** |  | 113.15d? | 2010-10-12 A | 2011-03-18 A | 100% | 2010-10-12 | 2011-03-18 | 113.15d? |  | S2; C3 | 2378.4h | 2378.4h | PEST | PCG-26 |  | Qualcomm | AC Mahendran (ac@qualcomm.com) | Rel-10 | SP-50 | Maurice |  | PEST |  |  |
| 1825 | 454.1 | Stage 2 for Policy Enhancements for Sponsored Connectivity and Coherent Access to Policy related Databases | milestone | 0d? | 2010-10-12 A | 2010-12-15 A | 100% | 2010-10-12 | 2010-12-15 | 0d? | finish no earlier than 2010-12-15 | S2 |  |  | PEST | PCG-26 | 23.002, 23.203 | Qualcomm | AC Mahendran (ac@qualcomm.com) | Rel-10 | SP-50 | Maurice |  |  |  |  |
| 1826 | 454.2 | CT3 aspects of Policy Enhancements for Sponsored Connectivity and Coherent Access to Policy related Databases |  | 71d? | 2010-12-10 A | 2011-03-18 A | 100% | 2010-12-10 | 2011-03-18 | 71d? | finish no earlier than 2011-03-18 | C3 | 568h | 568h | PEST-CT3 | PCG-26 | 29.212, 29.213, 29.214, 29.215 | ZTE | zhou.xiaoyun@zte.com.cn | Rel-10 | CP-50 | Adrian |  | PEST-CT3 |  |  |

Notes:
- 1803: SP#49 completed. Adds extensions to Rel-9 functionality in UID_400035 Enhanced Home NodeB / eNodeB (EHNB)
- 1804: SP#47 completed
- 1805: SP#47 completed. Chosen solution has no normative impacts
- 1806: SP#49 completed
- 1807: CP#52 completed. SP#47 Stage 2 completed. Triggered by TR 23.894 (UID_370050 Study on System enhancements for the use of IMS services in local breakout)
- 1808: SP#47 completed
- 1809: CP#51 completion 03/11=>06/11. WID updated CP-100327=>CP-110134
- 1810: CP#52 completed
- 1811: CP#51 completed. WID updated CP-100327=>CP-110134
- 1812: CP#51 stopped (CT4 specs not impacted). WID updated CP-100327=>CP-110134
- 1813: SP#52 completed. Stage 3: Linked to CT3 TS 29.079 OMR within the IMS; Stage 3 (UID_480110)
- 1814: CP#52 completed. SP#49 completed. Source of external requirements: ETSI TISPAN TS 181.019 (Business Communication Requirements)
- 1815: SP#47 completed
- 1816: SP#49 completed
- 1817: CP#52 completed
- 1818: CP#51 completed. SP#49 Stage 2 completed. Related to Rel-10 UID_470049 Study on S2b mobility based on GTP (TR23.834), UID_350027 SAE for support for non-3GPP accesses. Stage1 in Rel-8 UID_320022 Reqs for evolution of 3GPP system architecture (AIPN-SAE)
- 1819: SP#49 completed
- 1820: CP#51 Stage 3 completed
- 1821: CP#51 completed
- 1822: CP#51 completed
- 1823: CP#50 completed
- 1824: CP#51 completed. SP#50 Stage 2 completed. Triggered by the SA1,SA2 Rel-10 TR 23.813 Study on Policy solutions and enhancements (FS_PP) UID_440047. Provides Video Call seamless service continuity for 3G/LTE terminal user
- 1825: SP#51 updated WID SP-100702=>SP-110196. SP#49 work completed as SA2 CRs approved under TEI10 (SP-10557)
- 1826: CP#51 completed

| ID | WBS | Task | Duration | Start | Finish | Complete | Baseline start | Baseline finish | Baseline duration | Constraint | Resources | Work | Actual work | Acronym | PCG approved | WI rapporteur name | WI rapporteur e-mail | Release | TSG approved | MCC resp | Acronym_3GU_Export | PCG stopped | TSG stopped |
| --- | --- | --- | --- | --- | --- | --- | --- | --- | --- | --- | --- | --- | --- | --- | --- | --- | --- | --- | --- | --- | --- | --- | --- |
| 1827 | 455 | **Lawful Interception in the 3GPP Rel-10** | 315d? | 2010-03-25 A | 2011-06-08 A | 100% | 2010-03-25 | 2011-06-08 | 315d? |  | S3 | 20480h | 20480h | LI10 | PCG-24 | PIDS, BT | Koen Jaspers (k.b.jaspers@minjus.nl), alex.leadbeater@bt.com | Rel-10 | SP-47 | Mirko | LI10 |  |  |
| 1828 | 455.1 | LI for CAT (Customer Alerting Tones) | 315d? | 2010-03-25 A | 2011-06-08 A | 100% | 2010-03-25 | 2011-06-08 | 315d? | finish no earlier than 2011-03-23 | S3 | 2520h | 2520h | LI10 | PCG-24 | PIDS, BT | Koen Jaspers (k.b.jaspers@minjus.nl), alex.leadbeater@bt.com | Rel-10 | SP-47 | Mirko |  |  |  |
| 1829 | 455.2 | LI for CRS (Customized Ringing Signal) | 315d? | 2010-03-25 A | 2011-06-08 A | 100% | 2010-03-25 | 2011-06-08 | 315d? | finish no earlier than 2011-03-23 | S3 | 2520h | 2520h | LI10 | PCG-24 | PIDS, BT | Koen Jaspers (k.b.jaspers@minjus.nl), alex.leadbeater@bt.com | Rel-10 | SP-47 | Mirko |  |  |  |
| 1830 | 455.3 | LI for EPS enhancements | 315d? | 2010-03-25 A | 2011-06-08 A | 100% | 2010-03-25 | 2011-06-08 | 315d? | finish no earlier than 2011-03-23 | S3 | 2520h | 2520h | LI10 | PCG-24 | PIDS, BT | Koen Jaspers (k.b.jaspers@minjus.nl), alex.leadbeater@bt.com | Rel-10 | SP-47 | Mirko |  |  |  |
| 1831 | 455.4 | LI for VCC (Voice Call Continuity) | 260d? | 2010-03-25 A | 2011-03-23 A | 100% | 2010-03-25 | 2011-03-23 | 260d? | finish no earlier than 2011-03-23 | S3 | 2080h | 2080h | LI10 | PCG-24 | PIDS, BT | Koen Jaspers (k.b.jaspers@minjus.nl), alex.leadbeater@bt.com | Rel-10 | SP-47 | Mirko |  |  |  |
| 1832 | 455.5 | LI for MEDIASEC (IMS Media security) | 260d? | 2010-03-25 A | 2011-03-23 A | 100% | 2010-03-25 | 2011-03-23 | 260d? | finish no earlier than 2011-03-23 | S3 | 2080h | 2080h | LI10 | PCG-24 | PIDS, BT | Koen Jaspers (k.b.jaspers@minjus.nl), alex.leadbeater@bt.com | Rel-10 | SP-47 | Mirko |  |  |  |
| 1833 | 455.6 | LI for H(e)NB also with Local IP Access and Selected IP Traffic Offload (LIPA, SIPTO) | 260d? | 2010-03-25 A | 2011-03-23 A | 100% | 2010-03-25 | 2011-03-23 | 260d? | finish no earlier than 2011-03-23 | S3 | 2080h | 2080h | LI10 | PCG-24 | PIDS, BT | Koen Jaspers (k.b.jaspers@minjus.nl), alex.leadbeater@bt.com | Rel-10 | SP-47 | Mirko |  |  |  |
| 1834 | 455.7 | LI for MBMS enhancements | 260d? | 2010-03-25 A | 2011-03-23 A | 100% | 2010-03-25 | 2011-03-23 | 260d? | finish no earlier than 2011-03-23 | S3 | 2080h | 2080h | LI10 | PCG-24 | PIDS, BT | Koen Jaspers (k.b.jaspers@minjus.nl), alex.leadbeater@bt.com | Rel-10 | SP-47 | Mirko |  |  |  |
| 1835 | 455.8 | LI for LCLS (Local Call Local Switch) | 260d? | 2010-03-25 A | 2011-03-23 A | 100% | 2010-03-25 | 2011-03-23 | 260d? | finish no earlier than 2011-03-23 | S3 | 2080h | 2080h | LI10 | PCG-24 | PIDS, BT | Koen Jaspers (k.b.jaspers@minjus.nl), alex.leadbeater@bt.com | Rel-10 | SP-47 | Mirko |  |  |  |
| 1836 | 456 | Optimization of IMS based PSS and MBMS User Service | 260d? | 2010-03-25 A | 2011-03-23 A | 100% | 2010-03-25 | 2011-03-23 | 260d? | finish no earlier than 2011-03-23 | S4 | 2080h | 2080h | OPT_IMS_PSS_MBMS_US | PCG-24 | Ericsson | markus.kampmann@ericsson.com | Rel-10 | SP-47 | Paolo | OPT_IMS_PSS_MBMS_US |  |  |
| 1837 | 457 | **HTTP-based Streaming and Download Services** | 392d? | 2010-03-25 A | 2011-09-21 A | 100% | 2010-03-25 | 2011-09-21 | 392d? |  | S4; IETF | 10468.8h | 10468.8h | HTTP_SDS | PCG-24 | Qualcomm | Thomas Stockhammer (c_tstock@qualcomm.com) | Rel-10 | SP-47 | Paolo | HTTP_SDS |  |  |
| 1838 | 457.1 | HTTP-based Streaming and Download Services in 3GPP | 315d? | 2010-03-25 A | 2011-06-08 A | 100% | 2010-03-25 | 2011-06-08 | 315d? | finish no earlier than 2011-05-26 | S4 | 2520h | 2520h | HTTP_SDS | PCG-24 | Qualcomm | Thomas Stockhammer (c_tstock@qualcomm.com) | Rel-10 | SP-47 | Paolo |  |  |  |
| 1839 | 457.2 | (IETF) HTTP-based Streaming and Download Services in 3GPP | 211.6d? | 2010-03-25 A | 2011-09-21 A | 100% | 2010-03-25 | 2011-09-21 | 211.6d? | start no earlier than 2010-03-25 | S4-IETF | 1676.8h | 1676.8h | HTTP_SDS | PCG-27 |  |  | Rel-10 | CP-52 | Paolo |  |  |  |
| 1840 | 458 | PSS and MBMS enhancements | 205d? | 2010-06-10 A | 2011-03-23 A | 100% | 2010-06-10 | 2011-03-23 | 205d? | finish no earlier than 2011-03-23 | S4 | 1640h | 1640h | MBS_Enh | PCG-25 | Ericsson | Markus.Kampmann@ericsson.com | Rel-10 | SP-48 | Paolo | MBS_Enh |  |  |
| 1841 | 459 | Enhancements and Addition of Audio Tests to 26.131 and 26.132 | 260d? | 2010-06-10 A | 2011-06-08 A | 100% | 2010-06-10 | 2011-06-08 | 260d? | finish no earlier than 2011-06-08 | S4 | 2080h | 2080h | EAAT | PCG-25 | Vodafone | ramin.afchar@vodafone.com | Rel-10 | SP-48 | Paolo | EAAT |  |  |
| 1842 | 460 | Video Coding Enhancements in MTSI | 3d? | 2011-03-21 A | 2011-03-23 A | 100% | 2011-03-21 | 2011-03-23 | 3d? | start no earlier than 2011-03-21 | S4 | 24h | 24h | VCEM | PCG-26 | Ericsson | frederic.gabin@ericsson.com | Rel-10 | SP-51 | Paolo | VCEM |  |  |
| 1843 | 461 | **Rel-10 Operations, Administration, Maintenance and Provisioning (OAM&P)** | 467d? | 2009-12-10 A | 2011-09-21 A | 100% | 2009-12-10 | 2011-09-21 | 467d? |  | S5; C4 | 54144h | 54144h | OAM10 | PCG-24 |  |  | Rel-10 | SP-46 | Mirko | OAM10 |  |  |
| 1844 | 461.1 | **Rel-10 Network Infrastructure Management** | 467d? | 2009-12-10 A | 2011-09-21 A | 100% | 2009-12-10 | 2011-09-21 | 467d? |  | S5 | 14592h | 14592h | OAM10-NIM | PCG-24 |  |  | Rel-10 | SP-46 | Mirko | OAM10-NIM |  |  |
| 1845 | 461.1.1 | Common RAT Network Resource Model (NRM) | 390d? | 2009-12-10 A | 2011-06-08 A | 100% | 2009-12-10 | 2011-06-08 | 390d? | finish no earlier than 2011-06-08 | S5 | 3120h | 3120h | RAT_NRM_common | PCG-24 | Ericsson | robert.petersen@ericsson.com | Rel-10 | SP-46 | Mirko | RAT_NRM_common |  |  |
| 1846 | 461.1.2 | IRP Solution Set specification organisation improvements | 260d? | 2010-03-25 A | 2011-03-23 A | 100% | 2010-03-25 | 2011-03-23 | 260d? | finish no earlier than 2011-03-23 | S5 | 2080h | 2080h | OAM-IRP-SS | PCG-24 | Nokia Siemens Networks, Huawei | Jörg Schmidt (J.Schmidt@nsn.com), Lan Zou (zlan@huawei.com) | Rel-10 | SP-47 | Mirko | OAM-IRP-SS |  |  |
| 1847 | 461.1.3 | Deleted - Service Oriented Architecture (SOA) for IRP continuation from Rel-9 | 260d? | 2010-03-25 A | 2011-03-23 A | 100% | 2010-03-25 | 2011-03-23 | 260d? | finish no earlier than 2011-06-08 | S5 | 2080h | 2080h | OAM-SOA-IRP | PCG-24 | Nokia Siemens Networks, Ericsson | Jörg Schmidt (J.Schmidt@NSN.com), edwin.tse@ericsson.com | Rel-10 | SP-47 | Mirko | OAM-SOA-IRP | PCG-26 | SP-51 |
| 1848 | 461.1.4 | IRP Overview, Profiles & Usage Guide | 260d? | 2010-06-10 A | 2011-06-08 A | 100% | 2010-06-10 | 2011-06-08 | 260d? | finish no earlier than 2011-06-08 | S5 | 2080h | 2080h | OAM-NIM-IRP_OPU | PCG-25 | Nokia Siemens Networks | Jörg Schmidt (J.Schmidt@NSN.com) | Rel-10 | SP-48 | Mirko | OAM-NIM-IRP_OPU |  |  |
| 1849 | 461.1.5 | Alarm Correlation and Root Cause Analysis | 133d? | 2011-03-23 A | 2011-09-21 A | 100% | 2011-03-23 | 2011-09-21 | 133d? | finish no earlier than 2011-09-21 | S5 | 1048h | 1048h | OAM-AC-RCA | PCG-26 | Ericsson | brendan.hassett@ericsson.com | Rel-10 | SP-51 | Mirko | OAM-AC-RCA |  |  |
| 1850 | 461.1.6 | Inventory Management Network Resource Model enhancements | 56d? | 2011-03-23 A | 2011-06-08 A | 100% | 2011-03-23 | 2011-06-08 | 56d? | start no earlier than 2011-03-23 | S5 | 448h | 448h | OAM-IM-NMR | PCG-26 | Nokia Siemens Networks | olaf.pollakowski@nsn.com | Rel-10 | SP-51 | Mirko | OAM-IM-NMR |  |  |

Notes:
- 1827: SP#52 completed / Impacted TSs and TRs: 33.106 (LI requirements), 33.107 (LI architecture and functions), 33.108 (Handover interface for LI)
- 1828: SP#52 completed / Impacted TSs and TRs: 33.106, 33.107, 33.108
- 1829: SP#52 completed / Impacted TSs and TRs: 33.106, 33.107, 33.108
- 1830: SP#52 completed / Impacted TSs and TRs: 33.106, 33.107, 33.108
- 1831: SP#51 completed / Impacted TSs and TRs: 33.106, 33.107, 33.108
- 1832: SP#51 completed / Impacted TSs and TRs: 33.106, 33.107, 33.108
- 1833: SP#51 completed / Impacted TSs and TRs: 33.106, 33.107, 33.108
- 1834: SP#51 completed / Impacted TSs and TRs: 33.106, 33.107, 33.108
- 1835: SP#51 completed / Impacted TSs and TRs: 33.106, 33.107, 33.108
- 1836: SP#51 completed. Work to enhance UID_430046 Rel-9 IMS_PSS_MBMS_US_EXT / Impacted TSs and TRs: 26.237
- 1837: SP#52 completed. Work to enhance UID_430038 Rel-9 PSS and MBMS extensions
- 1838: SP#52 completed / Impacted TSs and TRs: 26.234, 26.244, 26.346, new TS 26.247
- 1839: SP#53/IETF#81: Draft not included in 3GPP documentation. LM: IETF RFC added / Impacted TSs and TRs: RFC 6381 (was draft-gellens-mime-bucket-bis)
- 1840: SP#51 completed. Linked to Rel-9 Feature UID_430038 PSS and MBMS extensions (PMA-MBS_Ext). / Impacted TSs and TRs: 26.234, 26.346
- 1841: SP#52 completed. Reduce fragmentation in acoustic testing (3GPP SA4, ETSI STQ, GCF CAG, CTIA) & Review existing acoustic tests to determine need for new spec / Impacted TSs and TRs: 26.131, 26.132
- 1842: SP#51 completed. Linked to Rel-7 UID_7040 Multimedia Telephony Service for IMS - Media handling and interaction in MTSI (MTSI-MHI) / Impacted TSs and TRs: 26.114
- 1843: OAM10 is an umbrella Feature also for OAM&P related TEI10 type of changes that are not part of any other dedicated feature/WI / Impacted TSs and TRs: TR 30.820
- 1844: umbrella BB
- 1845: SP#52 completed. Share equipment btw several RATs (RET,TMA,repeaters) to reduce costs. With existing modelling is difficult to see that several cells are affected when an antenna tilt is changed etc / Impacted TSs and TRs: 32.616, 32.642, 32.646, 32.652, 32.656, 32.762, 32.766 new (32.791, 32.792, 32.796)
- 1846: SP#51 completed / Impacted TSs and TRs: 32.153, new (32.111-6,32.126,32.176,32.306,32.316,32.326,32.336,32.346,32.356,32.366,32.376,32.386,32.396,32.416,32.446,32.506/26/36,32.606,32.616,32.626,32.636,32.646,32.656,32.666,32.676,32.696,32.716,32.726,32.736,32.746,32.756,32.766,32.776,32.786)
- 1847: SP#51 work stopped (Reason: lack of progress). Continuation of Rel-9 UID_440065 SOA for IRP (covering SOA Architecture & SOA-supporting Solution Set) to address SOA conforming Registration & Discovery capabilities / Impacted TSs and TRs: 32.101, 32.150
- 1848: SP#52 completed. Updated WID SP-100777=>SP-110277 / Impacted TSs and TRs: new TS 32.103
- 1849: SP#53 completed. Triggered by Rel-10 TR 32.832 Study on Alarm Correlation and Alarm Root Cause Analysis UID_480045 & TR 32.829 Study on Harmonization of 3GPP Alarm IRP and TMF Interface Program Fault Management UID_460038 / Impacted TSs and TRs: 32.111-1, 32.111-2, 32.111-6
- 1850: SP#52 completed. Inventory NRM specified in Rel-6 is mainly hardware related. Rel-10 TR 32.828 recommends extending the scope of inventory NRM. Additionally, NGMN Top OPE Recs, v1.0 sets inventory enhancements as one of top 10 priority items / Impacted TSs and TRs: 32.690, 32.691, 32.692, 32.696

| ID | WBS | Task | Duration | Start | Finish | Complete | Baseline start | Baseline finish | Baseline duration | Constraint | Resources | Work | Actual work | Acronym | PCG approved | Release | TSG approved | MCC resp | Special Focus Doc | Acronym_3GU_Export | WI rapporteur name |
| --- | --- | --- | --- | --- | --- | --- | --- | --- | --- | --- | --- | --- | --- | --- | --- | --- | --- | --- | --- | --- | --- |
| 1851 | 461.2 | **Rel-10 Self-Organizing Networks (SON) - OAM aspects** | 390d? | 2009-12-10 A | 2011-06-08 A | 100% | 2009-12-10 | 2011-06-08 | 390d? |  | S5 | 11000h | 11000h | OAM10-SON | PCG-24 | Rel-10 | SP-46 | Mirko | SON | OAM10-SON |  |
| 1852 | 461.2.1 | SON Self-optimization management continuation | 390d? | 2009-12-10 A | 2011-06-08 A | 100% | 2009-12-10 | 2011-06-08 | 390d? | finish no earlier than 2011-03-23 | S5 | 3120h | 3120h | LTE-SON-OAM_SO | PCG-24 | Rel-10 | SP-46 | Mirko | SON | LTE-SON-OAM_SO | Huawei |
| 1853 | 461.2.2 | SON Self-healing management | 335d? | 2009-12-10 A | 2011-03-23 A | 100% | 2009-12-10 | 2011-03-23 | 335d? | finish no earlier than 2011-03-23 | S5 | 2680h | 2680h | LTE-SON-OAM_SH | PCG-24 | Rel-10 | SP-46 | Mirko | SON | LTE-SON-OAM_SH | ZTE |
| 1854 | 461.2.3 | OAM aspects of Energy Saving in Radio Networks | 260d? | 2010-03-25 A | 2011-03-23 A | 100% | 2010-03-25 | 2011-03-23 | 260d? | finish no earlier than 2011-03-23 | S5 | 2080h | 2080h | OAM-ES | PCG-24 | Rel-10 | SP-47 | Mirko | SON | OAM-ES | Nokia Siemens Networks |
| 1855 | 461.3 | Rel-10 Subscription Management (SuM) evolution | 260d? | 2010-03-25 A | 2011-03-23 A | 100% | 2010-03-25 | 2011-03-23 | 260d? | finish no earlier than 2011-03-23 | S5 | 2080h | 2080h | OAM10-SuM | PCG-24 | Rel-10 | SP-47 | Mirko |  | OAM10-SuM | Ericsson |
| 1856 | 461.4 | **Rel-10 Performance Management** | 315d? | 2010-03-25 A | 2011-06-08 A | 100% | 2010-03-25 | 2011-06-08 | 315d? |  | S5; C4 | 19000h | 19000h |  | PCG-24 | Rel-10 | SP-47 | Mirko |  |  |  |
| 1857 | 461.4.1 | Key Performance Indicators (KPIs) for IMS | 260d? | 2010-03-25 A | 2011-03-23 A | 100% | 2010-03-25 | 2011-03-23 | 260d? | finish no earlier than 2011-03-23 | S5 | 2080h | 2080h | OAM-PM-KPI_IMS | PCG-24 | Rel-10 | SP-47 | Mirko |  | OAM-PM-KPI_IMS | China Mobile |
| 1858 | 461.4.2 | Key Performance Indicators (KPIs) for EPC | 260d? | 2010-03-25 A | 2011-03-23 A | 100% | 2010-03-25 | 2011-03-23 | 260d? | finish no earlier than 2011-03-23 | S5 | 2080h | 2080h | OAM-PM-KPI_EPC | PCG-24 | Rel-10 | SP-47 | Mirko |  | OAM-PM-KPI_EPC | China Mobile |
| 1859 | 461.4.3 | **Management of UE based network performance measurements** | 315d? | 2010-03-25 A | 2011-06-08 A | 100% | 2010-03-25 | 2011-06-08 | 315d? |  | S5; C4 | 7720h | 7720h | OAM-PM-UE | PCG-24 | Rel-10 | SP-47 | Mirko |  | OAM-PM-UE | Huawei, Nokia Siemens Networks, Ericsson |
| 1860 | 461.4.3.1 | SA5 aspects of Management of UE based network performance measurements | 315d? | 2010-03-25 A | 2011-06-08 A | 100% | 2010-03-25 | 2011-06-08 | 315d? | finish no earlier than 2011-06-08 | S5 | 2520h | 2520h |  | PCG-24 | Rel-10 | SP-47 | Mirko |  |  | Huawei, Nokia Siemens Networks, Ericsson |
| 1861 | 461.4.3.2 | CN aspects of Management of UE based network performance measurements | 20d? | 2011-02-21 A | 2011-03-18 A | 100% | 2011-02-21 | 2011-03-18 | 20d? | start no earlier than 2011-02-21 | C4 | 160h | 160h |  | PCG-26 | Rel-10 | CP-51 | Kimmo |  |  | Nokia Siemens Networks |
| 1862 | 461.4.4 | 3G HNB and LTE HeNB Subsystem performance measurements | 260d? | 2010-03-25 A | 2011-03-23 A | 100% | 2010-03-25 | 2011-03-23 | 260d? | finish no earlier than 2011-03-23 | S5 | 2080h | 2080h | OAM-PM-HeNS | PCG-24 | Rel-10 | SP-47 | Mirko | HNB | OAM-PM-HeNS | China Mobile |
| 1863 | 462 | **Rel-10 Charging Management small Enhancements** | 470d? | 2009-06-04 A | 2011-03-23 A | 100% | 2009-06-04 | 2011-03-23 | 470d? |  | S5 | 7520h | 7520h | CH10 | PCG-24 | Rel-10 | SP-47 | Mirko | WLAN | CH10 |  |
| 1864 | 462.1 | IWLAN mobility charging | 470d? | 2009-06-04 A | 2011-03-23 A | 100% | 2009-06-04 | 2011-03-23 | 470d? | finish no earlier than 2011-03-23 | S5 | 3760h | 3760h | eIWLAN_Mob | PCG-23 | Rel-10 | SP-44 | Mirko | WLAN | eIWLAN_Mob | Orange |
| 1865 | 463 | **Advice of Charge (AoC) service support enhancements** | 312d? | 2010-03-25 A | 2011-06-03 A | 100% | 2010-03-25 | 2011-06-03 | 312d? |  | S5; C1 | 8560h | 8560h | eAoC | PCG-24 | Rel-10 | SP-47 | Mirko |  | eAoC | Deutsche Telekom |
| 1866 | 463.1 | SA5 part - AoC enhancements | 260d? | 2010-03-25 A | 2011-03-23 A | 100% | 2010-03-25 | 2011-03-23 | 260d? | finish no earlier than 2011-03-23 | S5 | 2080h | 2080h | eAoC | PCG-24 | Rel-10 | SP-47 | Mirko |  |  | Deutsche Telekom |
| 1867 | 463.2 | CT1 part - AoC enhancements (Stage 3) | 186d? | 2010-09-17 A | 2011-06-03 A | 100% | 2010-09-17 | 2011-06-03 | 186d? | finish no earlier than 2011-06-03 | C1 | 1488h | 1488h | eAoC | PCG-25 | Rel-10 | CP-49 | Frederic |  |  | Deutsche Telekom |
| 1868 | 464 | IMS Stage 3 IETF Protocol Alignment - phase 4 | 261d? | 2010-03-19 A | 2011-03-18 A | 100% | 2010-03-19 | 2011-03-18 | 261d? | finish no earlier than 2011-03-18 | C1 | 2088h | 2088h | IMSProtoc4 | PCG-24 | Rel-10 | CP-47 | Frederic |  | IMSProtoc4 | Alcatel-Lucent |
| 1869 | 465 | Enhanced User Data Convergence (UDC) Model | 206d? | 2010-06-04 A | 2011-03-18 A | 100% | 2010-06-04 | 2011-03-18 | 206d? | finish no earlier than 2011-03-18 | C4 | 1648h | 1648h | eUDC | PCG-25 | Rel-10 | CP-48 | Kimmo |  | eUDC | China Mobile |
| 1870 | 466 | **Further improvements of II-NNI Stage 3 based on operational feedback and evolution of other specifications** | 724d? | 2010-06-04 A | 2013-03-01 A | 100% | 2010-06-04 | 2013-03-01 | 724d? |  | C3 | 10625.9h | 10625.9h | II-NNI2 | PCG-25 | Rel-10 | CP-48 | Adrian |  | II-NNI2 | Orange |
| 1871 | 466.1 | Further improvements of II-NNI Stage 3 | 206d? | 2010-06-04 A | 2011-03-18 A | 100% | 2010-06-04 | 2011-03-18 | 206d? | start no earlier than 2010-06-04 | C3 | 1648h | 1648h | II-NNI2 | PCG-25 | Rel-10 | CP-48 | Adrian |  |  | Orange |
| 1872 | 466.2 | (IETF) Further improvements of II-NNI Stage 3 (RFC 6794) | 230d? | 2012-04-20 A | 2013-03-01 A | 100% | 2012-04-20 | 2013-03-01 | 230d? | finish no earlier than 2013-03-01 | C3-IETF | 1832h | 1832h | II-NNI2 | PCG-29 | Rel-10 | CP-56 | Adrian |  |  | Lionel Morand |
| 1873 | 466.3 | (IETF) Further improvements of II-NNI Stage 3 (RFC 6809) | 170d? | 2012-04-20 A | 2012-12-07 A | 100% | 2012-04-20 | 2012-12-07 | 170d? | finish no earlier than 2012-12-04 | C3-IETF | 1353.89h | 1353.89h | II-NNI2 | PCG-29 | Rel-10 | CP-56 | Adrian |  |  | christer.holmberg@ericsson.com |
| 1874 | 467 | AT Commands for IMS-configuration | 206d? | 2010-06-04 A | 2011-03-18 A | 100% | 2010-06-04 | 2011-03-18 | 206d? |  | C1 | 1648h | 1648h | AT_IMS | PCG-25 | Rel-10 | CP-48 | Frederic |  | AT_IMS | Ericsson |
| 1875 | 468 | AT Commands for USIM Application Toolkit (USAT) | 131d? | 2010-09-17 A | 2011-03-18 A | 100% | 2010-09-17 | 2011-03-18 | 131d? |  | C1 | 52.4h | 52.4h | AT_UICC | PCG-25 | Rel-10 | CP-49 | Frederic |  | AT_UICC | ST-Ericsson |
| 1876 | 469 | Communication Control for IMS by USIM (Stage 3) | 131d? | 2010-09-17 A | 2011-03-18 A | 100% | 2010-09-17 | 2011-03-18 | 131d? | start no earlier than 2010-09-17 | C6 | 1048h | 1048h | CC_IMS_USIM | PCG-25 | Rel-10 | CP-49 | Xavier |  | CC_IMS_USIM | Gemalto |
| 1877 | 470 | Dynamic view of SIP message for Inter-IMS Network to Network Interface (II-NNI) (Stage 3) | 126d? | 2010-12-10 A | 2011-06-03 A | 100% | 2010-12-10 | 2011-06-03 | 126d? | finish no earlier than 2011-06-03 | C3 | 1008h | 1008h | NNI_DV | PCG-26 | Rel-10 | CP-50 | Adrian |  | NNI_DV | NTT |
| 1878 | 471 | Introduction of Smart Card Web Server launch functionality | 71d? | 2010-12-10 A | 2011-03-18 A | 100% | 2010-12-10 | 2011-03-18 | 71d? | finish no earlier than 2011-03-18 | C6 | 568h | 568h | SCWS_L | PCG-26 | Rel-10 | CP-50 | Xavier |  | SCWS_L | Telecom Italia |
| 1879 | 472 | USAT using AT Commands | 71d? | 2010-12-10 A | 2011-03-18 A | 100% | 2010-12-10 | 2011-03-18 | 71d? | finish no earlier than 2011-03-18 | C6 | 568h | 568h | USAT_AT | PCG-26 | Rel-10 | CP-50 | Xavier |  | USAT_AT | Giesecke & Devrient |

Notes:
- 1851: umbrella BB
- 1852: SP#52 completed. Cont'd Rel-9 SON self-optimization management UID_390007 / Impacted TSs and TRs: 32.425, 32.521, 32.522, 32.526, 32.762, 32.766 / WI rapporteur e-mail: Lan Zou (zlan@huawei.com)
- 1853: SP#51 completed. WID updated SP-100776=>SP-110150. Work moved to Rel-10 after split of the Rel-9 UID_390007 SON self-optimization (removed Self-Healing handling) / Impacted TSs and TRs: 32.522, 32.526, 32.762, 32.766, new TS 32.541 / WI rapporteur e-mail: zhu.weihong@zte.com.cn
- 1854: SP#51 completed. WID updated SP-100226=>SP-110128. Triggered by Rel-10 TR 32.826 Study on Telecommunication Management; Energy Savings Management (FS_OAM_ESM) UID_430044 / Impacted TSs and TRs: 32.425, 32.522, 32.526, 32.626, 32.762, 32.766, new TS 32.551 / WI rapporteur e-mail: clemens.suerbaum@nsn.com
- 1855: SP#51 completed / Impacted TSs and TRs: 32.172, 32.175, 32.176 / WI rapporteur e-mail: leo.yang@ericsson.com
- 1856: umbrella BB
- 1857: SP#51 completed / Impacted TSs and TRs: new 32.454 / WI rapporteur e-mail: Li Jian (lijian@chinamobile.com), Liang Shuangchun (liangshuangchun@cmdi.chinamobile.com)
- 1858: SP#51 completed / Impacted TSs and TRs: new 32.455 / WI rapporteur e-mail: Li Jian (lijian@chinamobile.com), Liang Shuangchun (liangshuangchun@cmdi.chinamobile.com)
- 1859: SP#52 completed. Stage 2/3. Linked to UID_460003 Minimization of drive tests for E-UTRAN and UTRAN (MDT_UMTSLTE) / WI rapporteur e-mail: Zou Lan (zlan@huawei.com), gyula.bodog@nsn.com, ulf.hubinette@ericsson.com
- 1860: SP#52 completed / Impacted TSs and TRs: 32.421, 32.422, 32.423, 32.441, 32.442, 32.446 / WI rapporteur e-mail: Zou Lan (zlan@huawei.com), gyula.bodog@nsn.com, ulf.hubinette@ericsson.com
- 1861: CP#51 completed under the SA5 WI code / Impacted TSs and TRs: 23.008 (CR#0330), 29.002 (CR#1007), 29.230 (CR#0207), 29.272 (CR#0329) / WI rapporteur e-mail: ulrich.wiehe@nsn.com
- 1862: SP#51 completed / Impacted TSs and TRs: 32.582, 32.592, new (32.452, 32.453) / WI rapporteur e-mail: Chen Gang (chengang@chinamobile.com)
- 1863: CH10 is an umbrella Feature also for OAM&P related TEI10 type of changes that are not part of any other dedicated feature/WI / Impacted TSs and TRs: TR 30.820
- 1864: SP#51 completed. RAT differentiation for charging. Completes Rel-8 Feature IWLAN_Mob UID_370049 Mobility between 3GPP-WLAN Interworking and 3GPP Systems. Cooperation with CT1,CT3 on affected protocols / Impacted TSs and TRs: 32.240, 32.252, 32.298, 32.299 / WI rapporteur e-mail: Jean-Luc Garcia (jl.garcia@orange-ftgroup.com)
- 1865: CP#52 completed. SP#51 completed SA5. Continuation of Rel-8 BB UID_80042: Advice of Charge (AoC) support in IMS Charging (IMSTSS). Stage 2/3 work / WI rapporteur e-mail: matthias.seibel@telekom.de
- 1866: SP#51 completed. SA1 Stage 1 in 22.115 / Impacted TSs and TRs: 32.275, 32.280, 32.298, 32.299 / WI rapporteur e-mail: matthias.seibel@telekom.de
- 1867: CP#52 completed. SA1 Stage 1 in 22.115, 22.173, 22.024. Add mobile-specific CAI format and volume charging elements. Extensions to existing AoC XML / Impacted TSs and TRs: 24.647 / WI rapporteur e-mail: reinhard.lauster@t-mobile.at
- 1868: CP#51 completed. Ensure protocol alignment between 3GPP Stage 3 IMS work and IETF. Review capabilities provided in SIP by IETF and document whether these capabilities are supported in the IM CN Subsystem or not / Impacted TSs and TRs: 23.218, 24.229, 24.930 / WI rapporteur e-mail: keith.drage@alcatel-lucent.com
- 1869: CP#51 completed. Specify CRUD (Create/Read/Update/Delete) operations based on SOAP protocol, which may be used by the applications having no high real-time requirement to the data access operations / Impacted TSs and TRs: 29.335 / WI rapporteur e-mail: Lan Sizhong (lansizhong@chinamobile.com)
- 1870: Improvements of Rel-9 Feature UID_440027 Operational description of the Inter-IMS Network to Network Interface (II-NNI) / WI rapporteur e-mail: beata.dobrowolska@orange-ftgroup.com
- 1871: CP#51 completed / Impacted TSs and TRs: 29.165 / WI rapporteur e-mail: beata.dobrowolska@orange-ftgroup.com
- 1872: CP#59 completed AUTH 48 RFC-to-be-6794 / Impacted TSs and TRs: RFC 6794 (was draft-ietf-sip-session-policy-framework) / WI rapporteur e-mail: Lionel Morand
- 1873: CP#58 completed / Impacted TSs and TRs: RFC 6809 (was draft-ietf-sipcore-proxy-feature) / WI rapporteur e-mail: Christer Holmberg
- 1874: CP#51 completed. Specify 1) IMS-related AT-commands to configure MT and 2) IMS-related unsolicited response codes from MT to present to end-user / Impacted TSs and TRs: 27.007 / WI rapporteur e-mail: atle.monrad@ericsson.com
- 1875: CP#51 completed / Impacted TSs and TRs: 27.007 / WI rapporteur e-mail: magnus.mk.karlsson@stericsson.com
- 1876: CP#51 completed. Stage 1 in TS 22.038 USAT service description. Linked to CT6's UID_1273 Rel-5 BB Provisioning of IP-based multimedia services (24.229, 31.103) and UID_390021 Rel-8 BB CT6 aspects of SAE (31.102, 31.111) / Impacted TSs and TRs: 31.102, 31.103, 31.111 / WI rapporteur e-mail: Denis.Lheriteau@gemalto.com
- 1877: CP#52 completed. Linked to CT3 Rel-10 Feature UID_480014 Further improvements of II-NNI Stage 3 based on operational feedback and evolution of other specifications (II-NNI2) / Impacted TSs and TRs: 29.165 / WI rapporteur e-mail: arai.kenjiro@lab.ntt.co.jp
- 1878: CP#51 completed. Define a solution which allows enabling to launch Smart Card Web Server services in an easy and simple manner / Impacted TSs and TRs: 31.102 / WI rapporteur e-mail: davide.pratone@telecomitalia.it
- 1879: CP#51 completed. Stage 3 based on SA1 22.038CR#37r1 (Make USAT proactive capability reqs applicable to ME as a whole without regard to any particular configuration; e.g. a modem connected to an external display) / Impacted TSs and TRs: Stage 3 31.102, 31.111 / WI rapporteur e-mail: enric.fort@gi-de.com

| ID | WBS | Task | Type | Duration | Start | Finish | Complete | Baseline start | Baseline finish | Baseline duration | Constraint | Resources | Work | Actual work | Acronym | PCG approved | WI rapporteur name | WI rapporteur e-mail | Release | TSG approved | MCC resp | Acronym_3GU_Export | Status Report | Special Focus Doc | PCG stopped | TSG stopped |
| --- | --- | --- | --- | --- | --- | --- | --- | --- | --- | --- | --- | --- | --- | --- | --- | --- | --- | --- | --- | --- | --- | --- | --- | --- | --- | --- |
| 1880 | 473 | **Single Radio Voice Call Continuity (SRVCC) enhancements (Stage 3)** |  | 528d? | 2010-12-10 A | 2012-12-07 A | 100% | 2010-12-10 | 2012-12-07 | 528d? |  | C1; C4; IETF | 17295.4h | 17295.4h | eSRVCC | PCG-26 | China Mobile | Jiang Y (jiangyi@chinamobile.com) | Rel-10 | CP-50 | Frederic | eSRVCC |  |  |  |  |
| 1881 | 473.1 | CT1 part of Stage 3 for SRVCC enhancements |  | 71d? | 2010-12-10 A | 2011-03-18 A | 100% | 2010-12-10 | 2011-03-18 | 71d? | finish no earlier than 2011-03-18 | C1 | 568h | 568h | eSRVCC | PCG-26 | China Mobile | Jiang Y (jiangyi@chinamobile.com) | Rel-10 | CP-50 | Frederic |  |  |  |  |  |
| 1882 | 473.2 | CT4 part of Stage 3 for SRVCC enhancements |  | 71d? | 2010-12-10 A | 2011-03-18 A | 100% | 2010-12-10 | 2011-03-18 | 71d? | finish no earlier than 2011-03-18 | C4 | 568h | 568h | eSRVCC | PCG-26 | China Mobile | Jiang Y (jiangyi@chinamobile.com) | Rel-10 | CP-50 | Kimmo |  |  |  |  |  |
| 1883 | 473.3 | (IETF) CT1 part of Stage 3 for SRVCC enhancements (RFC 6809) |  | 436.8d? | 2010-12-10 A | 2012-12-07 A | 100% | 2010-12-10 | 2012-12-07 | 436.8d? | finish no earlier than 2013-03-01 | C1-IETF | 3487.38h | 3487.38h | eSRVCC | PCG-27 | christer.holmberg@ericsson.com | christer.holmberg@ericsson.com | Rel-10 | CP-52 | Frederic |  |  |  |  |  |
| 1884 | 474 | **Single Radio Voice Call Continuity (SRVCC) in alerting phase (Stage 3)** |  | 589d? | 2010-12-10 A | 2013-03-01 A | 100% | 2010-12-10 | 2013-03-01 | 589d? |  | C1; R5 | 11440h | 11440h | aSRVCC | PCG-26 | ZTE | li.shitao@zte.com.cn | Rel-10 | CP-50 | Frederic | aSRVCC |  |  |  |  |
| 1885 | 474.1 | CT aspects of Single Radio Voice Call Continuity (SRVCC) in alerting phase (Stage 3) |  | 126d? | 2010-12-10 A | 2011-06-03 A | 100% | 2010-12-10 | 2011-06-03 | 126d? | finish no earlier than 2011-06-03 | C1 | 1008h | 1008h | aSRVCC | PCG-26 | ZTE | li.shitao@zte.com.cn | Rel-10 | CP-50 | Frederic |  |  |  |  |  |
| 1886 | 474.2 | Conformance test aspects SRVCC in alerting phase |  | 126d? | 2012-09-11 A | 2013-03-01 A | 100% | 2012-09-11 | 2013-03-01 | 126d? | finish no earlier than 2013-03-01 | R5 | 1008h | 1008h | aSRVCC-UEConTest | PCG-29 | NTT DoCoMo | Takao.Shimizu.rp@nttdocomo.com | Rel-10 | RP-57 | Ingbert | aSRVCC-UEConTest | RP-130042 |  |  |  |
| 1887 | 475 | **PCRF failure and restoration** |  | 71d? | 2010-12-10 A | 2011-03-18 A | 100% | 2010-12-10 | 2011-03-18 | 71d? |  | C4; C3 | 2130h | 2130h | PCRF_FR | PCG-26 | NEC | Toshiyuki Tamura (tamurato@aj.jp.nec.com) | Rel-10 | CP-50 | Kimmo | PCRF_FR |  |  |  |  |
| 1888 | 475.1 | CT4 part of PCRF failure and restoration |  | 71d? | 2010-12-10 A | 2011-03-18 A | 100% | 2010-12-10 | 2011-03-18 | 71d? | finish no earlier than 2011-03-18 | C4 | 568h | 568h | PCRF_FR | PCG-26 | NEC | Toshiyuki Tamura (tamurato@aj.jp.nec.com) | Rel-10 | CP-50 | Kimmo |  |  |  |  |  |
| 1889 | 475.2 | CT3 part of PCRF failure and restoration |  | 53.25d? | 2010-12-10 A | 2011-03-18 A | 100% | 2010-12-10 | 2011-03-18 | 53.25d? | start no earlier than 2010-12-10 | C3 | 426h | 426h | PCRF_FR | PCG-26 | NEC | Toshiyuki Tamura (tamurato@aj.jp.nec.com) | Rel-10 | CP-50 | Adrian |  |  |  |  |  |
| 1890 | 476 | Formalization of WLAN Files | milestone | 0d? | 2011-02-23 A | 2011-03-18 A | 100% | 2011-02-23 | 2011-03-18 | 0d? | start no earlier than 2011-03-16 | C1 |  |  | FoWF | PCG-26 | Deutsche Telekom | dieter.jacobsohn@telekom.de | Rel-10 | CP-51 | Frederic | FoWF |  | WLAN |  |  |
| 1891 | 477 | CS and IMS Interworking for CAT service - Early Session model |  | 58d? | 2011-03-16 A | 2011-06-03 A | 100% | 2011-03-16 | 2011-06-03 | 58d? |  | C3 | 464h | 464h | CIIC_ES | PCG-26 | ZTE | li.shitao@zte.com.cn | Rel-10 | CP-51 | Adrian | CIIC_ES |  |  |  |  |
| 1892 | 478 | EPC Node Restoration without Idle mode Signalling Reduction (ISR) activated |  | 3d? | 2011-03-16 A | 2011-03-18 A | 100% | 2011-03-16 | 2011-03-18 | 3d? | finish no earlier than 2011-03-18 | C4 | 24h | 24h | EPC_NR | PCG-26 | Alcatel-Lucent | bruno.landais@alcatel-lucent.com | Rel-10 | CP-51 | Kimmo | EPC_NR |  |  |  |  |
| 1893 | 479 | EPC Node Restoration with Idle mode Signalling Reduction (ISR) activated |  | 58d? | 2011-03-16 A | 2011-06-03 A | 100% | 2011-03-16 | 2011-06-03 | 58d? | finish no earlier than 2011-03-18 | C4 | 464h | 464h | EPC_NR_ISR | PCG-26 | NEC | Toshiyuki Tamura (tamurato@aj.jp.nec.com) | Rel-10 | CP-51 | Kimmo | EPC_NR_ISR |  |  |  |  |
| 1894 | 480 | Mobile Terminating Roaming Forwarding with pre-paging |  | 58d? | 2011-03-16 A | 2011-06-03 A | 100% | 2011-03-16 | 2011-06-03 | 58d? | finish no earlier than 2011-03-18 | C4 | 464h | 464h | MTRF | PCG-26 | Ericsson | philip.hodges@ericsson.com | Rel-10 | CP-51 | Kimmo | MTRF |  |  |  |  |
| 1895 | 481 | **UICC access to IMS Specification** |  | 58d? | 2011-03-16 A | 2011-06-03 A | 100% | 2011-03-16 | 2011-06-03 | 58d? |  | C6; C1 | 1416h | 1416h | IMS-UICC-S | PCG-26 | Gemalto | Denis.Lheriteau@gemalto.com | Rel-10 | CP-51 | Xavier | IMS-UICC-S |  |  |  |  |
| 1896 | 481.1 | CT6 part of UICC access to IMS Specification |  | 3d? | 2011-03-16 A | 2011-03-18 A | 100% | 2011-03-16 | 2011-03-18 | 3d? | start no earlier than 2011-03-16 | C6 | 24h | 24h | IMS-UICC-S | PCG-26 | Gemalto | Denis.Lheriteau@gemalto.com | Rel-10 | CP-51 | Xavier |  |  |  |  |  |
| 1897 | 481.2 | CT1 part of UICC access to IMS Specification |  | 58d? | 2011-03-16 A | 2011-06-03 A | 100% | 2011-03-16 | 2011-06-03 | 58d? | start no earlier than 2011-03-16 | C1 | 464h | 464h | IMS-UICC-S | PCG-26 | Gemalto | Denis.Lheriteau@gemalto.com | Rel-10 | CP-51 | Frederic |  |  |  |  |  |
| 1898 | 482 | Deleted - Testing for Terminal support of Rel-10 USIM, ISIM and USAT features |  | 463d? | 2012-03-05 A | 2013-12-03 A | 100% | 2012-03-05 | 2013-12-03 | 463d? | finish no earlier than 2013-06-14 | C6 | 3704h | 3704h | USIM_R10_Test | PCG-28 | Gemalto | Denis.Praca@gemalto.com | Rel-10 | CP-55 | Xavier | USIM_R10_Test |  |  | PCG-32 | CP-62 |
| 1899 | 483 | **CN aspects of Local Call Local Switch** |  | 472d? | 2009-05-29 A | 2011-03-18 A | 100% | 2009-05-29 | 2011-03-18 | 472d? |  | C4 | 13008h | 13008h | LCLS-CN | PCG-23 | Vodafone | David.Hutton@vodafone.com | Rel-10 | CP-44 | Kimmo | LCLS-CN |  |  |  |  |
| 1900 | 483.1 | TR on CN aspects of Local Call Local Switch |  | 341d? | 2009-05-29 A | 2010-09-16 A | 100% | 2009-05-29 | 2010-09-16 | 341d? | finish no earlier than 2010-09-17 | C4 | 2728h | 2728h | LCLS-CN | PCG-23 | Vodafone | David.Hutton@vodafone.com | Rel-10 | CP-44 | Kimmo |  |  |  |  |  |
| 1901 | 483.2 | Stage 2/3 for CN aspects of Local Call Local Switch |  | 131d? | 2010-09-17 A | 2011-03-18 A | 100% | 2010-09-17 | 2011-03-18 | 131d? | finish no earlier than 2011-03-18 | C4 | 1048h | 1048h | LCLS-CN | PCG-25 | Vodafone | David.Hutton@vodafone.com | Rel-10 | CP-49 | Kimmo |  |  |  |  |  |
| 1902 | 483.3 | Deleted - CT3 aspects of Local Call Local Switch |  | 341d? | 2009-05-29 A | 2010-09-16 A | 100% | 2009-05-29 | 2010-09-16 | 341d? | finish no earlier than 2010-09-17 | C3 | 2728h | 2728h | LCLS-CN | PCG-23 | Vodafone | David.Hutton@vodafone.com | Rel-10 | CP-44 | Adrian |  |  |  | PCG-25 | CP-49 |
| 1903 | 483.4 | Deleted - CT1 aspects of Local Call Local Switch |  | 341d? | 2009-05-29 A | 2010-09-16 A | 100% | 2009-05-29 | 2010-09-16 | 341d? | finish no earlier than 2010-09-17 | C1 | 2728h | 2728h | LCLS-CN | PCG-23 | Vodafone | David.Hutton@vodafone.com | Rel-10 | CP-44 | Frederic |  |  |  | PCG-25 | CP-49 |
| 1904 | 484 | Local Call Local Switch | milestone | 0d? | 2007-05-07 A | 2007-05-07 A | 100% | 2007-05-07 | 2011-05-20 | 1055.8d? |  | GP; G2 |  |  | LCLS | PCG-22 | Huawei | wang_zhixi@huawei.com | Rel-10 | GP-41 | Paolo | LCLS |  |  |  |  |

Notes:
- 1880: Triggered by SA2 TR 23.856 Study on Single Radio Voice Call Continuity enhancements (FS_eSRVCC) UID_440049
- 1881: CP#51 completed / Impacted TSs and TRs: 24.229, 24.237
- 1882: CP#51 completed / Impacted TSs and TRs: 23.003, 23.008, 29.002, 29.230, 29.272, 29.305, 29.328, 29.329
- 1883: CP#58 completed / Impacted TSs and TRs: RFC 6809 (was draft-ietf-sipcore-proxy-feature)
- 1884: Builds on Rel-8 UID_390057 (IMS-Cont) TS 23.216 Stage 2. Provide Stage 3 for SRVCC PS-CS transfer of a call in alerting phase. Stage 2 TEI10 in TS 23.237 (6.3.2.1.4c/d, 6.3.2.1.7a/b)
- 1885: CP#52 completed / Impacted TSs and TRs: 24.008, 24.237
- 1886: RP#59 completed / Impacted TSs and TRs: 36.523-1, 36.523-2, 36.523-3, 34.229-1, 34.229-2, 34.229-3
- 1887: CP#51 completed. Triggered by CT3 TR 29.816 Study on Policy and Charging Rules Function (PCRF) failure and restoration (FS_PCRF-FR) UID_450013 / Impacted TSs and TRs: Stage 2/3 work
- 1888: CP#51 completed / Impacted TSs and TRs: Stage 2 23.007, Stage 3 29.230
- 1889: CP#51 completed / Impacted TSs and TRs: Stage 3 29.212, 29.213, 29.214, 29.215
- 1890: CP#51 completed. TS 24.235 for Info+Approval. Define the ME files as specified in 24.234 in OMA Device Management structure / Impacted TSs and TRs: Stage 3: 24.234, New 24.235
- 1891: CP#52 completed. Stage 1 in Rel-8 TS 22.182 Customized Alerting Tones (CAT) service. Stage 3 TS 24.182 defines 3 impl models: Gateway, Forking, Early Session. Specify missing CAT service interworking procedures btw CS & IMS networks / Impacted TSs and TRs: Stage 3 29.163, 29.235, 29.292
- 1892: CP#51 completed. Triggered by DRAFT TR 23.857 Study on EPC Nodes Restoration (FS_EPC_NR) UID_490014 / Impacted TSs and TRs: Stage 2/3: 23.007, 29.274
- 1893: CP#52 completed. Triggered by DRAFT TR 23.857 Study on EPC Nodes Restoration (FS_EPC_NR) UID_490014 / Impacted TSs and TRs: Stage 2/3: 23.007, 29.274
- 1894: CP#52 completed. Provides Stage 2/3 alternative solution to Mobile Terminating Roaming Retry to solve roaming events during paging, in particular to support CSFB. Hence, no new Stage 1 requirements exist / Impacted TSs and TRs: Stage 2/3: 23.012, 23.018, 23.116, 29.002
- 1895: CP#52 completed. Triggered by Rel-10 TR 31.828 Study on UICC access to IMS (FS_IMS-UICC) UID_480017. Specify mechanism in UICC and ME to make use of IMS functionality implemented in ME for case a) an ISIM is present b) no ISIM is present in UICC
- 1896: CP#51 completed / Impacted TSs and TRs: 31.102, 31.103, 31.111
- 1897: CP#52 completed / Impacted TSs and TRs: 24.229
- 1898: CP#62 stopped (at 70% completion 06/13). Testing for New features in Rel-10 specifications for USIM, ISIM applications and USIM Application Toolkit (USAT) in TS 31.102, 31.103, 31.111 / Impacted TSs and TRs: 31.121, 31.124, New TS 31.ABC (Conformance Testing of specific features)
- 1899: CP#51 completed / Impacted TSs and TRs: GERAN Stage 2/3
- 1900: CP#49 completed / Impacted TSs and TRs: new TR 23.889
- 1901: CP#51 completed / Impacted TSs and TRs: 23.003, 23.009, 23.205, 23.231, 29.002, 29.205, 29.232, new TS 23.284
- 1902: CP#49 stopped. Result of study TR 23.889: no CT3 specification impact
- 1903: CP#49 stopped. Result of study TR 23.889: no CT1 specification impact
- 1904: GP#50 completed. GP#41 WID approved / Impacted TSs and TRs: GERAN Stage 3: 48.008, 48.103

| ID | WBS | Task | Duration | Start | Finish | Complete | Baseline start | Baseline finish | Baseline duration | Constraint | Resources | Work | Actual work | Acronym | PCG approved | WI rapporteur name | Release | TSG approved | MCC resp | Acronym_3GU_Export | Status Report | Special Focus Doc |
| --- | --- | --- | --- | --- | --- | --- | --- | --- | --- | --- | --- | --- | --- | --- | --- | --- | --- | --- | --- | --- | --- | --- |
| 1905 | 485 | **Tightened Link Level Performance Requirements for Single Antenna MS** | 659d? | 2010-09-03 A | 2013-03-01 A | 100% | 2010-09-03 | 2013-03-01 | 659d? |  | G1; G2; C1; G3new | 30856h | 30856h | TIGHTER | PCG-25 | Renesas Mobile | Rel-10 | GP-46 | Paolo | TIGHTER |  |  |
| 1906 | 485.1 | CT1 part for TIGHTER | 196d? | 2010-09-03 A | 2011-06-03 A | 100% | 2010-09-03 | 2011-06-03 | 196d? | finish no earlier than 2011-06-03 | C1 | 1568h | 1568h | TIGHTER | PCG-25 | Renesas Mobile | Rel-10 | GP-46 | Frederic |  |  |  |
| 1907 | 485.2 | TIGHTER Performance Requirements | 186d? | 2010-09-03 A | 2011-05-20 A | 100% | 2010-09-03 | 2011-05-20 | 186d? | finish no earlier than 2011-05-20 | G1; G2 | 2976h | 2976h | TIGHTER | PCG-25 | Renesas Mobile | Rel-10 | GP-46 | Paolo |  |  |  |
| 1908 | 485.3 | TIGHTER Testing | 654d? | 2010-09-08 A | 2013-03-01 A | 100% | 2010-09-08 | 2013-03-01 | 654d? | finish no earlier than 2013-03-01 | G3new | 5224h | 5224h | TIGHTER | PCG-25 | Renesas Mobile | Rel-10 | GP-46 | Ingbert |  |  |  |
| 1909 | 486 | **Support of Multi-Operator Core Network by GERAN** | 206d? | 2010-05-21 A | 2011-03-04 A | 100% | 2010-05-21 | 2011-03-04 | 206d? |  | G2; S2; C1 | 8392h | 8392h | MOCN-GERAN | PCG-25 | Alcatel-Lucent | Rel-10 | GP-47 | Gert | MOCN-GERAN |  |  |
| 1910 | 486.1 | Stage 2 for Support of Multi-Operator Core Network by GERAN | 150d? | 2010-05-21 A | 2010-12-16 A | 100% | 2010-05-21 | 2010-12-16 | 150d? | finish no earlier than 2010-12-15 | S2 | 1200h | 1200h | MOCN-GERAN | PCG-25 | Alcatel-Lucent | Rel-10 | GP-47 | Maurice |  |  |  |
| 1911 | 486.2 | CT1 part of Stage 3 for Support of Multi-Operator Core Network by GERAN | 146d? | 2010-05-21 A | 2010-12-10 A | 100% | 2010-05-21 | 2010-12-10 | 146d? | finish no earlier than 2010-12-10 | C1 | 1168h | 1168h | MOCN-GERAN | PCG-25 | Alcatel-Lucent | Rel-10 | GP-47 | Frederic |  |  |  |
| 1912 | 486.3 | GERAN2 part of Stage 3 for Support of Multi-Operator Core Network by GERAN | 135d? | 2010-08-30 A | 2011-03-04 A | 100% | 2010-08-30 | 2011-03-04 | 135d? | finish no earlier than 2011-03-04 | G2 | 1080h | 1080h | MOCN-GERAN | PCG-25 | Alcatel-Lucent | Rel-10 | GP-47 | Gert |  |  |  |
| 1913 | 487 | **Enhancements of Iur-g interface** | 196d? | 2010-09-03 A | 2011-06-03 A | 100% | 2010-09-03 | 2011-06-03 | 196d? |  | G2; R3 | 5752h | 5752h | eIurg | PCG-25 | China Mobile, ZTE | Rel-10 | GP-47 | Gert | eIurg |  |  |
| 1914 | 487.1 | GERAN part for Enhancements of Iur-g interface (Stage 2/3) | 131d? | 2010-09-03 A | 2011-03-04 A | 100% | 2010-09-03 | 2011-03-04 | 131d? | finish no earlier than 2011-03-04 | G2 | 1048h | 1048h | eIurg-GERAN | PCG-25 | China Mobile, ZTE | Rel-10 | GP-47 | Gert | eIurg-GERAN |  |  |
| 1915 | 487.2 | Core part: Enhancements of Iur-g interface (Stage 2/3) | 196d? | 2010-09-03 A | 2011-06-03 A | 100% | 2010-09-03 | 2011-06-03 | 196d? | finish no earlier than 2011-06-03 | R3 | 1568h | 1568h | eIurg-RAN | PCG-25 | ZTE | Rel-10 | RP-49 | Juha | eIurg-RAN | RP-110526 |  |
| 1916 | 488 | 1.28 Mcps TDD Repeater | 599d? | 2007-12-04 A | 2010-03-19 A | 100% | 2007-12-04 | 2010-03-19 | 599d? | finish no earlier than 2010-03-19 | R4 | 4792h | 4792h | RANimp-Repeaters1.28TDD | PCG-21 | RITT | Rel-10 | RP-38 | Issam | RANimp-Repeaters1.28TDD | RP-100039 |  |
| 1917 | 489 | 1.28 Mcps TDD Multi-carrier HSUPA | 321d? | 2009-09-18 A | 2010-12-10 A | 100% | 2009-09-18 | 2010-12-10 | 321d? | finish no earlier than 2010-12-10 | R1; R2; R3; R4 | 10272h | 10272h | TDD_MC_HSUPA | PCG-23 | CATR | Rel-10 | RP-45 | Patrick | TDD_MC_HSUPA | RP-101079 |  |
| 1918 | 490 | **1.28 Mcps TDD Home NodeB RF requirements** | 266d? | 2009-12-04 A | 2010-12-10 A | 100% | 2009-12-04 | 2010-12-10 | 266d? |  | R4 | 5304h | 5304h | HNB_LCRTDD_RF | PCG-24 | TD Tech | Rel-10 | RP-46 | Issam | HNB_LCRTDD_RF |  | HNB |
| 1919 | 490.1 | Core part: 1.28Mcps TDD Home NodeB RF requirements | 131d? | 2009-12-04 A | 2010-06-04 A | 100% | 2009-12-04 | 2010-06-04 | 131d? | finish no earlier than 2010-12-10 | R4 | 1048h | 1048h | HNB_LCRTDD_RF-Core | PCG-24 | TD Tech | Rel-10 | RP-46 | Issam | HNB_LCRTDD_RF-Core | RP-100446 | HNB |
| 1920 | 490.2 | Perf. part: 1.28Mcps TDD Home NodeB RF requirements | 266d? | 2009-12-04 A | 2010-12-10 A | 100% | 2009-12-04 | 2010-12-10 | 266d? | finish no earlier than 2010-12-10 | R4 | 2128h | 2128h | HNB_LCRTDD_RF-Perf | PCG-24 | TD Tech | Rel-10 | RP-46 | Issam | HNB_LCRTDD_RF-Perf | RP-101081 | HNB |
| 1921 | 491 | **Multi-User Multiple-Input and Multiple-Output (MU-MIMO) for 1.28Mcps TDD** | 316d? | 2010-03-19 A | 2011-06-03 A | 100% | 2010-03-19 | 2011-06-03 | 316d? |  | R1; R2; R3; R4 | 17224h | 17224h | MUMIMO_LCR_TDD | PCG-24 | CATT | Rel-10 | RP-47 | Patrick | MUMIMO_LCR_TDD |  |  |
| 1922 | 491.1 | Core part: MU-MIMO for 1.28Mcps TDD | 191d? | 2010-03-19 A | 2010-12-10 A | 100% | 2010-03-19 | 2010-12-10 | 191d? | finish no earlier than 2010-12-10 | R1; R2; R3 | 4584h | 4584h | MUMIMO_LCR_TDD-Core | PCG-24 | CATT | Rel-10 | RP-47 | Patrick | MUMIMO_LCR_TDD-Core | RP-101085 |  |
| 1923 | 491.2 | Perf. part: MU-MIMO for 1.28Mcps TDD | 316d? | 2010-03-19 A | 2011-06-03 A | 100% | 2010-03-19 | 2011-06-03 | 316d? | finish no earlier than 2011-06-03 | R4 | 2528h | 2528h | MUMIMO_LCR_TDD-Perf | PCG-24 | CATT | Rel-10 | RP-47 | Issam | MUMIMO_LCR_TDD-Perf | RP-110520 |  |
| 1924 | 492 | **AGNSS Minimum Performance for UTRAN** | 523d? | 2009-09-18 A | 2011-09-16 A | 100% | 2009-09-18 | 2011-09-16 | 523d? |  | R4; R5 | 13624h | 13624h | AGNSSPerf_UTRAN | PCG-23 | Thales | Rel-10 | RP-45 | Issam | AGNSSPerf_UTRAN |  |  |
| 1925 | 492.1 | AGNSS Minimum Performance Specification Development | 321d? | 2009-09-18 A | 2010-12-10 A | 100% | 2009-09-18 | 2010-12-10 | 321d? | finish no earlier than 2010-12-10 | R4 | 2568h | 2568h | AGNSSPerf_UTRAN | PCG-23 | Thales | Rel-10 | RP-45 | Issam | AGNSSPerf_UTRAN | RP-101078 |  |
| 1926 | 492.2 | AGNSS test case development for UMTS | 336d? | 2010-06-04 A | 2011-09-16 A | 100% | 2010-06-04 | 2011-09-16 | 336d? | finish no earlier than 2011-09-16 | R5 | 2688h | 2688h | AGNSSPerf_UTRAN | PCG-25 | Thales | Rel-10 | RP-48 | Ingbert | AGNSSPerf_UTRAN | RP-110979 |  |
| 1927 | 493 | **Inclusion of RF Pattern Matching Technologies as positioning method in the UTRAN** | 336d? | 2009-12-04 A | 2011-03-18 A | 100% | 2009-12-04 | 2011-03-18 | 336d? |  | R2; R3 | 10752h | 10752h | LCS_UMTS_RFPMT | PCG-24 | Polaris Wireless | Rel-10 | RP-46 | Yong-Jun | LCS_UMTS_RFPMT | RP-110048 |  |
| 1928 | 493.1 | Core part: Inclusion of RF Pattern Matching Technologies as positioning method in the UTRAN | 336d? | 2009-12-04 A | 2011-03-18 A | 100% | 2009-12-04 | 2011-03-18 | 336d? | finish no earlier than 2011-03-18 | R2; R3 | 5376h | 5376h | LCS_UMTS_RFPMT-Core | PCG-24 | Polaris Wireless | Rel-10 | RP-46 | Yong-Jun | LCS_UMTS_RFPMT-Core | RP-110048 |  |

Notes:
- 1905: GP#46 approved WID / Impacted TSs and TRs: GERAN / WI rapporteur e-mail: carsten.juncker@renesasmobile.com
- 1906: CP#52 completed / Impacted TSs and TRs: 24.008 / WI rapporteur e-mail: marko.niemi@renesasmobile.com
- 1907: GP#50 completed / Impacted TSs and TRs: 45.005, 45.015 / WI rapporteur e-mail: carsten.juncker@renesasmobile.com
- 1908: GP#57 completed / Impacted TSs and TRs: 51.010 / WI rapporteur e-mail: carsten.juncker@renesasmobile.com
- 1909: GP#47 approved WID. 900 MHz spectrum re-farming to other RATs lead operators to reduce GSM capacity and therefore share their GSM networks. Hence the need for the most suitable (GE)RAN sharing method / Impacted TSs and TRs: GERAN / WI rapporteur e-mail: michel.robert@alcatel-lucent.com
- 1910: SP#50 completed / Impacted TSs and TRs: 23.251 / WI rapporteur e-mail: michel.robert@alcatel-lucent.com
- 1911: CP#50 completed / Impacted TSs and TRs: 24.008 CR#1644 / WI rapporteur e-mail: michel.robert@alcatel-lucent.com
- 1912: GP#49 completed / Impacted TSs and TRs: 48.008 CR#0325, 48.018 CR#0303 / WI rapporteur e-mail: michel.robert@alcatel-lucent.com
- 1913: GP#47 approved WID / Impacted TSs and TRs: GERAN,UTRA / WI rapporteur e-mail: Ms Juan Deng (dengjuan@chinamobile.com), Xinhui Wang (wangxinhui@zte.com.cn)
- 1914: GP#49 completed. GP#48 updated WID GP-101659=>GP-101758 (restricting the scope to GERAN BSC and TD-SCDMA RNC only). GP#47 approved WID / Impacted TSs and TRs: 43.130, 48.008 / WI rapporteur e-mail: Ms Juan Deng (dengjuan@chinamobile.com), Xinhui Wang (wangxinhui@zte.com.cn)
- 1915: RP#52 completed / Impacted TSs and TRs: UTRA Stage 2 (25.401, 25.420), Stage 3 (25.423) / WI rapporteur e-mail: Liu Junqiang (liu.junqiang@zte.com.cn)
- 1916: RP#47 completed / Impacted TSs and TRs: UTRA 25.113, New 25.116, 25.153 (testing) / WI rapporteur e-mail: qinyan@chinattl.com
- 1917: RP#50 completed / Impacted TSs and TRs: UTRA 25.102, 25.105, 25.123, 25.221, 25.222, 25.223, 25.224, 25.225, 25.306, 25.319, 25.321, 25.331, 25.423, 25.427, 25.433 / WI rapporteur e-mail: Aihui Song (songaihui@mail.ritt.com.cn)
- 1918: RP#50 completed. Triggered by FS_RAN-HNBLCRTDD UID_410016 Study on 1.28 Mcps TDD Home NodeB (TR 25.866) / Impacted TSs and TRs: UTRA / WI rapporteur e-mail: Li Rong (lirong@td-tech.com)
- 1919: RP#48 completed / Impacted TSs and TRs: 25.105 / WI rapporteur e-mail: Li Rong (lirong@td-tech.com)
- 1920: RP#50 completed. TR 25.968 v100 for Approval / Impacted TSs and TRs: 25.142, new TR 25.968 / WI rapporteur e-mail: Li Rong (lirong@td-tech.com)
- 1921: RP#52 completed / Impacted TSs and TRs: UTRA / WI rapporteur e-mail: Yanping Xing (xingyanping@datangmobile.cn)
- 1922: RP#50 completed / Impacted TSs and TRs: 25.221, 25.222, 25.224, 25.306, 25.308, 25.319, 25.331, 25.423, 25.425, 25.433, 25.435 / WI rapporteur e-mail: Yanping Xing (xingyanping@datangmobile.cn)
- 1923: RP#52 completed / Impacted TSs and TRs: 25.102, 25.105, 25.142 / WI rapporteur e-mail: Sanjun Feng (fengsanjun@datangmobile.cn)
- 1924: RP#53 completed. Triggered by Rel-7 UID_20050 (GNSS in UTRAN) and Rel-8 UID_400051 (Support for Additional NSS). Linked to GERAN Rel-9 UID_38002 (AGNSS Performances and Testing Procedures) / Impacted TSs and TRs: UTRA / WI rapporteur e-mail: Michel.monnerat@thalesaleniaspace.com
- 1925: RP#50 completed / Impacted TSs and TRs: new 25.172 / WI rapporteur e-mail: Michel.monnerat@thalesaleniaspace.com
- 1926: RP#53 completed / Impacted TSs and TRs: 34.108, 34.109, 34.123-1, 34.123-2, 34.123-3, 36.37.571-5, new 34.172 / WI rapporteur e-mail: Michel.monnerat@thalesaleniaspace.com
- 1927: RP#51 completed. Triggered by Study UID_380079 Evaluation of the inclusion of Path Loss Based Technology in the UTRAN (25.907) / Impacted TSs and TRs: UTRA / WI rapporteur e-mail: Norman Shaw (nshaw@polariswireless.com)
- 1928: RP#51 completed / Impacted TSs and TRs: 25.305, 25.453 / WI rapporteur e-mail: Norman Shaw (nshaw@polariswireless.com)

| ID | WBS | Task | Duration | Start | Finish | Complete | Baseline start | Baseline finish | Baseline duration | Constraint | Resources | Work | Actual work | Acronym | PCG approved | WI rapporteur name | WI rapporteur e-mail | Release | TSG approved | MCC resp | Acronym_3GU_Export | Status Report | PCG stopped | TSG stopped | Special Focus Doc |
| --- | --- | --- | --- | --- | --- | --- | --- | --- | --- | --- | --- | --- | --- | --- | --- | --- | --- | --- | --- | --- | --- | --- | --- | --- | --- |
| 1929 | 494 | **Four carrier HSDPA** | 992d? | 2009-12-04 A | 2013-09-06 A | 100% | 2009-12-04 | 2013-09-06 | 992d? |  | R1; R2; R3; R4; R5 | 57872h | 57872h | 4C_HSDPA | PCG-24 | Qualcomm | Arjun Bharadwaj (arjunb@qualcomm.com) | Rel-10 | RP-46 | Patrick | 4C_HSDPA |  |  |  |  |
| 1930 | 494.1 | Core part: Four carrier HSDPA | 336d? | 2009-12-04 A | 2011-03-18 A | 100% | 2009-12-04 | 2011-03-18 | 336d? | finish no earlier than 2011-03-18 | R1; R2; R3; R4 | 10752h | 10752h | 4C_HSDPA-Core | PCG-24 | Qualcomm | Arjun Bharadwaj (arjunb@qualcomm.com) | Rel-10 | RP-46 | Patrick | 4C_HSDPA-Core | RP-110046 |  |  |  |
| 1931 | 494.2 | Perf. part: Four carrier HSDPA | 466d? | 2009-12-04 A | 2011-09-16 A | 100% | 2009-12-04 | 2011-09-16 | 466d? | finish no earlier than 2011-09-16 | R4 | 3728h | 3728h | 4C_HSDPA-Perf | PCG-24 | Qualcomm | Arjun Bharadwaj (arjunb@qualcomm.com) | Rel-10 | RP-46 | Issam | 4C_HSDPA-Perf | RP-110986 |  |  |  |
| 1932 | 494.3 | Test part: Four carrier HSDPA | 464d? | 2011-12-02 A | 2013-09-06 A | 100% | 2011-12-02 | 2013-09-06 | 464d? | finish no earlier than 2013-09-06 | R5 | 3712h | 3712h | 4C_HSDPA-UEConTest | PCG-28 | Qualcomm | Shubhang Vora (svora@qualcomm.com) | Rel-10 | RP-54 | Ingbert | 4C_HSDPA-UEConTest | RP-130940 |  |  |  |
| 1933 | 495 | **Performance Requirements for two-antenna 1.28Mcps TDD Type 1 and Type 2 UE receiver** | 316d? | 2010-03-19 A | 2011-06-03 A | 100% | 2010-03-19 | 2011-06-03 | 316d? |  | R4 | 5504h | 5504h | 2ant_UE_LCR_TDD | PCG-24 | TD Tech | dafei.wang@td-tech.com | Rel-10 | RP-47 | Issam | 2ant_UE_LCR_TDD |  |  |  |  |
| 1934 | 495.1 | Core part: Performance Requirements for two-antenna 1.28Mcps TDD Type 1 and Type 2 UE receiver | 56d? | 2010-03-19 A | 2010-06-04 A | 100% | 2010-03-19 | 2010-06-04 | 56d? | finish no earlier than 2010-06-04 | R4 | 448h | 448h | 2ant_UE_LCR_TDD-Core | PCG-24 | TD Tech | dafei.wang@td-tech.com | Rel-10 | RP-47 | Issam | 2ant_UE_LCR_TDD-Core | RP-100454 |  |  |  |
| 1935 | 495.2 | Perf. part: Performance Requirements for two-antenna 1.28Mcps TDD Type 1 and Type 2 UE receiver | 316d? | 2010-03-19 A | 2011-06-03 A | 100% | 2010-03-19 | 2011-06-03 | 316d? | finish no earlier than 2011-06-03 | R4 | 2528h | 2528h | 2ant_UE_LCR_TDD-Perf | PCG-24 | TD Tech | dafei.wang@td-tech.com | Rel-10 | RP-47 | Issam | 2ant_UE_LCR_TDD-Perf | RP-110521 |  |  |  |
| 1936 | 496 | **Automatic Neighbour Relation (ANR) for UTRAN** | 663d? | 2010-06-04 A | 2012-12-07 A | 100% | 2010-06-04 | 2012-12-07 | 663d? |  | R3; R2; R5 | 22672h | 22672h | ANR_UTRAN | PCG-25 | ZTE | Zhai.hengxing@zte.com.cn | Rel-10 | RP-48 | Juha | ANR_UTRAN |  |  |  |  |
| 1937 | 496.1 | Core part: Automatic Neighbour Relation (ANR) for UTRAN | 261d? | 2010-06-04 A | 2011-06-03 A | 100% | 2010-06-04 | 2011-06-03 | 261d? | finish no earlier than 2011-06-03 | R3; R2 | 4176h | 4176h | ANR_UTRAN-Core | PCG-25 | ZTE | Zhai.hengxing@zte.com.cn | Rel-10 | RP-48 | Juha | ANR_UTRAN-Core | RP-110522 |  |  |  |
| 1938 | 496.2 | Test part: Automatic Neighbour Relation (ANR) for UTRAN | 323d? | 2011-09-19 A | 2012-12-07 A | 100% | 2011-09-19 | 2012-12-07 | 323d? | finish no earlier than 2012-12-07 | R5 | 2584h | 2584h | ANR_UTRAN-UEConTest | PCG-27 | Ericsson | leif.mattisson@ericsson.com | Rel-10 | RP-53 | Ingbert | ANR_UTRAN-UEConTest | RP-121529 |  |  |  |
| 1939 | 497 | **Support of New Band Combinations for Dual-Band Dual Cell HSDPA** | 261d? | 2010-06-04 A | 2011-06-03 A | 100% | 2010-06-04 | 2011-06-03 | 261d? |  | R4; R2 | 9568h | 9568h | DB_DC_HSDPA | PCG-25 | AT&T | Vince Spatafora (vs5785@att.com) | Rel-10 | RP-48 | Issam | DB_DC_HSDPA |  |  |  |  |
| 1940 | 497.1 | Core part: Support of New Band Combinations for Dual-Band Dual Cell HSDPA | 261d? | 2010-06-04 A | 2011-06-03 A | 100% | 2010-06-04 | 2011-06-03 | 261d? | finish no earlier than 2011-06-03 | R4; R2 | 4176h | 4176h | DB_DC_HSDPA-Core | PCG-25 | AT&T | Vince Spatafora (vs5785@att.com) | Rel-10 | RP-48 | Issam | DB_DC_HSDPA-Core | RP-110523 |  |  |  |
| 1941 | 497.2 | Deleted - Perf. part: Support of New Band Combinations for Dual-Band Dual Cell HSDPA | 76d? | 2010-06-04 A | 2010-09-17 A | 100% | 2010-06-04 | 2010-09-17 | 76d? | finish no earlier than 2010-09-17 | R4; R2 | 1216h | 1216h | DB_DC_HSDPA-Perf | PCG-25 | AT&T | Vince Spatafora (vs5785@att.com) | Rel-10 | RP-48 | Issam | DB_DC_HSDPA-Perf | RP-100759 | PCG-25 | RP-49 |  |
| 1942 | 498 | **MIMO operation with non-MIMO coexistence in HSDPA** | 459d? | 2010-06-04 A | 2012-03-02 A | 100% | 2010-06-04 | 2012-03-02 | 459d? |  | R4; R5 | 12936h | 12936h | MIMO_HSDPA | PCG-25 | Qualcomm | Heechoon Lee | Rel-10 | RP-48 | Issam | MIMO_HSDPA |  |  |  |  |
| 1943 | 498.1 | Core part: MIMO operation with non-MIMO coexistence in HSDPA | 186d? | 2010-09-17 A | 2011-06-03 A | 100% | 2010-09-17 | 2011-06-03 | 186d? | finish no earlier than 2011-06-03 | R4 | 1488h | 1488h | MIMO_HSDPA-Core | PCG-25 | Qualcomm | Heechoon Lee | Rel-10 | RP-49 | Issam | MIMO_HSDPA-Core | RP-110524 |  |  |  |
| 1944 | 498.2 | Perf. part: MIMO operation with non-MIMO coexistence in HSDPA | 261d? | 2010-06-04 A | 2011-06-03 A | 100% | 2010-06-04 | 2011-06-03 | 261d? | finish no earlier than 2011-06-03 | R4 | 2088h | 2088h | MIMO_HSDPA-Perf | PCG-25 | Qualcomm | Heechoon Lee | Rel-10 | RP-48 | Issam | MIMO_HSDPA-Perf | RP-110525 |  |  |  |
| 1945 | 498.3 | Test part: MIMO operation with non-MIMO coexistence in HSDPA | 252d? | 2011-03-18 A | 2012-03-02 A | 100% | 2011-03-18 | 2012-03-02 | 252d? | finish no earlier than 2012-03-02 | R5 | 2016h | 2016h | MIMO_HSDPA-UEConTest | PCG-26 | Qualcomm | Shubhang Vora (svora@qualcomm.com) | Rel-10 | RP-51 | Ingbert | MIMO_HSDPA-UEConTest | RP-120042 |  |  |  |
| 1946 | 499 | Interfrequency detected set measurements for UMTS | 61d? | 2010-09-17 A | 2010-12-10 A | 100% | 2010-09-17 | 2010-12-10 | 61d? | finish no earlier than 2010-12-10 | R2; R4 | 976h | 976h | Interf_dset_meas_UMTS | PCG-25 | Nokia | Chris.callender@nokia.com | Rel-10 | RP-49 | Yong-Jun | Interf_dset_meas_UMTS | RP-101093 |  |  |  |
| 1947 | 500 | **Carrier Aggregation for LTE** | 793d? | 2009-12-04 A | 2012-12-07 A | 100% | 2009-12-04 | 2012-12-07 | 793d? |  | R1; R2; R3; R4; R5 | 51024h | 51024h | LTE_CA | PCG-24 | Nokia | Asbjorn.grovlen@nokia.com | Rel-10 | RP-46 | Patrick | LTE_CA |  |  |  | CA |
| 1948 | 500.1 | Core part: Carrier Aggregation for LTE | 391d? | 2009-12-04 A | 2011-06-03 A | 100% | 2009-12-04 | 2011-06-03 | 391d? | finish no earlier than 2011-06-03 | R1; R2; R3; R4 | 12512h | 12512h | LTE_CA-Core | PCG-24 | Nokia | lars.e.lindh@nokia.com | Rel-10 | RP-46 | Patrick | LTE_CA-Core | RP-110535 |  |  | CA |
| 1949 | 500.2 | Perf. part: Carrier Aggregation for LTE | 528d? | 2009-12-04 A | 2011-12-09 A | 100% | 2009-12-04 | 2011-12-09 | 528d? | finish no earlier than 2011-12-09 | R4 | 4224h | 4224h | LTE_CA-Perf | PCG-24 | Nokia | lars.e.lindh@nokia.com | Rel-10 | RP-46 | Issam | LTE_CA-Perf | RP-111452 |  |  | CA |
| 1950 | 500.3 | Test part: Carrier Aggregation for LTE | 321d? | 2011-09-19 A | 2012-12-07 A | 100% | 2011-09-19 | 2012-12-07 | 321d? | finish no earlier than 2012-12-07 | R5 | 2568h | 2568h | LTE_CA-UEConTest | PCG-27 | Nokia | jussi.kuusisto@nokia.com | Rel-10 | RP-53 | Ingbert | LTE_CA-UEConTest | RP-121528 |  |  | CA |
| 1951 | 501 | **Enhanced Downlink Multiple Antenna Transmission for LTE** | 930d? | 2009-12-04 A | 2013-06-14 A | 100% | 2009-12-04 | 2013-06-14 | 930d? |  | R1; R2; R4; R5 | 44624h | 44624h | LTE_eDL_MIMO | PCG-24 | NTT DoCoMo | Hidekazu Taoka (taoka@nttdocomo.com) | Rel-10 | RP-46 | Patrick | LTE_eDL_MIMO |  |  |  |  |
| 1952 | 501.1 | Core part: Enhanced Downlink Multiple Antenna Transmission for LTE | 336d? | 2009-12-04 A | 2011-03-18 A | 100% | 2009-12-04 | 2011-03-18 | 336d? | finish no earlier than 2011-03-18 | R1; R2; R4 | 8064h | 8064h | LTE_eDL_MIMO-Core | PCG-24 | NTT DoCoMo | Hidekazu Taoka (taoka@nttdocomo.com) | Rel-10 | RP-46 | Patrick | LTE_eDL_MIMO-Core | RP-110067 |  |  |  |
| 1953 | 501.2 | Perf. part: Enhanced Downlink Multiple Antenna Transmission for LTE | 589d? | 2009-12-04 A | 2012-03-02 A | 100% | 2009-12-04 | 2012-03-02 | 589d? | finish no earlier than 2012-03-02 | R4 | 4712h | 4712h | LTE_eDL_MIMO-Perf | PCG-24 | NTT DoCoMo | Hidekazu Taoka (taoka@nttdocomo.com) | Rel-10 | RP-46 | Issam | LTE_eDL_MIMO-Perf | RP-120053 |  |  |  |
| 1954 | 501.3 | Test part: Enhanced Downlink Multiple Antenna Transmission for LTE | 261d? | 2012-06-18 A | 2013-06-14 A | 100% | 2012-06-18 | 2013-06-14 | 261d? | finish no earlier than 2013-06-14 | R5 | 2088h | 2088h | LTE_eDL_MIMO-UEConTest | PCG-29 | ZTE | Carolyn Taylor (carolyn.tayl@zte.com.cn) | Rel-10 | RP-56 | Ingbert | LTE_eDL_MIMO-UEConTest | RP-130464 |  |  |  |

Notes:
- 1929: RP#53 completed / Impacted TSs and TRs: UTRA
- 1930: RP#51 completed. RP#52 TR 25.864 v200 for Approval / Impacted TSs and TRs: 25.101, 25.104, 25.133, 25.211, 25.212, 25.213, 25.214, 25.215, 25.308, 25.331, 25.423, 25.433, 26.306, new TR 25.864
- 1931: RP#53 completed / Impacted TSs and TRs: 25.101, 25.104, 25.133, 25.141
- 1932: RP#61 completed / Impacted TSs and TRs: 34.108, 34.121-1, 34.121-2, 34.123-1, 34.123-2, 34.123-3
- 1933: Stage 3. RP#52 completed / Impacted TSs and TRs: UTRA
- 1934: RP#48 completed / Impacted TSs and TRs: 25.102
- 1935: RP#52 completed / Impacted TSs and TRs: 25.102
- 1936: RP#52 Core completed. Automatic Neighbour Relation (ANR) function for UTRAN relieves operators from the burden of manually managing the Neighbour cell Relations (NRs) / Impacted TSs and TRs: UTRA
- 1937: RP#52 completed / Impacted TSs and TRs: 25.331, 25.413, 25.423, new TS 25.484 (Stage 2)
- 1938: RP#58 completed / Impacted TSs and TRs: 34.108, 34.123-1, 34.123-2, 34.123-3
- 1939: RP#52 completed. Rel-9 Dual-Band Dual-Cell HSDPA (UID_430015 Support for different bands for Dual-Cell HSDPA) has one combination per region in principle. This work adds additional combinations: Band I and XI (Region 3) and Band II and V (Region 2) / Impacted TSs and TRs: UTRA
- 1940: RP#52 completed. RP#62 existing TS 25.317 replaced by new TS 25.327 / Impacted TSs and TRs: 25.101, 25.104, 25.141, 25.317 replaced by new TS 25.327
- 1941: RP#49 stopped (Reason: no need for Performance work) / Impacted TSs and TRs: 25.101, 25.104, 25.141, 25.317
- 1942: RP#52 completed. RP#49 updated WID RP-100687=>RP-100993 (changed Title: MIMO Testing in HSDPA => MIMO operation with non-MIMO coexistence in HSDPA) / Impacted TSs and TRs: UTRA
- 1943: RP#52 completed / Impacted TSs and TRs: 25.104
- 1944: RP#52 completed / Impacted TSs and TRs: 25.101, 25.141
- 1945: RP#55 completed / Impacted TSs and TRs: 34.108, 34.121-1, 34.121-2, 34.123-1, 34.123-2, 34.123-3
- 1946: RP#50 completed / Impacted TSs and TRs: UTRA 25.133, 25.331
- 1947: - / Impacted TSs and TRs: LTE
- 1948: RP#52 completed. RP#56 new RAN4 TR (36.807, 36.808) v200 for Approval / Impacted TSs and TRs: 36.101, 36.104, 36.133, 36.211, 36.212, 36.213, 36.300, 36.302, 36.306, 36.321, 36.331, 36.413, 36.423, 37.104, new RAN4 TR (36.807, 36.808)
- 1949: RP#54 completed / Impacted TSs and TRs: 36.101, 36.104, 36.133, 36.141, 37.141
- 1950: RP#58 completed / Impacted TSs and TRs: 36.508, 36.521-1, 36.521-2, 36.521-3, 36.523-1, 36.523-2, 36.523-3, 37.571-1, 37.571-3, 37.571-5
- 1951: - / Impacted TSs and TRs: LTE
- 1952: RP#51 completed. RP#56 new RAN4 TR 36.807 v200 for Approval / Impacted TSs and TRs: 36.101, 36.104, 36.133, 36.201, 36.211, 36.212, 36.213, 36.300, 36.306, 36.321, 36.331, new RAN4 TR 36.807
- 1953: RP#55 completed / Impacted TSs and TRs: 36.101, 36.104, 36.133, 36.141
- 1954: RP#60 completed. Testing for 36.101, 36.133 / Impacted TSs and TRs: 36.508, 36.521-1, 36.521-2

| ID | WBS | Task | Duration | Start | Finish | Complete | Baseline start | Baseline finish | Baseline duration | Constraint | Resources | Work | Actual work | Acronym | PCG approved | WI rapporteur name | WI rapporteur e-mail | Release | TSG approved | MCC resp | Acronym_3GU_Export | Status Report | PCG stopped | TSG stopped |
| --- | --- | --- | --- | --- | --- | --- | --- | --- | --- | --- | --- | --- | --- | --- | --- | --- | --- | --- | --- | --- | --- | --- | --- | --- |
| 1955 | 502 | **Uplink Multiple Antenna Transmission for LTE** | 3445d? | 2000-01-03 A | 2013-03-01 A | 100% | 2000-01-03 | 2013-03-01 | 3445d? |  | R1; R2; R4; R5 | 125976h | 125976h | LTE_UL_MIMO | PCG-24 | Huawei | Mattias.wennstrom@huawei.com | Rel-10 | RP-46 | Patrick | LTE_UL_MIMO |  |  |  |
| 1956 | 502.1 | Core part: UL multiple antenna transmission for LTE | 391d? | 2000-01-03 A | 2001-06-29 A | 100% | 2000-01-03 | 2001-06-29 | 391d? |  | R1; R2; R4 | 9384h | 9384h | LTE_UL_MIMO-Core | PCG-24 | Huawei | Mattias.wennstrom@huawei.com | Rel-10 | RP-46 | Patrick | LTE_UL_MIMO-Core | RP-110537 |  |  |
| 1957 | 502.2 | Perf. part: UL multiple antenna transmission for LTE | 466d? | 2009-12-04 A | 2011-09-16 A | 100% | 2009-12-04 | 2011-09-16 | 466d? | finish no earlier than 2011-09-16 | R4 | 3728h | 3728h | LTE_UL_MIMO-Perf | PCG-24 | Huawei | Mattias.wennstrom@huawei.com | Rel-10 | RP-46 | Issam | LTE_UL_MIMO-Perf | RP-110992 |  |  |
| 1958 | 502.3 | Test part: UL multiple antenna transmission for LTE | 328d? | 2011-12-02 A | 2013-03-01 A | 100% | 2011-12-02 | 2013-03-01 | 328d? | finish no earlier than 2013-03-01 | R5 | 2624h | 2624h | LTE_UL_MIMO-UEConTest | PCG-28 | Huawei | Zhang Xin (suzanna.zhang@huawei.com) | Rel-10 | RP-54 | Ingbert | LTE_UL_MIMO-UEConTest | RP-130038 |  |  |
| 1959 | 503 | **Relays for LTE** | 394d? | 2009-12-04 A | 2011-06-08 A | 100% | 2009-12-04 | 2011-06-08 | 394d? |  | R1; R2; R4; S2; S3; C4; C6 | 36856h | 36856h | LTE_Relay | PCG-24 | Ericsson | christian.hoymann@ericsson.com | Rel-10 | RP-46 | Patrick | LTE_Relay |  |  |  |
| 1960 | 503.1 | Core part: Relays for LTE | 391d? | 2009-12-04 A | 2011-06-03 A | 100% | 2009-12-04 | 2011-06-03 | 391d? | finish no earlier than 2011-06-03 | R1; R2; R4 | 9384h | 9384h | LTE_Relay-Core | PCG-24 | Ericsson | christian.hoymann@ericsson.com | Rel-10 | RP-46 | Patrick | LTE_Relay-Core | RP-110540 |  |  |
| 1961 | 503.2 | Deleted - Perf. part: Relays for LTE | 391d? | 2009-12-04 A | 2011-06-03 A | 100% | 2009-12-04 | 2011-06-03 | 391d? | finish no earlier than 2011-09-16 | R4 | 3128h | 3128h | LTE_Relay-Perf | PCG-24 | Ericsson | christian.hoymann@ericsson.com | Rel-10 | RP-46 | Issam | LTE_Relay-Perf | RP-110541 | PCG-27 | RP-52 |
| 1962 | 503.3 | Stage 2 for Relays for LTE | 3d? | 2011-06-06 A | 2011-06-08 A | 100% | 2011-06-06 | 2011-06-08 | 3d? | start no earlier than 2011-06-06 | S2 | 24h | 24h | LTE_Relay | PCG-27 | Vodafone | chris.pudney@vodafone.com | Rel-10 | SP-52 | Maurice | LTE_Relay |  |  |  |
| 1963 | 503.4 | **LTE Relay Nodes Security** | 69d? | 2010-12-16 A | 2011-03-22 A | 100% | 2010-12-16 | 2011-03-22 | 69d? |  | S3; C6 | 2232h | 2232h | LTE_Relay-Sec | PCG-26 | Qualcomm | Adrian Escott (aescott@qualcomm.com) | Rel-10 | SP-50 | Mirko | LTE_Relay-Sec |  |  |  |
| 1964 | 503.4.1 | TR on LTE Relay Nodes Security | 69d? | 2010-12-16 A | 2011-03-22 A | 100% | 2010-12-16 | 2011-03-22 | 69d? | finish no earlier than 2011-03-23 | S3 | 552h | 552h | LTE_Relay-Sec | PCG-26 | Qualcomm | Adrian Escott (aescott@qualcomm.com) | Rel-10 | SP-50 | Mirko |  |  |  |  |
| 1965 | 503.4.2 | Security for LTE Relay Nodes (Stage 2) | 69d? | 2010-12-16 A | 2011-03-22 A | 100% | 2010-12-16 | 2011-03-22 | 69d? | finish no earlier than 2011-03-23 | S3 | 552h | 552h | LTE_Relay-Sec | PCG-26 | Qualcomm | Adrian Escott (aescott@qualcomm.com) | Rel-10 | SP-50 | Mirko |  |  |  |  |
| 1966 | 503.4.3 | CT6 aspects of LTE Relay Node Security | 3d? | 2011-03-16 A | 2011-03-18 A | 100% | 2011-03-16 | 2011-03-18 | 3d? | start no earlier than 2011-03-16 | C6 | 24h | 24h | LTE_Relay-Sec | PCG-26 | n/a | n/a | Rel-10 | CP-51 | Xavier |  |  |  |  |
| 1967 | 503.5 | Core Network Impacts for Relay Nodes | 3d? | 2011-03-16 A | 2011-03-18 A | 100% | 2011-03-16 | 2011-03-18 | 3d? | finish no earlier than 2011-03-18 | C4 | 24h | 24h | LTE_Relay-CN | PCG-26 | Vodafone | David.Hutton@vodafone.com | Rel-10 | CP-51 | Kimmo | LTE_Relay-CN |  |  |  |
| 1968 | 504 | **Enhanced Inter-Cell Interference Control (ICIC) for non-Carrier Aggregation (CA) based deployments of heterogeneous networks for LTE** | 1119d? | 2010-03-19 A | 2014-06-13 A | 100% | 2010-03-19 | 2014-06-13 | 1119d? |  | R1; R2; R3; R4; R5 | 64384h | 64384h | eICIC_LTE | PCG-24 | China Mobile | Xiaodong XU (xuxiaodong@chinamobile.com) | Rel-10 | RP-47 | Patrick | eICIC_LTE |  |  |  |
| 1969 | 504.1 | Core part: Enhanced Inter-Cell Interference Control (ICIC) for non-Carrier Aggregation (CA) based deployments of heterogeneous networks for LTE | 316d? | 2010-03-19 A | 2011-06-03 A | 100% | 2010-03-19 | 2011-06-03 | 316d? | finish no earlier than 2011-06-03 | R1; R2; R3; R4 | 10112h | 10112h | eICIC_LTE-Core | PCG-24 | China Mobile | Xiaodong XU (xuxiaodong@chinamobile.com) | Rel-10 | RP-47 | Patrick | eICIC_LTE-Core | RP-110543 |  |  |
| 1970 | 504.2 | Perf. part: Enhanced Inter-Cell Interference Control (ICIC) for non-Carrier Aggregation (CA) based deployments of heterogeneous networks for LTE | 589d? | 2010-03-19 A | 2012-06-15 A | 100% | 2010-03-19 | 2012-06-15 | 589d? | finish no earlier than 2012-06-15 | R4 | 4712h | 4712h | eICIC_LTE-Perf | PCG-24 | China Mobile | Xiaodong XU (xuxiaodong@chinamobile.com) | Rel-10 | RP-47 | Issam | eICIC_LTE-Perf | RP-120461 |  |  |
| 1971 | 504.3 | Test part: Enhanced Inter-Cell Interference Control (ICIC) for non-Carrier Aggregation (CA) based deployments of heterogeneous networks for LTE | 600d? | 2012-03-05 A | 2014-06-13 A | 100% | 2012-03-05 | 2014-06-13 | 600d? | finish no earlier than 2014-06-13 | R5 | 4800h | 4800h | eICIC_LTE-UEConTest | PCG-28 | Qualcomm | Anjali Mishra (ajha@qualcomm.com) | Rel-10 | RP-55 | Ingbert | eICIC_LTE-UEConTest | RP-140766 |  |  |
| 1972 | 505 | **LTE TDD in 2600MHz for US** | 191d? | 2010-03-19 A | 2010-12-10 A | 100% | 2010-03-19 | 2010-12-10 | 191d? |  | R4; R2; R3; R5 | 11392h | 11392h | LTE_TDD_2600_US | PCG-24 | Clearwire | michael.hart@clearwire.com | Rel-10 | RP-47 | Issam | LTE_TDD_2600_US |  |  |  |
| 1973 | 505.1 | Core part: LTE TDD in 2600MHz for US | 131d? | 2010-03-19 A | 2010-09-17 A | 100% | 2010-03-19 | 2010-09-17 | 131d? | finish no earlier than 2010-09-17 | R4; R2; R3 | 3144h | 3144h | LTE_TDD_2600_US-Core | PCG-24 | Clearwire | michael.hart@clearwire.com | Rel-10 | RP-47 | Issam | LTE_TDD_2600_US-Core | RP-100782 |  |  |
| 1974 | 505.2 | Perf. part: LTE TDD in 2600MHz for US | 131d? | 2010-03-19 A | 2010-09-17 A | 100% | 2010-03-19 | 2010-09-17 | 131d? | finish no earlier than 2010-09-17 | R4 | 1048h | 1048h | LTE_TDD_2600_US-Perf | PCG-24 | Clearwire | michael.hart@clearwire.com | Rel-10 | RP-47 | Issam | LTE_TDD_2600_US-Perf | RP-100783 |  |  |
| 1975 | 505.3 | UE conformance test part: LTE TDD in 2600MHz for US | 136d? | 2010-06-04 A | 2010-12-10 A | 100% | 2010-06-04 | 2010-12-10 | 136d? | finish no earlier than 2010-12-10 | R5 | 1088h | 1088h | LTE_TDD_2600_US-UEConTest | PCG-25 | Clearwire | michael.hart@clearwire.com | Rel-10 | RP-48 | Ingbert | LTE_TDD_2600_US-UEConTest | RP-101071 |  |  |
| 1976 | 506 | **Adding 2 GHz band LTE FDD (Band 23) for Ancillary Terrestrial Component (ATC) of Mobile Satellite Service (MSS) in North America** | 454d? | 2010-03-19 A | 2011-12-09 A | 100% | 2010-03-19 | 2011-12-09 | 454d? |  | R2; R4; R5 | 19568h | 19568h | S_Band_LTE_ATC_MSS | PCG-24 | DBSD | Mariam.Sorond@ico.com | Rel-10 | RP-47 | Yong-Jun | S_Band_LTE_ATC_MSS |  |  |  |
| 1977 | 506.1 | Core part: Adding 2 GHz band LTE FDD (Band 23) for ATC of MSS in North America | 316d? | 2010-03-19 A | 2011-06-03 A | 100% | 2010-03-19 | 2011-06-03 | 316d? | finish no earlier than 2011-06-03 | R4; R2 | 5056h | 5056h | S_Band_LTE_ATC_MSS-Core | PCG-24 | DBSD | Mariam.Sorond@ico.com | Rel-10 | RP-47 | Issam | S_Band_LTE_ATC_MSS-Core | RP-110545 |  |  |
| 1978 | 506.2 | Perf. part: Adding 2 GHz band LTE FDD (Band 23) for ATC of MSS in North America | 316d? | 2010-03-19 A | 2011-06-03 A | 100% | 2010-03-19 | 2011-06-03 | 316d? | finish no earlier than 2011-06-03 | R4 | 2528h | 2528h | S_Band_LTE_ATC_MSS-Perf | PCG-24 | DBSD | Mariam.Sorond@ico.com | Rel-10 | RP-47 | Issam | S_Band_LTE_ATC_MSS-Perf | RP-110546 |  |  |
| 1979 | 506.3 | Test part: Adding 2 GHz band LTE FDD (Band 23) for ATC of MSS in North America | 137d? | 2011-06-07 A | 2011-12-09 A | 100% | 2011-06-07 | 2011-12-09 | 137d? | finish no earlier than 2011-12-09 | R5 | 1088h | 1088h | S_Band_LTE_ATC_MSS-UEConTest | PCG-27 | DBSD | Mariam.Sorond@ico.com | Rel-10 | RP-52 | Ingbert | S_Band_LTE_ATC_MSS-UEConTest | RP-111444 |  |  |

Notes:
- 1955: - / Impacted TSs and TRs: LTE
- 1956: RP#52 completed. TR 36.817 v110 for Approval. RP#56 new TR 36.807 v200 for Approval / Impacted TSs and TRs: 36.101, 36.104, 36.133, 36.201, 36.211, 36.212, 36.213, 36.300, 36.306, 36.321, 36.331, new RAN4 (TR 36.807, 36.817)
- 1957: RP#53 completed / Impacted TSs and TRs: 36.101, 36.104, 36.133, 36.141, 36.817
- 1958: RP#59 completed / Impacted TSs and TRs: 36.508, 36.521-1, 36.521-2, 36.521-3, 36.523-1, 36.523-2, 36.523-3
- 1959: RP#52 completed (open RAN4 Core & Perf parts moved to new Rel-11) / Impacted TSs and TRs: LTE
- 1960: RP#52 completed. Updated WID RP-101417=>RP-101911 (contains only Core part completed in Rel-10). Open RAN4 Core & Perf parts moved to new Rel-11 / Impacted TSs and TRs: 36.201, 36.211, 36.212, 36.213, 36.300, 36.321, 36.323, 36.331, New RAN1 TS 36.216
- 1961: RP#52 stopped at 30% (no CRs so far) . Transferred completely to Rel-11 together with remaining core part / Impacted TSs and TRs: 36.133, New TS 36.117 (E-UTRA Relay conformance testing)
- 1962: SP#52 SP-110338 (S2-85/S2-112851) 23.401 Cat F CR#2128 Completion of Relay procedure overview / Impacted TSs and TRs: 23.401
- 1963: -
- 1964: SP#51 completed / Impacted TSs and TRs: 33.816
- 1965: SP#51 completed (impacting Stage 3 in CT and RAN) / Impacted TSs and TRs: 33.401 (CR#0437,0438), CT1 24.301, CT4 (29.272, 29.274), CT6 31.102, RAN2 (36.331, 36.323), RAN3 36.413
- 1966: CP#51 completed / Impacted TSs and TRs: 31.101, 31.102
- 1967: CP#51 completed / Impacted TSs and TRs: 23.003, 23.008, 29.303, 29.230, 29.272
- 1968: RP#56 completed / Impacted TSs and TRs: LTE
- 1969: RP#52 completed / Impacted TSs and TRs: 36.101, 36.133, 36.201, 36.211, 36.212, 36.213, 36.214, 36.300, 36.321, 36.331, 36.413, 36.423
- 1970: RP#56 completed / Impacted TSs and TRs: 36.101, 36.133
- 1971: RP#64 completed / Impacted TSs and TRs: 36.508, 36.521-1, 36.521-2, 36.521-3, 36.523-1, 36.523-2, 36.523-3
- 1972: RP#50 Testing completed. RP#49 Core+Perf completed / Impacted TSs and TRs: LTE
- 1973: RP#49 completed / Impacted TSs and TRs: 25.461, 25.466, 36.101, 36.104, 36.113, 36.124, 36.133, 36.141, 36.307, 36.331, 37.104, 37.113, 37.141, new TR 36.812
- 1974: RP#49 completed / Impacted TSs and TRs: 36.101, 36.104, 36.133, 36.141, 36.307, 37.104, 37.141, new TR 36.812
- 1975: RP#50 completed / Impacted TSs and TRs: 36.508, 36.521-1, 36.521-2, 36.521-3, 36.523-1, 36.523-2, 36.523-3
- 1976: RP#52 completed. Updated WID RP-101401=>RP-110775 (changed in Title "LTE" to "LTE FDD (Band 23)" / Impacted TSs and TRs: LTE
- 1977: RP#52 completed / Impacted TSs and TRs: 25.101, 25.104, 25.141, 25.461, 25.466, 36.101, 36.104, 36.113, 36.124, 36.133, 36.307, 37.104, 37.141, new TR 36.811
- 1978: RP#52 completed / Impacted TSs and TRs: 36.101, 36.104, 36.113, 36.124, 36.133, 36.141, 36.307, 36.811
- 1979: RP#54 completed / Impacted TSs and TRs: 36.508, 36.521-1, 36.521-2, 36.521-3, 36.523-1, 36.523-2, 36.523-3

| ID | WBS | Task | Duration | Start | Finish | Complete | Baseline start | Baseline finish | Baseline duration | Constraint | Resources | Work | Actual work | Acronym | PCG approved | WI rapporteur name | WI rapporteur e-mail | Release | TSG approved | MCC resp | Acronym_3GU_Export | Status Report | Special Focus Doc |
| --- | --- | --- | --- | --- | --- | --- | --- | --- | --- | --- | --- | --- | --- | --- | --- | --- | --- | --- | --- | --- | --- | --- | --- |
| 1980 | 507 | **Adding L-Band (Band 24) LTE for Ancillary Terrestrial Component (ATC) of Mobile Satellite Service (MSS) in North America** | 463d? | 2009-12-11 A | 2011-09-16 A | 100% | 2009-12-11 | 2011-09-16 | 463d? |  | R4; R2; R5 | 18864h | 18864h | L_Band_LTE_ATC_MSS | PCG-24 | LightSquared | Eric.Jacks@lightsquared.com, Maqbool.Aliani@lightsquared.com | Rel-10 | RP-47 | Issam | L_Band_LTE_ATC_MSS |  |  |
| 1981 | 507.1 | Core part: Adding L-Band (Band 24) LTE for ATC of MSS in North America | 261d? | 2009-12-11 A | 2010-12-10 A | 100% | 2009-12-11 | 2010-12-10 | 261d? | finish no earlier than 2010-12-10 | R4; R2 | 4176h | 4176h | L_Band_LTE_ATC_MSS-Core | PCG-24 | LightSquared | Eric.Jacks@lightsquared.com, Maqbool.Aliani@lightsquared.com | Rel-10 | RP-47 | Issam | L_Band_LTE_ATC_MSS-Core | RP-101117 |  |
| 1982 | 507.2 | Perf. part: Adding L-Band (Band 24) LTE for ATC of MSS in North America | 316d? | 2010-03-19 A | 2011-06-03 A | 100% | 2010-03-19 | 2011-06-03 | 316d? | finish no earlier than 2011-06-03 | R4 | 2528h | 2528h | L_Band_LTE_ATC_MSS-Perf | PCG-24 | LightSquared | Eric.Jacks@lightsquared.com, Maqbool.Aliani@lightsquared.com | Rel-10 | RP-47 | Issam | L_Band_LTE_ATC_MSS-Perf | RP-110548 |  |
| 1983 | 507.3 | Test part: Adding L-Band (Band 24) LTE for ATC of MSS in North America | 131d? | 2011-03-18 A | 2011-09-16 A | 100% | 2011-03-18 | 2011-09-16 | 131d? | finish no earlier than 2011-09-16 | R5 | 1048h | 1048h | L_Band_LTE_ATC_MSS-UEConTest | PCG-26 | LightSquared | masoud.olfat@lightsquared.com | Rel-10 | RP-51 | Ingbert | L_Band_LTE_ATC_MSS-UEConTest | RP-110980 |  |
| 1984 | 508 | **LTE Self Optimizing Networks (SON) enhancements** | 316d? | 2010-03-19 A | 2011-06-03 A | 100% | 2010-03-19 | 2011-06-03 | 316d? |  | R3; R2; R4 | 15168h | 15168h | SONenh_LTE | PCG-24 | Nokia Siemens Networks | krzysztof.kordybach@nsn.com | Rel-10 | RP-47 | Juha | SONenh_LTE |  | SON |
| 1985 | 508.1 | Core part: LTE Self Optimizing Networks (SON) enhancements | 316d? | 2010-03-19 A | 2011-06-03 A | 100% | 2010-03-19 | 2011-06-03 | 316d? | finish no earlier than 2011-06-03 | R3; R2; R4 | 7584h | 7584h | SONenh_LTE-Core | PCG-24 | Nokia Siemens Networks | krzysztof.kordybach@nsn.com | Rel-10 | RP-47 | Juha | SONenh_LTE-Core | RP-110547 | SON |
| 1986 | 509 | **Further enhancements to MBMS for LTE** | 459d? | 2010-06-04 A | 2012-03-02 A | 100% | 2010-06-04 | 2012-03-02 | 459d? |  | R2; R3; R5 | 14840h | 14840h | MBMS_LTE_enh | PCG-25 | Huawei | Ms Zhao Junhui (zhaojh@huawei.com) | Rel-10 | RP-48 | Yong-Jun | MBMS_LTE_enh |  |  |
| 1987 | 509.1 | Core part: Further enhancements to MBMS for LTE | 206d? | 2010-06-04 A | 2011-03-18 A | 100% | 2010-06-04 | 2011-03-18 | 206d? | finish no earlier than 2011-03-18 | R2; R3 | 3296h | 3296h | MBMS_LTE_enh-Core | PCG-25 | Huawei | Ms Zhao Junhui (zhaojh@huawei.com) | Rel-10 | RP-48 | Yong-Jun | MBMS_LTE_enh-Core | RP-110083 |  |
| 1988 | 509.2 | Test part: Further enhancements to MBMS for LTE | 66d? | 2011-12-02 A | 2012-03-02 A | 100% | 2011-12-02 | 2012-03-02 | 66d? | finish no earlier than 2012-03-02 | R5 | 528h | 528h | MBMS_LTE_enh-UEConTest | PCG-28 | Huawei | Zhang Xin (suzanna.zhang@huawei.com) | Rel-10 | RP-54 | Ingbert | MBMS_LTE_enh-UEConTest | RP-120049 |  |
| 1989 | 510 | **UMTS/LTE 3500 MHz** | 1456d? | 2007-11-30 A | 2013-06-14 A | 100% | 2007-11-30 | 2013-06-14 | 1456d? |  | R4; R2; R3; R5 | 87360h | 87360h | RInImp8-UMTSLTE3500 | PCG-21 | Ericsson | johan.skold@ericsson.com | Rel-10 | RP-38 | Issam | RInImp8-UMTSLTE3500 |  |  |
| 1990 | 510.1 | Core part: UMTS/LTE 3500 MHz | 994d? | 2007-11-30 A | 2011-09-16 A | 100% | 2007-11-30 | 2011-09-16 | 994d? | finish no earlier than 2011-09-16 | R4; R2; R3 | 23856h | 23856h | RInImp8-UMTSLTE3500 | PCG-21 | Ericsson | johan.skold@ericsson.com | Rel-10 | RP-38 | Issam | RInImp8-UMTSLTE3500 | RP-110987 |  |
| 1991 | 510.2 | Conformance Test Aspects – LTE 3500 | 1189d? | 2008-12-05 A | 2013-06-14 A | 100% | 2008-12-05 | 2013-06-14 | 1189d? | finish no earlier than 2013-06-14 | R5 | 9512h | 9512h | LTE-UEConTest_LTE3500 | PCG-22 | Ericsson | fredrik.sundstrom@ericsson.com | Rel-10 | RP-42 | Ingbert | LTE-UEConTest_LTE3500 | RP-130461 |  |
| 1992 | 510.3 | Conformance Test Aspects – UMTS 3500 | 925d? | 2008-12-05 A | 2012-06-15 A | 100% | 2008-12-05 | 2012-06-15 | 925d? | finish no earlier than 2012-06-15 | R5 | 7400h | 7400h | RInImp-UEConTest_UMTS3500 | PCG-22 | Ericsson | fredrik.sundstrom@ericsson.com | Rel-10 | RP-42 | Ingbert | RInImp-UEConTest_UMTS3500 | RP-120450 |  |
| 1993 | 511 | **Minimization of Drive Tests for E-UTRAN and UTRAN** | 854d? | 2009-12-04 A | 2013-03-01 A | 100% | 2009-12-04 | 2013-03-01 | 854d? |  | R2; R4; R3; R5 | 39784h | 39784h | MDT_UMTSLTE | PCG-24 | Nokia Siemens Networks | malgorzata.tomala@nsn.com | Rel-10 | RP-46 | Yong-Jun | MDT_UMTSLTE |  |  |
| 1994 | 511.1 | Core part: Minimization of Drive Tests for E-UTRAN and UTRAN | 391d? | 2009-12-04 A | 2011-06-03 A | 100% | 2009-12-04 | 2011-06-03 | 391d? | finish no earlier than 2011-06-03 | R2; R4; R3 | 9384h | 9384h | MDT_UMTSLTE-Core | PCG-24 | Nokia Siemens Networks | malgorzata.tomala@nsn.com | Rel-10 | RP-46 | Yong-Jun | MDT_UMTSLTE-Core | RP-110528 |  |
| 1995 | 511.2 | Test part: Minimization of Drive Tests for E-UTRAN | 384d? | 2011-09-19 A | 2013-03-01 A | 100% | 2011-09-19 | 2013-03-01 | 384d? | finish no earlier than 2013-03-01 | R5 | 3072h | 3072h | MDT_UMTSLTE-UEConTest | PCG-27 | Ericsson | leif.mattisson@ericsson.com | Rel-10 | RP-53 | Ingbert | MDT_UMTSLTE-UEConTest | RP-130036 |  |
| 1996 | 512 | **HNB and HeNB Mobility Enhancements** | 718d? | 2010-03-19 A | 2012-12-07 A | 100% | 2010-03-19 | 2012-12-07 | 718d? |  | R3; R2; R5 | 23016h | 23016h | HNB_HENB_mob_enh | PCG-24 | Alcatel-Lucent | Martin,Warner@alcatel-lucent.com | Rel-10 | RP-47 | Juha | HNB_HENB_mob_enh |  | HNB |
| 1997 | 512.1 | Core part: HNB and HeNB Mobility Enhancements | 261d? | 2010-03-19 A | 2011-03-18 A | 100% | 2010-03-19 | 2011-03-18 | 261d? | start no earlier than 2010-03-19 | R3; R2 | 4176h | 4176h | HNB_HENB_mob_enh-Core | PCG-24 | Alcatel-Lucent | Martin.Warner@alcatel-lucent.com | Rel-10 | RP-47 | Juha | HNB_HENB_mob_enh-Core | RP-110058 | HNB |
| 1998 | 512.2 | Test part: HeNB Mobility Enhancements | 201d? | 2012-03-05 A | 2012-12-07 A | 100% | 2012-03-05 | 2012-12-07 | 201d? | finish no earlier than 2012-12-07 | R5 | 1608h | 1608h | HNB_HENB_mob_enh-UEConTest_LTE | PCG-28 | Qualcomm | Anjali Mishra (ajha@qualcom.com) | Rel-10 | RP-55 | Ingbert | HNB_HENB_mob_enh-UEConTest_LTE | RP-121533 | HNB |
| 1999 | 513 | **Expanded 1900 MHz Band for UTRA and LTE** | 596d? | 2010-06-04 A | 2012-09-07 A | 100% | 2010-06-04 | 2012-09-07 | 596d? |  | R4; R2; R5 | 25312h | 25312h | E1900 | PCG-25 | Sprint | nick.j.baustert@sprint.com | Rel-10 | RP-48 | Issam | E1900 |  |  |
| 2000 | 513.1 | Core part: Expanded 1900 MHz Band for UTRA and LTE | 261d? | 2010-06-04 A | 2011-06-03 A | 100% | 2010-06-04 | 2011-06-03 | 261d? | finish no earlier than 2011-06-03 | R4; R2 | 4176h | 4176h | E1900-Core | PCG-25 | Sprint | nick.j.baustert@sprint.com | Rel-10 | RP-48 | Issam | E1900-Core | RP-110529 |  |
| 2001 | 513.2 | Perf. part: Expanded 1900 MHz Band for UTRA and LTE | 261d? | 2010-06-04 A | 2011-06-03 A | 100% | 2010-06-04 | 2011-06-03 | 261d? | finish no earlier than 2011-06-03 | R4; R2 | 4176h | 4176h | E1900-Perf | PCG-25 | Sprint | nick.j.baustert@sprint.com | Rel-10 | RP-48 | Issam | E1900-Perf | RP-110530 |  |
| 2002 | 513.3 | Test part: Expanded 1900 MHz Band for UTRA and LTE | 333d? | 2011-06-07 A | 2012-09-07 A | 100% | 2011-06-07 | 2012-09-07 | 333d? | finish no earlier than 2012-09-07 | R5 | 2656h | 2656h | E1900-UEConTest | PCG-27 | Sprint | nick.j.baustert@sprint.com | Rel-10 | RP-52 | Ingbert | E1900-UEConTest | RP-120957 |  |
| 2003 | 514 | **Multi-Standard Radio Base Station RF requirements for non-contiguous spectrum deployments** | 389d? | 2010-06-04 A | 2011-11-25 A | 100% | 2010-06-04 | 2011-11-25 | 389d? |  | R4; G1 | 16160h | 16160h | MSR_NC | PCG-25 | Ericsson | johan.skold@ericsson.com | Rel-10 | RP-48 | Issam | MSR_NC |  |  |
| 2004 | 514.1 | Core part: Multi-Standard Radio BS RF requirements for non-contiguous spectrum deployments | 261d? | 2010-06-04 A | 2011-06-03 A | 100% | 2010-06-04 | 2011-06-03 | 261d? | finish no earlier than 2011-06-03 | R4 | 2088h | 2088h | MSR_NC-Core | PCG-25 | Ericsson | johan.skold@ericsson.com | Rel-10 | RP-48 | Issam | MSR_NC-Core | RP-110531 |  |
| 2005 | 514.2 | Perf. part: Multi-Standard Radio BS RF requirements for non-contiguous spectrum deployments | 336d? | 2010-06-04 A | 2011-09-16 A | 100% | 2010-06-04 | 2011-09-16 | 336d? | finish no earlier than 2011-09-16 | R4 | 2688h | 2688h | MSR_NC-Perf | PCG-25 | Ericsson | johan.skold@ericsson.com | Rel-10 | RP-48 | Issam | MSR_NC-Perf | RP-110988 |  |

Notes:
- 1980: RP#53 completed / Impacted TSs and TRs: LTE
- 1981: RP#51 completed / Impacted TSs and TRs: 25.101, 25.104, 25.141, 25.461, 25.466, 34.124, 36.101, 36.104, 36.113, 36.124, 36.133, 36.307, 37.104, 37.141, new RAN4 TR 36.813
- 1982: RP#52 completed / Impacted TSs and TRs: 34.121-1, 36.101, 36.104, 36.113, 36.124, 36.133, 36.141, 36.307, 36.521-1, 36.813
- 1983: RP#53 completed / Impacted TSs and TRs: 36.508, 36.521-1, 36.521-2, 36.521-3, 36.523-2
- 1984: RP#52 completed / Impacted TSs and TRs: LTE
- 1985: RP#52 completed (Stage 1,2,3) / Impacted TSs and TRs: 36.300, 36.331, 36.413, 36.423
- 1986: RP#51 completed. SA2 decided not to support MBR>GBR in Rel-10 MBMS. For SA2, MBR=GBR in Rel-10 MBMS. Hence RAN removed enabling statistical multiplexing gains for variable bit rate services in Objectives / Impacted TSs and TRs: LTE
- 1987: RP#51 completed / Impacted TSs and TRs: 25.446, 36.300, 36.321, 36.322, 36.323, 36.331, 36.440, 36.441, 36.442, 36.443, 36.444, 36.445
- 1988: RP#55 completed / Impacted TSs and TRs: 36.508, 36.523-1, 36.523-2, 36.523-3
- 1989: - / Impacted TSs and TRs: UTRA, LTE
- 1990: RP#53 completed. TR 37.801v200 for Approval / Impacted TSs and TRs: 25.101, 25.104, 25.113, 25.133, 25.141, 25.307, 25.307, 25.331, 25.461, 25.463, 34.124, 36.101, 36.104, 36.113, 36.141, 36.331, new 37.801
- 1991: RP#60 completed / Impacted TSs and TRs: 36.508, 36.521-1, 36.521-2, 36.521-3
- 1992: RP#56 completed / Impacted TSs and TRs: 34.108, 34.121-1, 34.121-2
- 1993: Triggered by UID_430021 TR 36.805 (Study on Minimization of drive-tests in NGN) / Impacted TSs and TRs: UTRA, LTE
- 1994: RP#52 completed / Impacted TSs and TRs: 25.133, 25.215, 25.304, 25.331, 25.423, 36.133, 36.214, 36.300, 36.304, 36.331, 36.413, 36.423, new 37.320 (Stage 2)
- 1995: RP#59 completed. Testing for LTE only / Impacted TSs and TRs: LTE 34.108, 34.109, 34.123-1, 34.123-2, 34.123-3, 36.508, 36.509, 36.523-1, 36.523-2, 36.523-3
- 1996: - / Impacted TSs and TRs: UTRA, LTE
- 1997: RP#51 completed / Impacted TSs and TRs: 25.413, 25.467, 25.469, 36.300, 36.413, 36.423, new 25.471
- 1998: RP#58 completed / Impacted TSs and TRs: 34.108, 34.123-1, 34.123-2, 34.123-3, 36.508, 36.523-1, 36.523-2, 36.523-3
- 1999: Expand UTRA and E-UTRA band 2 to include frequencies between 1910 1915 MHz and 1990-1995 MHz (US FCC allocation) / Impacted TSs and TRs: UTRA, LTE
- 2000: RP#52 completed / Impacted TSs and TRs: 25.101, 25.104, 25.113, 25.133, 25.141, 25.461, 25.466, 36.101, 36.104, 36.113, 36.124, 36.133, 36.141, 36.307, 36.331, new TR 36.818
- 2001: RP#52 completed / Impacted TSs and TRs: 25.101, 25.104, 25.113, 25.133, 25.141, 25.461, 25.466, 36.101, 36.104, 36.113, 36.124, 36.133, 36.141, 36.307, 36.331, new TR 36.818
- 2002: RP#57 completed / Impacted TSs and TRs: 34.108, 34.121-1, 34.121-2, 34.123-1, 34.123-2, 34.123-3, 36.508, 36.521-1, 36.521-2, 36.521-3, 36.523-1, 36.523-2, 36.523-3
- 2003: - / Impacted TSs and TRs: UTRA, LTE, GERAN
- 2004: RP#52 completed / Impacted TSs and TRs: 25.104, 36.104, 37.104, new TR 37.802
- 2005: RP#53 completed / Impacted TSs and TRs: 25.141, 36.141, 37.141, 37.802

| ID | WBS | Task | Type | Duration | Start | Finish | Complete | Remaining | Baseline start | Baseline finish | Baseline duration | Total slack | Constraint | Resources | Work | Actual work | Acronym | PCG approved | WI rapporteur name | WI rapporteur e-mail | Release | TSG approved | MCC resp | Acronym_3GU_Export | Impacted TSs and TRs | PCG stopped | TSG stopped | Status Report | Special Focus Doc |
| --- | --- | --- | --- | --- | --- | --- | --- | --- | --- | --- | --- | --- | --- | --- | --- | --- | --- | --- | --- | --- | --- | --- | --- | --- | --- | --- | --- | --- | --- |
| 2006 | 514.3 | **GERAN part: Multi-Standard Radio BS RF requirements for non-contiguous spectrum deployments** |  | 324d? | 2010-09-03 A | 2011-11-25 A | 100% |  | 2010-09-03 | 2011-11-25 | 324d? |  |  | G1 | 5160h | 5160h | MSR_NC-GERAN | PCG-25 | Ericsson | mats.y.samuelsson@ericsson.com | Rel-10 | GP-47 | Paolo | MSR_NC-GERAN |  |  |  |  |  |
| 2007 | 514.3.1 | GERAN Core part: Multi-Standard Radio BS RF requirements for non-contiguous spectrum deployments |  | 261d? | 2010-09-03 A | 2011-09-02 A | 100% |  | 2010-09-03 | 2011-09-02 | 261d? |  | finish no earlier than 2011-09-02 | G1 | 2088h | 2088h | MSR_NC-GERAN | PCG-25 | Ericsson | mats.y.samuelsson@ericsson.com | Rel-10 | GP-47 | Paolo |  | 45.005 |  |  |  |  |
| 2008 | 514.3.2 | GERAN BS Test part: Multi-Standard Radio BS RF requirements for non-contiguous spectrum deployments |  | 62d? | 2011-09-02 A | 2011-11-25 A | 100% |  | 2011-09-02 | 2011-11-25 | 62d? |  | finish no earlier than 2011-11-25 | G1 | 496h | 496h | MSR_NC-GERAN | PCG-28 | Ericsson | mats.y.samuelsson@ericsson.com | Rel-10 | GP-52 | Paolo |  | 51.021 |  |  |  |  |
| 2009 | 515 | (Small) Technical Enhancements and Improvements for Rel-10 |  | 470d? | 2009-06-04 A | 2011-03-23 A | 100% |  | 2009-06-04 | 2011-03-23 | 470d? |  | finish no earlier than 2011-03-23 | SP; CP; RP; GP | 15040h | 15040h | TEI10 | PCG-23 |  |  | Rel-10 | SP-44 |  | TEI10 |  |  |  |  |  |
| 2010 | 516 | (IETF) (Small) Technical Enhancements and Improvements for Rel-10 (draft-atarius) |  | 1244d? | 2009-06-04 A | 2014-12-09 | 75% | 312.5d? | 2009-06-04 | 2014-12-05 | 1242d? | 657d | finish no earlier than 2014-12-09 | C1-IETF | 9952h | 7452h | TEI10_IETF | PCG-27 | Andrew Allen | Andrew Allen | Rel-10 | CP-52 | Frederic | TEI10_IETF | draft-atarius-dispatch-meid-urn |  |  |  |  |
| 2011 | 517 | (IETF) (Small) Technical Enhancements and Improvements for Rel-10 (RFC6275) |  | 562d? | 2009-06-04 A | 2011-07-29 A | 100% |  | 2009-06-04 | 2011-07-29 | 562d? |  | finish no earlier than 2011-07-29 | C1-IETF | 4496h | 4496h | TEI10_IETF1 | PCG-27 |  |  | Rel-10 | CP-53 | Frederic | TEI10_IETF1 | RFC 6275 (was draft-ietf-mext-rfc3775bis) |  |  |  |  |
| 2012 | 518 | Test - (Small) Technical Enhancements and Improvements for Rel-10 |  | 271d? | 2011-12-01 A | 2012-12-07 A | 100% |  | 2011-12-01 | 2012-12-07 | 271d? |  | finish no earlier than 2012-12-07 | R5; G3new | 4336h | 4336h | TEI10_Test | PCG-28 | n/a |  | Rel-10 | RP-54 | Ingbert | TEI10_Test |  |  |  |  |  |
| 2013 | 519 | **Deleted - Registration in Densely-populated area (RED)** |  | 665d? | 2007-03-12 A | 2009-09-24 A | 100% |  | 2007-03-12 | 2009-09-24 | 665d? |  |  | S1 | 9544h | 9544h | RED |  | NTT DoCoMo | tanakai@nttdocomo.co.jp | Rel-10 | SP-35 | Alain | RED |  | PCG-24 | SP-46 |  |  |
| 2014 | 519.1 | Deleted - Stage 1 for RED |  | 4d? | 2007-03-12 A | 2007-03-15 A | 100% |  | 2007-03-12 | 2007-03-15 | 4d? |  | start no earlier than 2007-03-12 | S1 | 32h | 32h | RED |  | NTT DoCoMo | takakurat@s1.nttdocomo.co.jp | Rel-10 | SP-35 | Alain |  | 22.101 CR#0207 | PCG-24 | SP-46 |  |  |
| 2015 | 519.2 | Deleted - Stage 2 for RED |  | 524d? | 2007-09-25 A | 2009-09-24 A | 100% |  | 2007-09-25 | 2009-09-24 | 524d? |  | finish no earlier than 2009-09-24 | S2 | 4192h | 4192h | RED |  | NTT DoCoMo | tanakai@nttdocomo.co.jp | Rel-10 | SP-37 | Maurice |  | draft TR 23.880 withdrawn, 23.002, 23.060, 23.221, 23.236 | PCG-23 | SP-45 |  |  |
| 2016 | 520 | **Deleted - Network Selection for non-3GPP Access** |  | 471d? | 2007-12-07 A | 2009-09-24 A | 100% |  | 2007-12-07 | 2009-09-24 | 471d? |  |  | S1; C6 | 15072h | 15072h | N3GtoNSP | PCG-21 | Telefónica O2 | chris.friel@O2.com | Rel-10 | SP-38 | Alain | N3GtoNSP |  | PCG-23 | SP-45 |  |  |
| 2017 | 520.1 | Deleted - Stage 1 for N3GtoNSP |  | 471d? | 2007-12-07 A | 2009-09-24 A | 100% |  | 2007-12-07 | 2009-09-24 | 471d? |  | finish no earlier than 2009-12-10 | S1 | 3768h | 3768h | N3GtoNSP | PCG-21 | Telefónica O2 | chris.friel@O2.com | Rel-10 | SP-38 | Alain |  | 22.011 | PCG-23 | SP-45 |  |  |
| 2018 | 520.2 | Deleted - CT6 issues for N3GtoNSP |  | 471d? | 2007-12-07 A | 2009-09-24 A | 100% |  | 2007-12-07 | 2009-09-24 | 471d? |  | finish no earlier than 2009-12-04 | C6 | 3768h | 3768h | N3GtoNSP | PCG-21 | Telefónica O2 | chris.friel@O2.com | Rel-10 | CP-38 | Xavier |  | 36.300 | PCG-23 | CP-45 |  |  |
| 2019 | 521 | **Deleted - GTP-based S8 chaining** |  | 337d? | 2008-12-11 A | 2010-03-25 A | 100% |  | 2008-12-11 | 2010-03-25 | 337d? |  |  | S2 | 5392h | 5392h | GTPchaining | PCG-22 | Huawei | Haining Wang (wanghaining@huawei.com) | Rel-10 | SP-42 | Maurice | GTPchaining |  | PCG-24 | SP-47 |  |  |
| 2020 | 521.1 | Deleted - Stage 2 for GTPchaining |  | 337d? | 2008-12-11 A | 2010-03-25 A | 100% |  | 2008-12-11 | 2010-03-25 | 337d? |  | finish no earlier than 2010-03-25 | S2 | 2696h | 2696h | GTPchaining | PCG-22 | Huawei | Haining Wang (wanghaining@huawei.com) | Rel-10 | SP-42 | Maurice |  | 23.402 | PCG-24 | SP-47 |  |  |
| 2021 | 522 | Deleted - UTRAN 2 ms TTI uplink range improvement |  | 272d? | 2009-03-06 A | 2010-03-19 A | 100% |  | 2009-03-06 | 2010-03-19 | 272d? |  | finish no earlier than 2010-03-19 | R1; R2; R3; R4 | 8704h | 8704h | RANimp-2mTTI_ULimp | PCG-22 | Nokia Siemens Networks | Karri Ranta-aho (karri.ranta-aho@nsn.com) | Rel-10 | RP-43 | Patrick | RANimp-2mTTI_ULimp | 25.133, 25.212, 25.214, 25.321, 25.331 | PCG-24 | RP-47 | RP-100040 |  |
| 2022 | 523 | Deleted - Enhanced Home NodeB / eNodeB continuation of Rel-9 |  | 337d? | 2008-12-11 A | 2010-03-25 A | 100% |  | 2008-12-11 | 2010-03-25 | 337d? |  |  | S2 | 2696h | 2696h | eEHNB | PCG-23 | Alcatel-Lucent | Nicolas Drevon | Rel-10 | SP-44 | Maurice | eEHNB |  | PCG-24 | SP-47 |  | HNB |
| 2023 | 524 | **Deleted - Fixed Wireless Customer-Premises Equipment (CPE) RF Requirements** |  | 391d? | 2009-12-04 A | 2011-06-03 A | 100% |  | 2009-12-04 | 2011-06-03 | 391d? |  |  | R4; R5 | 12512h | 12512h | FW_CPE_RF | PCG-24 | Verizon Wireless | zheng.zhao@verizonwireless.com | Rel-10 | RP-46 | Issam | FW_CPE_RF | LTE | PCG-27 | RP-52 |  |  |
| 2024 | 524.1 | Deleted - Core part: Fixed Wireless Customer-Premises Equipment (CPE) RF Requirements |  | 391d? | 2009-12-04 A | 2011-06-03 A | 100% |  | 2009-12-04 | 2011-06-03 | 391d? |  | finish no earlier than 2011-06-03 | R4 | 3128h | 3128h | FW_CPE_RF-Core | PCG-24 | Verizon Wireless | zheng.zhao@verizonwireless.com | Rel-10 | RP-46 | Issam | FW_CPE_RF-Core | 36.101 | PCG-27 | RP-52 | RP-110539 |  |
| 2025 | 524.2 | Deleted - Test part: Fixed Wireless Customer-Premises Equipment (CPE) RF Requirements |  | 391d? | 2009-12-04 A | 2011-06-03 A | 100% |  | 2009-12-04 | 2011-06-03 | 391d? |  | finish no earlier than 2011-06-03 | R5 | 3128h | 3128h | FW_CPE_RF-UEConTest | PCG-24 | Verizon Wireless | zheng.zhao@verizonwireless.com | Rel-10 | RP-46 | Ingbert | FW_CPE_RF-UEConTest | 36.521-1 | PCG-27 | RP-52 | RP-110504 |  |
| 2026 | 525 | **Deleted - Latency reductions for LTE** |  | 266d? | 2009-12-04 A | 2010-12-10 A | 100% |  | 2009-12-04 | 2010-12-10 | 266d? |  |  | R2; R1 | 8512h | 8512h | LTE_LATRED | PCG-24 | Ericsson | henrik.enbuske@ericsson.com | Rel-10 | RP-46 | Yong-Jun | LTE_LATRED | LTE | PCG-26 | RP-50 |  |  |
| 2027 | 525.1 | Deleted - Core part: Latency reductions for LTE |  | 266d? | 2009-12-04 A | 2010-12-10 A | 100% |  | 2009-12-04 | 2010-12-10 | 266d? |  | finish no earlier than 2010-12-10 | R2; R1 | 4256h | 4256h | LTE_LATRED-Core | PCG-24 | Ericsson | henrik.enbuske@ericsson.com | Rel-10 | RP-46 | Yong-Jun | LTE_LATRED-Core | 36.213, 36.300, 36.306, 36.321, 36.331 | PCG-26 | RP-50 | RP-101112 |  |
| 2028 | 526 | **Deleted - Enhanced Interference Management for Home NodeBs** |  | 131d? | 2010-03-19 A | 2010-09-17 A | 100% |  | 2010-03-19 | 2010-09-17 | 131d? |  |  | R3 | 2096h | 2096h | HNB_IM | PCG-24 | Qualcomm | Andrei Radulescu (aradules@qualcomm.com) | Rel-10 | RP-47 | Juha | HNB_IM | UTRA | PCG-25 | RP-49 | RP-100754 | HNB |
| 2029 | 526.1 | Deleted - Core part: Enhanced Interference Management for Home NodeBs |  | 131d? | 2010-03-19 A | 2010-09-17 A | 100% |  | 2010-03-19 | 2010-09-17 | 131d? |  | finish no earlier than 2010-09-17 | R3 | 1048h | 1048h | HNB_IM-Core | PCG-24 | Qualcomm | Andrei Radulescu (aradules@qualcomm.com) | Rel-10 | RP-47 | Juha | HNB_IM-Core | 25.413, 25.467, 25.469 | PCG-25 | RP-49 | RP-100754 | HNB |
| 2030 | 527 | Release 10 Studies | milestone | 0d? | 2009-03-12 A | 2009-03-12 A | 100% |  | 2009-03-12 | 2011-03-23 | 531d? |  | finish no earlier than 2011-03-23 | CP; GP; RP; SP |  |  |  |  |  |  | Rel-10 |  |  |  |  |  |  |  |  |

Notes:
- 2006: -
- 2007: GP#51 completed. GP#47 approved WID
- 2008: GP#52 completed
- 2009: -
- 2010: Not completed internet-draft, waiting for draft-montemurro to complete
- 2011: SP#53/IETF#81: RFC 6275 completed
- 2012: -
- 2013: SP#35 Stage 1 completed. SP#45 Stage 2 work stopped. SP#46 work stopped/abandoned
- 2014: SP#35 completed. SP#46 work stopped/abandoned
- 2015: SP#45 Stage 2 work stopped
- 2016: SP#45 work stopped/abandoned
- 2017: SP#45 work stopped/abandoned
- 2018: SP#45 work stopped/abandoned
- 2019: SP#47 work stopped (depending on ongoing related CT4 work). Stage 1 in UID_320022 Rel-8 Requirements for evolution of the 3GPP system architecture (AIPN-SAE): 22.278, 22.011, 22.246
- 2020: SP#47 work stopped
- 2021: RP#47 work stopped/abandoned (no CR approved). Cell sets the TTI (Transmission Time Interval) to 2 ms
- 2022: SP#47 deleted (SA2 work moved under SA1 UID_450053). SP#44 Umbrella Feature created to host WIs moved out of Rel-9 (SA2 UID_420034 on IMS aspects of Architecture for Home NodeB)
- 2023: RP#52 work stopped (lack of contributions). Add new power classes in E-UTRAN UL to allow CPE type applications to be operated at higher max output power
- 2024: RP#52 work stopped at 55% (lack of contributions)
- 2025: RP#52 work stopped (lack of contributions)
- 2026: RP#50 work stopped (RP-101266)
- 2027: RP#50 work stopped (RP-101266)
- 2028: RP#49 stopped (no further standardization needed). Ensure that Enhanced Interference Management methods identified in Rel-9 for HNBs do not fail in deployments with a large penetration of CSG-aware UEs
- 2029: RP#49 stopped (no further standardization needed)
- 2030: -

| ID | WBS | Task | Type | Duration | Start | Finish | Complete | Baseline start | Baseline finish | Baseline duration | Constraint | Resources | Work | Actual work | Acronym | Impacted TSs and TRs | WI rapporteur name | Release | TSG approved | MCC resp | Acronym_3GU_Export | PCG approved | Status Report | PCG stopped | TSG stopped |
| --- | --- | --- | --- | --- | --- | --- | --- | --- | --- | --- | --- | --- | --- | --- | --- | --- | --- | --- | --- | --- | --- | --- | --- | --- | --- |
| 2031 | 528 | **Study on enhanced voice service requirements for the Evolved Packet System (EPS)** |  | 670d? | 2007-09-03 A | 2010-03-25 A | 100% | 2007-09-03 | 2010-03-25 | 670d? |  | S1; S4 | 18744h | 18744h | FS_EV_EPS | 22.813 | France Telecom | Rel-10 | SP-37 | Alain | FS_EV_EPS |  |  |  |  |
| 2032 | 528.1 | Use cases definition and service and system requirements |  | 334d? | 2007-09-03 A | 2008-12-11 A | 100% | 2007-09-03 | 2008-12-11 | 334d? | finish no earlier than 2008-12-11 | S1 | 2672h | 2672h | FS_EV_EPS-S1 | 22.813 | France Telecom | Rel-10 | SP-37 | Alain | FS_EV_EPS-S1 |  |  |  |  |
| 2033 | 528.2 | Codec specific part of FS_EV_EPS |  | 669d? | 2007-09-03 A | 2010-03-25 A | 100% | 2007-09-03 | 2010-03-25 | 669d? | finish no earlier than 2010-03-25 | S4 | 5352h | 5352h | FS_EV_EPS-S4 | 22.813 | Ericsson | Rel-10 | SP-37 | Paolo | FS_EV_EPS-S4 |  |  |  |  |
| 2034 | 529 | Study on advanced requirements for IP interconnect |  | 528d? | 2007-12-04 A | 2009-12-10 A | 100% | 2007-12-04 | 2009-12-10 | 528d? | finish no earlier than 2009-12-10 | S1 | 4224h | 4224h | FS_IPXS | 22.893 | Telefónica O2 | Rel-10 | SP-38 | Alain | FS_IPXS | PCG-21 |  |  |  |
| 2035 | 530 | Study on Personal Broadcast Service |  | 397d? | 2008-09-18 A | 2010-03-25 A | 100% | 2008-09-18 | 2010-03-25 | 397d? | finish no earlier than 2010-03-25 | S1 | 3168h | 3168h | FS_PBS | 22.947 | ETRI | Rel-10 | SP-41 | Alain | FS_PBS | PCG-21 |  |  |  |
| 2036 | 531 | Study on LCS support in SAE for non-3GPP accesses |  | 397d? | 2008-09-18 A | 2010-03-25 A | 100% | 2008-09-18 | 2010-03-25 | 397d? | finish no earlier than 2010-03-25 | S1 | 3168h | 3168h | FS_LCS_n3GPP | 22.814 | SK Telecom | Rel-10 | SP-41 | Alain | FS_LCS_n3GPP | PCG-21 |  |  |  |
| 2037 | 532 | Study on Haptic Services |  | 272d? | 2009-03-12 A | 2010-03-25 A | 100% | 2009-03-12 | 2010-03-25 | 272d? | finish no earlier than 2010-03-25 | S1 | 2168h | 2168h | FS_Haptics | 22.987 | SK Telecom | Rel-10 | SP-43 | Alain | FS_Haptics | PCG-22 |  |  |  |
| 2038 | 533 | Study on System enhancements for the use of IMS services in Local BreakOut and Optimal Routing of Media |  | 575d? | 2007-10-01 A | 2009-12-10 A | 100% | 2007-10-01 | 2009-12-10 | 575d? | finish no earlier than 2009-12-10 | S2 | 4600h | 4600h | FS_IMS_LBO_ORM | 23.894 | Telecom Italia, BT | Rel-10 | SP-37 | Maurice | FS_IMS_LBO_ORM |  |  |  |  |
| 2039 | 534 | Study on Intra Domain Connection of RAN Nodes to Multiple CN Nodes |  | 533d? | 2008-03-12 A | 2010-03-25 A | 100% | 2008-03-12 | 2010-03-25 | 533d? | finish no earlier than 2010-03-25 | S2 | 4264h | 4264h | FS_IDC | 23.924 (was 23.823) | China Mobile | Rel-10 | SP-39 | Maurice | FS_IDC | PCG-21 |  |  |  |
| 2040 | 535 | Study on Single Radio Voice Call Continuity enhancements |  | 341d? | 2009-06-04 A | 2010-09-23 A | 100% | 2009-06-04 | 2010-09-23 | 341d? | finish no earlier than 2010-09-23 | S2 | 2728h | 2728h | FS_eSRVCC | 23.856 | China Mobile | Rel-10 | SP-44 | Maurice | FS_eSRVCC | PCG-23 |  |  |  |
| 2041 | 536 | Study on Single Radio Video Call Continuity for 3G-CS |  | 131d? | 2010-03-25 A | 2010-09-23 A | 100% | 2010-03-25 | 2010-09-23 | 131d? | finish no earlier than 2010-09-23 | S2 | 1048h | 1048h | FS_vSRVCC | 23.886 | Samsung | Rel-10 | SP-47 | Maurice | FS_vSRVCC | PCG-24 |  |  |  |
| 2042 | 537 | Study on S2b Mobility based on GTP |  | 56d? | 2010-03-25 A | 2010-06-10 A | 100% | 2010-03-25 | 2010-06-10 | 56d? | finish no earlier than 2010-06-07 | S2 | 448h | 448h | FS_SMOG | 23.834 | Alcatel-Lucent | Rel-10 | SP-47 | Maurice | FS_SMOG | PCG-24 |  |  |  |
| 2043 | 538 | Study on Surround Sound codec extension for PSS and MBMS |  | 530d? | 2009-03-12 A | 2011-03-23 A | 100% | 2009-03-12 | 2011-03-23 | 530d? | finish no earlier than 2011-03-23 | S4 | 4240h | 4240h | FS_SS_PSS_MBMS | 26.950 | Fraunhofer Gesellschaft | Rel-10 | SP-43 | Paolo | FS_SS_PSS_MBMS | PCG-22 |  |  |  |
| 2044 | 539 | Study on Improved Video Coding Support |  | 205d? | 2010-06-10 A | 2011-03-23 A | 100% | 2010-06-10 | 2011-03-23 | 205d? | finish no earlier than 2011-03-23 | S4 | 1640h | 1640h | FS_IVCS | 26.904 | Nokia, ETRI | Rel-10 | SP-48 | Paolo | FS_IVCS | PCG-25 |  |  |  |
| 2045 | 540 | Study on Rc Reference Point Functionalities and Message Flows |  | 397d? | 2008-09-18 A | 2010-03-25 A | 100% | 2008-09-18 | 2010-03-25 | 397d? | finish no earlier than 2010-03-23 | S5 | 3170.08h | 3170.08h | FS_OAM_Rc | 32.825 | Huawei | Rel-10 | SP-41 | Mirko | FS_OAM_Rc | PCG-21 |  |  |  |
| 2046 | 541 | Study on Telecommunication Management; Energy Savings Management |  | 271d? | 2009-03-12 A | 2010-03-25 A | 100% | 2009-03-12 | 2010-03-25 | 271d? | finish no earlier than 2010-03-25 | S5 | 2168h | 2168h | FS_OAM_ESM | 32.826 | Orange, Vodafone | Rel-10 | SP-43 | Mirko | FS_OAM_ESM | PCG-22 |  |  |  |
| 2047 | 542 | Study on Integration of Device Management Information with Itf-N |  | 211d? | 2009-06-04 A | 2010-03-25 A | 100% | 2009-06-04 | 2010-03-25 | 211d? | finish no earlier than 2010-03-25 | S5 | 1688h | 1688h | FS_IDMI_Itf-N | 32.827 | Motorola | Rel-10 | SP-44 | Mirko | FS_IDMI_Itf-N | PCG-23 |  |  |  |
| 2048 | 543 | Study on Alignment of 3GPP Generic NRM IRP and TMF Shared Information Data (SID) model |  | 335d? | 2009-12-10 A | 2011-03-23 A | 100% | 2009-12-10 | 2011-03-23 | 335d? | finish no earlier than 2011-03-23 | S5 | 2680h | 2680h | FS_3GNRM_TMFSID | 32.828 | Nokia Siemens Networks | Rel-10 | SP-46 | Mirko | FS_3GNRM_TMFSID | PCG-24 |  |  |  |
| 2049 | 544 | Study on Harmonization of 3GPP Alarm IRP and TMF Interface Program (TIP) Fault Management |  | 335d? | 2009-12-10 A | 2011-03-23 A | 100% | 2009-12-10 | 2011-03-23 | 335d? | finish no earlier than 2011-03-23 | S5 | 2680h | 2680h | FS_3G_TMF_FM | 32.829 | Nokia Siemens Networks, Alcatel-Lucent | Rel-10 | SP-46 | Mirko | FS_3G_TMF_FM | PCG-24 |  |  |  |
| 2050 | 545 | Study on Alarm Correlation and Alarm Root Cause Analysis |  | 205d? | 2010-06-10 A | 2011-03-23 A | 100% | 2010-06-10 | 2011-03-23 | 205d? | finish no earlier than 2011-03-23 | S5 | 1640h | 1640h | FS_AC_ARCA | 32.832 | Ericsson | Rel-10 | SP-48 | Mirko | FS_AC_ARCA | PCG-25 |  |  |  |
| 2051 | 546 | Study on Alignment of 3GPP PM IRP and TMF Interface Program (TIP) PM |  | 205d? | 2010-06-10 A | 2011-03-23 A | 100% | 2010-06-10 | 2011-03-23 | 205d? | finish no earlier than 2011-03-23 | S5 | 1640h | 1640h | FS_3G_TMF_PM | 32.831 | Alcatel-Lucent | Rel-10 | SP-48 | Mirko | FS_3G_TMF_PM | PCG-25 |  |  |  |
| 2052 | 547 | Study on Policy and Charging Rules Function (PCRF) failure and restoration |  | 261d? | 2009-08-18 A | 2010-09-17 A | 100% | 2009-08-18 | 2010-09-17 | 261d? | finish no earlier than 2010-09-17 | C3 | 2088h | 2088h | FS_PCRF-FR | 29.816 | NEC | Rel-10 | CP-45 | Adrian | FS_PCRF-FR | PCG-23 |  |  |  |
| 2053 | 548 | Study on User Data Convergence (UDC) evolution |  | 206d? | 2010-06-04 A | 2011-03-18 A | 100% | 2010-06-04 | 2011-03-18 | 206d? | finish no earlier than 2011-03-18 | C4 | 1648h | 1648h | FS_UDCe | 23.845 | Alcatel-Lucent | Rel-10 | CP-48 | Kimmo | FS_UDCe | PCG-25 |  |  |  |
| 2054 | 549 | Study on UICC access to IMS |  | 206d? | 2010-06-04 A | 2011-03-18 A | 100% | 2010-06-04 | 2011-03-18 | 206d? | finish no earlier than 2011-03-18 | C6 | 1648h | 1648h | FS_IMS-UICC | 31.828 | Gemalto | Rel-10 | CP-48 | Xavier | FS_IMS-UICC | PCG-25 |  |  |  |
| 2055 | 550 | Study on Uplink Tx Diversity for HSPA |  | 208.4d? | 2009-08-18 A | 2010-06-04 A | 100% | 2009-08-18 | 2010-06-04 | 208.4d? | finish no earlier than 2010-06-04 | R4 | 1667.2h | 1667.2h | FS_UL-TxDiv-HSPA | UTRA 25.863 | Qualcomm | Rel-10 | RP-45 | Issam | FS_UL-TxDiv-HSPA | PCG-23 | RP-100499 |  |  |
| 2056 | 551 | Study on Solutions for Energy Saving within UTRA Node B |  | 206d? | 2009-12-04 A | 2010-09-17 A | 100% | 2009-12-04 | 2010-09-17 | 206d? | finish no earlier than 2010-09-17 | R1; R3 | 3296h | 3296h | FS_Energy_UMTS | UTRA 25.927 | Vodafone | Rel-10 | RP-46 | Patrick | FS_Energy_UMTS | PCG-24 | RP-100796 |  |  |
| 2057 | 552 | Study on Potential solutions for energy saving for E-UTRAN |  | 348.75d? | 2010-02-02 A | 2011-06-03 A | 100% | 2010-02-02 | 2011-06-03 | 348.75d? | finish no earlier than 2011-06-03 | R3; R2 | 5580h | 5580h | FS_Energy_LTE | LTE 36.927 | China Mobile | Rel-10 | RP-47 | Juha | FS_Energy_LTE | PCG-24 | RP-110597 |  |  |
| 2058 | 553 | Study on Improvements of distributed antenna for 1.28Mcps TDD |  | 200.55d? | 2010-03-05 A | 2010-12-10 A | 100% | 2010-03-05 | 2010-12-10 | 200.55d? | finish no earlier than 2010-12-10 | R1; R2; R3 | 4813.2h | 4813.2h | FS_distr_ant_LCR_TDD | UTRA 25.865 | ZTE | Rel-10 | RP-47 | Patrick | FS_distr_ant_LCR_TDD | PCG-24 | RP-101287 |  |  |
| 2059 | 554 | Deleted - Study on Unauthenticated PS Emergency Calls |  | 471d? | 2008-06-05 A | 2010-03-25 A | 100% | 2008-06-05 | 2010-03-25 | 471d? | finish no earlier than 2010-03-25 | S1 | 3768h | 3768h | FS_UAPSEC | 22.984 | Nokia Siemens Networks | Rel-10 | SP-40 | Alain | FS_UAPSEC | PCG-21 |  | PCG-24 | SP-47 |
| 2060 | 555 | Deleted - Study on enhancements to IMS border functions for IMS Interconnection of services |  | 586d? | 2008-09-18 A | 2010-12-15 A | 100% | 2008-09-18 | 2010-12-15 | 586d? | finish no earlier than 2010-12-15 | S2 | 4688h | 4688h | FS_eIMS_IBCF | 23.848 | Starent Networks | Rel-10 | SP-41 | Maurice | FS_eIMS_IBCF | PCG-21 |  | PCG-26 | SP-50 |
| 2061 | 556 | Deleted - Study on EPC Charging enhancement |  | 211d? | 2009-06-04 A | 2010-03-25 A | 100% | 2009-06-04 | 2010-03-25 | 211d? | finish no earlier than 2010-03-25 | S5 | 1688h | 1688h | FS_EPCcharg |  | Nokia Siemens Networks | Rel-10 | SP-44 | Mirko | FS_EPCcharg | PCG-23 |  | PCG-24 | SP-47 |
| 2062 | 557 | Deleted - Study on Interworking Proxy between GTP based and PMIP based interfaces |  | 186d? | 2009-09-18 A | 2010-06-04 A | 100% | 2009-09-18 | 2010-06-04 | 186d? | finish no earlier than 2010-06-04 | C4 | 1488h | 1488h | FS_GTP-MIP-IW | 29.875 | NTT DoCoMo | Rel-10 | CP-45 | Kimmo | FS_GTP-MIP-IW | PCG-23 |  | PCG-25 | CP-48 |
| 2063 | 558 | Release 9 Features | milestone | 0d? | 2000-01-01 A | 2000-01-01 A | 100% | 2000-01-01 | 2000-01-01 | 0d? |  | CP; GP; RP; SP |  |  |  |  |  | Rel-9 |  |  |  |  |  |  |  |

Notes:
- 2031: SP#47 completed. TR 22.813-100 for Approval. Spin-off Feature UID_470030 Codec for Enhanced Voice Services / WI rapporteur e-mail: philippe.lottin@orange.com
- 2032: SP#47 completed. TR 22.813-100 for Approval / WI rapporteur e-mail: philippe.lottin@orange.com
- 2033: SP#47 completed. TR 22.813-100 for Approval / WI rapporteur e-mail: stefan.bruhn@ericson.com
- 2034: SP#46 completed. Linked to Rel-8 Feature UID_380060 IP Interconnection of Services (IPinterc). Spin-off Feature Rel-11 UID_470051 Advanced IP Interconnection of Services / WI rapporteur e-mail: chris.friel@O2.com
- 2035: SP#47 completed / WI rapporteur e-mail: Jaihyung Cho
- 2036: SP#47 completed / WI rapporteur e-mail: jinhan.song@sktelecom.com
- 2037: SP#47 completed. Covers Mobile/Fixed/Cordless/etc terminals. Haptic (human-machine tactile communication) extend service offering & richness of user experience beyond current visual & auditory senses / WI rapporteur e-mail: jinhan.song@sktelecom.com
- 2038: SP#46 completed. Spin-off Feature UID_460028 Optimal Media Routeing (OMR). Linked to Study on Multimedia Session Continuity UID_350051, Study on Centralized IMS Service Control UID_330012, IMS inter-operator service interconnection interface UID_360011 / WI rapporteur e-mail: mario.madella@telecomitalia.it, victor.kueh@bt.com
- 2039: SP#47 completed. Concluded no further normative work expected. Linked to 23.236 / WI rapporteur e-mail: LIU HONG (liuhongyfw@chinamobile.com)
- 2040: SP#49 completed (Conclusion: select the SIP anchoring based solution for normative work CR (TEI10) introducing and completing stage-2). Analyzed performance of Rel-8 SRVCC solution from E-UTRAN/HSPA to UTRAN/GERAN / WI rapporteur e-mail: Hou zhiqiang (houzhiqiang@chinamobile.com), Jiang Yi (jiangyi@chinamobile.com)
- 2041: SP#49 completed. TR 23.886v100 for Approval. Related to Rel-8 UID_350030 Single Radio Voice Call Continuity for 3GPP (SAES-SRVCC). Study how to provide Video Call seamless service continuity for 3G/LTE terminal user / WI rapporteur e-mail: Haris Zisimopoulos (haris.z@samsung.com)
- 2042: SP#48 completed. Triggered by Rel-8 UID_350027 SAE for support for non-3GPP accesses. Nature of relationship: S2b one of the interfaces defined for non-3GPP accesses support in EPS. Stage 1 in Rel-8 UID_320022 (AIPN-SAE) 22.278,22.101 / WI rapporteur e-mail: bruno.landais@alcatel-lucent.com
- 2043: SP#51 completed. Extend Rel-8 UID_34043 (Extending PSS and MBMS User Services for optimized Mobile TV) / WI rapporteur e-mail: jan.plogsties@iis.franhofer.de
- 2044: SP#51 completed. Extends Rel-9 Improved Video Support for PSS and MBMS (UID_430039) / WI rapporteur e-mail: imed.bouazizi@nokia.com, jaihyung@etri.re.kr
- 2045: SP#47 completed / WI rapporteur e-mail: shan.mingjun@huawei.com
- 2046: SP#47 completed. Study result might impact Feature UID_420011 Self Organising Networks (SON) / WI rapporteur e-mail: Jean-Michel Cornilly (Orange)
- 2047: SP#47 completed / WI rapporteur e-mail: Yizhi Yao (yzyao@motorola.com)
- 2048: SP#51 completed / WI rapporteur e-mail: olaf.pollakowski@nsn.com
- 2049: SP#51 completed / WI rapporteur e-mail: olaf.pollakowski@nsn.com, Padma.Sudarsan@alcatel-lucent.com
- 2050: SP#51 completed / WI rapporteur e-mail: edwin.tse@ericsson.com
- 2051: SP#51 completed / WI rapporteur e-mail: Padma.Sudarsan@alcatel-lucent.com
- 2052: CP#49 completed / WI rapporteur e-mail: gottfried.punz@nw.neclab.eu
- 2053: CP#51 completed. Study UDC evolution from Features in Rel-9 UID_400034 and Rel-10 UID_480011 UDC Data Model / WI rapporteur e-mail: jean-jacques.trottin@alcatel-lucent.com
- 2054: CP#51 completed / WI rapporteur e-mail: Denis.Lheriteau@gemalto.com
- 2055: RP#48 completed / WI rapporteur e-mail: Heechoon Lee (heechoon@qualcomm.com)
- 2056: RP#49 completed. Based on ETSI EE TS 102 706. / WI rapporteur e-mail: Prakash.bhat@vodafone.com
- 2057: RP#52 completed / WI rapporteur e-mail: Yang Ning (yangning@chinamobile.com)
- 2058: RP#50 completed. TR 25.865 v101 for Approval / WI rapporteur e-mail: huang.he4@zte.com.cn
- 2059: SP#47 work stopped/abandoned / WI rapporteur e-mail: Juergen.Merkel@nsn.com
- 2060: SP#50 work stopped. Additional work may be addressed as part of the Rel-11 Feature UID_470051 Advanced IP Interconnection of Services (IPXS) / WI rapporteur e-mail: Rajat Ghai (rghai@starentnetworks.com)
- 2061: SP#47 work stopped. Issue covered by Rel-10 UID_460039 Charging for LIPA_SIPTO and UID_4700xy Charging for IFOM / WI rapporteur e-mail: Gerald.Goermer@nsn.com
- 2062: CP#48 work stopped/abandoned / WI rapporteur e-mail: takaaki.matsuura.sp@s1.nttdocomo.com
- 2063: -

| ID | WBS | Task | Duration | Start | Finish | Complete | Baseline start | Baseline finish | Baseline duration | Constraint | Resources | Work | Actual work | Acronym | PCG approved | WI rapporteur name | WI rapporteur e-mail | Release | TSG approved | MCC resp | Special Focus Doc | Acronym_3GU_Export | Status Report |
| --- | --- | --- | --- | --- | --- | --- | --- | --- | --- | --- | --- | --- | --- | --- | --- | --- | --- | --- | --- | --- | --- | --- | --- |
| 2064 | 559 | **Enhanced Home NodeB / eNodeB** | 921d? | 2008-06-05 A | 2011-12-09 A | 100% | 2008-06-05 | 2011-12-09 | 921d? |  | S1; S2; S3; S5; C1; C6; R2; R3; R4; R5; GP | 113136h | 113136h | EHNB | PCG-21 | T-Mobile | michael.kurz@t-mobile.at | Rel-9 | SP-40 | Alain | HNB | EHNB |  |
| 2065 | 559.1 | Stage 1 for EHNB | 261d? | 2008-06-05 A | 2009-06-04 A | 100% | 2008-06-05 | 2009-06-04 | 261d? | finish no earlier than 2009-06-04 | S1 | 2088h | 2088h | EHNB | PCG-21 | T-Mobile | michael.kurz@t-mobile.at | Rel-9 | SP-40 | Alain | HNB |  |  |
| 2066 | 559.2 | Architecture aspects of EHNB | 266d? | 2008-09-18 A | 2009-09-24 A | 100% | 2008-09-18 | 2009-09-24 | 266d? | finish no earlier than 2009-09-22 | S2 | 2128h | 2128h | EHNB | PCG-21 | T-Mobile | sebastian.speicher@telekom.de | Rel-9 | SP-41 | Maurice | HNB |  |  |
| 2067 | 559.3 | Security aspects of Enhanced Home NodeB / eNodeB | 262d? | 2008-12-11 A | 2009-12-10 A | 100% | 2008-12-11 | 2009-12-10 | 262d? | finish no earlier than 2009-12-10 | S3 | 2096h | 2096h | EHNB-Sec | PCG-22 | Huawei | Marcus Wong (mwong@huawei.com) | Rel-9 | SP-42 | Mirko | HNB | EHNB-Sec |  |
| 2068 | 559.4 | CT1 aspects - Support of Home NB and Home eNB enhancements | 321d? | 2009-09-18 A | 2010-12-10 A | 100% | 2009-09-18 | 2010-12-10 | 321d? | finish no earlier than 2010-12-10 | C1 | 2568h | 2568h | EHNB-CT1 | PCG-23 | Qualcomm | Ramachandran Subramanian (rsubrama@qualcomm.com) | Rel-9 | CP-45 | Frederic | HNB | EHNB-CT1 |  |
| 2069 | 559.5 | CT6 aspects - Support of Home NB and Home eNB enhancements | 131d? | 2009-09-18 A | 2010-03-19 A | 100% | 2009-09-18 | 2010-03-19 | 131d? | finish no earlier than 2010-03-19 | C6 | 1048h | 1048h | EHNB-CT6 | PCG-23 | Qualcomm | Ramachandran Subramanian (rsubrama@qualcomm.com) | Rel-9 | CP-45 | Xavier | HNB | EHNB-CT6 |  |
| 2070 | 559.6 | 3G HNB Gateway and LTE HeNB Gateway OAM&P | 336d? | 2008-12-11 A | 2010-03-25 A | 100% | 2008-12-11 | 2010-03-25 | 336d? | finish no earlier than 2010-03-25 | S5 | 2688h | 2688h | HNB-OAM_GW | PCG-22 | China Mobile | GangChen (chengang@chinamobile.com) | Rel-9 | SP-42 | Mirko | HNB | HNB-OAM_GW |  |
| 2071 | 559.7 | 3G HNB and LTE HeNB OAM&P Type 1 Interface | 272d? | 2009-03-12 A | 2010-03-25 A | 100% | 2009-03-12 | 2010-03-25 | 272d? | finish no earlier than 2010-03-25 | S5 | 2168h | 2168h | HNB_eHNB-OAM_Type1 | PCG-22 | Huawei | Zou Lan (zlan@huawei.com) | Rel-9 | SP-43 | Mirko | HNB | HNB_eHNB-OAM_Type1 |  |
| 2072 | 559.8 | 3G HNB and LTE HeNB OAM&P Type 2 Interface | 225d? | 2009-05-15 A | 2010-03-25 A | 100% | 2009-05-15 | 2010-03-25 | 225d? | finish no earlier than 2010-03-25 | S5 | 1800h | 1800h | HNB_eHNB-OAM_Type2 | PCG-23 | Ericsson | edwin.tse@ericsson.com | Rel-9 | SP-44 | Mirko | HNB | HNB_eHNB-OAM_Type2 |  |
| 2073 | 559.9 | LTE FDD Home eNodeB RF Requirements | 336d? | 2008-12-05 A | 2010-03-19 A | 100% | 2008-12-05 | 2010-03-19 | 336d? | finish no earlier than 2010-03-19 | R4 | 2688h | 2688h | HeNB-RF_FDD | PCG-22 | Motorola | Ying Cai (yingcai@motorola.com) | Rel-9 | RP-42 | Issam | HNB | HeNB-RF_FDD | RP-100035 |
| 2074 | 559.10 | LTE TDD Home eNodeB RF Requirements | 271d? | 2009-03-06 A | 2010-03-19 A | 100% | 2009-03-06 | 2010-03-19 | 271d? | finish no earlier than 2010-03-19 | R4 | 2168h | 2168h | HeNB-RF_TDD | PCG-22 | China Mobile | Nan Li (linan@chinamobile.com) | Rel-9 | RP-43 | Issam | HNB | HeNB-RF_TDD | RP-100036 |
| 2075 | 559.11 | Home NB and Home eNB enhancements - RAN3 aspects | 197d? | 2009-03-06 A | 2009-12-04 A | 100% | 2009-03-06 | 2009-12-04 | 197d? | finish no earlier than 2009-12-04 | R3 | 1576h | 1576h | EHNB-RAN3 | PCG-22 | Alcatel-Lucent | Martin Warner (mw15@alcatel-lucent.com) | Rel-9 | RP-43 | Juha | HNB | EHNB-RAN3 | RP-091050 |
| 2076 | 559.12 | Home NB and Home eNB enhancements - RAN2 aspects | 271d? | 2009-03-06 A | 2010-03-19 A | 100% | 2009-03-06 | 2010-03-19 | 271d? | finish no earlier than 2010-03-19 | R2 | 2168h | 2168h | EHNB-RAN2 | PCG-22 | Huawei | Yang Xudong (yangxudong@huawei.com) | Rel-9 | RP-43 | Yong-Jun | HNB | EHNB-RAN2 | RP-100037 |
| 2077 | 559.13 | Conformance Test Aspects – Home NB enhancements for FDD | 322d? | 2010-09-17 A | 2011-12-09 A | 100% | 2010-09-17 | 2011-12-09 | 322d? | finish no earlier than 2011-12-09 | R5 | 2568h | 2568h | EHNB-UTRA_FDD_UEConTest | PCG-25 | Huawei | trica_li@huawei.com | Rel-9 | RP-49 | Ingbert | HNB | EHNB-UTRA_FDD_UEConTest | RP-111679 |
| 2078 | 559.14 | Conformance Test Aspects – Home eNB enhancements | 201d? | 2010-12-10 A | 2011-09-16 A | 100% | 2010-12-10 | 2011-09-16 | 201d? | finish no earlier than 2011-09-16 | R5 | 1608h | 1608h | EHNB-LTE_UEConTest | PCG-26 | Qualcomm | Mrs Lena Chaponniere (lchaponn@qualcomm.com) | Rel-9 | RP-50 | Ingbert | HNB | EHNB-LTE_UEConTest | RP-110972 |
| 2079 | 559.15 | Home NB and Home eNB enhancements - GERAN aspects | 341d? | 2009-05-18 A | 2010-09-03 A | 100% | 2009-05-18 | 2010-09-03 | 341d? | finish no earlier than 2010-09-03 | GP | 2728h | 2728h | EHNB-GERAN | PCG-23 | Nokia Siemens Networks | leonardo.provvedi@roke.co.uk | Rel-9 | GP-42 | Paolo | HNB | EHNB-GERAN |  |
| 2080 | 560 | **Value-Added Services for Short Message Service** | 586d? | 2007-09-10 A | 2009-12-04 A | 100% | 2007-09-10 | 2009-12-04 | 586d? |  | S1; C4; C1 | 20264h | 20264h | VAS4SMS |  | China Mobile | Wu Bin (wubin@chinamobile.com) | Rel-9 | SP-37 | Alain |  | VAS4SMS |  |
| 2081 | 560.1 | Stage 1 for VAS4SMS | 133d? | 2007-09-10 A | 2008-03-12 A | 100% | 2007-09-10 | 2008-03-12 | 133d? | finish no earlier than 2008-03-21 | S1 | 1064h | 1064h | VAS4SMS |  | China Mobile | Wu Bin (wubin@chinamobile.com) | Rel-9 | SP-37 | Alain |  |  |  |
| 2082 | 560.2 | CT4 aspects of VAS4SMS Interface and Signalling Flow | 322d? | 2008-09-12 A | 2009-12-04 A | 100% | 2008-09-12 | 2009-12-04 | 322d? | finish no earlier than 2009-12-04 | C4 | 2568h | 2568h | VAS4SMS | PCG-21 | China Mobile | Wu Bin (wubin@chinamobile.com) | Rel-9 | CP-41 | Kimmo |  |  |  |
| 2083 | 560.3 | CT1 aspects of VAS4SMS Interface and Signalling Flow | 321d? | 2008-09-09 A | 2009-12-04 A | 100% | 2008-09-09 | 2009-12-04 | 321d? | finish no earlier than 2009-12-04 | C1 | 2568h | 2568h | VAS4SMS | PCG-21 | China Mobile | Wu Bin (wubin@chinamobile.com) | Rel-9 | CP-41 | Frederic |  |  |  |
| 2084 | 561 | **Definition of End-User Identity** | 334d? | 2007-09-03 A | 2008-12-11 A | 100% | 2007-09-03 | 2008-12-11 | 334d? |  | S1 | 5344h | 5344h | EUI |  | Nokia Siemens Networks | Juergen.Merkel@nsn.com | Rel-9 | SP-38 | Alain |  | EUI |  |
| 2085 | 561.1 | Stage 1 for Definition of End-User Identity | 334d? | 2007-09-03 A | 2008-12-11 A | 100% | 2007-09-03 | 2008-12-11 | 334d? | finish no earlier than 2008-12-11 | S1 | 2672h | 2672h | EUI | PCG-21 | Nokia Siemens Networks | Juergen.Merkel@nsn.com | Rel-9 | SP-38 | Alain |  |  |  |
| 2086 | 562 | **Customized Ringing Signal** | 522d? | 2007-12-06 A | 2009-12-03 A | 100% | 2007-12-06 | 2009-12-03 | 522d? |  | S1; C1 | 11296h | 11296h | CRS | PCG-21 | SK Telecom, China Mobile | Donghee Shim (SK Telecom), Jianping Zheng (China Mobile) | Rel-9 | SP-38 | Alain |  | CRS |  |
| 2087 | 562.1 | Stage 1 for Customized Ringing Signal | 266d? | 2007-12-06 A | 2008-12-11 A | 100% | 2007-12-06 | 2008-12-11 | 266d? | finish no earlier than 2008-12-11 | S1 | 2128h | 2128h | CRS | PCG-21 | SK Telecom, China Mobile | Donghee Shim (SK Telecom), Jianping Zheng (China Mobile) | Rel-9 | SP-38 | Alain |  |  |  |
| 2088 | 562.2 | Stage 3 for IMS Customized Ringing Signal (CRS) Service | 136d? | 2009-05-29 A | 2009-12-03 A | 100% | 2009-05-29 | 2009-12-03 | 136d? | finish no earlier than 2010-06-04 | C1 | 816h | 816h | CRS | PCG-23 | China Mobile | wangzhao | Rel-9 | CP-44 | Frederic |  |  |  |

Notes:
- 2064: RP#54 Testing completed / Impacted TSs and TRs: UTRA, LTE
- 2065: CP#49 the SA1-reqs are moving. CT1 will align when the work in SA1 is clear. (was SP#44 completed.) / Impacted TSs and TRs: 22.220, 22.011
- 2066: SP#45 completed / Impacted TSs and TRs: 23.401, 23.402, 23.060, New 23.830
- 2067: SP#46 completed / Impacted TSs and TRs: New 33.320
- 2068: CP#50 completed (Roaming aspects for manual CSG selection, Support of temporary users and CSG membership changes, Support of user controlled and operator controlled lists) / Impacted TSs and TRs: 23.122, 24.008, 24.285, 24.301
- 2069: CP#47 completed. Storing of CSG related data items on the USIM / Impacted TSs and TRs: 31.102
- 2070: SP#47 completed / Impacted TSs and TRs: 32.632, 32.633, 32.635, New (32.771, 32.772, 32.773, 32.775, 32.781, 32.782, 32.783, 32.785)
- 2071: SP#47 completed / Impacted TSs and TRs: 32.581, 32.582, 32.583, 32.584, New (32.591, 32.592, 32.593, 32.594)
- 2072: SP#47 completed / Impacted TSs and TRs: New (32.571, 32.572)
- 2073: RP#47 completed / Impacted TSs and TRs: 36.104, 36.141, New TR 36.921
- 2074: RP#47 completed / Impacted TSs and TRs: 36.104, 36.141, 36.300, 36.331, 36.413, New TR 36.922
- 2075: RP#46 completed (based on high priority items specified in RP-090995) / Impacted TSs and TRs: 25.413, 25.467, 25.467, 25.468, 25.469, 25.469, 36.401, 36.413, New 25.444
- 2076: RP#47 completed / Impacted TSs and TRs: 25.304, 25.331, 25.367, 36.300, 36.304, 36.331
- 2077: UTRA. RP#54 completed. Testing for UID_430026 Support of Home NB and Home eNB enhancements RAN2 aspects (25.304, 25.331, 25.367) / Impacted TSs and TRs: 34.108, 34.121-1, 34.121-2, 34.123-1, 34.123-2, 34.123-3
- 2078: RP#53 completed / Impacted TSs and TRs: 36.508, 36.523-1, 36.523-2, 36.523-3
- 2079: GP#47 completed. GP#42 WID approved / Impacted TSs and TRs: 43.055, 43.129, 44.018, 44.060, 45.008, 48.008, 48.018
- 2080: CP#46 completed
- 2081: SP#39 completed. SP#43 Feature moved to Rel-9 / Impacted TSs and TRs: new 22.142
- 2082: CP#46 completed / Impacted TSs and TRs: new 23.142
- 2083: CP#46 completed / Impacted TSs and TRs: 23.040
- 2084: SP#42 closed. Stage 1 work closed at 5% completion due to lack of input (added only the EUI definition in 21.905)
- 2085: SP#42 closed. Stage 1 work closed at 5% completion due to lack of input (added only the EUI definition in 21.905) / Impacted TSs and TRs: 21.905
- 2086: CP#48 completed
- 2087: SP#42 completed. / Impacted TSs and TRs: 22.173, new 22.183
- 2088: CP#48 completed / Impacted TSs and TRs: 24.173, new 24.183

| ID | WBS | Task | Type | Duration | Start | Finish | Complete | Baseline start | Baseline finish | Baseline duration | Constraint | Resources | Work | Actual work | Acronym | PCG approved | Impacted TSs and TRs | WI rapporteur name | Release | TSG approved | MCC resp | Special Focus Doc | Acronym_3GU_Export | Status Report |
| --- | --- | --- | --- | --- | --- | --- | --- | --- | --- | --- | --- | --- | --- | --- | --- | --- | --- | --- | --- | --- | --- | --- | --- | --- |
| 2089 | 563 | **Public Warning System** |  | 1315d? | 2007-12-06 A | 2012-12-07 A | 100% | 2007-12-06 | 2012-12-07 | 1315d? |  | S1; C1; C4; R2; R3; R5 | 73920h | 73920h | PWS | PCG-21 | LTE | T-Mobile | Rel-9 | SP-38 | Alain | Public Safety (I-A) | PWS |  |
| 2090 | 563.1 | Stage 1 for Public Warning System |  | 266d? | 2007-12-06 A | 2008-12-11 A | 100% | 2007-12-06 | 2008-12-11 | 266d? | finish no earlier than 2008-12-11 | S1 | 2128h | 2128h | PWS | PCG-21 | 22.268 | T-Mobile | Rel-9 | SP-38 | Alain | Public Safety (I-A) |  |  |
| 2091 | 563.2 | **Stage 3 for Public Warning System** |  | 137d? | 2009-05-29 A | 2009-12-04 A | 100% | 2009-05-29 | 2009-12-04 | 137d? |  | C1; C4 | 4368h | 4368h | PWS-St3 | PCG-23 |  | Qualcomm | Rel-9 | CP-44 | Frederic | Public Safety (I-A) | PWS-St3 |  |
| 2092 | 563.2.1 | CT1 aspects of Stage 3 for Public Warning System |  | 137d? | 2009-05-29 A | 2009-12-04 A | 100% | 2009-05-29 | 2009-12-04 | 137d? | finish no earlier than 2009-12-04 | C1 | 1088h | 1088h | PWS-St3 | PCG-23 | 23.041 | Qualcomm | Rel-9 | CP-44 | Frederic | Public Safety (I-A) |  |  |
| 2093 | 563.2.2 | CT4 aspects of Stage 3 for Public Warning System |  | 136d? | 2009-05-30 A | 2009-12-04 A | 100% | 2009-05-30 | 2009-12-04 | 136d? | finish no earlier than 2009-12-04 | C4 | 1088h | 1088h | PWS-St3 | PCG-23 | 29.168 | Qualcomm | Rel-9 | CP-44 | Kimmo | Public Safety (I-A) |  |  |
| 2094 | 563.3 | Public Warning System (PWS) – RAN aspects |  | 136d? | 2009-05-30 A | 2009-12-04 A | 100% | 2009-05-30 | 2009-12-04 | 136d? | finish no earlier than 2009-12-04 | R2; R3 | 2176h | 2176h | PWS-RAN | PCG-23 | LTE 36.300, 36.302, 36.331, 36.413 | AT&T | Rel-9 | RP-44 | Yong-Jun | Public Safety (I-A) | PWS-RAN | RP-091052 |
| 2095 | 563.4 | Conformance Test Aspects – Public Warning System (PWS) – RAN aspects for LTE |  | 267d? | 2011-12-02 A | 2012-12-07 A | 100% | 2011-12-02 | 2012-12-07 | 267d? | finish no earlier than 2012-12-07 | R5 | 2128h | 2128h | PWS-RAN_UEConTest | PCG-28 | 36.508, 36.523-1, 36.523-2, 36.523-3 | Qualcomm | Rel-9 | RP-54 | Ingbert | Public Safety (I-A) | PWS-RAN_UEConTest | RP-121525 |
| 2096 | 564 | **Support of Personal Area Networks and Enhancements to Personal Network Management** |  | 523d? | 2008-06-05 A | 2010-06-04 A | 100% | 2008-06-05 | 2010-06-04 | 523d? |  | S1; C1 | 12544h | 12544h | PAN_EPNM | PCG-21 |  | Vodafone | Rel-9 | SP-40 | Alain |  | PAN_EPNM |  |
| 2097 | 564.1 | Stage 1 for Support of Personal Area Networks and Enhancements to Personal Network Management | milestone | 0d? | 2008-06-05 A | 2008-06-05 A | 100% | 2008-06-05 | 2008-06-05 | 0d? | finish no earlier than 2008-06-05 | S1 |  |  | PAN_EPNM | PCG-21 | 22.259 | Vodafone | Rel-9 | SP-40 | Alain |  |  |  |
| 2098 | 564.2 | Stage 2 for Support of Personal Area Networks and Enhancements to Personal Network Management |  | 196d? | 2009-03-06 A | 2009-12-04 A | 100% | 2009-03-06 | 2009-12-04 | 196d? | finish no earlier than 2009-12-04 | C1 | 1568h | 1568h | PAN_EPNM | PCG-22 | 23.259 | Huawei | Rel-9 | CP-43 | Frederic |  |  |  |
| 2099 | 564.3 | Stage 3 for Support of Personal Area Networks and Enhancements to Personal Network Management |  | 326d? | 2009-03-09 A | 2010-06-04 A | 100% | 2009-03-09 | 2010-06-04 | 326d? | finish no earlier than 2010-06-04 | C1 | 2608h | 2608h | PAN_EPNM | PCG-22 | 24.259 | Huawei | Rel-9 | CP-43 | Frederic |  |  |  |
| 2100 | 565 | **Multi-Media Telephony Service enhancements** |  | 472d? | 2008-06-05 A | 2010-03-25 A | 100% | 2008-06-05 | 2010-03-25 | 472d? |  | S1; S5; C1 | 17840h | 17840h | eMMTel | PCG-21 |  | France Telecom | Rel-9 | SP-40 | Alain |  | eMMTel |  |
| 2101 | 565.1 | Stage 1 for eMMTel |  | 136d? | 2008-06-05 A | 2008-12-11 A | 100% | 2008-06-05 | 2008-12-11 | 136d? | start no earlier than 2008-06-05 | S1 | 1088h | 1088h | eMMTel | PCG-21 | 22.173 | France Telecom | Rel-9 | SP-40 | Alain |  |  |  |
| 2102 | 565.2 | Multimedia Telephony (MMTel) Service and Supplementary Services - Online Charging and completion for Offline Charging (all supplementary services) |  | 272d? | 2009-03-12 A | 2010-03-25 A | 100% | 2009-03-12 | 2010-03-25 | 272d? | finish no earlier than 2010-03-25 | S5 | 2168h | 2168h | eMMTel-SS-CH | PCG-22 | 32.275, 32.298, 32.299 | Alcatel-Lucent | Rel-9 | SP-43 | Mirko |  | eMMTel-SS-CH |  |
| 2103 | 565.3 | Support of Real-time Transfer of Tariff Information (RTTI) in IMS charging |  | 271d? | 2009-03-12 A | 2010-03-25 A | 100% | 2009-03-12 | 2010-03-25 | 271d? | finish no earlier than 2010-03-25 | S5 | 2168h | 2168h | IMSTSS-RTTI-CH | PCG-22 | 32.240, 32.280, 32.298, 32.299 | Orange | Rel-9 | SP-43 | Mirko |  | IMSTSS-RTTI-CH |  |
| 2104 | 565.4 | Stage 3 - Enhancements for Completion of Communications Supplementary service |  | 136d? | 2009-05-30 A | 2009-12-04 A | 100% | 2009-05-30 | 2009-12-04 | 136d? | finish no earlier than 2009-12-04 | C1 | 1088h | 1088h | eMMTel-CC | PCG-23 | 24.642 | France Telecom | Rel-9 | CP-44 | Frederic |  | eMMTel-CC |  |
| 2105 | 566 | **User Data Convergence (UDC)** |  | 527d? | 2008-06-05 A | 2010-06-10 A | 100% | 2008-06-05 | 2010-06-10 | 527d? |  | S1; S5; C4 | 25056h | 25056h | UDC | PCG-21 |  | Nokia Siemens Networks | Rel-9 | SP-40 | Alain |  | UDC |  |
| 2106 | 566.1 | Stage 1 for User Data Convergence (UDC) |  | 136d? | 2008-06-05 A | 2008-12-11 A | 100% | 2008-06-05 | 2008-12-11 | 136d? | start no earlier than 2008-06-05 | S1 | 1088h | 1088h | UDC | PCG-21 | 22.101, new 22.985 | Nokia Siemens Networks | Rel-9 | SP-40 | Alain |  |  |  |
| 2107 | 566.2 | **Stage 2/3 for User Data Convergence (UDC) Technical Realization** |  | 272d? | 2009-03-06 A | 2010-03-19 A | 100% | 2009-03-06 | 2010-03-19 | 272d? |  | C4 | 5376h | 5376h | UDC-CN | PCG-22 |  | Ericsson | Rel-9 | CP-43 | Kimmo |  | UDC-CN |  |
| 2108 | 566.2.1 | User Data Convergence (UDC) Technical Realization (Stage 2) |  | 271d? | 2009-03-06 A | 2010-03-19 A | 100% | 2009-03-06 | 2010-03-19 | 271d? | finish no earlier than 2010-03-19 | C4 | 2168h | 2168h | UDC-CN | PCG-22 | new 23.335 | Ericsson | Rel-9 | CP-43 | Kimmo |  |  |  |
| 2109 | 566.2.2 | User Data Convergence (UDC) Protocol Description |  | 130d? | 2009-09-18 A | 2010-03-19 A | 100% | 2009-09-18 | 2010-03-19 | 130d? | finish no earlier than 2010-03-19 | C4 | 1040h | 1040h | UDC-CN | PCG-23 | new 29.335 | China Mobile, Ericsson | Rel-9 | CP-45 | Kimmo |  |  |  |
| 2110 | 566.3 | **User Data Convergence (UDC) Modelling and Management** |  | 266d? | 2009-06-04 A | 2010-06-10 A | 100% | 2009-06-04 | 2010-06-10 | 266d? |  | S5 | 5944h | 5944h | UDC-MMAN | PCG-23 |  | T-Mobile, China Mobile, Ericsson | Rel-9 | SP-44 | Mirko |  | UDC-MMAN |  |
| 2111 | 566.3.1 | UDC – Framework for Model Handling and Management |  | 266d? | 2009-06-04 A | 2010-06-10 A | 100% | 2009-06-04 | 2010-06-10 | 266d? | finish no earlier than 2010-06-10 | S5 | 2128h | 2128h | UDC-MMAN-MFRM | PCG-23 | 32.172, new 32.181 | T-Mobile | Rel-9 | SP-44 | Mirko |  | UDC-MMAN-MFRM |  |
| 2112 | 566.3.2 | UDC – Common Baseline Information Model |  | 211d? | 2009-06-04 A | 2010-03-25 A | 100% | 2009-06-04 | 2010-03-25 | 211d? | finish no earlier than 2010-03-25 | S5 | 1688h | 1688h | UDC-MMAN-CBIM | PCG-23 | 32.172, new 32.182 | China Mobile, Ericsson | Rel-9 | SP-44 | Mirko |  | UDC-MMAN-CBIM |  |

Notes:
- 2089: TSG#46 completed. Larger scope than Rel-8 Feature UID_370051 (ETWS). Triggered by TR 22.968 Study UID_320025 (FS_PWS) / WI rapporteur e-mail: Mark.Younge@t-mobile.com
- 2090: SP#42 completed / WI rapporteur e-mail: Mark.Younge@t-mobile.com
- 2091: RP#46 completed / WI rapporteur e-mail: Ramachandran Subramanian (rsubrama@qualcomm.com)
- 2092: CP#46 completed / WI rapporteur e-mail: Ramachandran Subramanian (rsubrama@qualcomm.com)
- 2093: CP#46 completed / WI rapporteur e-mail: Ramachandran Subramanian (rsubrama@qualcomm.com)
- 2094: RP#46 completed / WI rapporteur e-mail: don.zelmer@att.com
- 2095: RP#58 completed / WI rapporteur e-mail: Shubhang Vora (svora@qualcomm.com)
- 2096: CP#48 completed / WI rapporteur e-mail: armin.toepfer@vodafone.com
- 2097: SP#40 completed / WI rapporteur e-mail: armin.toepfer@vodafone.com
- 2098: CP#46 completed / WI rapporteur e-mail: Lili Yang (kadyyang@huawei.com)
- 2099: CP#48 completed / WI rapporteur e-mail: Lili Yang (kadyyang@huawei.com)
- 2100: SP#47 completed / WI rapporteur e-mail: philippe.lottin@orange.com
- 2101: SP#42 completed / WI rapporteur e-mail: philippe.lottin@orange.com
- 2102: SP#47 completed / WI rapporteur e-mail: maryse.gardella@alcatel-lucent.com
- 2103: SP#47 completed. Linked to SA5 Rel-8 UID_380042 AoC support in IMS Charging (IMSTSS) / WI rapporteur e-mail: Jean-Luc Garcia (jl.garcia@orange-ftgroup.com)
- 2104: CP#46 completed / WI rapporteur e-mail: Youssef.chadli@orange-ftgroup.com
- 2105: SP#48 completed. Triggered by Rel-8 SA5 Study of Common Profile Storage Framework of User Data for network services and management (UID_320006) TR 32.808 / WI rapporteur e-mail: juergen.merkel@nsn.com
- 2106: SP#42 completed / WI rapporteur e-mail: juergen.merkel@nsn.com
- 2107: - / WI rapporteur e-mail: emiliano.merino@ericsson.com
- 2108: CP#47 completed / WI rapporteur e-mail: emiliano.merino@ericsson.com
- 2109: CP#47 completed / WI rapporteur e-mail: Lan Si Zhong (lansizhong@chinamobile.com), emiliano.merino@ericsson.com
- 2110: SP#48 completed / WI rapporteur e-mail: istvan.aba@t-mobile.at, lansizhong@chinamobile.com, miguel.a.garcia@ericsson.com
- 2111: SP#48 completed / WI rapporteur e-mail: istvan.aba@t-mobile.at
- 2112: SP#47 completed / WI rapporteur e-mail: Lan Si Zhong, Miguel Garcia

| ID | WBS | Task | Duration | Start | Finish | Complete | Baseline start | Baseline finish | Baseline duration | Constraint | Resources | Work | Actual work | Acronym | PCG approved | WI rapporteur name | WI rapporteur e-mail | Release | TSG approved | MCC resp | Acronym_3GU_Export | Status Report | Special Focus Doc |
| --- | --- | --- | --- | --- | --- | --- | --- | --- | --- | --- | --- | --- | --- | --- | --- | --- | --- | --- | --- | --- | --- | --- | --- |
| 2113 | 567 | **IMS Services Centralization and Continuity** | 393d? | 2008-09-18 A | 2010-03-19 A | 100% | 2008-09-18 | 2010-03-19 | 393d? |  | S1; S2; C1 | 30992h | 30992h | IMS_SCC | PCG-21 | NEC | joerg.swetina@neclab.eu | Rel-9 | SP-41 | Alain | IMS_SCC |  |  |
| 2114 | 567.1 | Stage 1 - Inter-Device Transfer – Requirements | 61d? | 2008-09-18 A | 2008-12-11 A | 100% | 2008-09-18 | 2008-12-11 | 61d? | finish no earlier than 2009-06-18 | S1 | 488h | 488h | IMS_SCC-IDT | PCG-21 | NEC | joerg.swetina@neclab.eu | Rel-9 | SP-41 | Alain | IMS_SCC-IDT |  |  |
| 2115 | 567.2 | **Stage 2/3 for IMS Service Continuity Enhancements: Service, Policy and Interactions** | 393d? | 2008-09-18 A | 2010-03-19 A | 100% | 2008-09-18 | 2010-03-19 | 393d? |  | S2; C1 | 9456h | 9456h | IMS_SCC-SPI | PCG-21 | Huawei | HengLiang Zhang (hl_zhang@huawei.com) | Rel-9 | SP-41 | Maurice | IMS_SCC-SPI |  |  |
| 2116 | 567.2.1 | Stage 2 for IMS Service Continuity Enhancements: Service, Policy and Interactions | 186d? | 2008-09-18 A | 2009-06-04 A | 100% | 2008-09-18 | 2009-06-04 | 186d? | finish no earlier than 2009-06-04 | S2 | 1488h | 1488h | IMS_SCC-SPI | PCG-21 | Huawei | HengLiang Zhang (hl_zhang@huawei.com) | Rel-9 | SP-41 | Maurice |  |  |  |
| 2117 | 567.2.2 | Stage 3 for IMS Service Continuity Enhancements: Service, Policy, Interactions and Inter UE Transfer | 212d? | 2009-05-29 A | 2010-03-19 A | 100% | 2009-05-29 | 2010-03-19 | 212d? | finish no earlier than 2010-03-19 | C1 | 1696h | 1696h | IMS_SCC-SPI | PCG-23 | Qualcomm | Roozbeh Atarius (ratarius@qualcomm.com) | Rel-9 | CP-44 | Frederic |  |  |  |
| 2118 | 567.3 | **Stage 2/3 for IMS Centralized Services** | 393d? | 2008-09-18 A | 2010-03-19 A | 100% | 2008-09-18 | 2010-03-19 | 393d? |  | S2; C1 | 9448h | 9448h | IMS_SCC-ICS | PCG-21 | Alcatel-Lucent | andy.bennett@alcatel-lucent.com | Rel-9 | SP-41 | Maurice | IMS_SCC-ICS |  |  |
| 2119 | 567.3.1 | Stage 2 for IMS Centralized Services | 186d? | 2008-09-18 A | 2009-06-04 A | 100% | 2008-09-18 | 2009-06-04 | 186d? | finish no earlier than 2009-06-04 | S2 | 1488h | 1488h | IMS_SCC-ICS | PCG-21 | Alcatel-Lucent | andy.bennett@alcatel-lucent.com | Rel-9 | SP-41 | Maurice |  |  |  |
| 2120 | 567.3.2 | Stage 3 for Enhancements to IMS Centralized Services | 212d? | 2009-05-29 A | 2010-03-19 A | 100% | 2009-05-29 | 2010-03-19 | 212d? | finish no earlier than 2010-03-19 | C1 | 1688h | 1688h | IMS_SCC-ICS | PCG-23 | Nokia Siemens Networks | Peter.Leis@nsn.com | Rel-9 | CP-44 | Frederic |  |  |  |
| 2121 | 567.4 | Stage 3 - IMS Centralized Services support via I1 interface | 271d? | 2009-03-06 A | 2010-03-19 A | 100% | 2009-03-06 | 2010-03-19 | 271d? | finish no earlier than 2010-03-19 | C1 | 2168h | 2168h | IMS_SCC-ICS_I1 | PCG-22 | Huawei | Lili Yang(kadyyang@huawei.com) | Rel-9 | CP-43 | Frederic | IMS_SCC-ICS_I1 |  |  |
| 2122 | 568 | **Service Specific Access Control in EPS** | 922d? | 2008-12-11 A | 2012-06-15 A | 100% | 2008-12-11 | 2012-06-15 | 922d? |  | S1; C1; R5 | 26000h | 26000h | SSAC | PCG-22 | NTT DoCoMo | Frederic Thepot (thepot@docomolab-euro.com) | Rel-9 | SP-42 | Alain | SSAC |  |  |
| 2123 | 568.1 | Stage 1 for Service Specific Access Control in EPS | 1d? | 2008-12-11 A | 2008-12-11 A | 100% | 2008-12-11 | 2008-12-11 | 1d? | start no earlier than 2008-12-11 | S1 | 8h | 8h | SSAC | PCG-22 | NTT DoCoMo | Frederic Thepot (thepot@docomolab-euro.com) | Rel-9 | SP-42 | Alain |  |  |  |
| 2124 | 568.2 | Stage 3 for Service Specific Access Control in EPS | 212d? | 2009-05-29 A | 2010-03-19 A | 100% | 2009-05-29 | 2010-03-19 | 212d? | finish no earlier than 2010-03-19 | C1 | 1696h | 1696h | SSAC | PCG-23 | NTT DoCoMo | Hideyuki Yamashita (yamashitahi@s1.nttdocomo.co.jp) | Rel-9 | CP-44 | Frederic |  |  |  |
| 2125 | 568.3 | Conformance Test Aspects - Service Specific Access Control | 272d? | 2011-06-07 A | 2012-06-15 A | 100% | 2011-06-07 | 2012-06-15 | 272d? | finish no earlier than 2012-06-15 | R5 | 2168h | 2168h | SSAC_UEConTest | PCG-27 | NTT DoCoMo | Takao.Shimizu.rp@nttdocomo.com | Rel-9 | RP-52 | Ingbert | SSAC_UEConTest | RP-120447 |  |
| 2126 | 569 | **Support for IMS Emergency Calls over GPRS and EPS** | 3785d? | 2000-01-03 A | 2014-06-13 A | 100% | 2000-01-03 | 2014-06-13 | 3785d? |  | S1; S2; S3; C1; C3; C4; R2; R3; R5; IETF | 293512h | 293512h | IMS_EMER_GPRS_EPS | PCG-21 | Alcatel-Lucent | Deborah Barclay | Rel-9 | SP-38 | Maurice | IMS_EMER_GPRS_EPS |  | Public Safety (I-A) |
| 2127 | 569.1 | Stage 1 for IMS Emergency Calls over GPRS and EPS | 239d? | 2008-01-14 A | 2008-12-11 A | 100% | 2008-01-14 | 2008-12-11 | 239d? | finish no earlier than 2008-12-11 | S1 | 1912h | 1912h | IMS_EMER_GPRS_EPS | PCG-21 | Alcatel-Lucent | Deborah Barclay | Rel-9 | SP-38 | Alain |  |  | Public Safety (I-A) |
| 2128 | 569.2 | Stage 2 for IMS Emergency Calls over GPRS and EPS | 364d? | 2008-01-14 A | 2009-06-04 A | 100% | 2008-01-14 | 2009-06-04 | 364d? | finish no earlier than 2009-06-04 | S2 | 2912h | 2912h | IMS_EMER_GPRS_EPS | PCG-21 | Alcatel-Lucent | Deborah Barclay | Rel-9 | SP-38 | Maurice |  |  | Public Safety (I-A) |
| 2129 | 569.3 | Security aspects for IMS Emergency Calls over GPRS and EPS | 391d? | 2008-12-12 A | 2010-06-10 A | 100% | 2008-12-12 | 2010-06-10 | 391d? | finish no earlier than 2010-03-25 | S3 | 3128h | 3128h | IMS_EMER_GPRS_EPS-Sec | PCG-22 | Alcatel-Lucent | Deborah Barclay | Rel-9 | SP-42 | Mirko | IMS_EMER_GPRS_EPS-Sec |  | Public Safety (I-A) |
| 2130 | 569.4 | **Stage 3 for IMS Emergency Calls over GPRS and EPS** | 801d? | 2009-05-29 A | 2012-06-15 A | 100% | 2009-05-29 | 2012-06-15 | 801d? |  | C1; C3; C4; R5 | 33331.7h | 33331.7h | IMS_EMER_GPRS_EPS | PCG-23 | Alcatel-Lucent | Frank Alfano (falfano@alcatel-lucent.com) | Rel-9 | CP-44 | Frederic |  |  | Public Safety (I-A) |
| 2131 | 569.4.1 | CT1 aspects - Stage 3 for IMS Emergency Calls over GPRS and EPS | 212d? | 2009-05-29 A | 2010-03-19 A | 100% | 2009-05-29 | 2010-03-19 | 212d? | finish no earlier than 2010-03-19 | C1 | 1696h | 1696h | IMS_EMER_GPRS_EPS-Sec | PCG-23 | Alcatel-Lucent | Frank Alfano (falfano@alcatel-lucent.com) | Rel-9 | CP-44 | Frederic |  |  | Public Safety (I-A) |
| 2132 | 569.4.2 | Conformance Test Aspects - CT1 aspects for IMS Emergency Calls over GPRS and EPS | 532d? | 2010-06-04 A | 2012-06-15 A | 100% | 2010-06-04 | 2012-06-15 | 532d? | finish no earlier than 2012-06-15 | R5 | 4256h | 4256h | IMS_EMER_GPRS_EPS_UEConTest | PCG-25 | Samsung | stoyan.baev@partner.samsung.com | Rel-9 | RP-48 | Ingbert | IMS_EMER_GPRS_EPS_UEConTest | RP-120445 | Public Safety (I-A) |
| 2133 | 569.4.3 | CT3 aspects - Stage 3 for IMS Emergency Calls over GPRS and EPS | 82d? | 2009-05-29 A | 2009-09-18 A | 100% | 2009-05-29 | 2009-09-18 | 82d? | start no earlier than 2009-05-29 | C3 | 651.68h | 651.68h | IMS_EMER_GPRS_EPS | PCG-23 | Alcatel-Lucent | Frank Alfano (falfano@alcatel-lucent.com) | Rel-9 | CP-44 | Adrian |  |  | Public Safety (I-A) |
| 2134 | 569.4.4 | CT4 aspects - Stage 3 for IMS Emergency Calls over GPRS and EPS | 137d? | 2009-05-29 A | 2009-12-04 A | 100% | 2009-05-29 | 2009-12-04 | 137d? | finish no earlier than 2009-12-04 | C4 | 1096h | 1096h | IMS_EMER_GPRS_EPS | PCG-23 | Alcatel-Lucent | Frank Alfano (falfano@alcatel-lucent.com) | Rel-9 | CP-44 | Kimmo |  |  | Public Safety (I-A) |
| 2135 | 569.5 | Support for IMS Emergency Calls over LTE | 207d? | 2000-01-03 A | 2000-10-16 A | 100% | 2000-01-03 | 2000-10-16 | 207d? |  | R2; R3 | 3312h | 3312h | IMS_EMER_LTE | PCG-22 | Alcatel-Lucent | Sudeep Palat (spalat@alcatel-lucent.com) | Rel-9 | RP-42 | Yong-Jun | IMS_EMER_LTE | RP-090698 | Public Safety (I-A) |
| 2136 | 569.6 | Conformance Test Aspects – Support for IMS Emergency Calls over LTE | 187d? | 2010-03-25 A | 2010-12-10 A | 100% | 2010-03-25 | 2010-12-10 | 187d? | finish no earlier than 2010-12-10 | R5 | 1496h | 1496h | IMS_EMER_LTE_UEConTest | PCG-24 | Ericsson | leif.mattisson@ericsson.com | Rel-9 | RP-47 | Ingbert | IMS_EMER_LTE_UEConTest | RP-101068 | Public Safety (I-A) |

Notes:
- 2113: CP#47 completed
- 2114: SP#42 completed / Impacted TSs and TRs: 22.101, 22.228
- 2115: -
- 2116: SP#57 Removal of the MSC server assisted mid-call feature from Rel-9 by 23.237CR#0433 (CT1 proposed moving this feature to Rel-10). SP#44 completed. TR 23.838 for Approval / Impacted TSs and TRs: 23.237, 23.292, 23.216, new 23.838
- 2117: CP#47 completed / Impacted TSs and TRs: 24.216, 24.229, 24.237
- 2118: -
- 2119: SP#44 completed. TR 23.883 for Information + Approval / Impacted TSs and TRs: 23.292, new 23.883
- 2120: CP#47 completed / Impacted TSs and TRs: 24.292, 24.604, 24.607, 24.608, 24.611, 24.623
- 2121: CP#47 completed / Impacted TSs and TRs: 24.237, 24.292, new 24.294
- 2122: CP#47 completed. Triggered by TR 22.986 Study on Service Specific Access Control in EPS. As EPS is a PS-Domain only system, Domain Specific Access Control (DSAC) doesn't apply, hence SSAC allows restriction of voice and non-voice calls separately
- 2123: SP#42 completed. If UE supports E-UTRA and IMS, SSAC is a mandatory Rel-9 function (during congestion in emergency case earthquake/tsunami improves mobile communications). / Impacted TSs and TRs: 22.011 CR0136
- 2124: CP#47 completed / Impacted TSs and TRs: 24.173, 27.007
- 2125: RP#56 completed. Testing for Stage 3 for Service Specific Access Control in EPS (24.173, 27.007) UID_440040 / Impacted TSs and TRs: 34.229-1, 34.229-2, 34.229-3
- 2126: RP#56 completed testing. CP#47 completed. SP#48 completed / Impacted TSs and TRs: GERAN, LTE
- 2127: SP#42 completed / Impacted TSs and TRs: 22.101
- 2128: SP#44 completed / Impacted TSs and TRs: 23.869, 23.060, 23.167, 23.203, 23.221, 23.228, 23.271, 23.401, 23.402
- 2129: SP#48 completed / Impacted TSs and TRs: 33.401, 33.402
- 2130: RP#56 completed testing. CP#47 completed / Impacted TSs and TRs: GERAN, LTE
- 2131: CP#47 completed / Impacted TSs and TRs: 23.122, 24.008, 24.229, 24.301, 24.302
- 2132: RP#56 completed / Impacted TSs and TRs: 34.108, 34.123-1, 34.123-2, 34.123-3, 34.229-1, 34.229-2, 34.229-3, 36.508, 36.523-1, 36.523-2, 36.523-3
- 2133: CP#45 completed / Impacted TSs and TRs: 29.212, 29.213, 29.214, 29.215
- 2134: CP#46 completed / Impacted TSs and TRs: 23.003, 23.008, 29.060, 29.272, 29.273, 29.274, 29.275, 29.276
- 2135: RP#45 completed / Impacted TSs and TRs: 36.331, 36.413
- 2136: RP#50 completed / Impacted TSs and TRs: 36.508, 36.523-1, 36.523-2, 36.523-3

| ID | WBS | Task | Type | Duration | Start | Finish | Complete | Baseline start | Baseline finish | Baseline duration | Constraint | Resources | Work | Actual work | Acronym | PCG approved | WI rapporteur name | WI rapporteur e-mail | Release | TSG approved | MCC resp | Special Focus Doc | Acronym_3GU_Export | Status Report |
| --- | --- | --- | --- | --- | --- | --- | --- | --- | --- | --- | --- | --- | --- | --- | --- | --- | --- | --- | --- | --- | --- | --- | --- | --- |
| 2137 | 569.7 | **Single Radio Voice Call Continuity (SRVCC) support for IMS Emergency Calls** |  | 1511d? | 2008-09-18 A | 2014-06-13 A | 100% | 2008-09-18 | 2014-06-13 | 1511d? |  | S2; C1; C4; C3; IETF | 112300h | 112300h | IMS_EMER_GPRS_EPS-SRVCC | PCG-21 | China Mobile | Yu Qing (Yuqing@chinamobile.com) | Rel-9 | SP-41 | Maurice | Public Safety (I-A) | IMS_EMER_GPRS_EPS-SRVCC |  |
| 2138 | 569.7.1 | SRVCC support for IMS Emergency Calls |  | 322d? | 2008-09-18 A | 2009-12-10 A | 100% | 2008-09-18 | 2009-12-10 | 322d? | finish no earlier than 2009-12-10 | S2 | 2576h | 2576h | IMS_EMER_GPRS_EPS-SRVCC | PCG-21 | China Mobile | Yu Qing (Yuqing@chinamobile.com) | Rel-9 | SP-41 | Maurice | Public Safety (I-A) |  |  |
| 2139 | 569.7.2 | **CT aspects of SRVCC support for IMS Emergency Calls** |  | 1330d? | 2009-05-29 A | 2014-06-13 A | 100% | 2009-05-29 | 2014-06-13 | 1330d? |  | C1; C4; C3; IETF | 49284h | 49284h | IMS_EMER_GPRS_EPS-SRVCC | PCG-24 | China Mobile | jiangyi@chinamobile.com | Rel-9 | CP-46 | Frederic | Public Safety (I-A) |  |  |
| 2140 | 569.7.2.1 | CT1 aspects of SRVCC support for IMS Emergency Calls |  | 137d? | 2009-05-29 A | 2009-12-04 A | 100% | 2009-05-29 | 2009-12-04 | 137d? | finish no earlier than 2009-12-04 | C1 | 1096h | 1096h | IMS_EMER_GPRS_EPS-SRVCC | PCG-23 | China Mobile | jiangyi@chinamobile.com | Rel-9 | CP-44 | Frederic | Public Safety (I-A) |  |  |
| 2141 | 569.7.2.2 | CT4 aspects of SRVCC support for IMS Emergency Calls |  | 137d? | 2009-05-29 A | 2009-12-04 A | 100% | 2009-05-29 | 2009-12-04 | 137d? | finish no earlier than 2009-12-04 | C4 | 1096h | 1096h | IMS_EMER_GPRS_EPS-SRVCC | PCG-23 | China Mobile | jiangyi@chinamobile.com | Rel-9 | CP-44 | Kimmo | Public Safety (I-A) |  |  |
| 2142 | 569.7.2.3 | CT3 aspects of SRVCC support for IMS Emergency Calls |  | 1d? | 2009-12-04 A | 2009-12-04 A | 100% | 2009-12-04 | 2009-12-04 | 1d? | finish no earlier than 2009-12-04 | C3 | 8h | 8h | IMS_EMER_GPRS_EPS-SRVCC | PCG-24 | China Mobile | jiangyi@chinamobile.com | Rel-9 | CP-46 | Kimmo | Public Safety (I-A) |  |  |
| 2143 | 569.7.2.4 | (IETF) CT3 aspects of SRVCC support for IMS Emergency Calls (RFC 7254) |  | 568d? | 2012-04-20 A | 2014-06-13 A | 100% | 2012-04-20 | 2014-06-13 | 568d? | finish no earlier than 2014-06-13 | C3-IETF | 4524h | 4524h | IMS_EMER_GPRS_EPS-SRVCC | PCG-29 | Andrew Allen | Andrew Allen | Rel-9 | CP-56 | Adrian | Public Safety (I-A) |  |  |
| 2144 | 570 | **LCS for LTE and EPS** |  | 981d? | 2008-06-05 A | 2012-03-02 A | 100% | 2008-06-05 | 2012-03-02 | 981d? |  | S2; C1; C4; R2; R1; R3; R4; R5 | 83592h | 83592h | LCS_LTE_EPS | PCG-22 |  |  | Rel-9 | SP-43 | Maurice | Public Safety (I-A) | LCS_LTE_EPS |  |
| 2145 | 570.1 | **LCS Control Plane Solution for EPS** |  | 468d? | 2008-06-05 A | 2010-03-19 A | 100% | 2008-06-05 | 2010-03-19 | 468d? |  | S2; C4; C1 | 16712h | 16712h | LCS_EPS-CPS | PCG-21 | Polaris Wireless | Robert Gross (rgross@polariswireless.com) | Rel-9 | SP-40 | Maurice | Public Safety (I-A) | LCS_EPS-CPS |  |
| 2146 | 570.1.1 | Stage 2 for LCS Control Plane Solution for EPS |  | 261d? | 2008-06-05 A | 2009-06-04 A | 100% | 2008-06-05 | 2009-06-04 | 261d? | finish no earlier than 2009-06-04 | S2 | 2088h | 2088h | LCS_EPS-CPS | PCG-21 | Polaris Wireless | Robert Gross (rgross@polariswireless.com) | Rel-9 | SP-40 | Maurice | Public Safety (I-A) |  |  |
| 2147 | 570.1.2 | CT4 aspects of Control Plane LCS in the EPC |  | 212d? | 2009-05-29 A | 2010-03-19 A | 100% | 2009-05-29 | 2010-03-19 | 212d? | finish no earlier than 2010-03-19 | C4 | 1696h | 1696h | LCS_EPS-CPS | PCG-23 | Polaris Wireless | Robert Gross (rgross@polariswireless.com) | Rel-9 | CP-44 | Kimmo | Public Safety (I-A) |  |  |
| 2148 | 570.1.3 | CT1 aspects of Control Plane LCS in the EPC |  | 212d? | 2009-05-29 A | 2010-03-19 A | 100% | 2009-05-29 | 2010-03-19 | 212d? | finish no earlier than 2010-03-19 | C1 | 1696h | 1696h | LCS_EPS-CPS | PCG-23 | Polaris Wireless | Robert Gross (rgross@polariswireless.com) | Rel-9 | CP-44 | Frederic | Public Safety (I-A) |  |  |
| 2149 | 570.2 | Positioning Support for LTE | milestone | 0d? | 2008-12-05 A | 2008-12-05 A | 100% | 2008-12-05 | 2010-06-04 | 392d? | finish no earlier than 2010-06-04 | R2; R1; R3; R4 |  |  | LCS_LTE | PCG-22 | Qualcomm | Nathan Tenny (ntenny@qualcomm.com) | Rel-9 | RP-42 | Yong-Jun | Public Safety (I-A) | LCS_LTE | RP-100442 |
| 2150 | 570.3 | Conformance Test Aspects – Positioning Support for LTE |  | 512d? | 2010-03-19 A | 2012-03-02 A | 100% | 2010-03-19 | 2012-03-02 | 512d? | finish no earlier than 2012-03-02 | R5 | 4096h | 4096h | LCS_LTE_UEConTest | PCG-24 | Qualcomm | Shubhang Vora (svoral@qualcomm.com) | Rel-9 | RP-47 | Ingbert | Public Safety (I-A) | LCS_LTE_UEConTest | RP-120034 |
| 2151 | 571 | **MBMS support in EPS** |  | 921d? | 2008-06-05 A | 2011-12-09 A | 100% | 2008-06-05 | 2011-12-09 | 921d? |  | S2; S3; S5; C3; C4; R2; R3; R4; R5 | 82896h | 82896h | MBMS_EPS | PCG-21 | China Mobile | Liu Hong (liuhongyfw@chinamobile.com) | Rel-9 | SP-40 | Maurice |  | MBMS_EPS |  |
| 2152 | 571.1 | Stage 2 for MBMS support in EPS |  | 261d? | 2008-06-05 A | 2009-06-04 A | 100% | 2008-06-05 | 2009-06-04 | 261d? | finish no earlier than 2009-06-04 | S2 | 2088h | 2088h | MBMS_EPS | PCG-21 | China Mobile | Liu Hong (liuhongyfw@chinamobile.com) | Rel-9 | SP-40 | Maurice |  |  |  |
| 2153 | 571.2 | Security for MBMS support in EPS |  | 261d? | 2008-12-11 A | 2009-12-10 A | 100% | 2008-12-11 | 2009-12-10 | 261d? | finish no earlier than 2009-12-10 | S3 | 2088h | 2088h | MBMS_EPS | PCG-22 | China Mobile | Liu Hong (liuhongyfw@chinamobile.com) | Rel-9 | SP-42 | Mirko |  |  |  |
| 2154 | 571.3 | MBMS Charging in EPS |  | 201d? | 2009-03-06 A | 2009-12-10 A | 100% | 2009-03-06 | 2009-12-10 | 201d? | finish no earlier than 2009-12-10 | S5 | 1600h | 1600h | MBMS_EPS | PCG-22 | ZTE | guo.wenjie1@zte.com.cn | Rel-9 | SP-43 | Mirko |  |  |  |
| 2155 | 571.4 | CT4 aspects of MBMS support in EPS (Stage 3) |  | 137d? | 2009-05-29 A | 2009-12-04 A | 100% | 2009-05-29 | 2009-12-04 | 137d? | finish no earlier than 2009-12-04 | C4 | 1096h | 1096h | MBMS_EPS | PCG-23 | China Mobile, ZTE | wangjingyf@chinamobile.com, lu.fei1@zte.com.cn | Rel-9 | CP-44 | Kimmo |  |  |  |
| 2156 | 571.5 | CT3 aspects of MBMS support in EPS (Stage 3) |  | 137d? | 2009-05-29 A | 2009-12-04 A | 100% | 2009-05-29 | 2009-12-04 | 137d? | start no earlier than 2009-05-29 | C3 | 1096h | 1096h | MBMS_EPS | PCG-23 | ZTE, China Mobile | zhou.xiaoyun@zte.com.cn, wangjingyf@chinamobile.com | Rel-9 | CP-44 | Adrian |  |  |  |
| 2157 | 571.6 | MBMS support in LTE |  | 272d? | 2009-03-06 A | 2010-03-19 A | 100% | 2009-03-06 | 2010-03-19 | 272d? | finish no earlier than 2010-03-19 | R2; R3; R4 | 6528h | 6528h | MBMS_LTE | PCG-22 | Huawei | arnaud.meylan@huawei.com | Rel-9 | RP-43 | Yong-Jun |  | MBMS_LTE | RP-100033 |
| 2158 | 571.7 | Conformance Test Aspects – MBMS support in LTE |  | 262d? | 2010-12-10 A | 2011-12-09 A | 100% | 2010-12-10 | 2011-12-09 | 262d? | finish no earlier than 2011-12-09 | R5 | 2088h | 2088h | MBMS_LTE-UEConTest | PCG-26 | Huawei | Zhang Xin (zhangxin0208@huawei.com) | Rel-9 | RP-50 | Ingbert |  | MBMS_LTE-UEConTest | RP-111437 |
| 2159 | 572 | **Access Network Discovery and Selection Function enhancements** |  | 333d? | 2008-12-11 A | 2010-03-19 A | 100% | 2008-12-11 | 2010-03-19 | 333d? |  | S2; C1 | 7384h | 7384h | eANDSF | PCG-22 | Motorola | Apostolis Salkintzis (salki@motorola.com) | Rel-9 | SP-42 | Maurice |  | eANDSF |  |
| 2160 | 572.1 | Stage 2 for Access Network Discovery and Selection Function enhancements |  | 126d? | 2008-12-11 A | 2009-06-04 A | 100% | 2008-12-11 | 2009-06-04 | 126d? | finish no earlier than 2009-06-04 | S2 | 1008h | 1008h | eANDSF | PCG-22 | Motorola | Apostolis Salkintzis (salki@motorola.com) | Rel-9 | SP-42 | Maurice |  |  |  |
| 2161 | 572.2 | CT1 aspects of Access Network Discovery and Selection Function enhancements |  | 131d? | 2009-09-18 A | 2010-03-19 A | 100% | 2009-09-18 | 2010-03-19 | 131d? | finish no earlier than 2010-03-19 | C1 | 1048h | 1048h | eANDSF | PCG-23 | Panasonic | benjamin.limck@sg.panasonic.com | Rel-9 | CP-45 | Frederic |  |  |  |

Notes:
- 2137: CP#56 added IETF dependency
- 2138: SP#46 completed / Impacted TSs and TRs: 23.870, 23.216, 23.237
- 2139: CP#46 completed
- 2140: CP#46 completed / Impacted TSs and TRs: 24.229, 24.237
- 2141: CP#46 completed / Impacted TSs and TRs: 29.205, 29.280
- 2142: CP#46 completed / Impacted TSs and TRs: 29.163
- 2143: CP#64 completed / Impacted TSs and TRs: RFC 7254 (was draft-montemurro-gsma-imei-urn)
- 2144: - / Impacted TSs and TRs: LTE
- 2145: Triggered by abandoned Study UID_380068 (FS_LCS_EPS). Linked to Feature UID_380064 Support for IMS Emergency Calls over GPRS and EPS
- 2146: SP#44 completed / Impacted TSs and TRs: 23.891, 23.271, 23.401, 23.402
- 2147: CP#47 completed (IANA registrations outstanding). Stage 3 SLs and SLg interfaces & transport of positioning messages between E-SMLC and MME in the scope of UID_420006 (Positioning Support for LTE) / Impacted TSs and TRs: 24.080, 29.002, 29.272, 29.230, new 24.171, 29.171, 29.172, 29.173
- 2148: CP#47 completed / Impacted TSs and TRs: 24.301
- 2149: RP#48 completed. UID_400038 (LCS Control Plane Solution for EPS) depends on this WI / Impacted TSs and TRs: 34.213, 36.133, 36.211, 36.214, 36.300, 36.305, 36.331, 36.355, 36.410, 36.413, 36.455, new 36.171
- 2150: RP#55 completed. RP#56 TS 37.571-4 v200 for Approval / Impacted TSs and TRs: 36.508, 36.509, new (37.571-1, 37.571-2, 37.571-3, 37.571-4, 37.571-5)
- 2151: RP#47 completed. SP#46, CP#46 completed / Impacted TSs and TRs: LTE
- 2152: SP#44 completed / Impacted TSs and TRs: 23.246
- 2153: SP#46 completed / Impacted TSs and TRs: 33.246
- 2154: SP#46 completed / Impacted TSs and TRs: 32.273, 32.251, 32.298, 32.299
- 2155: CP#46 completed / Impacted TSs and TRs: 29.274, 29.281, 23.007, 23.008
- 2156: CP#46 completed / Impacted TSs and TRs: 29.061
- 2157: RP#47 completed / Impacted TSs and TRs: 25.446, 36.101, 36.104, 36.141, 36.300, 36.304, 36.321, 36.322, 36.323, 36.331, 36.440, 36.441, 36.442, 36.444, 36.445
- 2158: RP#54 completed / Impacted TSs and TRs: 36.508, 36.521-1, 36.521-2, 36.523-1, 36.523-2, 36.523-3
- 2159: CP#47 completed. No new Rel-9 use cases defined. Implement service requirements not covered in Rel-8 / Impacted TSs and TRs: 22.278, SA3 33.402 CR#0055
- 2160: SP#44 completed / Impacted TSs and TRs: 23.402, 23.002
- 2161: CP#47 completed / Impacted TSs and TRs: 24.302, 24.312

| ID | WBS | Task | Duration | Start | Finish | Complete | Baseline start | Baseline finish | Baseline duration | Constraint | Resources | Work | Actual work | Acronym | PCG approved | WI rapporteur name | WI rapporteur e-mail | Release | TSG approved | MCC resp | Acronym_3GU_Export | Impacted TSs and TRs | Status Report |
| --- | --- | --- | --- | --- | --- | --- | --- | --- | --- | --- | --- | --- | --- | --- | --- | --- | --- | --- | --- | --- | --- | --- | --- |
| 2162 | 573 | **Multiple PDN Connection to the Same APN for PMIP-based Interfaces** | 267d? | 2009-03-13 A | 2010-03-19 A | 100% | 2009-03-13 | 2010-03-19 | 267d? |  | S2; C4; C1 | 8392h | 8392h | MUPSAP | PCG-22 | Samsung | erik.guttman@partner.samsung.com | Rel-9 | SP-43 | Maurice | MUPSAP |  |  |
| 2163 | 573.1 | Stage 2 for Multiple PDN Connection to the Same APN for PMIP-based Interfaces | 61d? | 2009-03-13 A | 2009-06-04 A | 100% | 2009-03-13 | 2009-06-04 | 61d? | finish no earlier than 2009-06-04 | S2 | 488h | 488h | MUPSAP | PCG-22 | Samsung | erik.guttman@partner.samsung.com | Rel-9 | SP-43 | Maurice |  | 23.060, 23.203, 23.401, 23.402 |  |
| 2164 | 573.2 | CT4 aspects of Multiple PDN Connection to the Same APN for PMIP-based Interfaces | 56d? | 2009-09-18 A | 2009-12-04 A | 100% | 2009-09-18 | 2009-12-04 | 56d? | finish no earlier than 2009-12-04 | C4 | 448h | 448h | MUPSAP | PCG-23 | Samsung | Surjyakanta Mohapatra (surjya.kanta@samsung.com) | Rel-9 | CP-45 | Kimmo |  | 29.275, 23.008, 29.282 |  |
| 2165 | 573.3 | CT1 aspects of Multiple PDN Connection to the Same APN for PMIP-based Interfaces | 131d? | 2009-09-18 A | 2010-03-19 A | 100% | 2009-09-18 | 2010-03-19 | 131d? | finish no earlier than 2010-03-19 | C1 | 1048h | 1048h | MUPSAP | PCG-23 | Samsung | Surjyakanta Mohapatra (surjya.kanta@samsung.com) | Rel-9 | CP-45 | Frederic |  | 24.302 |  |
| 2166 | 574 | **System aspects of vocoder rate adaptation for LTE** | 1403.68d? | 2007-05-07 A | 2012-09-12 A | 100% | 2007-05-07 | 2012-09-12 | 1403.68d? |  | S2; S4; C1; C3; R2; IETF | 108798h | 108798h | LTEimp-Vocoder | PCG-23 | Qualcomm | AC Mahendran (ac@qualcomm.com) | Rel-9 | SP-45 | Maurice | LTEimp-Vocoder | LTE |  |
| 2167 | 574.1 | SA2 system aspects of vocoder rate adaptation for LTE | 81d? | 2009-06-04 A | 2009-09-24 A | 100% | 2009-06-04 | 2009-09-24 | 81d? | start no earlier than 2009-06-04 | S2 | 648h | 648h | LTEimp-Vocoder | PCG-23 | Qualcomm | AC Mahendran (ac@qualcomm.com) | Rel-9 | SP-45 | Maurice |  | 23.401 CR#1103r3 |  |
| 2168 | 574.2 | SA4 system aspects of vocoder rate adaptation for LTE | 136d? | 2009-06-04 A | 2009-12-10 A | 100% | 2009-06-04 | 2009-12-10 | 136d? | finish no earlier than 2009-12-07 | S4 | 1088h | 1088h | LTEimp-Vocoder | PCG-23 | Qualcomm | Nikolai Leung | Rel-9 | SP-45 | Paolo |  | 26.114 |  |
| 2169 | 574.3 | Vocoder rate adaptation for LTE | 81d? | 2009-05-30 A | 2009-09-18 A | 100% | 2009-05-30 | 2009-09-18 | 81d? | finish no earlier than 2009-09-18 | R2 | 648h | 648h | LTEimp-Vocoder | PCG-23 | Alcatel-Lucent | Sudeep Palat (spalat@alcatel-lucent.com) | Rel-9 | RP-44 | Yong-Jun |  | 36.300 CR#0114 | RP-090704 |
| 2170 | 574.4 | (IETF) SA4 system aspects of vocoder rate adaptation for LTE | 677.6d? | 2009-06-04 A | 2012-09-12 A | 100% | 2009-06-04 | 2012-09-12 | 677.6d? | finish no earlier than 2012-09-14 | S4-IETF | 5420.8h | 5420.8h | LTEimp-Vocoder | PCG-27 | Lionel Morand |  | Rel-9 | SP-52 | Paolo |  | RFC 6679 (was draft-ietf-avtcore-ecn-for-rtp) |  |
| 2171 | 574.5 | (IETF) CT aspects of vocoder rate adaptation for LTE | 1400.68d? | 2007-05-07 A | 2012-09-07 A | 100% | 2007-05-07 | 2012-09-07 | 1400.68d? | finish no earlier than 2012-09-07 | C1-IETF; C3-IETF; C4-IETF | 33616.3h | 33616.3h | LTEimp-Vocoder | PCG-27 | Lionel Morand |  | Rel-9 | CP-52 | Frederic |  | RFC 6679 (was draft-ietf-avtcore-ecn-for-rtp) |  |
| 2172 | 575 | Access Security Enhancements | 505d? | 2007-07-02 A | 2009-06-04 A | 100% | 2007-07-02 | 2009-06-04 | 505d? | finish no earlier than 2009-06-03 | S3 | 4040h | 4040h | ACCSEC2 |  | Ericsson | Bengt.Sahlin@ericsson.com | Rel-9 | SP-26 | Mirko | ACCSEC2 | 33.102, 43.020 |  |
| 2173 | 576 | **Protection against Unsolicited Communication for IMS (PUCI)** | 322d? | 2008-09-18 A | 2009-12-10 A | 100% | 2008-09-18 | 2009-12-10 | 322d? |  | S3; S1 | 8216h | 8216h | PUCI | PCG-21 | NEC | Anand R. Prasad (anand@bq.jp.nec.com) | Rel-9 | SP-41 | Alain | PUCI |  |  |
| 2174 | 576.1 | Stage 1 for PUCI | 61d? | 2008-09-18 A | 2008-12-11 A | 100% | 2008-09-18 | 2008-12-11 | 61d? | finish no earlier than 2009-06-18 | S1 | 488h | 488h | PUCI | PCG-21 | NEC | Anand R. Prasad (anand@bq.jp.nec.com) | Rel-9 | SP-41 | Alain |  | 22.228 |  |
| 2175 | 576.2 | SA3 work on PUCI | 322d? | 2008-09-18 A | 2009-12-10 A | 100% | 2008-09-18 | 2009-12-10 | 322d? | finish no earlier than 2009-12-10 | S3 | 2576h | 2576h | PUCI | PCG-21 | NEC | Anand R. Prasad (anand@bq.jp.nec.com) | Rel-9 | SP-41 | Mirko |  | New 33.937 |  |
| 2176 | 577 | **IMS Media Plane Security** | 922d? | 2009-03-13 A | 2012-09-14 A | 100% | 2009-03-13 | 2012-09-14 | 922d? |  | S3; C1; C4; C3; IETF | 67928h | 67928h | MEDIASEC | PCG-22 | Vodafone | Peter.Howard@vodafone.com | Rel-9 | SP-43 | Mirko | MEDIASEC |  |  |
| 2177 | 577.1 | SA3 aspects of IMS Media Plane Security | 271d? | 2009-03-13 A | 2010-03-25 A | 100% | 2009-03-13 | 2010-03-25 | 271d? | finish no earlier than 2010-03-25 | S3 | 2168h | 2168h | MEDIASEC | PCG-22 | Vodafone | Peter.Howard@vodafone.com | Rel-9 | SP-43 | Mirko |  | New 33.828, 33.328 |  |
| 2178 | 577.2 | (IETF) SA3, CT1, CT3 aspects of IMS Media Plane Security | 919d? | 2009-03-18 A | 2012-09-14 A | 100% | 2009-03-18 | 2012-09-14 | 919d? | finish no earlier than 2012-09-14 | S3-IETF; C1-IETF; C3-IETF | 22056h | 22056h | MEDIASEC | PCG-27 | Peter Dawes |  | Rel-9 | SP-52 | Mirko |  | draft-dawes-dispatch-mediasec-parameter |  |
| 2179 | 577.3 | **CN aspects of IMS Media Plane Security** | 186d? | 2009-09-18 A | 2010-06-04 A | 100% | 2009-09-18 | 2010-06-04 | 186d? |  | C1; C4; C3 | 6824h | 6824h | MEDIASEC_CORE | PCG-23 | Vodafone | peter.dawes@vodafone.com | Rel-9 | CP-45 | Frederic | MEDIASEC_CORE |  |  |
| 2180 | 577.3.1 | CT1 aspects of IMS Media Plane Security | 33d? | 2009-09-18 A | 2010-03-19 A | 100% | 2009-09-18 | 2010-03-19 | 33d? | finish no earlier than 2010-03-19 | C1 | 264h | 264h | MEDIASEC_CORE | PCG-23 | Vodafone | peter.dawes@vodafone.com | Rel-9 | CP-45 | Frederic |  | 23.218, 24.229 |  |
| 2181 | 577.3.2 | CT4 aspects of IMS Media Plane Security | 131d? | 2009-09-18 A | 2010-03-19 A | 100% | 2009-09-18 | 2010-03-19 | 131d? | finish no earlier than 2010-03-19 | C4 | 1048h | 1048h | MEDIASEC_CORE | PCG-23 | Vodafone | peter.dawes@vodafone.com | Rel-9 | CP-45 | Kimmo |  | 29.238, 23.334, 29.334 |  |
| 2182 | 577.3.3 | CT3 aspects of IMS Media Plane Security | 131d? | 2009-12-04 A | 2010-06-04 A | 100% | 2009-12-04 | 2010-06-04 | 131d? | finish no earlier than 2010-06-04 | C3 | 1048h | 1048h | MEDIASEC_CORE | PCG-24 | Vodafone | peter.dawes@vodafone.com | Rel-9 | CP-46 | Adrian |  | 29.162 |  |
| 2183 | 578 | **GBAPush enhancements (Generic push layer)** | 533d? | 2008-03-12 A | 2010-03-25 A | 100% | 2008-03-12 | 2010-03-25 | 533d? |  | S3 | 8528h | 8528h | eGBAPush | PCG-23 | Ericsson | Rolf Blom | Rel-9 | SP-44 | Mirko | eGBAPush | New 33.224 |  |
| 2184 | 578.1 | SA3 part of eGBAPush (Generic push layer) | 533d? | 2008-03-12 A | 2010-03-25 A | 100% | 2008-03-12 | 2010-03-25 | 533d? | finish no earlier than 2010-03-25 | S3 | 4264h | 4264h | eGBAPush | PCG-21 | Ericsson | Rolf Blom | Rel-9 | SP-39 | Mirko |  | New 33.224 |  |
| 2185 | 579 | Extended Identity Management | 136d? | 2009-06-04 A | 2009-12-10 A | 100% | 2009-06-04 | 2009-12-10 | 136d? | finish no earlier than 2009-12-10 | S3 | 1088h | 1088h | GBA-IdM | PCG-23 | Nokia | Silke.Holtmanns@nokia.com | Rel-9 | SP-44 | Mirko | GBA-IdM | New 33.924, CT4 29.109 (added service code) |  |

Notes:
- 2162: CP#47 completed. Continues Rel-8 SAES Stage 2 UID_320005. Stage 1 in 22.278 (EPS Service requirements)
- 2163: SP#44 completed
- 2164: CP#46 completed
- 2165: CP#47 completed
- 2166: Triggered by RAN2 UID_440013 Vocoder rate adaptation for LTE
- 2167: SP#45 completed (CR adding support for Explicit Congestion Notification)
- 2168: SP#46 completed
- 2169: RP#45 completed
- 2170: SP#57 completed
- 2171: CP#57 completed
- 2172: SP#44 completed. Stopped TR 33.801. CRs 33.102,43.020 on A5/2 removal done long time ago. A5/4 introduction CRs will be done under UID_440057 128 bit encryption for GSM and GPRS. SP#26 approved WID (improved GERAN security)
- 2173: SP#46 TR 33.937 completed but no specification work done in Rel-9. Related work in OMA Categorization Based Content Screening
- 2174: SP#42 completed
- 2175: SP#46 completed. No normative work done in Rel-9
- 2176: -
- 2177: SP#47 completed
- 2178: CP#57 completed, ietf-draft discontinued, documented within 3GPP
- 2179: CP#48 completed
- 2180: CP#47 completed
- 2181: CP#47 completed
- 2182: CP#48 completed
- 2183: SP#43 umbrella to host 33.224, moved from Rel-8 to Rel-9. SP#47 completed
- 2184: SP#47 completed
- 2185: SP#46 completed. Stage 1 not identified (GBA Liberty Interworking has been outlined and GBAOpenID interworking is analogous)

| ID | WBS | Task | Duration | Start | Finish | Complete | Baseline start | Baseline finish | Baseline duration | Constraint | Resources | Work | Actual work | Acronym | PCG approved | WI rapporteur name | Release | TSG approved | MCC resp | Acronym_3GU_Export | PCG stopped | TSG stopped |
| --- | --- | --- | --- | --- | --- | --- | --- | --- | --- | --- | --- | --- | --- | --- | --- | --- | --- | --- | --- | --- | --- | --- |
| 2186 | 580 | **Network Domain Security (NDS) enhancements to support backhaul security** | 924d? | 2009-06-04 A | 2012-12-07 A | 100% | 2009-06-04 | 2012-12-07 | 924d? |  | S3; IETF | 23452.8h | 23452.8h | NDS_Backhaul | PCG-23 | Vodafone | Rel-9 | SP-44 | Mirko | NDS_Backhaul |  |  |
| 2187 | 580.1 | SA3 part of Network Domain Security (NDS) enhancements to support backhaul security | 211d? | 2009-06-04 A | 2010-03-25 A | 100% | 2009-06-04 | 2010-03-25 | 211d? | finish no earlier than 2010-03-25 | S3 | 1688h | 1688h | NDS_Backhaul | PCG-23 | Vodafone | Rel-9 | SP-44 | Mirko |  |  |  |
| 2188 | 580.2 | (IETF) SA3 part of Network Domain Security (NDS) enhancements to support backhaul security | 740.6d? | 2009-06-04 A | 2012-12-07 A | 100% | 2009-06-04 | 2012-12-07 | 740.6d? | finish no earlier than 2012-12-07 | S3-IETF | 5924.8h | 5924.8h | NDS_Backhaul | PCG-27 | Bengt Sahlin | Rel-9 | SP-52 | Mirko |  |  |  |
| 2189 | 580.3 | Deleted - CT4 part of Network Domain Security (NDS) enhancements to support backhaul security | 132d? | 2009-06-04 A | 2009-12-04 A | 100% | 2009-06-04 | 2009-12-04 | 132d? | finish no earlier than 2009-12-04 | C4 | 1056h | 1056h | NDS_Backhaul | PCG-23 | Vodafone | Rel-9 | SP-44 | Kimmo |  | PCG-24 | CP-46 |
| 2190 | 581 | **128 bit encryption for GSM and GPRS** | 136d? | 2009-06-04 A | 2009-12-10 A | 100% | 2009-06-04 | 2009-12-10 | 136d? |  | S3; C1; C4; G2; G3new | 10392h | 10392h | A5/4-GEA4 | PCG-23 | Ericsson | Rel-9 | SP-44 | Mirko | A5/4-GEA4 |  |  |
| 2191 | 581.1 | SA3 part of 128 bit encryption for GSM and GPRS | 136d? | 2009-06-04 A | 2009-12-10 A | 100% | 2009-06-04 | 2009-12-10 | 136d? | finish no earlier than 2010-01-06 | S3 | 1088h | 1088h | A5/4-GEA4 | PCG-23 | Ericsson | Rel-9 | SP-44 | Mirko |  |  |  |
| 2192 | 581.2 | CT1 part of 128 bit encryption for GSM and GPRS | 77d? | 2009-06-04 A | 2009-09-18 A | 100% | 2009-06-04 | 2009-09-18 | 77d? | start no earlier than 2009-06-04 | C1 | 616h | 616h | A5/4-GEA4 | PCG-23 | Ericsson | Rel-9 | SP-44 | Frederic |  |  |  |
| 2193 | 581.3 | CT4 part of 128 bit encryption for GSM and GPRS | 136d? | 2009-06-04 A | 2009-12-10 A | 100% | 2009-06-04 | 2009-12-10 | 136d? | start no earlier than 2009-06-04 | C4 | 1088h | 1088h | A5/4-GEA4 | PCG-23 | Ericsson | Rel-9 | SP-44 | Kimmo |  |  |  |
| 2194 | 581.4 | GERAN2 part of 128 bit encryption for GSM and GPRS | 67d? | 2009-06-04 A | 2009-09-04 A | 100% | 2009-06-04 | 2009-09-04 | 67d? | finish no earlier than 2009-09-04 | G2 | 536h | 536h | A5/4-GEA4 | PCG-23 | Ericsson | Rel-9 | SP-44 | Gert |  |  |  |
| 2195 | 581.5 | GERAN3new (testing) part of 128 bit encryption for GSM and GPRS | 122d? | 2009-06-04 A | 2009-11-20 A | 100% | 2009-06-04 | 2009-11-20 | 122d? | finish no earlier than 2009-11-20 | G3new | 976h | 976h | A5/4-GEA4 | PCG-23 | Ericsson | Rel-9 | SP-44 | Ingbert |  |  |  |
| 2196 | 581.6 | Deleted - SA2 part of 128 bit encryption for GSM and GPRS | 81d? | 2009-06-04 A | 2009-09-24 A | 100% | 2009-06-04 | 2009-09-24 | 81d? | finish no earlier than 2009-09-24 | S2 | 648h | 648h | A5/4-GEA4 | PCG-23 | Ericsson | Rel-9 | SP-44 | Maurice |  | PCG-23 | SP-45 |
| 2197 | 582 | Timed Graphics | 337d? | 2008-12-11 A | 2010-03-25 A | 100% | 2008-12-11 | 2010-03-25 | 337d? | finish no earlier than 2010-03-25 | S4 | 2696h | 2696h | TG | PCG-22 | Ericsson | Rel-9 | SP-42 | Paolo | TG |  |  |
| 2198 | 583 | Managing MTSI Media Adaptation | 197d? | 2009-03-12 A | 2009-12-10 A | 100% | 2009-03-12 | 2009-12-10 | 197d? | finish no earlier than 2009-12-10 | S4 | 1568h | 1568h | M3A | PCG-22 | Samsung | Rel-9 | SP-43 | Paolo | M3A |  |  |
| 2199 | 584 | **PSS and MBMS Aspects** | 272d? | 2009-03-12 A | 2010-03-25 A | 100% | 2009-03-12 | 2010-03-25 | 272d? |  | S4 | 6512h | 6512h | PMA | PCG-23 | Ericsson, Nokia | Rel-9 | SP-44 | Paolo | PMA |  |  |
| 2200 | 584.1 | PSS and MBMS extensions | 271d? | 2009-03-12 A | 2010-03-25 A | 100% | 2009-03-12 | 2010-03-25 | 271d? | finish no earlier than 2010-03-25 | S4 | 2168h | 2168h | PMA-MBS_Ext | PCG-22 | Ericsson | Rel-9 | SP-43 | Paolo | PMA-MBS_Ext |  |  |
| 2201 | 584.2 | Improved Video Support for PSS and MBMS | 271d? | 2009-03-12 A | 2010-03-25 A | 100% | 2009-03-12 | 2010-03-25 | 271d? | finish no earlier than 2010-03-25 | S4 | 2168h | 2168h | PMA-IVS | PCG-22 | Nokia | Rel-9 | SP-43 | Paolo | PMA-IVS |  |  |
| 2202 | 585 | IMS based PSS and MBMS User Service extensions | 197d? | 2009-03-12 A | 2009-12-10 A | 100% | 2009-03-12 | 2009-12-10 | 197d? | finish no earlier than 2009-12-10 | S4 | 1576h | 1576h | IMS_PSS_MBMS_US_EXT | PCG-22 | Ericsson | Rel-9 | SP-43 | Paolo | IMS_PSS_MBMS_US_EXT |  |  |
| 2203 | 586 | Syndicated Feed Reception within 3GPP environments | 136d? | 2009-06-04 A | 2009-12-10 A | 100% | 2009-06-04 | 2009-12-10 | 136d? | start no earlier than 2009-06-04 | S4 | 1088h | 1088h | SFR | PCG-23 | Ericsson | Rel-9 | SP-44 | Paolo | SFR |  |  |
| 2204 | 587 | Distortion Measurement Test Methods and Requirements | 131d? | 2009-09-24 A | 2010-03-25 A | 100% | 2009-09-24 | 2010-03-25 | 131d? | finish no earlier than 2010-03-25 | S4 | 1048h | 1048h | DTMR | PCG-23 | Motorola | Rel-9 | SP-45 | Paolo | DTMR |  |  |
| 2205 | 588 | **Rel-9 Operations, Administration, Maintenance and Provisioning (OAM&P)** | 601d? | 2008-02-22 A | 2010-06-10 A | 100% | 2008-02-22 | 2010-06-10 | 601d? |  | S5 | 36890.4h | 36890.4h | OAM9 | PCG-22 |  | Rel-9 | SP-42 | Mirko | OAM9 |  |  |
| 2206 | 588.1 | **Rel-9 Network Infrastructure Management** | 337d? | 2008-12-11 A | 2010-03-25 A | 100% | 2008-12-11 | 2010-03-25 | 337d? |  | S5 | 8760h | 8760h | OAM9-NIM | PCG-22 |  | Rel-9 | SP-42 | Mirko | OAM9-NIM |  |  |
| 2207 | 588.1.1 | Software Management for Network Elements | 336d? | 2008-12-11 A | 2010-03-25 A | 100% | 2008-12-11 | 2010-03-25 | 336d? | finish no earlier than 2010-03-25 | S5 | 2688h | 2688h | OAM9-NE_SWM | PCG-22 | Huawei, Nokia Siemens Networks | Rel-9 | SP-42 | Mirko | OAM9-NE_SWM |  |  |
| 2208 | 588.1.2 | Service Oriented Architecture (SOA) for IRP | 211d? | 2009-06-04 A | 2010-03-25 A | 100% | 2009-06-04 | 2010-03-25 | 211d? | finish no earlier than 2010-03-25 | S5 | 1688h | 1688h |  | PCG-23 | Ericsson, Nokia Siemens Networks | Rel-9 | SP-44 | Mirko |  |  |  |
| 2209 | 588.1.3 | IRP SOAP Solution Sets continuation from Rel-8 | 211d? | 2009-06-04 A | 2010-03-25 A | 100% | 2009-06-04 | 2010-03-25 | 211d? | finish no earlier than 2010-03-25 | S5 | 1688h | 1688h |  | PCG-23 | Ericsson | Rel-9 | SP-44 | Mirko |  |  |  |

Notes:
- 2186: Continuation of Rel-8 UID_390044 SAE security architecture. Covers gaps in backhaul security in SAE (also applicable to UTRAN and GERAN backhaul) / WI rapporteur e-mail: Peter.Howard@vodafone.com
- 2187: SP#47 completed / Impacted TSs and TRs: 33.102, 33.210, 33.310, 33.401, 33.402 / WI rapporteur e-mail: Peter.Howard@vodafone.com
- 2188: CP#58 completed / Impacted TSs and TRs: RFC 6712 (was draft-ietf-pkix-cmp-transport-protocols)
- 2189: CP#46 completed. No impact on CT4 specs / WI rapporteur e-mail: Peter.Howard@vodafone.com
- 2190: Allow 128 as an alternative to 64 bit keys (Stage 2/3 + Test spec) / WI rapporteur e-mail: Karl Norrman
- 2191: SP#46 completed / Impacted TSs and TRs: 33.102,43.020, New 55.226 / WI rapporteur e-mail: Karl Norrman
- 2192: CP#45 completed / Impacted TSs and TRs: 24.008,44.064 / WI rapporteur e-mail: Karl Norrman
- 2193: CP#46 completed. Kc128 enhancements are carried as UMTS keys => no impact on CT4 29.002, 29.060 / WI rapporteur e-mail: Karl Norrman
- 2194: GP#43 WID approved + completed / Impacted TSs and TRs: 44.018,48.008,48.018,48.058 / WI rapporteur e-mail: Karl Norrman
- 2195: GP#44 completed. GP#43 WID approved / Impacted TSs and TRs: 51.010 / WI rapporteur e-mail: Karl Norrman
- 2196: SP#45 work stopped/abandoned / Impacted TSs and TRs: 23.060 / WI rapporteur e-mail: Karl Norrman
- 2197: SP#47 completed. Provide graphics in parallel to a video stream (without requiring an umbrella scene descriptor such as 3GPP DIMS in TS 26.142) / Impacted TSs and TRs: 26.114, 26.140, 26.234, 26.244, 26.245, 26.346, New 26.430 / WI rapporteur e-mail: clinton.priddle@ericsson.com
- 2198: SP#46 completed. Work extending Rel-8 UID_34041 MTSI Video - Dynamic Rate Adaptation/Signalling of Image Size. Update speech/video adaptation algorithms used by network to control MTSI client terminal in congestion or poor transmission conditions. / Impacted TSs and TRs: 26.114 / WI rapporteur e-mail: kyunghun.jung@samsung.com
- 2199: Umbrella WI / WI rapporteur e-mail: Clinton.Priddle@ericsson.com, imed.bouazizi@nokia.com
- 2200: SP#47 completed. Extends Rel-8 UID_34043 (PSS_MBMS_OMTV) & ensures compatibility with UID_34046 (IMS_PSS_MBMS_US) / Impacted TSs and TRs: 26.234, 26.346 / WI rapporteur e-mail: Clinton.Priddle@ericsson.com
- 2201: SP#47 completed / Impacted TSs and TRs: 26.234, 26.244, 26.346, new 26.903 / WI rapporteur e-mail: imed.bouazizi@nokia.com
- 2202: SP#46 completed. Work extending Rel-8 UID_34046 (IMS_PSS_MBMS_US), SA2 UID_410034 IMSSCC-SPI (IMS Service Continuity Enhancements: Service, Policy and Interactions) / Impacted TSs and TRs: 26.237 / WI rapporteur e-mail: Markus Kampmann
- 2203: SP#46 completed. TS 26.150v100 for Approval. RSS optimized for mobile use. Reuse/reference OMA's enabler DCD. / Impacted TSs and TRs: New 26.150 / WI rapporteur e-mail: Thorsten.Lohmar@ericsson.com
- 2204: SP#47 completed / Impacted TSs and TRs: 26.131, 26.132 / WI rapporteur e-mail: Stephen Kendall (wcsk01@motorola.com)
- 2205: OAM9 is an umbrella Feature also for OAM&P related TEI9 type of changes that are not part of any other dedicated feature/WI / Impacted TSs and TRs: TR 30.819
- 2206: SP#42 umbrella BB created to host OAM WIs
- 2207: SP#47 completed / Impacted TSs and TRs: 32.531, 32.532, 32.533, new 32.537 / WI rapporteur e-mail: Bidipta Das (bidipta@huawei.com), Clemens Suerbaum (clemens.suerbaum@nsn.com)
- 2208: SP#47 completed (covering SOA Architecture & SOA-supporting Solution Set). Triggered by UID_400029 Study on Service Oriented Architecture (SOA) for IRP (TR 32.824) / Impacted TSs and TRs: 32.101, 32.102, 32.150 / WI rapporteur e-mail: edwin.tse@ericsson.com, Jörg Schmidt (joerg@cox.net)
- 2209: SP#47 completed. Continuation of Rel-8 UID_400030 IRP SOAP Solution Sets / Impacted TSs and TRs: New (32.127/ 327/ 337/ 357/ 387/ 397/ 447/ 397/ 447/ 507/ 537), 32.121,32.122,32.123,32,32.321,32.322,32.323,32.325,32.331,32.332,32.333,32.335,32.351,32.352,32.353,32.381,32.382,32.383,32.385,32.391,32.392,32.393,32.395,32.441,32.442,32.443 / WI rapporteur e-mail: John Power

| ID | WBS | Task | Duration | Start | Finish | Complete | Baseline start | Baseline finish | Baseline duration | Constraint | Resources | Work | Actual work | Acronym | PCG approved | Release | TSG approved | MCC resp | Acronym_3GU_Export | Impacted TSs and TRs | WI rapporteur name | Special Focus Doc | PCG stopped | TSG stopped |
| --- | --- | --- | --- | --- | --- | --- | --- | --- | --- | --- | --- | --- | --- | --- | --- | --- | --- | --- | --- | --- | --- | --- | --- | --- |
| 2210 | 588.2 | **Rel-9 Performance Management** | 327d? | 2009-03-12 A | 2010-06-10 A | 100% | 2009-03-12 | 2010-06-10 | 327d? |  | S5 | 7890.41h | 7890.41h | OAM9-PM | PCG-22 | Rel-9 | SP-42 | Mirko | OAM9-PM |  |  |  |  |  |
| 2211 | 588.2.1 | Enhancement of UTRAN Performance Measurements | 136d? | 2009-06-04 A | 2009-12-10 A | 100% | 2009-06-04 | 2009-12-10 | 136d? | start no earlier than 2009-06-04 | S5 | 1088h | 1088h |  | PCG-23 | Rel-9 | SP-44 | Mirko |  | 32.405 | China Mobile |  |  |  |
| 2212 | 588.2.2 | Enhancement of E-UTRAN Performance Measurements | 327d? | 2009-03-12 A | 2010-06-10 A | 100% | 2009-03-12 | 2010-06-10 | 327d? | finish no earlier than 2010-06-10 | S5 | 2616h | 2616h |  | PCG-22 | Rel-9 | SP-43 | Mirko |  | 32.425 | Motorola, Huawei |  |  |  |
| 2213 | 588.2.3 | Enhancement of EPC Performance Measurements | 197d? | 2009-03-12 A | 2009-12-10 A | 100% | 2009-03-12 | 2009-12-10 | 197d? | finish no earlier than 2010-03-25 | S5 | 1570.41h | 1570.41h |  | PCG-22 | Rel-9 | SP-43 | Mirko |  | 32.426 | China Mobile |  |  |  |
| 2214 | 588.3 | **Rel-9 Self-Organizing Networks (SON) - OAM aspects** | 601d? | 2008-02-22 A | 2010-06-10 A | 100% | 2008-02-22 | 2010-06-10 | 601d? |  | S5 | 11736h | 11736h | OAM9-SON | PCG-22 | Rel-9 | SP-43 | Mirko | OAM9-SON |  |  | SON |  |  |
| 2215 | 588.3.1 | SON self-optimization management (moved from Rel-8 LTE_SON-OAM) | 600d? | 2008-02-22 A | 2010-06-10 A | 100% | 2008-02-22 | 2010-06-10 | 600d? | finish no earlier than 2010-06-10 | S5 | 4800h | 4800h |  | PCG-21 | Rel-9 | SP-39 | Mirko |  | 32.425, new (32.521, 32.522, 32.523, 32.525) | Huawei | SON |  |  |
| 2216 | 588.3.2 | Automatic Radio Network Configuration Data Preparation | 266d? | 2009-06-04 A | 2010-06-10 A | 100% | 2009-06-04 | 2010-06-10 | 266d? | finish no earlier than 2010-06-10 | S5 | 2128h | 2128h |  | PCG-23 | Rel-9 | SP-44 | Mirko |  | 32.501, 32.502, 32.503, 32.505, new 32.507 | Nokia Siemens Networks | SON |  |  |
| 2217 | 588.4 | Rel-9 Subscription Management (SuM) evolution | 266d? | 2009-06-04 A | 2010-06-10 A | 100% | 2009-06-04 | 2010-06-10 | 266d? | finish no earlier than 2010-06-10 | S5 | 2128h | 2128h | OAM9-SuM | PCG-23 | Rel-9 | SP-44 | Mirko | OAM9-SuM | 32.140, 32.141, 32.152, 32.172, 32.175 | Ericsson |  |  |  |
| 2218 | 588.5 | Deleted - Rel-9 Trace | 196d? | 2009-03-13 A | 2009-12-10 A | 100% | 2009-03-13 | 2009-12-10 | 196d? | finish no earlier than 2009-12-10 | S5 | 1568h | 1568h | OAM9-Trace | PCG-22 | Rel-9 | SP-42 | Mirko | OAM9-Trace |  |  |  | PCG-24 | SP-46 |
| 2219 | 589 | Rel-9 Charging Management small Enhancements | 211d? | 2009-06-04 A | 2010-03-25 A | 100% | 2009-06-04 | 2010-03-25 | 211d? |  | S5 | 1688h | 1688h | CH9 | PCG-23 | Rel-9 | SP-44 | Mirko | CH9 | TR 30.819 |  |  |  |  |
| 2220 | 590 | **CS-IBCF and CS-TrGW definition in 3GPP specifications** | 472d? | 2008-05-30 A | 2010-03-19 A | 100% | 2008-05-30 | 2010-03-19 | 472d? |  | C3; C4 | 14490.3h | 14490.3h | CS-IBCF | PCG-21 | Rel-9 | CP-40 | Adrian | CS-IBCF |  | Telecom Italia |  |  |  |
| 2221 | 590.1 | CT3 aspects of CS-IBCF and CS-TrGW definition in 3GPP specifications | 472d? | 2008-05-30 A | 2010-03-19 A | 100% | 2008-05-30 | 2010-03-19 | 472d? | finish no earlier than 2009-12-04 | C3 | 3770.34h | 3770.34h | CS-IBCF | PCG-21 | Rel-9 | CP-40 | Adrian |  | 29.235 | Telecom Italia |  |  |  |
| 2222 | 590.2 | CT4 aspects of CS-IBCF and CS-TrGW definition in 3GPP specifications | 396d? | 2008-05-30 A | 2009-12-04 A | 100% | 2008-05-30 | 2009-12-04 | 396d? | finish no earlier than 2009-12-04 | C4 | 3168h | 3168h | CS-IBCF | PCG-21 | Rel-9 | CP-40 | Kimmo |  | 23.231, 29.232, new 29.238 | Telecom Italia |  |  |  |
| 2223 | 591 | **IMS – Interconnection Border Control Function (IBCF) – Transition Gateway (TrGW); Ix Interface; Stage 3** | 322d? | 2008-09-12 A | 2009-12-04 A | 100% | 2008-09-12 | 2009-12-04 | 322d? |  | C4; C3 | 10086.4h | 10086.4h | IMS_IBCF | PCG-21 | Rel-9 | CP-41 | Kimmo | IMS_IBCF |  | Alcatel-Lucent |  |  |  |
| 2224 | 591.1 | CT4 part of IMS – Interconnection Border Control Function (IBCF) – Transition Gateway (TrGW); Ix Interface; Stage 3 | 321d? | 2008-09-12 A | 2009-12-04 A | 100% | 2008-09-12 | 2009-12-04 | 321d? | finish no earlier than 2009-12-04 | C4 | 2568h | 2568h | IMS_IBCF | PCG-21 | Rel-9 | CP-41 | Kimmo |  | new 29.238 | Alcatel-Lucent |  |  |  |
| 2225 | 591.2 | CT3 part of IMS – Interconnection Border Control Function (IBCF) – Transition Gateway (TrGW); Ix Interface; Stage 3 | 295.8d? | 2008-09-12 A | 2009-12-04 A | 100% | 2008-09-12 | 2009-12-04 | 295.8d? | finish no earlier than 2010-03-19 | C3 | 2366.4h | 2366.4h | IMS_IBCF | PCG-21 | Rel-9 | CP-41 | Adrian |  | 29.162, 29.235 | Alcatel-Lucent |  |  |  |
| 2226 | 592 | IMS Application Level Gateway Control Function (ALGCF) – IMS Access Media Gateway (IMA-MGW); Iq Interface; Stage 2 and Stage 3 | 321d? | 2008-09-12 A | 2009-12-04 A | 100% | 2008-09-12 | 2009-12-04 | 321d? | finish no earlier than 2009-12-04 | C4 | 2568h | 2568h | IMS_AGCF | PCG-21 | Rel-9 | CP-41 | Kimmo | IMS_AGCF | New 23.334, 29.334 | Alcatel-Lucent |  |  |  |
| 2227 | 593 | **Enhancements of IMS Customized Alerting Tone (CAT) Service** | 392d? | 2008-12-05 A | 2010-06-04 A | 100% | 2008-12-05 | 2010-06-04 | 392d? |  | C1 | 5846.4h | 5846.4h | eCAT | PCG-22 | Rel-9 | CP-42 | Frederic | eCAT |  | China Mobile |  |  |  |
| 2228 | 593.1 | Stage 3 for Enhancements of IMS Customized Alerting Tone (CAT) Service | 391d? | 2008-12-05 A | 2010-06-04 A | 100% | 2008-12-05 | 2010-06-04 | 391d? | finish no earlier than 2010-06-04 | C1 | 3128h | 3128h | eCAT-SS | PCG-22 | Rel-9 | CP-42 | Frederic | eCAT-SS | 24.182 | China Mobile |  |  |  |
| 2229 | 594 | **Completion of IMS Restoration Procedures** | 212d? | 2009-05-29 A | 2010-03-19 A | 100% | 2009-05-29 | 2010-03-19 | 212d? |  | C3; C4; C1 | 10176h | 10176h | eIMS_RP | PCG-23 | Rel-9 | CP-44 | Kimmo | eIMS_RP |  | Ericsson |  |  |  |
| 2230 | 594.1 | CT4 aspects of Completion of IMS Restoration Procedures | 212d? | 2009-05-29 A | 2010-03-19 A | 100% | 2009-05-29 | 2010-03-19 | 212d? | finish no earlier than 2010-03-19 | C4 | 1696h | 1696h | eIMS_RP | PCG-23 | Rel-9 | CP-44 | Kimmo |  | 23.380, 23.820 | Ericsson |  |  |  |
| 2231 | 594.2 | CT1 aspects of Completion of IMS Restoration Procedures | 212d? | 2009-05-29 A | 2010-03-19 A | 100% | 2009-05-29 | 2010-03-19 | 212d? | finish no earlier than 2010-03-19 | C1 | 1696h | 1696h | eIMS_RP | PCG-23 | Rel-9 | CP-44 | Kimmo |  | 24.229 | Ericsson |  |  |  |
| 2232 | 594.3 | CT3 aspects of Completion of IMS Restoration Procedures | 212d? | 2009-05-29 A | 2010-03-19 A | 100% | 2009-05-29 | 2010-03-19 | 212d? | finish no earlier than 2010-03-19 | C3 | 1696h | 1696h | eIMS_RP | PCG-24 | Rel-9 | CP-46 | Kimmo |  | 29.061, 29.212, 29.213, 29.214, 29.215 | Ericsson |  |  |  |
| 2233 | 595 | **IMS Stage 3 IETF Protocol Alignment - phase 3** | 1458d? | 2009-05-29 A | 2014-12-05 A | 100% | 2009-05-29 | 2014-12-05 | 1455d? |  | C1; IETF | 40216h | 40216h | IMSProtoc3 | PCG-23 | Rel-9 | CP-44 | Frederic | IMSProtoc3 |  | Alcatel-Lucent |  |  |  |
| 2234 | 595.1 | CT1 aspects of IMS Stage 3 - IETF Protocol Alignment - phase 3 | 212d? | 2009-05-29 A | 2010-03-19 A | 100% | 2009-05-29 | 2010-03-19 | 212d? | finish no earlier than 2010-03-19 | C1 | 1696h | 1696h | IMSProtoc3 | PCG-23 | Rel-9 | CP-44 | Frederic |  | 23.218, 24.229, 24.930 | Alcatel-Lucent |  |  |  |
| 2235 | 595.2 | (IETF) CT1 IMS Stage 3 - IETF Protocol Alignment (RFC 7329) | 1242d? | 2009-05-29 A | 2014-12-05 A | 100% | 2009-05-29 | 2014-12-05 | 1240d? | finish no earlier than 2014-12-09 | C1-IETF | 9936h | 9936h | IMSProtoc3 | PCG-27 | Rel-9 | CP-52 | Frederic |  | RFC 7329 (was draft-kaplan-insipid-session-id) | christer.holmberg@ericsson.com |  |  |  |
| 2236 | 595.3 | (IETF) CT1 IMS Stage 3 - IETF Protocol Alignment (RFC 7044) | 659d? | 2011-09-13 A | 2014-03-07 A | 100% | 2011-09-13 | 2014-03-07 | 659d? | finish no earlier than 2014-02-10 | C1-IETF | 5256h | 5256h | IMSProtoc3 | PCG-27 | Rel-9 | CP-53 | Frederic |  | RFC 7044 (was draft-ietf-sipcore-rfc4244bis) | christer.holmberg@ericsson.com |  |  |  |

Notes:
- 2210: SP#42 umbrella BB created to host OAM WIs
- 2211: SP#46 completed / WI rapporteur e-mail: liangshuangchun@cmdi.chinamobile.com, lijian@chinamobile.com, Bao Haitao
- 2212: SP#48 completed / WI rapporteur e-mail: Yizhi Yao (yzyao@motorola.com),Lan Zou (zlan@huawei.com)
- 2213: SP#46 completed / WI rapporteur e-mail: Li Jian (lijian@chinamobile.com), Liang Shuangchun (liangshuangchun@cmdi.chinamobile.com)
- 2214: SP#43 umbrella BB created to host OAM WIs
- 2215: SP#48 completed / WI rapporteur e-mail: Lan Zou (zlan@huawei.com)
- 2216: SP#48 completed / WI rapporteur e-mail: clemens.suerbaum@nsn.com
- 2217: SP#48 completed / WI rapporteur e-mail: frode.nergard@ericsson.com
- 2218: SP#46 stopped (no work in Rel-9)
- 2219: CH9 is an umbrella Feature also for OAM&P related TEI9 type of changes that are not part of any other dedicated feature/WI
- 2220: CP#47 completed. Rel-8 UID_380061 (Ipinterc) covers Stage 1 in SA1 22.101, 22.228 / WI rapporteur e-mail: mauro.ficaccio@telecomitalia.it
- 2221: CP#47 completed / WI rapporteur e-mail: mauro.ficaccio@telecomitalia.it
- 2222: CP#46 completed / WI rapporteur e-mail: mauro.ficaccio@telecomitalia.it
- 2223: CP#46 completed / WI rapporteur e-mail: bruno.landais@alcatel-lucent.fr
- 2224: CP#46 completed / WI rapporteur e-mail: bruno.landais@alcatel-lucent.fr
- 2225: CP#46 completed / WI rapporteur e-mail: bruno.landais@alcatel-lucent.fr
- 2226: CP#46 completed / WI rapporteur e-mail: bruno.landais@alcatel-lucent.fr
- 2227: CP#48 completed. Stage 1 in 22.182 / WI rapporteur e-mail: Jiang Yi
- 2228: CP#48 completed / WI rapporteur e-mail: Jiang Yi
- 2229: CP#47 completed. Continuation of Rel-8 Feature UID_400012 IMS Restoration Procedures / WI rapporteur e-mail: Emiliano Merino (emiliano.merino@ericsson.com)
- 2230: CP#47 completed / WI rapporteur e-mail: Emiliano Merino (emiliano.merino@ericsson.com)
- 2231: CP#47 completed / WI rapporteur e-mail: Emiliano Merino (emiliano.merino@ericsson.com)
- 2232: CP#47 completed / WI rapporteur e-mail: Emiliano Merino (emiliano.merino@ericsson.com)
- 2233: CP#47 completed / WI rapporteur e-mail: Keith Drage (drage@alcatel-lucent.com)
- 2234: CP#47 completed / WI rapporteur e-mail: Keith Drage (drage@alcatel-lucent.com)
- 2235: CP#65 completed / WI rapporteur e-mail: christer.holmberg@ericsson.com
- 2236: CP#63 completed / WI rapporteur e-mail: christer.holmberg@ericsson.com

| ID | WBS | Task | Type | Duration | Start | Finish | Complete | Remaining | Baseline start | Baseline finish | Baseline duration | Total slack | Constraint | Resources | Work | Actual work | Acronym | PCG approved | WI rapporteur name | WI rapporteur e-mail | Release | TSG approved | MCC resp | Acronym_3GU_Export | Special Focus Doc | Status Report |
| --- | --- | --- | --- | --- | --- | --- | --- | --- | --- | --- | --- | --- | --- | --- | --- | --- | --- | --- | --- | --- | --- | --- | --- | --- | --- | --- |
| 2237 | 596 | **Operational description of the Inter-IMS Network to Network Interface (II-NNI)** |  | 1460d? | 2009-05-29 A | 2014-12-09 | 95% | 69.98d? | 2009-05-29 | 2014-12-05 | 1455d? | 657d |  | C3; IETF | 58408h | 37634.4h | II-NNI | PCG-23 | Orange | sebastien.daudet@orange-ftgroup.com | Rel-9 | CP-44 | Adrian | II-NNI |  |  |
| 2238 | 596.1 | Operational description of the Inter-IMS Network to Network Interface |  | 267d? | 2009-05-29 A | 2010-06-04 A | 100% |  | 2009-05-29 | 2010-06-04 | 267d? |  | start no earlier than 2009-05-29 | C3 | 2136h | 2136h | II-NNI | PCG-23 | Orange |  | Rel-9 | CP-44 | Adrian |  |  |  |
| 2239 | 596.2 | (IETF) Operational description of the Inter-IMS Network to Network Interface (RFC 7329) |  | 633d? | 2012-04-20 A | 2014-09-12 A | 100% |  | 2012-04-20 | 2014-12-05 | 693d? |  | finish no earlier than 2014-09-12 | C3-IETF | 5040h | 5040h | II-NNI | PCG-29 | christer.holmberg@ericsson.com | christer.holmberg@ericsson.com | Rel-9 | CP-56 | Adrian |  |  |  |
| 2240 | 596.3 | (IETF) Operational description of the Inter-IMS Network to Network Interface (RFC 7316) |  | 634d? | 2012-04-20 A | 2014-09-12 A | 100% |  | 2012-04-20 | 2014-12-05 | 694d? |  | finish no earlier than 2014-12-09 | C3-IETF | 5064h | 5064h | II-NNI | PCG-29 | Keith Drage | Keith Drage | Rel-9 | CP-56 | Adrian |  |  |  |
| 2241 | 596.4 | (IETF) Operational description of the Inter-IMS Network to Network Interface |  | 696d? | 2012-04-20 A | 2014-12-09 | 90% | 69.6d? | 2012-04-20 | 2014-12-05 | 694d? | 657d | finish no earlier than 2014-12-09 | C3-IETF | 5560h | 5003.2h | II-NNI | PCG-29 | Roland Jesske | Roland Jesske | Rel-9 | CP-56 | Adrian |  |  |  |
| 2242 | 596.5 | (IETF) Operational description of the Inter-IMS Network to Network Interface |  | 696d? | 2012-04-20 A | 2014-12-09 | 90% | 71.4d? | 2012-04-20 | 2014-12-05 | 694d? | 657d | finish no earlier than 2014-12-09 | C3-IETF | 5536h | 4964.8h | II-NNI | PCG-29 | Roland Jesske | Roland Jesske | Rel-9 | CP-56 | Adrian |  |  |  |
| 2243 | 596.6 | (IETF) Operational description of the Inter-IMS Network to Network Interface |  | 697d? | 2012-04-20 A | 2014-12-09 | 90% | 69.7d? | 2012-04-20 | 2014-12-05 | 695d? | 657d | finish no earlier than 2014-12-09 | C3-IETF | 5560h | 5002.4h | II-NNI | PCG-29 | Keith Drage | Keith Drage | Rel-9 | CP-56 | Adrian |  |  |  |
| 2244 | 596.7 | Deleted - (IETF) Operational description of the Inter-IMS Network to Network Interface |  | 433d? | 2012-04-20 A | 2013-12-06 A | 100% |  | 2012-04-20 | 2014-12-05 | 694d? |  | finish no earlier than 2013-12-06 | C3-IETF | 3456h | 3456h | II-NNI | PCG-29 | Peter Dawes | peter.dawes@vodafone.com | Rel-9 | CP-56 | Adrian |  |  |  |
| 2245 | 596.8 | Deleted - (IETF) Operational description of the Inter-IMS Network to Network Interface (avasarala-dispatch-comm-div-notification) |  | 340d? | 2013-03-01 A | 2014-06-13 A | 100% |  | 2013-03-01 | 2014-06-13 | 340d? |  | finish no earlier than 2014-06-13 | C3-IETF | 2696h | 2696h | II-NNI | PCG-30 | Andrew Allen | Andrew Allen | Rel-9 | CP-59 | Adrian |  |  |  |
| 2246 | 597 | Definition of Ml interface for Control Plane LCS (Stage 3) |  | 131d? | 2009-09-18 A | 2010-03-19 A | 100% |  | 2009-09-18 | 2010-03-19 | 131d? |  | finish no earlier than 2010-03-19 | C1 | 1048h | 1048h | EMC2 | PCG-23 | Alcatel-Lucent | Keith Drage (drage@alcatel-lucent.com) | Rel-9 | CP-45 | Frederic | EMC2 | Public Safety (I-A) |  |
| 2247 | 598 | PCC enhancements |  | 56d? | 2009-09-18 A | 2009-12-04 A | 100% |  | 2009-09-18 | 2009-12-04 | 56d? |  | finish no earlier than 2009-12-04 | C3 | 448h | 448h | PCC-Enh | PCG-23 | Huawei | Wei Weihua (weiwh@huawei.com) | Rel-9 | CP-45 | Adrian | PCC-Enh |  |  |
| 2248 | 599 | 3GPP IMS Conferencing Management Object (MO) |  | 2d? | 2009-12-03 A | 2009-12-04 A | 100% |  | 2009-12-03 | 2009-12-04 | 2d? |  | start no earlier than 2009-12-03 | C1 | 16h | 16h | IMS_ConfMO | PCG-24 |  |  | Rel-9 | CP-46 | Frederic | IMS_ConfMO |  |  |
| 2249 | 600 | In Case of Emergency (ICE) Graphics |  | 3d? | 2010-03-17 A | 2010-03-19 A | 100% |  | 2010-03-17 | 2010-03-19 | 3d? |  | finish no earlier than 2010-03-19 | C6 | 24h | 24h | ICE_Graphics | PCG-24 | Sagem-Orga | heiko.kruse@sagem-orga.com | Rel-9 | CP-47 | Xavier | ICE_Graphics |  |  |
| 2250 | 601 | **Rel-9 Improvements of the Radio Interface** |  | 397d? | 2008-09-12 A | 2010-03-19 A | 100% |  | 2008-09-12 | 2010-03-19 | 397d? |  |  | RP; GP | 19744h | 19744h | RInImp9 | PCG-21 |  |  | Rel-9 | RP-41 | Issam | RInImp9 |  |  |
| 2251 | 601.1 | LCR TDD UE OTA Performance Requirements |  | 186d? | 2008-09-12 A | 2009-05-29 A | 100% |  | 2008-09-12 | 2009-05-29 | 186d? |  | finish no earlier than 2009-05-29 | R4 | 1488h | 1488h | RInImp9-RFLCROTA | PCG-21 | RITT | Wu Xiang (wuxiang@chinattl.com) | Rel-9 | RP-41 | Issam | RInImp9-RFLCROTA |  | RP-090389 |
| 2252 | 601.2 | **RF requirements for Multicarrier and Multi-RAT BS** |  | 347d? | 2008-11-21 A | 2010-03-19 A | 100% |  | 2008-11-21 | 2010-03-19 | 347d? |  |  | R4; G1 | 10336h | 10336h | RInImp9-RFmulti | PCG-21 | Ericsson | Johan.skold@ericsson.com | Rel-9 | RP-41 | Issam | RInImp9-RFmulti |  |  |
| 2253 | 601.2.1 | RAN4 part of RF requirements for Multicarrier and Multi RAT BS |  | 337d? | 2008-12-05 A | 2010-03-19 A | 100% |  | 2008-12-05 | 2010-03-19 | 337d? |  | finish no earlier than 2010-03-19 | R4 | 2696h | 2696h | RInImp9-Rfmulti | PCG-22 | Ericsson | johan.skold@ericsson.com | Rel-9 | RP-42 | Issam |  |  | RP-100027 |
| 2254 | 601.2.2 | GERAN part of RF requirements for Multicarrier and Multi RAT BS |  | 261d? | 2008-11-21 A | 2009-11-20 A | 100% |  | 2008-11-21 | 2009-11-20 | 261d? |  | finish no earlier than 2009-11-20 | G1 | 2088h | 2088h | RInImp9-RFmulti-GERAN | PCG-22 | Ericsson | mats.y.samuelsson@ericsson.com | Rel-9 | GP-40 | Paolo | RInImp9-RFmulti-GERAN |  |  |
| 2255 | 601.3 | Extended UMTS/LTE 800 MHz | milestone | 0d? | 2008-12-05 A | 2008-12-05 A | 100% |  | 2008-12-05 | 2009-09-18 | 207d? |  |  | R4; R2; R3 |  |  | RInImp9-UMTSLTE800 | PCG-22 | NTT DoCoMo | Shingo Suwa (suwas@nttdocomo.co.jp) | Rel-9 | RP-42 | Issam | RInImp9-UMTSLTE800 |  | RP-090687 |
| 2256 | 601.4 | UMTS/LTE 800 MHz for Europe | milestone | 0d? | 2009-03-06 A | 2009-03-06 A | 100% |  | 2009-03-06 | 2010-03-19 | 272d? |  | finish no earlier than 2010-03-19 | R4; R2; R3 |  |  | RInImp9-UMTSLTE800EU | PCG-22 | Ericsson | olav.queseth@ericsson.com | Rel-9 | RP-43 | Issam | RInImp9-UMTSLTE800EU |  | RP-100028 |
| 2257 | 601.5 | Performance requirement for LCR TDD with UE speeds up to 350 km/h |  | 196d? | 2009-03-06 A | 2009-12-04 A | 100% |  | 2009-03-06 | 2009-12-04 | 196d? |  | finish no earlier than 2009-12-04 | R4 | 1568h | 1568h | RInImp9-LCRTDD350 | PCG-22 | CATT | Yuexia Song (songyuexia@catt.cn) | Rel-9 | RP-43 | Issam | RInImp9-LCRTDD350 |  | RP-091035 |
| 2258 | 601.6 | Extended UMTS/LTE 1500 MHz | milestone | 0d? | 2009-05-30 A | 2009-05-30 A | 100% |  | 2009-05-30 | 2010-03-19 | 211d? |  | finish no earlier than 2010-03-19 | R4; R2; R3 |  |  | UMTSLTE1500 | PCG-23 | NTT DoCoMo | Shingo Suwa (suwas@nttdocomo.co.jp) | Rel-9 | RP-44 | Issam | UMTSLTE1500 |  | RP-100029 |
| 2259 | 602 | **Rel-9 Improvements of the Radio Interface - UE Conformance Testing** |  | 350d? | 2009-05-19 A | 2010-09-17 A | 100% |  | 2009-05-19 | 2010-09-17 | 350d? |  |  | R5 | 8184h | 8184h |  | PCG-23 |  |  | Rel-9 | RP-44 | Ingbert |  |  |  |
| 2260 | 602.1 | Conformance Test Aspects – UMTS/LTE in 800 MHz for Europe |  | 350d? | 2009-05-19 A | 2010-09-17 A | 100% |  | 2009-05-19 | 2010-09-17 | 350d? |  | finish no earlier than 2010-09-17 | R5 | 2800h | 2800h | RInImp-UEConTest-UMTSLTE800EU | PCG-23 | Ericsson | fredrik.sundstrom@ericsson.com | Rel-9 | RP-44 | Ingbert | RInImp-UEConTest-UMTSLTE800EU |  | RP-100736 |
| 2261 | 602.2 | Conformance Test Aspects – Extended UMTS/LTE 1500 MHz |  | 186d? | 2009-09-18 A | 2010-06-04 A | 100% |  | 2009-09-18 | 2010-06-04 | 186d? |  | finish no earlier than 2010-06-04 | R5 | 1488h | 1488h | UMTSLTE1500_UEConTest | PCG-23 | NTT DoCoMo | Nguyen Dung Dao (dao@nttdocomo.co.jp) | Rel-9 | RP-45 | Ingbert | UMTSLTE1500_UEConTest |  | RP-100487 |
| 2262 | 602.3 | TDD UE Over The Air (Antenna) conformance testing methodology |  | 81d? | 2009-05-30 A | 2009-09-18 A | 100% |  | 2009-05-30 | 2009-09-18 | 81d? |  | finish no earlier than 2009-09-18 | R5 | 648h | 648h | UEAnt_TDDTest | PCG-23 | CATR | Qu Yan (quyan@emcite.com) | Rel-9 | RP-44 | Ingbert | UEAnt_TDDTest |  | RP-090727 |
| 2263 | 602.4 | Conformance Test Aspects – Performance requirement for LCR TDD with UE speeds up to 350 km/h |  | 56d? | 2010-03-19 A | 2010-06-04 A | 100% |  | 2010-03-19 | 2010-06-04 | 56d? |  | finish no earlier than 2010-06-04 | R5 | 448h | 448h | RInImp9-LCRTDD350_UEConTest | PCG-24 | CATT | Xiaozhong Chen (chexiaozhong@datangmobile.cn) | Rel-9 | RP-47 | Ingbert | RInImp9-LCRTDD350_UEConTest |  | RP-100496 |
| 2264 | 603 | Conformance Test Aspects – SMS over IMS in E-UTRAN |  | 131d? | 2009-09-18 A | 2010-03-19 A | 100% |  | 2009-09-18 | 2010-03-19 | 131d? |  | finish no earlier than 2010-06-18 | R5 | 1048h | 1048h | SMSoverIMS_UEConTest | PCG-23 | Alcatel-Lucent | Nidal Khrais (khrais@alcatel-lucent.com) | Rel-9 | RP-45 | Ingbert | SMSoverIMS_UEConTest |  | RP-100072 |

Notes:
- 2237: -
- 2238: CP#48 completed / Impacted TSs and TRs: 29.165
- 2239: CP#65 complete / Impacted TSs and TRs: RFC 7329 (was draft-kaplan-insipid-session-id)
- 2240: CP#65 complete / Impacted TSs and TRs: RFC 7316 (was draft-vanelburg-dispatch-private-network-ind)
- 2241: In RFC Editors Queue. LM: 75->90 / Impacted TSs and TRs: draft-ietf-salud-alert-info-urns
- 2242: In RFC Editors Queue / Impacted TSs and TRs: draft-ietf-cuss-sip-uui
- 2243: In RFC Editors Queue. LM: 75->90 / Impacted TSs and TRs: draft-ietf-cuss-sip-uui-isdn
- 2244: CP#62 removed from Rel-8 to Rel-11. Not completed internet-draft / Impacted TSs and TRs: Rel-12 remains draft-dawes-sipping-debug
- 2245: CP#64 Draft removed from 3GPP documentation / Impacted TSs and TRs: draft-avasarala-dispatch-comm-div-notification
- 2246: CP#47 completed [Stage 3 for Rel-7 Emergency Calls (EMC1)]. Related to Rel-9 UID_400038 LCS Control Plane Solution for EPS. Stage 2 in Rel-9 UID_400038 (23.271), UID_410037 (23.167) / Impacted TSs and TRs: 24.229
- 2247: CP#46 completed / Impacted TSs and TRs: 29.212, 29.213, 29.215
- 2248: CP#46 completed. Linked to Rel-6 UID_11051 (IMS Management objects) under the Feature UID_32021 (IMS Phase 2). MO compatible with OMA DM v1.2 & upwards and defined using OMA DM Device Description Framework (OMA-ERELD _DM-V1_2) / Impacted TSs and TRs: New 24.166
- 2249: CP#47 approved WID and completed. Added capability to store ICE graphical information (picture). Linked to CT6 Rel-8 ICE Feature UID_380059 In Case of Emergency numbers storage and easy access on UICC / Impacted TSs and TRs: 31.102 CR#0433
- 2250: RP#41 umbrella Feature created to host Rel-9 WIs / Impacted TSs and TRs: GERAN, UTRA, LTE
- 2251: RP#44 completed technical work (RAN4 internal TR abandoned) / Impacted TSs and TRs: UTRA (no TR 25.8xy produced)
- 2252: RP#47 completed. RF requirements specification applicable to Multi-Standard Radio (MSR) Base Station with multiple carriers and/or multiple 3GPP Radio Access Technologies (RAT) / Impacted TSs and TRs: GERAN, UTRA, LTE
- 2253: RP#48 completed / Impacted TSs and TRs: UTRA, LTE 25.104, 25.105, 36.104, new 37.104, 37.113, 37.141, 37.900
- 2254: GP#44 Core spec completed. GP#40 WID approved / Impacted TSs and TRs: GERAN 45.005, 51.021
- 2255: RP#45 completed / Impacted TSs and TRs: UTRA, LTE 25.101, 25.104, 25.113, 25.133, 34.124, 36.101, 36.104, 36.113, 36.124, 36.133, 36.141, 25.306, 25.307, 25.331, 36.331, 25.461, 25.466, new 36.800
- 2256: RP#47 completed / Impacted TSs and TRs: UTRA, LTE 25.101, 25.104, 25.113, 25.133, 25.141, 34.124, 36.101, 36.104, 36.113, 36.124, 36.133, 36.141, new 36.810, 25.306, 25.307, 25.331, 36.331, 25.461, 25.466
- 2257: RP#46 completed / Impacted TSs and TRs: UTRA 25.102, 25.105, 25.142
- 2258: RP#47 completed. For potential deployment in Japan / Impacted TSs and TRs: UTRA, LTE 25.101, 25.104, 25.113, 25.133, 25.141, 25.306, 25.307, 25.331, 25.461, 25.466, 34.124, 36.101, 36.104, 36.113, 36.124, 36.133, 36.141, 36.331, new (36.821, 36.307)
- 2259: - / Impacted TSs and TRs: UTRA, LTE
- 2260: RP#49 completed. Testing for UID_430009 UMTS/LTE 800 MHz for Europe / Impacted TSs and TRs: UTRA, LTE 34.108, 34.121-1, 34.121-2, 36.508, 36.521-1, 36.521-2, 36.521-3
- 2261: RP#48 completed / Impacted TSs and TRs: UTRA, LTE 34.108, 34.121-1, 34.121-2, 34.123-1, 34.123-2, 36.508, 36.521-1, 36.521-2, 36.521-3, 36.523-1, 36.523-2, 36.523-3
- 2262: RP#45 completed. Finalized TDD UE test methodology based on R4 TR 25.914 (UE and MS antenna performance evaluation method) and TS 25.144 Over the Air (Antenna) minimum performance requirements for the speech mode (terminal close to head) / Impacted TSs and TRs: UTRA 34.114
- 2263: RP#48 completed. Testing for UID_430010 Performance requirement for LCR TDD with UE speeds up to 350 km/h / Impacted TSs and TRs: UTRA 34.122
- 2264: RP#47 completed / Impacted TSs and TRs: LTE 34.229-1, 34.229-2, 34.229-3

| ID | WBS | Task | Type | Duration | Start | Finish | Complete | Remaining | Baseline start | Baseline finish | Baseline duration | Total slack | Constraint | Resources | Work | Actual work | PCG approved | Release | TSG approved | MCC resp | Acronym | WI rapporteur name | WI rapporteur e-mail | Status Report | Acronym_3GU_Export | Special Focus Doc |
| --- | --- | --- | --- | --- | --- | --- | --- | --- | --- | --- | --- | --- | --- | --- | --- | --- | --- | --- | --- | --- | --- | --- | --- | --- | --- | --- |
| 2265 | 604 | **Rel-9 RAN improvements** |  | 2395d? | 2000-01-03 A | 2009-03-06 | 99% | 0d? | 2000-01-03 | 2010-03-19 | 2667d? | 0d |  | RP | 3264h | 3264h | PCG-22 | Rel-9 | RP-43 | Issam |  |  |  |  |  |  |
| 2266 | 604.1 | Dual-Cell HSUPA | milestone | 0d? | 2009-03-06 A | 2009-03-06 A | 100% |  | 2009-03-06 | 2010-03-19 | 272d? |  | finish no earlier than 2010-03-19 | R1; R2; R3; R4 |  |  | PCG-22 | Rel-9 | RP-43 | Patrick | RANimp-DC_HSUPA | Nokia Siemens Networks | Karri Ranta-aho (karri.ranta-aho@nsn.com) | RP-100030 | RANimp-DC_HSUPA |  |
| 2267 | 604.2 | Support for different bands for Dual-Cell HSDPA | milestone | 0d? | 2009-03-06 A | 2009-03-06 A | 100% |  | 2009-03-06 | 2009-12-04 | 197d? |  |  | R4; R2; R3 |  |  | PCG-22 | Rel-9 | RP-43 | Issam | RANimp-MultiBand_DC_HSDPA | Nokia Siemens Networks | Tuomo Säynäjäkangas (tuomo.saynajakangas@nsn.com) | RP-091038 | RANimp-MultiBand_DC_HSDPA |  |
| 2268 | 604.3 | Combination of DC-HSDPA with MIMO | milestone | 0d? | 2009-03-06 A | 2009-03-06 A | 100% |  | 2009-03-06 | 2009-12-04 | 197d? |  |  | R1; R2; R3; R4 |  |  | PCG-22 | Rel-9 | RP-43 | Patrick | RANimp-DC_MIMO | Ericsson | johan.bergman@ericsson.com | RP-091039 | RANimp-DC_MIMO |  |
| 2269 | 604.4 | Transmit Antenna Array (TxAA) extension for non-MIMO UEs | milestone | 0d? | 2009-03-06 A | 2009-03-06 A | 100% |  | 2009-03-06 | 2009-12-04 | 197d? |  |  | R1; R2; R3; R4 |  |  | PCG-22 | Rel-9 | RP-43 | Patrick | RANimp-TxAA_nonMIMO | Nokia | Arto Lehti (arto.lehti@nokia.com) | RP-091040 | RANimp-TxAA_nonMIMO |  |
| 2270 | 604.5 | Cell Portion for 1.28 Mcps TDD |  | 136d? | 2000-01-03 A | 2000-07-07 A | 100% |  | 2000-01-03 | 2000-07-07 | 136d? |  |  | R3; R1; R4 | 3264h | 3264h | PCG-23 | Rel-9 | RP-44 | Juha | CP_LCRTDD | CATT | Ying Zhang (zhangying2@datangmobile.cn) | RP-091041 | CP_LCRTDD |  |
| 2271 | 605 | **Rel-9 RAN improvements - UE Conformance Testing** |  | 588d? | 2010-09-17 A | 2012-12-07 A | 100% |  | 2010-09-17 | 2012-12-07 | 588d? |  |  | R5 | 11848h | 11848h | PCG-25 | Rel-9 | RP-49 | Ingbert |  |  |  |  |  |  |
| 2272 | 605.1 | Conformance Test Aspects – Combination of DC-HSDPA with MIMO |  | 186d? | 2010-09-17 A | 2011-06-03 A | 100% |  | 2010-09-17 | 2011-06-03 | 186d? |  | finish no earlier than 2011-06-03 | R5 | 1488h | 1488h | PCG-25 | Rel-9 | RP-49 | Ingbert | RANimp-DC_MIMO_UEConTest | Ericsson | leif.mattisson@ericsson.com | RP-110510 | RANimp-DC_MIMO_UEConTest |  |
| 2273 | 605.2 | Conformance Test Aspects – Dual-Cell HSUPA |  | 453d? | 2011-03-18 A | 2012-12-07 A | 100% |  | 2011-03-18 | 2012-12-07 | 453d? |  | finish no earlier than 2012-12-07 | R5 | 3624h | 3624h | PCG-26 | Rel-9 | RP-51 | Ingbert | RANimp-DC_HSUPA_UEConTest | Ericsson | leif.mattisson@ericsson.com | RP-121524 | RANimp-DC_HSUPA_UEConTest |  |
| 2274 | 605.3 | Conformance Test Aspects – Support for different bands for Dual-Cell HSDPA |  | 254d? | 2011-03-18 A | 2012-03-02 A | 100% |  | 2011-03-18 | 2012-03-02 | 254d? |  | finish no earlier than 2012-03-02 | R5 | 2032h | 2032h | PCG-26 | Rel-9 | RP-51 | Ingbert | RANimp-MultiBand_DC_HSDPA_UEConTest | Ericsson | leif.mattisson@ericsson.com | RP-120036 | RANimp-MultiBand_DC_HSDPA_UEConTest |  |
| 2275 | 606 | **LTE improvements** |  | 587d? | 2009-03-06 A | 2011-06-03 A | 100% |  | 2009-03-06 | 2011-06-03 | 587d? |  |  | R1; R2; R4; R5 | 21840h | 21840h | PCG-22 | Rel-9 | RP-42 | Patrick | LTEimp |  |  |  | LTEimp |  |
| 2276 | 606.1 | LTE Pico NodeB RF Requirements |  | 196d? | 2009-03-06 A | 2009-12-04 A | 100% |  | 2009-03-06 | 2009-12-04 | 196d? |  | finish no earlier than 2010-03-05 | R4 | 1568h | 1568h | PCG-22 | Rel-9 | RP-43 | Issam | LTEimp-Pico_eNB-RF | Huawei | Liyan Yin (yinliyan@huawei.com) | RP-091045 | LTEimp-Pico_eNB-RF |  |
| 2277 | 606.2 | Enhanced Dual-Layer transmission for LTE | milestone | 0d? | 2009-03-06 A | 2009-03-06 A | 100% |  | 2009-03-06 | 2010-03-19 | 272d? |  | finish no earlier than 2010-03-18 | R1; R2; R4 |  |  | PCG-22 | Rel-9 | RP-43 | Patrick | LTEimp-eDL | China Mobile | Xu Xiaodong (xuxiaodong@chinamobile.com) | RP-100034 | LTEimp-eDL |  |
| 2278 | 606.3 | UE Conformance Test Aspects – Enhanced Dual-layer transmission for LTE TDD |  | 186d? | 2010-09-17 A | 2011-06-03 A | 100% |  | 2010-09-17 | 2011-06-03 | 186d? |  | finish no earlier than 2011-06-03 | R5 | 1488h | 1488h | PCG-25 | Rel-9 | RP-49 | Ingbert | LTEimp-eDL_UEConTest | China Mobile | Shanpeng Xiao (xiaoshanpeng@chinamobile.com) | RP-110509 | LTEimp-eDL_UEConTest |  |
| 2279 | 607 | Rel-9 Self-Organizing Networks (SON) | milestone | 0d? | 2009-03-06 A | 2009-03-06 A | 100% |  | 2009-03-06 | 2010-03-19 | 272d? |  | finish no earlier than 2010-03-19 | R3; R2 |  |  | PCG-22 | Rel-9 | SP-42 | Juha | SON | Nokia Siemens Networks | krzysztof.kordybach@nsn.com | RP-100038 | SON | SON |
| 2280 | 608 | **AGNSS Performances and Testing Procedures** |  | 787d? | 2008-05-16 A | 2011-05-20 A | 100% |  | 2008-05-16 | 2011-05-20 | 787d? |  |  | G1; G3new | 22664h | 22664h |  | Rel-9 |  | Paolo | AGNSSPTP | Thales | Michel.monnerat@thalesaleniaspace.com |  | AGNSSPTP |  |
| 2281 | 608.1 | AGNSS Minimum Performances |  | 472d? | 2008-05-16 A | 2010-03-05 A | 100% |  | 2008-05-16 | 2010-03-05 | 472d? |  | finish no earlier than 2010-03-05 | G1 | 3776h | 3776h |  | Rel-9 |  | Paolo | AGNSSPTP-Perfreq | Thales | Michel.monnerat@thalesaleniaspace.com |  | AGNSSPTP-Perfreq |  |
| 2282 | 608.2 | AGNSS Testing Procedures |  | 787d? | 2008-05-16 A | 2011-05-20 A | 100% |  | 2008-05-16 | 2011-05-20 | 787d? |  | finish no earlier than 2011-05-20 | G3new | 6296h | 6296h |  | Rel-9 |  | Ingbert | AGNSSPTP-MStest | Thales | Michel.monnerat@thalesaleniaspace.com |  | AGNSSPTP-MStest |  |
| 2283 | 609 | **Voice services over Adaptive Multi-user channels on One Slot** |  | 860d? | 2008-11-21 A | 2012-03-02 A | 100% |  | 2008-11-21 | 2012-03-02 | 860d? |  |  | GP; G1; G2; G3new | 71592h | 71592h | PCG-22 | Rel-9 | SP-42 | Paolo | VAMOS | Nokia Siemens Networks, China Mobile | juergen.hofmann@nsn.com, liuxiaoyu@chinamobile.com |  | VAMOS |  |
| 2284 | 609.1 | Stage 2 for Voice services over Adaptive Multi-user channels on One Slot |  | 392d? | 2008-11-21 A | 2010-05-21 A | 100% |  | 2008-11-21 | 2010-05-21 | 392d? |  | finish no earlier than 2010-05-21 | GP; G1; G2 | 9408h | 9408h | PCG-22 | Rel-9 | GP-40 | Paolo | VAMOS | Nokia Siemens Networks, China Mobile | juergen.hofmann@nsn.com, liuxiaoyu@chinamobile.com |  |  |  |
| 2285 | 609.2 | Stage 3 for Voice services over Adaptive Multi-user channels on One Slot |  | 596d? | 2008-11-24 A | 2011-03-04 A | 100% |  | 2008-11-24 | 2011-03-04 | 596d? |  | finish no earlier than 2011-03-04 | GP; G1; G2 | 14304h | 14304h | PCG-22 | Rel-9 | GP-40 | Paolo | VAMOS | Nokia Siemens Networks, China Mobile | juergen.hofmann@nsn.com, liuxiaoyu@chinamobile.com |  |  |  |
| 2286 | 609.3 | VAMOS Radio Performance Requirements |  | 651d? | 2008-11-24 A | 2011-05-20 A | 100% |  | 2008-11-24 | 2011-05-20 | 651d? |  | finish no earlier than 2011-05-20 | GP; G1; G2 | 15624h | 15624h | PCG-22 | Rel-9 | GP-40 | Paolo | VAMOS | Nokia Siemens Networks, China Mobile | juergen.hofmann@nsn.com, liuxiaoyu@chinamobile.com |  |  |  |
| 2287 | 609.4 | VAMOS - MS conformance testing |  | 392d? | 2010-09-03 A | 2012-03-02 A | 100% |  | 2010-09-03 | 2012-03-02 | 392d? |  | finish no earlier than 2012-03-02 | G3new | 3128h | 3128h | PCG-25 | Rel-9 | GP-47 | Ingbert | VAMOS_MStest | BlackBerry | Raveendra Seetharam (rseetharam@rim.com) |  | VAMOS_MStest |  |
| 2288 | 609.5 | VAMOS - BTS conformance testing |  | 201d? | 2010-11-26 A | 2011-09-02 A | 100% |  | 2010-11-26 | 2011-09-02 | 201d? |  | finish no earlier than 2011-09-02 | G1 | 1608h | 1608h | PCG-26 | Rel-9 | GP-48 | Paolo | VAMOS_BTStest | Nokia Siemens Networks | eddie.riddington@nsn.com |  | VAMOS_BTStest |  |

Notes:
- 2265: RP#47 completed / Impacted TSs and TRs: UTRA
- 2266: RP#47 completed / Impacted TSs and TRs: 25.101, 25.104, 25.133, 25.211, 25.212, 25.213, 25.214, 25.215, 25.319, 25.306, 25.321, 25.331, 25.423, 25.433
- 2267: RP#46 completed. RP#62 existing TS 25.317 replaced by new TS 25.327 / Impacted TSs and TRs: 25.101, 25.104, 25.133, 25.306, 25.308, 25.331, 25.423, 25.433, new 25.317 replaced by new TS 25.327
- 2268: RP#46 completed / Impacted TSs and TRs: 25.101, 25.104, 25.133, 25.211, 25.212, 25.213, 25.214, 25.215, 25.308, 25.321, 25.331, 26.306, 25.423, 25.433
- 2269: RP#46 completed / Impacted TSs and TRs: 25.101, 25.104, 25.211, 25.212, 25.213, 25.214, 25.215, 25.308, 25.306, 25.321, 25.331, 25.423, 25.433
- 2270: RP#46 completed / Impacted TSs and TRs: 25.102, 25.105, 25.123, 25.225, 25.423, 25.433
- 2271: -
- 2272: UTRA. RP#52 completed. Testing for Rel-9 UID_430016 Combination of DC-HSDPA with MIMO / Impacted TSs and TRs: UTRA 34.108, 34.121-1, 34.121-2, 34.123-1, 34.123-2, 34.123-3
- 2273: RP#58 completed. Testing for Rel-9 UID_430014 Dual-Cell HSUPA / Impacted TSs and TRs: UTRA 34.108, 34.121-1, 34.121-2, 34.123-1, 34.123-2, 34.123-3
- 2274: RP#55 completed. Testing for Rel-9 UID_430015 Support for different bands for Dual-Cell HSDPA / Impacted TSs and TRs: UTRA 34.108, 34.121-1, 34.121-2, 34.123-1, 34.123-2, 34.123-3
- 2275: - / Impacted TSs and TRs: LTE
- 2276: RP#46 completed / Impacted TSs and TRs: 36.104, 36.141, new 36.931
- 2277: RP#47 completed / Impacted TSs and TRs: 36.101, 36.211, 36.212, 36.213, 36.331
- 2278: RP#52 completed. Testing for UID_430029 (Enhanced Dual-Layer transmission for LTE) / Impacted TSs and TRs: 36.508, 36.521-1, 36.521-2
- 2279: RP#47 completed / Impacted TSs and TRs: LTE 25.413, 36.300, 36.413, 36.423, 48.018, New 36.902
- 2280: GP#46 still ongoing MS testing. Linked to Rel-10 RAN4 UID_450027 (AGNSS Minimum Performance for UTRAN)
- 2281: GP#45 completed (open performance requirements alignment GPS/Galileo) / Impacted TSs and TRs: 45.005
- 2282: GP#50 completed / Impacted TSs and TRs: 51.010-1, new 51.010-7
- 2283: Triggered by UID_50590 (MUROS) Study on Multi-User Reusing-One-Slot
- 2284: GP#46 completed. GP#40 WID approved / Impacted TSs and TRs: 45.001
- 2285: GP#49 completed. GP#40 WID approved / Impacted TSs and TRs: 24.008, 44.018, 45.002, 45.003, 45.004, 45.008, 48.008, 48.058
- 2286: GP#50 completed. GP#40 WID approved / Impacted TSs and TRs: 45.005
- 2287: GP#53 completed. GP#47 WID approved / Impacted TSs and TRs: 51.010-1, 51.010-2
- 2288: GP#51 completed. GP#48 WID approved / Impacted TSs and TRs: 51.021

| ID | WBS | Task | Type | Duration | Start | Finish | Complete | Baseline start | Baseline finish | Baseline duration | Constraint | Resources | Work | Actual work | Acronym | PCG approved | WI rapporteur name | WI rapporteur e-mail | Release | TSG approved | MCC resp | Acronym_3GU_Export | PCG stopped | TSG stopped | Special Focus Doc | Status Report |
| --- | --- | --- | --- | --- | --- | --- | --- | --- | --- | --- | --- | --- | --- | --- | --- | --- | --- | --- | --- | --- | --- | --- | --- | --- | --- | --- |
| 2289 | 610 | **Cell Broadcast protocol Base Station Controller – Cell Broadcast Centre (BSC-CBC)** |  | 222d? | 2009-05-15 A | 2010-03-19 A | 100% | 2009-05-15 | 2010-03-19 | 222d? |  | GP; C1 | 7024h | 7024h | CEBRO | PCG-23 | Ericsson | claes-goran.persson@ericsson.com | Rel-9 | GP-42 | Paolo | CEBRO |  |  |  |  |
| 2290 | 610.1 | GERAN part of Cell Broadcast protocol Base Station Controller – Cell Broadcast Centre |  | 212d? | 2009-05-15 A | 2010-03-05 A | 100% | 2009-05-15 | 2010-03-05 | 212d? | finish no earlier than 2010-03-05 | GP | 1696h | 1696h | CEBRO | PCG-23 | Ericsson | claes-goran.persson@ericsson.com | Rel-9 | GP-42 | Paolo |  |  |  |  |  |
| 2291 | 610.2 | CT1 part of Cell Broadcast protocol Base Station Controller – Cell Broadcast Centre |  | 222d? | 2009-05-15 A | 2010-03-19 A | 100% | 2009-05-15 | 2010-03-19 | 222d? | finish no earlier than 2010-03-19 | C1 | 1776h | 1776h | CEBRO | PCG-23 | Ericsson | claes-goran.persson@ericsson.com | Rel-9 | GP-42 | Frederic |  |  |  |  |  |
| 2292 | 611 | Hybrid Location |  | 136d? | 2009-05-18 A | 2009-11-20 A | 100% | 2009-05-18 | 2009-11-20 | 136d? | finish no earlier than 2009-11-20 | GP | 1088h | 1088h | HILT | PCG-23 | TruePosition | Matt Ward (mward@trueposition.com) | Rel-9 | GP-42 | Paolo | HILT |  |  |  |  |
| 2293 | 612 | (Small) Technical Enhancements and Improvements for Rel-9 |  | 325d? | 2008-09-15 A | 2009-12-10 A | 100% | 2008-09-15 | 2009-12-10 | 325d? | finish no earlier than 2009-12-10 | SP; CP; RP; GP | 10400h | 10400h | TEI9 | PCG-22 |  |  | Rel-9 | SP-42 | All | TEI9 |  |  |  |  |
| 2294 | 613 | Test - (Small) Technical Enhancements and Improvements for Rel-9 |  | 286d? | 2009-11-20 A | 2010-12-24 A | 100% | 2009-11-20 | 2010-12-24 | 286d? | finish no earlier than 2010-12-24 | R5; G3new | 4576h | 4576h | TEI9_Test | PCG-24 |  |  | Rel-9 | GP-44 | Ingbert | TEI9_Test |  |  |  |  |
| 2295 | 614 | **Deleted - Services Alignment and Migration** |  | 467d? | 2006-12-06 A | 2008-09-18 A | 100% | 2006-12-06 | 2008-09-18 | 467d? |  | S1 | 7472h | 7472h | ServAl |  | Telefónica O2 | chris.friel@O2.com | Rel-9 | SP-33 | Alain | ServAl | PCG-21 | SP-41 |  |  |
| 2296 | 614.1 | Deleted - Stage 1 for ServAl |  | 467d? | 2006-12-06 A | 2008-09-18 A | 100% | 2006-12-06 | 2008-09-18 | 467d? | finish no earlier than 2008-12-11 | S1 | 3736h | 3736h |  | PCG-21 | Telefónica O2 | chris.friel@O2.com | Rel-9 | SP-33 | Alain |  | PCG-21 | SP-41 |  |  |
| 2297 | 615 | Deleted - Harmonization of Gq'/Rx for Common IMS |  | 304d? | 2008-01-14 A | 2009-03-12 A | 100% | 2008-01-14 | 2009-03-12 | 304d? | finish no earlier than 2009-03-12 | S2 | 2432h | 2432h | IMS_Comm_GqRx_Harm | PCG-21 | Alcatel-Lucent | geoffrey.cristallo@alcatel-lucent.be | Rel-9 | SP-38 | Maurice | IMS_Comm_GqRx_Harm | PCG-22 | SP-43 |  |  |
| 2298 | 616 | Deleted - Support of WiMAX - LTE Mobility |  | 407d? | 2008-06-06 A | 2009-12-25 A | 100% | 2008-06-06 | 2009-12-25 | 407d? | start no earlier than 2008-06-06 | R2 | 3248h | 3248h | WiMAX_LTE_Mobility | PCG-21 | Samsung |  | Rel-9 | RP-38 | Yong-Jun | WiMAX_LTE_Mobility | PCG-21 | SP-39 |  |  |
| 2299 | 617 | Deleted - Support of WiMAX - UMTS Mobility |  | 407d? | 2008-06-06 A | 2009-12-25 A | 100% | 2008-06-06 | 2009-12-25 | 407d? | start no earlier than 2008-06-06 | R2 | 3248h | 3248h | WiMAX_UMTS_Mobility | PCG-21 | Intel |  | Rel-9 | RP-38 | Yong-Jun | WiMAX_UMTS_Mobility | PCG-21 | SP-39 |  |  |
| 2300 | 618 | Deleted - Definition of 3GPP UICC services over the new high-speed interface | milestone | 0d? | 2010-03-19 A | 2010-03-19 A | 100% | 2010-03-19 | 2010-03-19 | 0d? |  | C6 |  |  | UICCHS | PCG-21 | Gemalto | Denis.Lheriteau@gemalto.com | Rel-9 | CP-38 | Xavier | UICCHS | PCG-24 | CP-47 |  |  |
| 2301 | 619 | **Deleted - SAES Enhancements (non RAN aspects)** |  | 381d? | 2007-06-25 A | 2008-12-08 A | 100% | 2007-06-25 | 2008-12-08 | 381d? |  | S2 | 11664h | 11664h | SAES_Ph2 | PCG-21 | Nokia Siemens Networks |  | Rel-9 | SP-39 | Maurice | SAES_Ph2 | PCG-21 | SP-39 |  |  |
| 2302 | 619.1 | Deleted - Functions and procedures for SAE to support LTE MBMS |  | 381d? | 2007-06-25 A | 2008-12-08 A | 100% | 2007-06-25 | 2008-12-08 | 381d? | finish no earlier than 2008-12-08 | S2 | 3048h | 3048h | SAES_Ph2 |  |  |  | Rel-9 | SP-35 | Maurice |  | PCG-21 | SP-39 |  |  |
| 2303 | 619.2 | Deleted - CS over EPS |  | 194d? | 2008-03-12 A | 2008-12-08 A | 100% | 2008-03-12 | 2008-12-08 | 194d? | finish no earlier than 2008-12-08 | S2 | 1552h | 1552h | SAES_Ph2 | PCG-21 |  |  | Rel-9 | SP-39 | Maurice |  | PCG-21 | SP-39 |  |  |
| 2304 | 619.3 | **Deleted - SAE for generic support for non-3GPP accesses** |  | 251d? | 2007-06-25 A | 2008-06-09 A | 100% | 2007-06-25 | 2008-06-09 | 251d? |  | S2 | 4016h | 4016h | SAES_Ph2 | PCG-21 |  |  | Rel-9 | SP-39 | Maurice |  | PCG-21 | SP-39 |  |  |
| 2305 | 619.3.1 | Deleted - Single Radio Aspects of SAE for Optimized Handover with WiMAX |  | 251d? | 2007-06-25 A | 2008-06-09 A | 100% | 2007-06-25 | 2008-06-09 | 251d? | finish no earlier than 2008-06-09 | S2 | 2008h | 2008h | SAES_Ph2 | PCG-21 |  |  | Rel-9 | SP-39 | Maurice |  | PCG-21 | SP-39 |  |  |
| 2306 | 620 | Deleted - Lawful Interception in the 3GPP Rel-9 |  | 211d? | 2009-06-04 A | 2010-03-25 A | 100% | 2009-06-04 | 2010-03-25 | 211d? | finish no earlier than 2010-03-25 | S3 | 1688h | 1688h | LI9 | PCG-23 | PIDS, Nortel | Koen Jaspers, Ronald Ryan | Rel-9 | SP-44 | Mirko | LI9 | PCG-24 | SP-47 |  |  |
| 2307 | 621 | Release 9 Studies | milestone | 0d? | 2008-06-05 A | 2008-06-05 A | 100% | 2008-06-05 | 2010-03-19 | 468d? |  | CP; RP; SP |  |  |  |  |  |  | Rel-9 |  |  |  |  |  |  |  |
| 2308 | 622 | Study on Service Specific Access Control in EPS |  | 136d? | 2008-06-05 A | 2008-12-11 A | 100% | 2008-06-05 | 2008-12-11 | 136d? | start no earlier than 2008-06-05 | S1 | 1088h | 1088h | FS_SSAC | PCG-21 | NTT DoCoMo | Shin-ichi Isobe (isobes@nttdocomo.co.jp) | Rel-9 | SP-40 | Alain | FS_SSAC |  |  |  |  |
| 2309 | 623 | Study on CS Domain Services over EPS access |  | 492d? | 2007-04-25 A | 2009-03-12 A | 100% | 2007-04-25 | 2009-03-12 | 492d? | finish no earlier than 2009-03-12 | S2 | 3936h | 3936h | FS_CSoPS |  | T-Mobile | Karl-Heinz.Nenner@T-Mobile.net | Rel-9 | SP-35 | Maurice | FS_CSoPS |  |  |  |  |
| 2310 | 624 | Study on Extended Support of IMS Emergency Calls |  | 319d? | 2007-09-24 A | 2008-12-11 A | 100% | 2007-09-24 | 2008-12-11 | 319d? | finish no earlier than 2009-06-18 | S2 | 2552h | 2552h | FS_IMS-eCall |  | Qualcomm | Stephen Edge | Rel-9 | SP-37 | Maurice | FS_IMS-eCall |  |  | Public Safety (I-A) |  |
| 2311 | 625 | Study on Service Continuity for Emergency Voice Calls |  | 721d? | 2006-06-08 A | 2009-03-12 A | 100% | 2006-06-08 | 2009-03-12 | 721d? | finish no earlier than 2009-03-12 | S2 | 5768h | 5768h | FS_VCCEm |  | Nortel | Ricky Kaura (rkaura@nortel.com) | Rel-9 | SP-32 | Maurice | FS_VCCEm |  |  | Public Safety (I-A) |  |
| 2312 | 626 | Study on Security Aspects of Remote Provisioning and Change of Subscription for M2M Equipment |  | 1483.15d? | 2004-04-06 A | 2009-12-10 A | 100% | 2004-04-06 | 2009-12-10 | 1483.15d? | finish no earlier than 2009-12-10 | S3; C6 | 23730.4h | 23730.4h | FS_UM2M |  | Ericsson | vesa.lehtovirta@ericsson.com | Rel-9 | SP-37 | Mirko | FS_UM2M |  |  | MTC, M2M |  |
| 2313 | 627 | Study on System Maintenance over Itf-N |  | 602d? | 2007-06-07 A | 2009-09-24 A | 100% | 2007-06-07 | 2009-09-24 | 602d? | finish no earlier than 2009-09-24 | S5 | 4808h | 4808h | FS_OAM-Maint-Itf-N |  | ZTE | Shuqiang Huang (huangsq@zte.com.cn) | Rel-9 | SP-36 | Mirko | FS_OAM-Maint-Itf-N |  |  |  |  |
| 2314 | 628 | Study on Self-Organizing Networks (SON) related OAM interfaces for Home NodeB |  | 522d? | 2007-06-07 A | 2009-06-04 A | 100% | 2007-06-07 | 2009-06-04 | 522d? | finish no earlier than 2009-12-10 | S5 | 4168h | 4168h | FS_OAM-SON-HNB |  | Huawei | Zou Lan (zlan@huawei.com) | Rel-9 | SP-36 | Mirko | FS_OAM-SON-HNB |  |  | HNB, SON |  |
| 2315 | 629 | Study on Self-healing of Self-Organizing Networks (SON) |  | 416d? | 2008-02-22 A | 2009-09-24 A | 100% | 2008-02-22 | 2009-09-24 | 416d? | finish no earlier than 2009-09-24 | S5 | 3320.15h | 3320.15h | FS_OAM-SON-SH | PCG-21 | ZTE | zhu.weihong@zte.com.cn | Rel-9 | SP-39 | Mirko | FS_OAM-SON-SH |  |  | SON |  |
| 2316 | 630 | Study on Service Oriented Architecture (SOA) for IRP |  | 262d? | 2008-06-05 A | 2009-06-04 A | 100% | 2008-06-05 | 2009-06-04 | 262d? | finish no earlier than 2009-05-20 | S5 | 2088h | 2088h | FS_OAM_SOA_IRP | PCG-21 | Ericsson | edwin.tse@ericsson.com | Rel-9 | SP-40 | Mirko | FS_OAM_SOA_IRP |  |  |  |  |
| 2317 | 631 | Study on Evaluation of the inclusion of Path Loss Based Technology in the UTRAN |  | 516d? | 2007-12-17 A | 2009-12-04 A | 100% | 2007-12-17 | 2009-12-04 | 516d? | finish no earlier than 2009-09-18 | R4 | 4120h | 4120h | FS_RAN-Pathloss | PCG-21 | Polaris Wireless | Norman Shaw (nshaw@polariswireless.com) | Rel-9 | RP-38 | Issam | FS_RAN-Pathloss |  |  |  | RP-091080 |
| 2318 | 632 | Study on LTE-Advanced |  | 781.2d? | 2007-03-23 A | 2010-03-19 A | 100% | 2007-03-23 | 2010-03-19 | 781.2d? | finish no earlier than 2010-03-19 | R1; R2; R3; R4 | 24998.4h | 24998.4h | FS_RAN_LTEA | PCG-21 | NTT DoCoMo | Tetsushi Abe | Rel-9 | RP-39 | Patrick | FS_RAN_LTEA |  |  | CA | RP-100080 |
| 2319 | 633 | Study on 1.28 Mcps TDD Home NodeB |  | 387d? | 2008-02-20 A | 2009-12-04 A | 100% | 2008-02-20 | 2009-12-04 | 387d? | finish no earlier than 2009-12-04 | R4 | 3096h | 3096h | FS_RAN-HNBLCRTDD | PCG-21 | TD Tech | Li Rong (lirong@td-tech.com) | Rel-9 | RP-41 | Issam | FS_RAN-HNBLCRTDD |  |  | HNB | RP-091081 |
| 2320 | 634 | Study on E-UTRAN Mobility Evaluation and Enhancement |  | 126d? | 2008-12-05 A | 2009-05-29 A | 100% | 2008-12-05 | 2009-05-29 | 126d? | finish no earlier than 2009-05-29 | R1 | 1008h | 1008h | FS_EUTRAN_mob | PCG-22 | Qualcomm | Rajat Prakash (rprakash@qualcomm.com) | Rel-9 | RP-42 | Patrick | FS_EUTRAN_mob |  |  |  | RP-090426 |
| 2321 | 635 | Study on Minimization of drive-tests in Next Generation Networks |  | 196d? | 2009-03-06 A | 2009-12-04 A | 100% | 2009-03-06 | 2009-12-04 | 196d? | finish no earlier than 2009-12-04 | R2 | 1568h | 1568h | FS_NGN_min_drive-tests | PCG-22 | Qualcomm | Masato Kitazoe (mkitazoe@qualcomm.com) | Rel-9 | RP-43 | Yong-Jun | FS_NGN_min_drive-tests |  |  |  | RP-091084 |
| 2322 | 636 | Study on Enhanced Interference Management for HNBs |  | 61d? | 2009-03-06 A | 2009-05-29 A | 100% | 2009-03-06 | 2009-05-29 | 61d? | start no earlier than 2009-03-06 | R4 | 488h | 488h | FS_eInterfMgmt_HNB | PCG-22 | Qualcomm | Farhad Meshkati (fmeshkat@qualcomm.com) | Rel-9 | RP-43 | Issam | FS_eInterfMgmt_HNB |  |  | HNB | RP-090429 |
| 2323 | 637 | Study on Enhanced Interference Management Mechanisms for HNBs |  | 81d? | 2009-05-30 A | 2009-09-18 A | 100% | 2009-05-30 | 2009-09-18 | 81d? | finish no earlier than 2009-09-18 | R3 | 648h | 648h | FS_eInterfMgmtMchsm_HNB | PCG-23 | Qualcomm | Farhad Meshkati (fmeshkat@qualcomm.com) | Rel-9 | RP-44 | Juha | FS_eInterfMgmtMchsm_HNB |  |  | HNB | RP-090733 |
| 2324 | 638 | Deleted - Study on Protection against SMS and MMS spam |  | 862d? | 2006-06-08 A | 2009-09-24 A | 100% | 2006-06-08 | 2009-09-24 | 862d? | finish no earlier than 2009-09-24 | S3 | 6896h | 6896h | FS_CPSMal |  | Orange | eric.gauthier@orange.ch | Rel-9 | SP-32 | Mirko | FS_CPSMal | PCG-23 | SP-45 |  |  |
| 2325 | 639 | Release 8 Features |  | 914.3d? | 2006-09-19 A | 2010-03-19 A | 100% | 2006-09-19 | 2010-03-19 | 914.3d? | start no earlier than 2000-01-03 | CP; GP; RP; SP | 29257.6h | 29257.6h |  |  |  |  | Rel-8 |  |  |  |  |  |  |  |

Notes:
- 2289: CP#47 completed. GP#45 completed. GP#42 WID approved
- 2290: GP#45 completed. GP#42 WID approved / Impacted TSs and TRs: new 48.049
- 2291: CP#47 completed / Impacted TSs and TRs: 23.041
- 2292: GP#44 completed. GP#42 WID approved (Hybrid Integrated Location Technology=HILT) / Impacted TSs and TRs: 43.059, 48.071
- 2293: SP#46 completed
- 2294: GP#44 created
- 2295: SP#41 closed (no tangible result of this work; no CR against TR 22.983). Triggered by Study UID_370086 (FSServAl)
- 2296: SP#41 closed (no tangible result of this work; no CR against TR 22.983) / Impacted TSs and TRs: 22.983
- 2297: SP#43 stopped. LS_out to TISPAN informs about stopping this activity / Impacted TSs and TRs: 23.822, 23.203
- 2298: RP#39: No agreed WID / Impacted TSs and TRs: 36.306, 36.331, 36.413, 36.300, 36.214, 36.133, 36.304
- 2299: RP#39: No agreed WID / Impacted TSs and TRs: 25.306, 25.331, 25.413
- 2300: CP#47 work stopped/abandoned / Impacted TSs and TRs: 31.xyz
- 2301: SP#39 created to host Rel-9 Wis. BUT no agreed WID
- 2302: SP#39 SAE functionality moved to Rel-9. WID returned to SA2 for re-consideration & remove MBMS for EPS from Rel 8
- 2303: SP#39 SAE functionality moved to Rel-9. BUT no agreed WID
- 2304: SP#39 SAE functionality moved to Rel-9. BUT no agreed WID
- 2305: SP#39 SAE functionality moved to Rel-9. BUT no agreed WID
- 2306: SP#47 stopped. WI + new topics moved to Rel-10 / Impacted TSs and TRs: 33.106, 33.107, 33.108
- 2307: -
- 2308: SP#42 completed. Spin-off Feature UID_420020 (SSAC) / Impacted TSs and TRs: 22.986
- 2309: SP#43 completed. Linked to Combinational Services UID_31064, Services Alignment and Migration (ServAl) UID_330017 and 3GPP System Architecture Evolution (SAES) UID_3208 / Impacted TSs and TRs: 23.879
- 2310: SP#42 completed / Impacted TSs and TRs: 23.868
- 2311: SP#43 completed / Impacted TSs and TRs: 23.826
- 2312: SP#46 completed. Triggered by the SA1 Rel-8 Study on Facilitating Machine to Machine Communication in GSM and UMTS (FS_M2M) UID_7027 in TR 22.868. / Impacted TSs and TRs: 33.812
- 2313: SP#45 completed / Impacted TSs and TRs: 32.822
- 2314: SP#44 completed. Linked to SA5 TR 32.816 Study of Management for LTE and SAE (UID_340036) / Impacted TSs and TRs: 32.821
- 2315: SP#45 completed. Linked to SA5 TR 32.816 Study of Management for LTE and SAE (UID_340036) / Impacted TSs and TRs: 32.823
- 2316: SP#44 completed. Spin-off implementation WI UID_440064 Service Oriented Architecture (SOA) for IRP / Impacted TSs and TRs: 32.824
- 2317: RP#46 completed / Impacted TSs and TRs: 25.907
- 2318: RP#47 completed / Impacted TSs and TRs: 36.913 , New 36.814, 36.912, R2 36.806 (Relay architectures for E-UTRA), R4 36.815 (LTE-Advanced feasibility studies in RAN4)
- 2319: RP#46 completed / Impacted TSs and TRs: 25.866
- 2320: RP#44 closed (RP-090452 R1 LS to RAN on Conclusions for LTE Mobility Study Item - no further Rel-9 action / no TR needed) / Impacted TSs and TRs: none
- 2321: RP#46 completed / Impacted TSs and TRs: 36.805
- 2322: RP#44 completed. Linked to UID_420008 LTE FDD Home eNodeB RF Requirements. Spin-off RAN3 UID_440015 Study on Enhanced Interference Management Mechanisms for HNBs / Impacted TSs and TRs: 25.967
- 2323: RP#45 completed. Triggered by RAN4 UID_430027 Study on Enhanced Interference Management for HNBs / Impacted TSs and TRs: 25.967
- 2324: SP#45 work stopped/abandoned / Impacted TSs and TRs: 33.9xx
- 2325: -

| ID | WBS | Task | Duration | Start | Finish | Complete | Remaining | Baseline start | Baseline finish | Baseline duration | Total slack | Constraint | Resources | Work | Actual work | Acronym | WI rapporteur name | WI rapporteur e-mail | Release | MCC resp | Acronym_3GU_Export | TSG approved | PCG approved |
| --- | --- | --- | --- | --- | --- | --- | --- | --- | --- | --- | --- | --- | --- | --- | --- | --- | --- | --- | --- | --- | --- | --- | --- |
| 2326 | 640 | **3GPP System Architecture Evolution Specification - Evolved Packet System (non RAN aspects)** | 1618d? | 2006-04-12 A | 2012-06-15 | 99% | 0d? | 2006-04-12 | 2012-06-15 | 1618d? | 0d |  | S1; S2; S3; S5; C1; C3; C4; C6; IETF | 512323h | 510115h | SAES | T-Mobile | michael.kurz@t-mobile.at | Rel-8 | Alain | SAES |  |  |
| 2327 | 640.1 | Requirements for evolution of the 3GPP system architecture | 395d? | 2006-06-08 A | 2007-12-12 A | 100% |  | 2006-06-08 | 2007-12-12 | 395d? |  | finish no earlier than 2007-11-30 | S1 | 3160h | 3160h | AIPN-SAE | T-Mobile | michael.kurz@t-mobile.at | Rel-8 | Alain | AIPN-SAE |  |  |
| 2328 | 640.2 | **High level and common (for all accesses) functions** | 629d? | 2007-01-02 A | 2009-05-29 A | 100% |  | 2007-01-02 | 2009-05-29 | 629d? |  |  | S2; S3; C1; C3; C4 | 62664h | 62664h | EPS-ComF | Nokia Siemens Networks | balazs.bertenyi@nsn.com | Rel-8 | Maurice | EPS-ComF | SP-37 |  |
| 2329 | 640.2.1 | Stage 2 for High level functions | 370d? | 2007-01-02 A | 2008-06-02 A | 100% |  | 2007-01-02 | 2008-06-02 | 370d? |  | finish no earlier than 2008-06-02 | S2 | 2960h | 2960h | SAES-SA-HLF | Motorola | Irfan.Ali@motorola.com | Rel-8 | Maurice | SAES-SA-HLF |  |  |
| 2330 | 640.2.2 | Stage 2 Security Architecture | 197d? | 2008-03-12 A | 2008-12-11 A | 100% |  | 2008-03-12 | 2008-12-11 | 197d? |  | finish no earlier than 2008-12-11 | S3 | 1576h | 1576h | SAES | Nokia Siemens Networks | marc.blommaert.ext@nsn.com | Rel-8 | Mirko |  | SP-39 | PCG-21 |
| 2331 | 640.2.3 | Stage 3 (CT1) for SAE impact on services, network functions and capabilities | 545d? | 2007-02-05 A | 2009-03-06 A | 100% |  | 2007-02-05 | 2009-03-06 | 545d? |  | finish no earlier than 2009-03-06 | C1 | 4360h | 4360h | SAES | Nokia Siemens Networks | robert.zaus@nsn.com | Rel-8 | Frederic |  |  |  |
| 2332 | 640.2.4 | Stage 3 SAE impact on existing capabilities | 480d? | 2007-02-05 A | 2008-12-05 A | 100% |  | 2007-02-05 | 2008-12-05 | 480d? |  | finish no earlier than 2008-12-12 | C3 | 3840h | 3840h | SAES | Huawei | Wei Weihua (weiwh@huawei.com) | Rel-8 | Adrian |  |  |  |
| 2333 | 640.2.5 | Stage 3 (CT4) of SAE impact on existing capabilities | 545d? | 2007-02-05 A | 2009-03-06 A | 100% |  | 2007-02-05 | 2009-03-06 | 545d? |  | finish no earlier than 2009-03-06 | C4 | 4360h | 4360h | SAES | Huawei | shahab.lavasani@huawei.com | Rel-8 | Kimmo |  |  |  |
| 2334 | 640.2.6 | Stage 2/3 for Network selection procedures | 480d? | 2007-02-05 A | 2008-12-05 A | 100% |  | 2007-02-05 | 2008-12-05 | 480d? |  | finish no earlier than 2009-03-06 | C1 | 3840h | 3840h | SAES | Nokia Siemens Networks | robert.zaus@nsn.com | Rel-8 | Frederic |  |  |  |
| 2335 | 640.2.7 | Stage 3 EPC interworking with external PDNs (SGi) | 605d? | 2007-02-05 A | 2009-05-29 A | 100% |  | 2007-02-05 | 2009-05-29 | 605d? |  | finish no earlier than 2009-05-29 | C3 | 4840h | 4840h | SAES-St3-intwk | Huawei | Wei Weihua (weiwh@huawei.com) | Rel-8 | Adrian | SAES-St3-intwk |  |  |
| 2336 | 640.2.8 | Stage 3 PCC within SAE | 605d? | 2007-02-05 A | 2009-05-29 A | 100% |  | 2007-02-05 | 2009-05-29 | 605d? |  | finish no earlier than 2009-05-29 | C3 | 4840h | 4840h | SAES-St3-PCC | Ericsson | j.javier.pastor@ericsson.com | Rel-8 | Adrian | SAES-St3-PCC |  |  |
| 2337 | 640.2.9 | Stage 3 for SAE / LTE identities | 545d? | 2007-02-05 A | 2009-03-06 A | 100% |  | 2007-02-05 | 2009-03-06 | 545d? |  | finish no earlier than 2009-03-06 | C4 | 4360h | 4360h | SAES | Huawei | shahab.lavasani@huawei.com | Rel-8 | Kimmo |  |  |  |
| 2338 | 640.2.10 | Unified guidelines for Diameter usage within 3GPP | 316d? | 2007-09-21 A | 2008-12-05 A | 100% |  | 2007-09-21 | 2008-12-05 | 316d? |  | finish no earlier than 2008-12-05 | C3 | 2528h | 2528h | SAES-DIAM | Huawei | Javier Gonzalez Gallego | Rel-8 | Adrian | SAES-DIAM | CP-37 |  |
| 2339 | 640.3 | **SAE for LTE access** | 569d? | 2007-01-02 A | 2009-03-06 A | 100% |  | 2007-01-02 | 2009-03-06 | 569d? |  |  | S2; C1; C3; C4 | 80584h | 80584h | SAES-LTE | Motorola | Irfan.Ali@motorola.com | Rel-8 | Maurice | SAES-LTE |  |  |
| 2340 | 640.3.1 | CT4 Stage 3 for protocol between EPCs | 545d? | 2007-02-05 A | 2009-03-06 A | 100% |  | 2007-02-05 | 2009-03-06 | 545d? |  | finish no earlier than 2009-03-06 | C4 | 4360h | 4360h | SAES-LTE | Huawei | shahab.lavasani@huawei.com | Rel-8 | Kimmo |  |  |  |
| 2341 | 7.2.2.1 | **SAES-SA-FP_LTE with GTP variant** | 569d? | 2007-01-02 A | 2009-03-06 A | 100% |  | 2007-01-02 | 2009-03-06 | 569d? |  |  | S2; C4 | 16448h | 16448h | SAES-SA-FP_LTE-GTP | Nokia Siemens Networks | balazs.bertenyi@nsn.com | Rel-8 | Maurice | SAES-SA-FP_LTE-GTP |  |  |
| 2342 | 640.3.2.1 | Stage 2 for SAES-SA-FP_LTE with GTP variant | 373d? | 2007-01-02 A | 2008-06-05 A | 100% |  | 2007-01-02 | 2008-06-05 | 373d? |  | finish no earlier than 2008-06-02 | S2 | 2984h | 2984h | SAES-SA-FP_LTE-GTP-St2 | Nokia Siemens Networks | balazs.bertenyi@nsn.com | Rel-8 | Maurice | SAES-SA-FP_LTE-GTP-St2 |  |  |
| 2343 | 640.3.2.2 | CT4 Stage 3 for GTP v2 protocol | 545d? | 2007-02-05 A | 2009-03-06 A | 100% |  | 2007-02-05 | 2009-03-06 | 545d? |  | finish no earlier than 2009-03-06 | C4 | 4360h | 4360h | SAES-SA-FP_LTE-GTP | Huawei | shahab.lavasani@huawei.com | Rel-8 | Kimmo | SAES-SA-FP_LTE-GTP |  |  |
| 2344 | 7.2.2.2 | **SAES-SA-FP_LTE with PMIP variant** | 569d? | 2007-01-02 A | 2009-03-06 A | 100% |  | 2007-01-02 | 2009-03-06 | 569d? |  |  | S2; C4 | 20288h | 20288h | SAES-SA-FP_LTE-IETF | Nokia Siemens Networks | balazs.bertenyi@nsn.com | Rel-8 | Maurice | SAES-SA-FP_LTE-IETF |  |  |
| 2345 | 640.3.3.1 | Stage 2 for SAES-SA-FP_LTE with PMIP variant | 373d? | 2007-01-02 A | 2008-06-05 A | 100% |  | 2007-01-02 | 2008-06-05 | 373d? |  | finish no earlier than 2008-06-02 | S2 | 2984h | 2984h | SAES-SA-FP_LTE-IETF-St2 | Nokia Siemens Networks | balazs.bertenyi@nsn.com | Rel-8 | Maurice | SAES-SA-FP_LTE-IETF-St2 |  |  |
| 2346 | 640.3.3.2 | CT4 Stage 3 for PMIP protocol within EPC | 545d? | 2007-02-05 A | 2009-03-06 A | 100% |  | 2007-02-05 | 2009-03-06 | 545d? |  | finish no earlier than 2009-03-06 | C4 | 4360h | 4360h | SAES-SA-FP_LTE-IETF | Huawei | shahab.lavasani@huawei.com | Rel-8 | Kimmo | SAES-SA-FP_LTE-IETF | CP-37 |  |
| 2347 | 640.3.3.3 | Mobile IPv4 (MIPv4) based Mobility protocols | 480d? | 2007-02-05 A | 2008-12-05 A | 100% |  | 2007-02-05 | 2008-12-05 | 480d? |  | finish no earlier than 2008-12-05 | C4 | 3840h | 3840h | SAES-SA-FP_LTE-IETF | Motorola | Lewis Milton | Rel-8 | Kimmo |  | CP-41 |  |
| 2348 | 640.3.4 | Stage 3 for UE Non-Access-Stratum (NAS) mobility procedures in idle and active mode | 545d? | 2007-02-05 A | 2009-03-06 A | 100% |  | 2007-02-05 | 2009-03-06 | 545d? |  | finish no earlier than 2009-03-06 | C1 | 4360h | 4360h | SAES-LTE | Nokia Siemens Networks | robert.zaus@nsn.com | Rel-8 | Frederic |  |  |  |
| 2349 | 640.3.5 | Stage 3 for Session management, bearer control and QoS aspects | 545d? | 2007-02-05 A | 2009-03-06 A | 100% |  | 2007-02-05 | 2009-03-06 | 545d? |  | finish no earlier than 2009-03-06 | C1 | 4360h | 4360h | SAES-LTE | Nokia Siemens Networks | robert.zaus@nsn.com | Rel-8 | Frederic |  |  |  |
| 2350 | 640.3.6 | Stage 3 for security aspects of LTE Access | 545d? | 2007-02-05 A | 2009-03-06 A | 100% |  | 2007-02-05 | 2009-03-06 | 545d? |  | finish no earlier than 2009-03-06 | C1 | 4360h | 4360h | SAES-LTE | Nokia Siemens Networks | robert.zaus@nsn.com | Rel-8 | Frederic |  |  |  |
| 2351 | 640.3.7 | Stage 3 for QoS mechanisms | 480d? | 2007-02-05 A | 2008-12-05 A | 100% |  | 2007-02-05 | 2008-12-05 | 480d? |  | finish no earlier than 2008-12-12 | C3 | 3840h | 3840h | SAES-LTE | Ericsson | j.javier.pastor@ericsson.com | Rel-8 | Adrian |  |  |  |
| 2352 | 640.3.8 | Stage 3 for EPC - HSS interface | 545d? | 2007-02-05 A | 2009-03-06 A | 100% |  | 2007-02-05 | 2009-03-06 | 545d? |  | finish no earlier than 2009-03-06 | C4 | 4360h | 4360h | SAES-LTE | Huawei | shahab.lavasani@huawei.com | Rel-8 | Kimmo |  |  |  |

Notes:
- 2326: Role model for SAE/LTE system wide project management by SA2 in SP-060166
- 2327: SP#38 completed / Impacted TSs and TRs: 22.011, 22.246, New 22.278
- 2328: CP#44 completed
- 2329: SP#40 completed / Impacted TSs and TRs: New 23.402
- 2330: SP#42 completed / Impacted TSs and TRs: 33.210, 33.310, New 33.401
- 2331: CP#43 completed / Impacted TSs and TRs: 24.229, 27.007, New 24.305
- 2332: CP#42 completed / Impacted TSs and TRs: 29.061
- 2333: CP#43 completed / Impacted TSs and TRs: New (29.274, 29.275)
- 2334: CP#42 completed / Impacted TSs and TRs: 23.122, New 24.302
- 2335: CP#44 completed / Impacted TSs and TRs: 29.061
- 2336: CP#44 completed / Impacted TSs and TRs: 29.212, 29.213, 29.214, New 29.215
- 2337: CP#43 completed / Impacted TSs and TRs: 23.003
- 2338: CP#42 completed / Impacted TSs and TRs: New 29.909
- 2339: CP#43 completed
- 2340: CP#43 completed / Impacted TSs and TRs: 29.274, 29.275
- 2341: CP#43 completed
- 2342: SP#40 completed / Impacted TSs and TRs: 23.401, 23.060, 23.002, 23.246, 23.203, 23.107, 23.234, 23.271
- 2343: CP#43 completed / Impacted TSs and TRs: 29.274
- 2344: CP#43 completed
- 2345: SP#40 completed
- 2346: CP#43 completed / Impacted TSs and TRs: 29.275, 29.282
- 2347: CP#42 completed / Impacted TSs and TRs: 29.279
- 2348: CP#43 completed / Impacted TSs and TRs: 24.007, 24.301
- 2349: CP#43 completed / Impacted TSs and TRs: 24.007, 24.301
- 2350: CP#43 completed / Impacted TSs and TRs: 24.008, 24.301
- 2351: CP#42 completed / Impacted TSs and TRs: 29.213
- 2352: CP#43 completed / Impacted TSs and TRs: 29.272

| ID | WBS | Task | Type | Duration | Start | Finish | Complete | Baseline start | Baseline finish | Baseline duration | Constraint | Resources | Work | Actual work | Acronym | WI rapporteur name | WI rapporteur e-mail | Release | MCC resp | Acronym_3GU_Export | Impacted TSs and TRs | TSG approved | PCG approved | TSG stopped |
| --- | --- | --- | --- | --- | --- | --- | --- | --- | --- | --- | --- | --- | --- | --- | --- | --- | --- | --- | --- | --- | --- | --- | --- | --- |
| 2353 | 640.4 | **SAE for Interoperation between LTE and legacy cellular PS accesses** |  | 545d? | 2007-02-05 A | 2009-03-06 A | 100% | 2007-02-05 | 2009-03-06 | 545d? |  | S2; C1; C4 | 48872h | 48872h | SAES-SA-FP_3GPP | Motorola | Irfan.Ali@motorola.com | Rel-8 | Maurice | SAES-SA-FP_3GPP |  |  |  |  |
| 2354 | 640.4.1 | Stage 2 for Interoperation between LTE and 2G/3G |  | 424d? | 2007-02-05 A | 2008-09-18 A | 100% | 2007-02-05 | 2008-09-18 | 424d? | finish no earlier than 2008-09-11 | S2 | 3392h | 3392h | EPSto2_3G | Motorola | Irfan.Ali@motorola.com | Rel-8 | Maurice | EPSto2_3G | 23.401, 23.402 | SP-37 |  |  |
| 2355 | 640.4.2 | Stage 3 for Inter-system mobility between E-UTRAN and 2G/3G |  | 545d? | 2007-02-05 A | 2009-03-06 A | 100% | 2007-02-05 | 2009-03-06 | 545d? | finish no earlier than 2009-03-06 | C1 | 4360h | 4360h | SAES-SA-FP_3GPP | Nokia Siemens Networks | robert.zaus@nsn.com | Rel-8 | Frederic | SAES-SA-FP_3GPP | 24.008, 24.301 | CP-38 | PCG-21 |  |
| 2356 | 640.4.3 | Stage 2 GPRS enhancements for LTE access |  | 272d? | 2007-09-04 A | 2008-09-18 A | 100% | 2007-09-04 | 2008-09-18 | 272d? | start no earlier than 2007-09-04 | S2 | 2176h | 2176h | SAES-GPRS_LTE | Vodafone | chris.pudney@vodafone.com | Rel-8 | Maurice | SAES-GPRS_LTE | 23.401 |  |  |  |
| 2357 | 640.4.4 | Stage 2 GPRS for EPC (23.060, etc.) |  | 179d? | 2008-01-14 A | 2008-09-18 A | 100% | 2008-01-14 | 2008-09-18 | 179d? | finish no earlier than 2008-09-18 | S2 | 1432h | 1432h | SAES-SA-FP_3GPP | Nokia Siemens Networks | balazs.bertenyi@nsn.com | Rel-8 | Maurice |  | 23.060 | SP-39 | PCG-21 |  |
| 2358 | 640.4.5 | Stage 3 for EPC - GPRS |  | 545d? | 2007-02-05 A | 2009-03-06 A | 100% | 2007-02-05 | 2009-03-06 | 545d? | finish no earlier than 2009-03-06 | C4 | 4360h | 4360h | SAES-SA-FP_3GPP | Huawei | shahab.lavasani@huawei.com | Rel-8 | Kimmo |  | 29.274, 29.275, 29.281 |  |  |  |
| 2359 | 640.4.6 | Stage 3 for EPC to UTRAN |  | 545d? | 2007-02-05 A | 2009-03-06 A | 100% | 2007-02-05 | 2009-03-06 | 545d? | finish no earlier than 2009-03-06 | C4 | 4360h | 4360h | SAES-SA-FP_3GPP | Huawei | shahab.lavasani@huawei.com | Rel-8 | Kimmo |  | 29.274, 29.275, 29.281 | CP-38 | PCG-21 |  |
| 2360 | 640.4.7 | Stage 3 for EPC to 3GPP2 |  | 545d? | 2007-02-05 A | 2009-03-06 A | 100% | 2007-02-05 | 2009-03-06 | 545d? | finish no earlier than 2009-03-06 | C4 | 4360h | 4360h | SAES-SA-FP_3GPP | Huawei | shahab.lavasani@huawei.com | Rel-8 | Kimmo |  | 29.277, 29.276 | CP-38 | PCG-21 |  |
| 2361 | 640.4.8 | Stage 2 for Interoperation between LTE and CDMA2000 |  | 329d? | 2007-06-18 A | 2008-09-18 A | 100% | 2007-06-18 | 2008-09-18 | 329d? | finish no earlier than 2008-04-25 | S2 | 2632h | 2632h | EPStoC2k | Motorola, Vodafone | Irfan.Ali@motorola.com, chris.pudney@vodafone.com | Rel-8 | Maurice | EPStoC2k | 23.401, 23.402 | CP-37 |  |  |
| 2362 | 640.4.9 | Stage 3 for Inter-system mobility between E-UTRAN and CDMA2000 |  | 545d? | 2007-02-05 A | 2009-03-06 A | 100% | 2007-02-05 | 2009-03-06 | 545d? | finish no earlier than 2009-03-06 | C1 | 4360h | 4360h | SAES-SA-FP_3GPP | Nokia Siemens Networks | robert.zaus@nsn.com | Rel-8 | Frederic |  | 24.301, 24.302 |  |  |  |
| 2363 | 640.4.10 | Stage 3 for MME - SGSN signalling free protocol |  | 545d? | 2007-02-05 A | 2009-03-06 A | 100% | 2007-02-05 | 2009-03-06 | 545d? | finish no earlier than 2009-03-06 | C4 | 4360h | 4360h | SAES-SA-FP_3GPP | Huawei | shahab.lavasani@huawei.com | Rel-8 | Kimmo |  | 29.272, 29.274 |  |  |  |
| 2364 | 640.5 | **SAE for support for non-3GPP accesses** |  | 1429d? | 2007-01-02 A | 2012-06-15 A | 100% | 2007-01-02 | 2012-06-15 | 1429d? |  | S2; S3; C1; C4; IETF | 123829h | 123829h | SAES-SA-FP_n3GPP | Motorola | Irfan.Ali@motorola.com | Rel-8 | Maurice | SAES-SA-FP_n3GPP |  |  |  |  |
| 2365 | 7.2.4.1 | Stage 2 for Host-based Mobility aspects |  | 373d? | 2007-01-02 A | 2008-06-05 A | 100% | 2007-01-02 | 2008-06-05 | 373d? | finish no earlier than 2008-04-11 | S2 | 2984h | 2984h | SAES-SA-FP_n3GPP-HBMob | Motorola | Irfan.Ali@motorola.com | Rel-8 | Maurice | SAES-SA-FP_n3GPP-HBMob | 23.402 |  |  |  |
| 2366 | 7.2.4.2 | Stage 2 for Network-based Mobility aspects |  | 448d? | 2007-01-02 A | 2008-09-18 A | 100% | 2007-01-02 | 2008-09-18 | 448d? | finish no earlier than 2008-09-18 | S2 | 3584h | 3584h | SAES-SA-FP_n3GPP-NBMob | Motorola | Irfan.Ali@motorola.com | Rel-8 | Maurice | SAES-SA-FP_n3GPP-NBMob | 23.402 |  |  |  |
| 2367 | 640.5.3 | Stage 3 for Mobility management based on DSMIPv6 |  | 480d? | 2007-02-05 A | 2008-12-05 A | 100% | 2007-02-05 | 2008-12-05 | 480d? | finish no earlier than 2008-12-05 | C1 | 3840h | 3840h | SAES-SA-FP_n3GPP | Nokia Siemens Networks | robert.zaus@nsn.com | Rel-8 | Frederic |  | 24.303 |  |  |  |
| 2368 | 640.5.4 | (IETF) Stage 3 for Mobility management based on DSMIPv6 (draft-ietf-mip6-hiopt) |  | 589d? | 2007-02-05 A | 2012-06-15 A | 100% | 2007-02-05 | 2012-06-15 | 589d? | finish no earlier than 2012-09-14 | C1-IETF | 4712h | 4712h | SAES-SA-FP_n3GPP | Mark Jones |  | Rel-8 | Frederic |  | RFC 6610 (was draft-ietf-mip6-hiopt) | CP-52 | PCG-27 |  |
| 2369 | 640.5.5 | (IETF) Stage 3 for Mobility management based on DSMIPv6 (RFC6275) |  | 356d? | 2007-02-05 A | 2011-07-29 A | 100% | 2007-02-05 | 2011-07-29 | 356d? | finish no earlier than 2011-07-29 | C1-IETF | 2848h | 2848h | SAES-SA-FP_n3GPP |  |  | Rel-8 | Frederic |  | RFC 6275 (was draft-ietf-mext-rfc3775bis) | CP-52 | PCG-27 |  |
| 2370 | 640.5.6 | Stage 3 for Mobility management based on MIP v4 |  | 480d? | 2007-02-05 A | 2008-12-05 A | 100% | 2007-02-05 | 2008-12-05 | 480d? | start no earlier than 2007-02-05 | C1 | 3840h | 3840h | SAES-SA-FP_n3GPP | Nokia Siemens Networks | robert.zaus@nsn.com | Rel-8 | Frederic |  | 24.304 | CP-39 | PCG-21 |  |
| 2371 | 640.5.7 | Stage 3 for Inter-system mobility between E-UTRAN and non 3GPP accesses |  | 545d? | 2007-02-05 A | 2009-03-06 A | 100% | 2007-02-05 | 2009-03-06 | 545d? | finish no earlier than 2009-03-06 | C1 | 4360h | 4360h | SAES-SA-FP_n3GPP | Nokia Siemens Networks | robert.zaus@nsn.com | Rel-8 | Frederic |  | 24.008, 24.301 | CP-38 | PCG-21 |  |
| 2372 | 640.5.8 | Stage 2 for Optimized Dual-Radio Handover with WiMAX |  | 249d? | 2007-06-25 A | 2008-06-05 A | 100% | 2007-06-25 | 2008-06-05 | 249d? | finish no earlier than 2008-06-09 | S2 | 1992h | 1992h | SAES-SA-FP_n3GPP-OptWIMAX | Motorola | Irfan.Ali@motorola.com | Rel-8 | Maurice | SAES-SA-FP_n3GPP-OptWIMAX | 23.402 |  |  |  |
| 2373 | 640.5.9 | Stage 2 Security aspects for non-3GPP Access |  | 197d? | 2008-03-12 A | 2008-12-11 A | 100% | 2008-03-12 | 2008-12-11 | 197d? | finish no earlier than 2008-12-11 | S3 | 1576h | 1576h | SAES-SA-FP_n3GPP | Nokia Siemens Networks | marc.blommaert.ext@nsn.com | Rel-8 | Mirko |  | 33.402, 33.210, 33.310 | SP-39 | PCG-21 |  |
| 2374 | 640.5.10 | Stage 3 security aspects for DSMIPv6 Access |  | 480d? | 2007-02-05 A | 2008-12-05 A | 100% | 2007-02-05 | 2008-12-05 | 480d? | finish no earlier than 2008-12-05 | C1 | 3840h | 3840h | SAES-SA-FP_n3GPP | Nokia Siemens Networks | robert.zaus@nsn.com | Rel-8 | Frederic |  | 24.303 | CP-37 |  |  |
| 2375 | 640.5.11 | Stage 3 security aspects for MIPv4 Access |  | 480d? | 2007-02-05 A | 2008-12-05 A | 100% | 2007-02-05 | 2008-12-05 | 480d? | finish no earlier than 2008-12-05 | C1 | 3840h | 3840h | SAES-SA-FP_n3GPP | Nokia Siemens Networks | robert.zaus@nsn.com | Rel-8 | Frederic |  | 24.304 | CP-39 | PCG-21 |  |
| 2376 | 640.5.12 | Stage 3 for Access to the EPC via non-3GPP access networks |  | 545d? | 2007-02-05 A | 2009-03-06 A | 100% | 2007-02-05 | 2009-03-06 | 545d? | finish no earlier than 2009-03-06 | C1 | 4360h | 4360h | SAES-SA-FP_n3GPP | Nokia Siemens Networks | robert.zaus@nsn.com | Rel-8 | Frederic |  | 24.302, 24.312 |  |  |  |
| 2377 | 640.5.13 | Stage 3 for interfaces within EPC |  | 383d? | 2007-09-19 A | 2009-03-06 A | 100% | 2007-09-19 | 2009-03-06 | 383d? | finish no earlier than 2009-03-06 | C4 | 3064h | 3064h | SAES-SA-FP_n3GPP | Huawei | shahab.lavasani@huawei.com | Rel-8 | Kimmo |  | 29.274, 29.281 | CP-37 |  |  |
| 2378 | 640.5.14 | Stage 3 for Interfaces EPC - non-3GPP IP access |  | 545d? | 2007-02-05 A | 2009-03-06 A | 100% | 2007-02-05 | 2009-03-06 | 545d? | finish no earlier than 2009-03-06 | C4 | 4360h | 4360h | SAES-SA-FP_n3GPP | Huawei | shahab.lavasani@huawei.com | Rel-8 | Kimmo |  | 29.273, 29.275 |  |  |  |
| 2379 | 640.5.15 | (IETF) Stage 3 for Interfaces EPC - non-3GPP IP access |  | 1224.6d? | 2007-02-05 A | 2012-06-15 A | 100% | 2007-02-05 | 2012-06-15 | 1224.6d? | finish no earlier than 2012-06-15 | C4-IETF | 9788.8h | 9788.8h | SAES-SA-FP_n3GPP | Lionel Morand |  | Rel-8 | Kimmo |  | RFC 6611 (was draft-ietf-mip6-bootstrapping-integrated) | CP-52 | PCG-27 |  |
| 2380 | 640.5.16 | Stage 3 for AAA/HSS related |  | 480d? | 2007-02-05 A | 2008-12-05 A | 100% | 2007-02-05 | 2008-12-05 | 480d? | finish no earlier than 2008-12-05 | C4 | 3840h | 3840h | SAES-SA-FP_n3GPP | Huawei | shahab.lavasani@huawei.com | Rel-8 | Kimmo |  | 29.273 |  |  |  |
| 2381 | 640.5.17 | Stage 3 for EPC - AAA interface |  | 480d? | 2007-02-05 A | 2008-12-05 A | 100% | 2007-02-05 | 2008-12-05 | 480d? | finish no earlier than 2008-12-05 | C4 | 3840h | 3840h | SAES-SA-FP_n3GPP | Huawei | shahab.lavasani@huawei.com | Rel-8 | Kimmo |  | 29.273 |  |  |  |
| 2382 | 640.5.18 | Deleted (already covered) SAES-SA-FP_n3GPP Optimized Handover with CDMA | milestone | 0d? | 2007-06-25 A | 2007-06-25 A | 100% | 2007-06-25 | 2007-06-25 | 0d? | finish no earlier than 2007-06-25 | S2 |  |  | SAES-SA-FP_n3GPP-OptCDMA | Nokia Siemens Networks |  | Rel-8 | Maurice | SAES-SA-FP_n3GPP-OptCDMA |  |  |  | SP-37 |

Notes:
- 2353: CP#43 completed
- 2354: SP#41 completed
- 2355: CP#43 completed
- 2356: SP#41 completed
- 2357: SP#41 completed
- 2358: CP#43 completed
- 2359: CP#43 completed
- 2360: CP#43 completed
- 2361: SP#41 completed (except: Handover of multiple PDNs=>Rel-9)
- 2362: CP#43 completed
- 2363: CP#43 completed
- 2364: CP#43 completed. SP#39 retained in Rel-8 (in addition to the essential functionality defined in SP-070699). Replaces UID_340037
- 2365: SP#40 completed
- 2366: SP#41 completed
- 2367: CP#42 completed
- 2368: CP#56 completed
- 2369: SP#53/IETF#81 completed
- 2370: CP#42 completed
- 2371: CP#43 completed
- 2372: SP#40 completed
- 2373: SP#42 completed
- 2374: CP#42 completed
- 2375: CP#42 completed
- 2376: CP#43 completed
- 2377: CP#43 completed
- 2378: CP#43 completed
- 2379: CP#56 completed
- 2380: CP#42 completed
- 2381: CP#42 completed
- 2382: SP#37 stopped

| ID | WBS | Task | Type | Duration | Start | Finish | Complete | Baseline start | Baseline finish | Baseline duration | Constraint | Resources | Work | Actual work | Acronym | WI rapporteur name | Release | MCC resp | Acronym_3GU_Export | Impacted TSs and TRs | PCG approved | TSG approved | PCG stopped | TSG stopped | Special Focus Doc |
| --- | --- | --- | --- | --- | --- | --- | --- | --- | --- | --- | --- | --- | --- | --- | --- | --- | --- | --- | --- | --- | --- | --- | --- | --- | --- |
| 2383 | 640.6 | **Single Radio Voice Call Continuity for 3GPP (SRVCC)** |  | 569d? | 2007-01-02 A | 2009-03-06 A | 100% | 2007-01-02 | 2009-03-06 | 569d? |  | S2; C1; C4 | 19856h | 19856h | SAES-SRVCC | Nokia Siemens Networks | Rel-8 | Maurice | SAES-SRVCC |  |  |  |  |  |  |
| 2384 | 640.6.1 | Stage 2 for 2G/3G SRVCC |  | 448d? | 2007-01-02 A | 2008-09-18 A | 100% | 2007-01-02 | 2008-09-18 | 448d? | finish no earlier than 2008-09-15 | S2 | 3584h | 3584h | SAES-SRVCC | Nokia Siemens Networks | Rel-8 | Maurice |  | New 23.216 |  |  |  |  |  |
| 2385 | 640.6.2 | Stage 3 for SRVCC in EPS |  | 201d? | 2008-05-30 A | 2009-03-06 A | 100% | 2008-05-30 | 2009-03-06 | 201d? | finish no earlier than 2009-03-06 | C1 | 1608h | 1608h | SAES-SRVCC | Nokia Siemens Networks | Rel-8 | Frederic |  | 23.009, 24.008, New 24.301 | PCG-21 | CP-41 |  |  |  |
| 2386 | 640.6.3 | MME to MSC interface for SRVCC |  | 126d? | 2008-09-12 A | 2009-03-06 A | 100% | 2008-09-12 | 2009-03-06 | 126d? | finish no earlier than 2009-03-06 | C4 | 1008h | 1008h | SAES-SRVCC | Nokia Siemens Networks | Rel-8 | Kimmo |  | 23.003, 23.008, New (29.274, 29.277, 29.280) | PCG-21 | CP-41 |  |  |  |
| 2387 | 640.7 | Voice Call Continuity for CDMA2000 1X |  | 249d? | 2007-06-25 A | 2008-06-05 A | 100% | 2007-06-25 | 2008-06-05 | 249d? | finish no earlier than 2008-06-13 | S2 | 1992h | 1992h | SAES-VCC_1X | Nokia Siemens Networks | Rel-8 | Maurice | SAES-VCC_1X |  |  |  |  |  |  |
| 2388 | 640.8 | SAE impacts on IMS |  | 373d? | 2007-01-02 A | 2008-06-05 A | 100% | 2007-01-02 | 2008-06-05 | 373d? | finish no earlier than 2008-06-13 | S2 | 2984h | 2984h | SAES-SA_IMS | Nokia Siemens Networks | Rel-8 | Maurice | SAES-SA_IMS |  |  |  |  |  |  |
| 2389 | 640.9 | **CS Fallback in EPS** |  | 258d? | 2008-03-12 A | 2009-03-06 A | 100% | 2008-03-12 | 2009-03-06 | 258d? |  | S2; C1; C4 | 9384h | 9384h | SAES-CSFB | T-Mobile, Vodafone | Rel-8 | Maurice | SAES-CSFB |  | PCG-21 | SP-39 |  |  |  |
| 2390 | 640.9.1 | Stage 2 for CS Fallback in EPS |  | 62d? | 2008-03-12 A | 2008-06-05 A | 100% | 2008-03-12 | 2008-06-05 | 62d? | finish no earlier than 2008-12-05 | S2 | 496h | 496h | SAES-CSFB | T-Mobile, Vodafone | Rel-8 | Maurice |  | New (23.272, 23.401) | PCG-21 | SP-40 |  |  |  |
| 2391 | 640.9.2 | CT1 part of Stage 3 for CS Fallback in EPS |  | 201d? | 2008-05-30 A | 2009-03-06 A | 100% | 2008-05-30 | 2009-03-06 | 201d? | finish no earlier than 2009-03-06 | C1 | 1608h | 1608h | SAES-CSFB | NEC | Rel-8 | Frederic |  | 24.007, 24.008, 24.011, 29.018, New (24.301, 24.801, 29.118) | PCG-21 | CP-40 |  |  |  |
| 2392 | 640.9.3 | CT4 part of Stage 3 for CS Fallback in EPS |  | 136d? | 2008-05-30 A | 2008-12-05 A | 100% | 2008-05-30 | 2008-12-05 | 136d? | finish no earlier than 2008-12-05 | C4 | 1088h | 1088h | SAES-CSFB | NEC | Rel-8 | Kimmo |  | 23.007, 23.008, 29.274, New 29.277 | PCG-21 | CP-40 |  |  |  |
| 2393 | 640.10 | System enhancements for the use of IMS services in local breakout |  | 62d? | 2008-03-12 A | 2008-06-05 A | 100% | 2008-03-12 | 2008-06-05 | 62d? | finish no earlier than 2008-06-05 | S2 | 496h | 496h | SAES-IMS_LBO | Telecom Italia | Rel-8 | Maurice | SAES-IMS_LBO | 23.228, 23.221, 23.203 | PCG-21 | SP-39 |  |  |  |
| 2394 | 640.11 | **EPC Data Definitions** |  | 309d? | 2008-01-07 A | 2009-03-12 A | 100% | 2008-01-07 | 2009-03-12 | 309d? |  | S5 | 7144h | 7144h | EPC-OAM |  | Rel-8 | Mirko | EPC-OAM |  | PCG-21 | SP-39 |  |  |  |
| 2395 | 640.11.1 | EPC Network Resource Model (NRM) Integration Reference Point (IRP) |  | 309d? | 2008-01-07 A | 2009-03-12 A | 100% | 2008-01-07 | 2009-03-12 | 309d? | finish no earlier than 2009-03-12 | S5 | 2472h | 2472h | EPC-OAM | Huawei | Rel-8 | Mirko |  | New (32.751, 32.752, 32.753, 32.755) | PCG-21 | SP-38 |  |  |  |
| 2396 | 640.11.2 | Performance measurements for EPC |  | 275d? | 2008-02-22 A | 2009-03-12 A | 100% | 2008-02-22 | 2009-03-12 | 275d? | finish no earlier than 2009-03-12 | S5 | 2200h | 2200h | EPC-OAM | China Mobile | Rel-8 | Mirko |  | New 32.426 | PCG-21 | SP-39 |  |  |  |
| 2397 | 640.12 | EPC Charging |  | 309d? | 2008-01-07 A | 2009-03-12 A | 100% | 2008-01-07 | 2009-03-12 | 309d? | finish no earlier than 2009-03-12 | S5 | 2472h | 2472h | EPC-CH | Nokia Siemens Networks | Rel-8 | Mirko | EPC-CH | 32.240, 32.296, 32.251, 32.252, 32.298, 32.299 | PCG-21 | SP-38 |  |  |  |
| 2398 | 640.13 | Domain Name System Procedures for Evolved Packet System (DEPS) |  | 179.75d? | 2008-05-30 A | 2009-03-06 A | 100% | 2008-05-30 | 2009-03-06 | 179.75d? | finish no earlier than 2009-03-06 | C4 | 1438h | 1438h | SAES-DEPS | TeliaSonera | Rel-8 | Kimmo | SAES-DEPS | 23.003, New 29.303 | PCG-21 | CP-40 |  |  |  |
| 2399 | 640.14 | InterWorking Function (IWF) between MAP based and Diameter based interfaces |  | 126d? | 2008-09-12 A | 2009-03-06 A | 100% | 2008-09-12 | 2009-03-06 | 126d? | finish no earlier than 2009-03-06 | C4 | 1008h | 1008h | SAES-MAP2Diam | Huawei | Rel-8 | Kimmo | SAES-MAP2Diam | New 29.305 | PCG-21 | CP-41 |  |  |  |
| 2400 | 640.15 | **CT6 aspects of SAE** |  | 847d? | 2008-03-07 A | 2011-06-03 A | 100% | 2008-03-07 | 2011-06-03 | 847d? |  | C6 | 13480h | 13480h | SAES | Nokia | Rel-8 | Xavier |  |  | PCG-21 | SP-39 |  |  |  |
| 2401 | 640.15.1 | Core specification for CT6 aspects of SAE |  | 321d? | 2008-03-07 A | 2009-05-29 A | 100% | 2008-03-07 | 2009-05-29 | 321d? | finish no earlier than 2009-05-29 | C6 | 2568h | 2568h | SAES | Nokia | Rel-8 | Xavier |  | 31.102, 31.111 | PCG-21 | CP-39 |  |  |  |
| 2402 | 640.15.2 | Test interworking of LTE Terminals with the USIM |  | 526d? | 2008-12-05 A | 2010-12-10 A | 100% | 2008-12-05 | 2010-12-10 | 526d? | finish no earlier than 2010-12-10 | C6 | 4208h | 4208h | SAES-USIM_LTE-Test | Comprion | Rel-8 | Xavier | SAES-USIM_LTE-Test | 31.121, 31.124 | PCG-22 | CP-42 |  |  |  |
| 2403 | 640.15.3 | Test interworking of IP Multimedia Services Identity Module (ISIM) terminals with IP Multimedia Subsystem (IMS) |  | 186d? | 2010-09-17 A | 2011-06-03 A | 100% | 2010-09-17 | 2011-06-03 | 186d? | finish no earlier than 2011-06-03 | C6 | 1488h | 1488h | SAES-ISIM_IMS_Test | Comprion | Rel-8 | Xavier | SAES-ISIM_IMS_Test | 31.121, 31.124, New TS 31.134 | PCG-25 | CP-49 |  |  |  |
| 2404 | 640.16 | Issues for CT1 TR 24.801 |  | 420d? | 2007-01-04 A | 2008-12-05 A | 100% | 2007-01-04 | 2008-12-05 | 420d? | finish no earlier than 2008-12-05 | C1 | 3360h | 3360h | SAES | Nokia Siemens Networks | Rel-8 | Frederic |  | 24.801 | PCG-21 | CP-39 |  |  |  |
| 2405 | 640.17 | Issues for CT3 TR 29.804 |  | 420d? | 2007-02-05 A | 2008-09-12 A | 100% | 2007-02-05 | 2008-09-12 | 420d? | finish no earlier than 2008-12-12 | C3 | 3360h | 3360h | SAES | Ericsson | Rel-8 | Adrian |  | 29.804 | PCG-21 | CP-39 |  |  |  |
| 2406 | 640.18 | Deleted - Issues for CT4 TR 29.803 |  | 420d? | 2007-01-04 A | 2008-09-12 A | 100% | 2007-01-04 | 2008-09-12 | 420d? | finish no earlier than 2008-12-11 | C4 | 3360h | 3360h | SAES | Huawei | Rel-8 | Kimmo |  | 29.803 | PCG-21 | CP-39 | PCG-21 | CP-41 |  |
| 2407 | 640.19 | Deleted (covered by 380068): Functions and procedures for SAE to support LCS | milestone | 0d? | 2008-03-03 A | 2008-03-03 A | 100% | 2008-03-03 | 2008-03-03 | 0d? | finish no earlier than 2008-03-03 | S2 |  |  | SAES-SA-FP_LCS | Nokia Siemens Networks | Rel-8 | Maurice | SAES-SA-FP_LCS |  |  |  |  | SP-37 |  |
| 2408 | 640.20 | Deleted (covered by 380064): SAE aspects of Emergency Calls | milestone | 0d? | 2008-03-03 A | 2008-03-03 A | 100% | 2008-03-03 | 2008-03-03 | 0d? | start no earlier than 2008-03-03 | S2 |  |  | SAES-SA-EmCall | Nokia Siemens Networks | Rel-8 | Maurice | SAES-SA-EmCall |  |  |  |  | SP-37 | Public Safety (I-A) |

Notes:
- 2383: CP#43 completed. SP#38 WID approved (extract from SAE WID SP-070817). / WI rapporteur e-mail: curt.c.wong@nokia.com
- 2384: SP#41 completed. SP#38 WID approved / WI rapporteur e-mail: curt.c.wong@nokia.com
- 2385: CP#43 completed / WI rapporteur e-mail: robert.zaus@nsn.com
- 2386: CP#43 completed / WI rapporteur e-mail: Giorgi Gulbani
- 2387: SP#40 completed / WI rapporteur e-mail: balazs.bertenyi@nsn.com
- 2388: SP#40 completed / WI rapporteur e-mail: balazs.bertenyi@nsn.com
- 2389: CP#43 completed / WI rapporteur e-mail: sabine.demel@t-mobile.at, chris.pudney@vodafone.com
- 2390: SP#40 completed / WI rapporteur e-mail: sabine.demel@t-mobile.at, chris.pudney@vodafone.com
- 2391: CP#43 completed / WI rapporteur e-mail: yannick.lair@nectech.fr
- 2392: CP#42 completed / WI rapporteur e-mail: yannick.lair@nectech.fr
- 2393: SP#40 completed / WI rapporteur e-mail: mario.madella@telecomitalia.it
- 2394: SP#43 completed
- 2395: SP#43 completed / WI rapporteur e-mail: WANG, Xuelong
- 2396: SP#43 completed / WI rapporteur e-mail: Li Jian (lijian@chinamobile.com), Liang Shuangchun (liangshuangchun@cmdi.chinamobile.com)
- 2397: SP#43 completed / WI rapporteur e-mail: Gerald.Goermer@nsn.com
- 2398: CP#43 completed / WI rapporteur e-mail: jouni.korhonen@teliasonera.com
- 2399: CP#43 completed. Triggered by UID_380023 (FS_MAP2Diam) / WI rapporteur e-mail: liming49985@huawei.com
- 2400: CP#44 completed core specification / WI rapporteur e-mail: Rune Lindholm
- 2401: CP#44 completed (specified Network Measurement Results collection via USAT) / WI rapporteur e-mail: Rune Lindholm
- 2402: CP#50 completed. Steering of Roaming test cases have been introduced. Remaining issues CSG display testing (Provide Local Information, Call Control for EPS/PDN, Event Download (Access Technology Change - Multiple Access Technologies) / WI rapporteur e-mail: Udo Willenbrink (uwillenbrink@comprion.com )
- 2403: CP#52 completed. Linked to R5 UID_1273 Provisioning of IP-based multimedia services (24.229, 31.103), R8 UID_390021 CT6 aspects of SAE, UID_420018 Test interworking of LTE Terminals with the USIM, R UID_450018 Testing SMS over IMS in E-UTRAN (34.229). / WI rapporteur e-mail: Udo Willenbrink (uwillenbrink@comprion.com )
- 2404: CP#43 completed / WI rapporteur e-mail: robert.zaus@nsn.com
- 2405: CP#41 completed / WI rapporteur e-mail: j.javier.pastor@ericsson.com
- 2406: CP#41 Work stopped and continued in Normative specifications
- 2407: SP#37 stopped
- 2408: SP#37 stopped

| ID | WBS | Task | Type | Duration | Start | Finish | Complete | Remaining | Baseline start | Baseline finish | Baseline duration | Total slack | Constraint | Resources | Work | Actual work | Acronym | Release | MCC resp | TSG stopped | Acronym_3GU_Export | WI rapporteur name | WI rapporteur e-mail | PCG approved | TSG approved | Status Report | PCG stopped |
| --- | --- | --- | --- | --- | --- | --- | --- | --- | --- | --- | --- | --- | --- | --- | --- | --- | --- | --- | --- | --- | --- | --- | --- | --- | --- | --- | --- |
| 2409 | 640.21 | **Deleted - CT aspects of SAES** |  | 138d? | 2007-09-04 A | 2008-03-14 | 100% | 0d? | 2007-09-04 | 2008-03-14 | 138d? | 0d |  | C3; C1; C4 | 3312h | 1104h | SAES-St3 | Rel-8 | Frederic | SP-37 | SAES-St3 |  |  |  |  |  |  |
| 2410 | 640.21.1 | Deleted - CT1 aspects of SAES | milestone | 0d? | 2007-09-04 A | 2007-09-04 A | 100% |  | 2007-09-04 | 2007-09-04 | 0d? |  | start no earlier than 2007-09-04 | C1 |  |  | SAES-St3 | Rel-8 | Frederic | SP-37 |  |  |  |  |  |  |  |
| 2411 | 640.21.2 | Deleted - Interoperability | milestone | 0d? | 2008-03-14 A | 2008-03-14 A | 100% |  | 2008-03-14 | 2008-03-14 | 0d? |  | start no earlier than 2008-03-14 | C1 |  |  | SAES-St3-interop | Rel-8 | Frederic | SP-37 | SAES-St3-interop |  |  |  |  |  |  |
| 2412 | 640.21.3 | Deleted - CT3 aspects of SAES | milestone | 0d? | 2007-09-04 A | 2007-09-04 A | 100% |  | 2007-09-04 | 2007-09-04 | 0d? |  | start no earlier than 2007-09-04 | C3 |  |  | SAES | Rel-8 | Adrian | SP-37 |  |  |  |  |  |  |  |
| 2413 | 640.21.4 | Deleted - CT4 aspects of SAES | milestone | 0d? | 2007-09-04 A | 2007-09-04 A | 100% |  | 2007-09-04 | 2007-09-04 | 0d? |  | start no earlier than 2007-09-04 | C4 |  |  | SAES | Rel-8 | Kimmo | SP-37 |  |  |  |  |  |  |  |
| 2414 | 640.21.5 | Deleted - UE to EPC NAS signalling (incl. MBMS and QoS aspects) | milestone | 0d? | 2008-03-14 A | 2008-03-14 A | 100% |  | 2008-03-14 | 2008-03-14 | 0d? |  | start no earlier than 2008-03-14 | C1 |  |  | SAES-St3-sig | Rel-8 | Frederic | SP-37 | SAES-St3-sig |  |  |  |  |  |  |
| 2415 | 640.21.6 | Deleted - User and Control plane protocols | milestone | 0d? | 2007-09-21 A | 2007-09-21 A | 100% |  | 2007-09-21 | 2007-09-21 | 0d? |  | start no earlier than 2007-09-21 | C4 |  |  | SAES-St3-prot | Rel-8 | Kimmo | SP-37 | SAES-St3-prot |  |  |  |  |  |  |
| 2416 | 640.22 | Deleted - Architecture enhancements for non-3GPP accesses | milestone | 0d? | 2007-09-04 A | 2007-09-04 A | 100% |  | 2007-09-04 | 2007-09-04 | 0d? |  | start no earlier than 2007-09-04 | S2 |  |  | SAES-non_3GPP | Rel-8 | Maurice | SP-34 | SAES-non_3GPP | Motorola | Irfan.Ali@motorola.com |  |  |  |  |
| 2417 | 640.23 | Deleted - Stage 2 of architecture for the 3GPP System Architecture Evolution | milestone | 0d? | 2007-10-02 A | 2007-10-02 A | 100% |  | 2007-10-02 | 2007-10-02 | 0d? |  | start no earlier than 2007-10-02 | S2 |  |  | SAES-St2 | Rel-8 | Maurice | SP-34 | SAES-St2 | Vodafone | chris.pudney@vodafone.com |  |  |  |  |
| 2418 | 640.24 | Deleted - SA aspects of System Architecture Evolution |  | 384d? | 2006-04-12 A | 2007-10-01 A | 100% |  | 2006-04-12 | 2007-10-01 | 384d? |  | finish no earlier than 2007-10-02 | S2 | 3072h | 3072h | SAES-SA | Rel-8 | Maurice | SP-34 | SAES-SA |  |  |  |  |  |  |
| 2419 | 641 | Conformance Test Aspects – Mobility management based on DSMIPv6 (Dual-Stack Mobile IPv6) |  | 261d? | 2009-09-18 A | 2010-09-17 A | 100% |  | 2009-09-18 | 2010-09-17 | 261d? |  | finish no earlier than 2010-09-17 | R5 | 2088h | 2088h | DSMIPv6_UEConTest | Rel-8 | Ingbert |  | DSMIPv6_UEConTest | Qualcomm | Lena Chaponniere (lchaponn@qualcomm.com) | PCG-23 | RP-45 | RP-100738 |  |
| 2420 | 642 | **IMS Centralized Service control** |  | 2392.1d? | 2005-11-01 A | 2014-12-09 | 98% | 49.36d? | 2005-11-01 | 2014-12-05 | 2387.1d? | 657d |  | S1; S2; C1; C3; C4; IETF | 239598h | 100747h | ICSRA | Rel-8 | Alain |  | ICSRA | AT&T | Randolph Wohlert (rwohlert@tri.sbc.com) |  | SP-37 |  |  |
| 2421 | 642.1 | Stage 1 for ICS Requirement and Architecture |  | 138d? | 2007-09-03 A | 2008-03-12 A | 100% |  | 2007-09-03 | 2008-03-12 | 138d? |  | finish no earlier than 2007-12-14 | S1 | 1104h | 1104h | ICSRA | Rel-8 | Alain |  |  | AT&T | Randolph Wohlert (rwohlert@tri.sbc.com) | PCG-21 | SP-38 |  |  |
| 2422 | 642.2 | Stage 2 for ICS Requirement and Architecture |  | 125d? | 2007-12-14 A | 2008-06-05 A | 100% |  | 2007-12-14 | 2008-06-05 | 125d? |  | start no earlier than 2007-12-14 | S2 | 1000h | 1000h | ICSRA-St2 | Rel-8 | Maurice |  | ICSRA-St2 | Alcatel-Lucent |  | PCG-21 | SP-38 |  |  |
| 2423 | 642.3 | **Stage 3 for ICSRA – Protocol, Addressing, Subscriber Data** |  | 2392.1d? | 2005-11-01 A | 2014-12-09 | 98% | 51.61d? | 2005-11-01 | 2014-12-05 | 2387.1d? | 657d |  | C1; C3; C4; IETF | 122674h | 69070.4h | ICSRA | Rel-8 | Frederic |  |  | Ericsson | sean.schneyer@ericsson.com |  |  |  |  |
| 2424 | 642.3.1 | CT1 aspects - Stage 3 for ICSRA |  | 201d? | 2008-05-30 A | 2009-03-06 A | 100% |  | 2008-05-30 | 2009-03-06 | 201d? |  | finish no earlier than 2009-03-06 | C1 | 1608h | 1608h | ICSRA | Rel-8 | Frederic |  |  | Ericsson | Sean Schneyer | PCG-21 | CP-40 |  |  |
| 2425 | 642.3.2 | (IETF) CT1 aspects - Stage 3 for ICSRA (draft-ietf-salud-alert-info-urns) |  | 1244d? | 2008-05-30 A | 2014-12-09 | 90% | 124.4d? | 2008-05-30 | 2014-12-05 | 1242d? | 657d | finish no earlier than 2014-12-09 | C1-IETF | 9952h | 8956.8h | ICSRA | Rel-8 | Frederic |  |  | Roland Jesske | Roland Jesske | PCG-27 | CP-52 |  |  |
| 2426 | 642.3.3 | (IETF) CT1 aspects - Stage 3 for ICSRA (RFC 6871) |  | 779d? | 2008-05-30 A | 2013-03-01 A | 100% |  | 2008-05-30 | 2013-03-01 | 779d? |  | finish no earlier than 2013-02-28 | C1-IETF | 6232h | 6232h | ICSRA | Rel-8 | Frederic |  |  | Andrew Allen |  | PCG-27 | CP-52 |  |  |
| 2427 | 642.3.4 | (IETF) CT1 aspects - Stage 3 for ICSRA (RFC 7195) |  | 1117d? | 2008-05-30 A | 2014-06-13 A | 100% |  | 2008-05-30 | 2014-06-13 | 1117d? |  | finish no earlier than 2014-06-13 | C1-IETF | 8936h | 8936h | ICSRA | Rel-8 | Frederic |  |  | Andrew Allen |  | PCG-27 | CP-52 |  |  |
| 2428 | 642.3.5 | (IETF) CT1 aspects - Stage 3 for ICSRA (RFC 7006) |  | 977d? | 2008-06-03 A | 2013-12-06 A | 100% |  | 2008-06-03 | 2013-12-06 | 977d? |  | finish no earlier than 2013-12-06 | C1-IETF | 7816h | 7816h | ICSRA | Rel-8 | Frederic |  |  | Andrew Allen |  | PCG-27 | CP-52 |  |  |
| 2429 | 642.3.6 | CT3 aspects - Stage 3 for ICSRA |  | 201d? | 2008-05-30 A | 2009-03-06 A | 100% |  | 2008-05-30 | 2009-03-06 | 201d? |  | finish no earlier than 2009-03-06 | C3 | 1608h | 1608h | ICSRA | Rel-8 | Adrian |  |  | Mavenir | Brett Wallis ( brett@mavenir.com) | PCG-21 | CP-40 |  |  |
| 2430 | 642.3.7 | CT4 aspects - Stage 3 for ICSRA |  | 136d? | 2008-05-30 A | 2008-12-05 A | 100% |  | 2008-05-30 | 2008-12-05 | 136d? |  | start no earlier than 2008-05-30 | C4 | 1088h | 1088h | ICSRA | Rel-8 | Kimmo |  |  | Ericsson | Sean Schneyer | PCG-21 | CP-40 |  |  |
| 2431 | 642.3.8 | (IETF) CT4 aspects - Stage 3 for ICSRA (RFC 7254) |  | 1034.8d? | 2005-11-01 A | 2014-06-13 A | 100% |  | 2005-11-01 | 2014-06-13 | 1034.8d? |  | finish no earlier than 2014-06-13 | C4-IETF | 8278.4h | 8278.4h | ICSRA | Rel-8 | Kimmo |  |  | Andrew Allen |  | PCG-27 | CP-52 |  |  |
| 2432 | 642.3.9 | Deleted - Stage 3 for ICSRA – I1 interface |  | 76d? | 2008-05-30 A | 2008-09-12 A | 100% |  | 2008-05-30 | 2008-09-12 | 76d? |  | finish no earlier than 2008-09-12 | C1 | 608h | 608h | ICSRA | Rel-8 | Frederic | CP-41 |  | Huawei | xupeili@huawei.com | PCG-21 | CP-40 |  | PCG-21 |

Notes:
- 2409: SP#37 stopped
- 2410: SP#37 stopped
- 2411: SP#37 stopped
- 2412: SP#37 stopped
- 2413: SP#37 stopped / Impacted TSs and TRs: 29.803
- 2414: SP#37 stopped
- 2415: SP#37 stopped
- 2416: SP#34 stopped. Replaced by UID_350027 and its children / Impacted TSs and TRs: 23.402
- 2417: SP#34 stopped. Replaced by UIDs 340018 and 340037. (SP#34 report discussion of SP-060917.) / Impacted TSs and TRs: 23.002, 23.060, 23.107, 23.203, 23.228, 23.234, 23.246, 23.271, 23.279
- 2418: SP#34 stopped
- 2419: RP#49 completed. Testing for CT1's UID_360022 (24.303) under Rel-8 Feature SAES / Impacted TSs and TRs: 36.508, 36.523-1, 36.523-2, 36.523-3
- 2420: CP#46 completed
- 2421: SP#39 completed / Impacted TSs and TRs: 22.101
- 2422: SP#40 completed / Impacted TSs and TRs: 23.292, 23.206
- 2423: CP#46 completed
- 2424: CP#46 completed / Impacted TSs and TRs: 24.229, new (24.292, 24.286)
- 2425: In RFC Editors Queue. LM: 75->90 / Impacted TSs and TRs: draft-ietf-salud-alert-info-urns
- 2426: CP#59 completed / Impacted TSs and TRs: RFC 6871 (was draft-ietf-mmusic-sdp-media-capabilities)
- 2427: CP#64 complete / Impacted TSs and TRs: RFC 7195 (was draft-ietf-mmusic-sdp-cs)
- 2428: CP#62 completed / Impacted TSs and TRs: RFC7006 (was draft-ietf-mmusic-sdp-miscellaneous-caps)
- 2429: CP#43 completed / Impacted TSs and TRs: new 29.292
- 2430: CP#42 completed / Impacted TSs and TRs: 23.003, 29.232, 23.018, 29.002
- 2431: CP#64 complete / Impacted TSs and TRs: RFC 7254 (was draft-montemurro-gsma-imei-urn)
- 2432: CP#41 work stopped / Impacted TSs and TRs: 24.293

| ID | WBS | Task | Duration | Start | Finish | Complete | Remaining | Baseline start | Baseline finish | Baseline duration | Total slack | Constraint | Resources | Work | Actual work | Acronym | Release | TSG approved | MCC resp | Acronym_3GU_Export | WI rapporteur name | WI rapporteur e-mail | PCG approved |
| --- | --- | --- | --- | --- | --- | --- | --- | --- | --- | --- | --- | --- | --- | --- | --- | --- | --- | --- | --- | --- | --- | --- | --- |
| 2433 | 643 | **IMS Multimedia Telephony and Supplementary Services** | 2002d? | 2007-05-02 A | 2014-12-09 | 98% | 39.13d? | 2007-05-02 | 2014-12-05 | 1997d? | 657d |  | S1; S5; C1; C3; C4; IETF | 272222h | 261799h | IMSTSS | Rel-8 | SP-37 | Alain | IMSTSS |  |  |  |
| 2434 | 643.1 | **General aspects of IMS Sup Services** | 395d? | 2007-09-03 A | 2009-03-06 A | 100% |  | 2007-09-03 | 2009-03-06 | 395d? |  |  | S1; C1; C3; C4 | 19232h | 19232h | IMSSS-Gal | Rel-8 | SP-37 | Alain | IMSSS-Gal | Ericsson | Susana Sabater |  |
| 2435 | 643.1.1 | Service and Capability for Core IMS - inclusion of TISPAN requirements | 75d? | 2007-09-03 A | 2007-12-14 A | 100% |  | 2007-09-03 | 2007-12-14 | 75d? |  | finish no earlier than 2007-12-14 | S1 | 600h | 600h | TISCAPR8 | Rel-8 | SP-37 | Alain | TISCAPR8 | Ericsson | Susana Sabater |  |
| 2436 | 643.1.2 | Documentation of TISPAN R1 and R2 in CT1 | 208d? | 2007-11-28 A | 2008-09-12 A | 100% |  | 2007-11-28 | 2008-09-12 | 208d? |  | finish no earlier than 2008-09-12 | C1 | 1664h | 1664h | REDOC_TIS-C1 | Rel-8 | CP-38 | Frederic | REDOC_TIS-C1 | Nokia Siemens Networks | peter.leis@nsn.com | PCG-21 |
| 2437 | 643.1.3 | Documentation of TISPAN R1 and R2 in CT3 | 333d? | 2007-11-28 A | 2009-03-06 A | 100% |  | 2007-11-28 | 2009-03-06 | 333d? |  | finish no earlier than 2009-03-06 | C3 | 2664h | 2664h | REDOC_TIS-C3 | Rel-8 | CP-38 | Adrian | REDOC_TIS-C3 | Nokia Siemens Networks | peter.leis@nsn.com | PCG-21 |
| 2438 | 643.1.4 | Documentation of TISPAN R1 and R2 in CT4 | 208d? | 2007-11-28 A | 2008-09-12 A | 100% |  | 2007-11-28 | 2008-09-12 | 208d? |  | finish no earlier than 2008-09-12 | C4 | 1664h | 1664h | REDOC_TIS-C4 | Rel-8 | CP-38 | Kimmo | REDOC_TIS-C4 | Nokia Siemens Networks | peter.leis@nsn.com | PCG-21 |
| 2439 | 643.2 | **IMS Multimedia Telephony Service** | 394d? | 2007-09-10 A | 2009-03-12 A | 100% |  | 2007-09-10 | 2009-03-12 | 394d? |  |  | S1; S5 | 9296h | 9296h | IMS-MMTel | Rel-8 | SP-37 | Alain | IMS-MMTel |  |  |  |
| 2440 | 643.2.1 | Merging TISPAN MMTel [requirements] for Common IMS | 65d? | 2007-09-10 A | 2007-12-07 A | 100% |  | 2007-09-10 | 2007-12-07 | 65d? |  | finish no earlier than 2007-12-07 | S1 | 520h | 520h | TMMTEL | Rel-8 | SP-37 | Alain | TMMTEL | Nokia Siemens Networks |  |  |
| 2441 | 643.2.2 | Multimedia Telephony Service and Supplementary Services (MMTel) offline Charging | 309d? | 2008-01-07 A | 2009-03-12 A | 100% |  | 2008-01-07 | 2009-03-12 | 309d? |  | finish no earlier than 2009-03-12 | S5 | 2472h | 2472h | MMTel-CH | Rel-8 | SP-38 | Mirko | MMTel-CH | Alcatel-Lucent | maryse.gardella@alcatel-lucent.com | PCG-21 |
| 2442 | 643.3 | **Call Completion on Busy Subscriber (CCBS)/Call Completion on Non-Reachable (CCNR) on IMS** | 1608d? | 2007-05-02 A | 2013-06-14 A | 100% |  | 2007-05-02 | 2013-06-14 | 1608d? |  |  | C1; C3; IETF | 71528h | 71528h | CCBS_CCNR | Rel-8 | SP-38 | Frederic | CCBS_CCNR | Deutsche Telekom | martin.huelsemann@telekom.de | PCG-21 |
| 2443 | 643.3.1 | CT1 part of Stage 3 CCBS_CCNR | 483d? | 2007-05-02 A | 2009-03-06 A | 100% |  | 2007-05-02 | 2009-03-06 | 483d? |  | finish no earlier than 2009-03-06 | C1 | 3864h | 3864h | CCBS_CCNR | Rel-8 | CP-38 | Frederic |  | Deutsche Telekom | martin.huelsemann@telekom.de | PCG-21 |
| 2444 | 643.3.2 | CT3 part of Stage 3 CCBS_CCNR | 418d? | 2007-05-02 A | 2008-12-05 A | 100% |  | 2007-05-02 | 2008-12-05 | 418d? |  | finish no earlier than 2008-12-05 | C3 | 3344h | 3344h | CCBS_CCNR | Rel-8 | CP-38 | Adrian |  | Deutsche Telekom | martin.huelsemann@telekom.de | PCG-21 |
| 2445 | 643.3.3 | (IETF) Stage 3 CCBS_CCNR [RFC 6910 (was draft-ietf-bliss-call-completion)] | 1608d? | 2007-05-02 A | 2013-06-14 A | 100% |  | 2007-05-02 | 2013-06-14 | 1608d? |  | finish no earlier than 2013-06-10 | C1-IETF; C3-IETF | 25728h | 25728h | CCBS_CCNR | Rel-8 | CP-52 | Frederic |  | Roland Jesske |  | PCG-27 |
| 2446 | 643.4 | **Flexible Alerting** | 288d? | 2008-01-30 A | 2009-03-06 A | 100% |  | 2008-01-30 | 2009-03-06 | 288d? |  |  | S1; C1 | 7582.4h | 7582.4h | FA | Rel-8 | SP-39 | Alain | FA | Nortel | milanpa@nortel.com | PCG-21 |
| 2447 | 643.4.1 | Stage 1 FA | 92d? | 2008-01-30 A | 2008-06-05 A | 100% |  | 2008-01-30 | 2008-06-05 | 92d? |  |  | S1 | 670.4h | 670.4h | FA | Rel-8 | SP-39 | Alain |  | Telecom Italia |  | PCG-21 |
| 2448 | 643.4.2 | Stage 3 FA | 288d? | 2008-01-30 A | 2009-03-06 A | 100% |  | 2008-01-30 | 2009-03-06 | 288d? |  | finish no earlier than 2009-03-06 | C1 | 2304h | 2304h | FA | Rel-8 | CP-39 | Frederic |  | Nortel | milanpa@nortel.com | PCG-21 |
| 2449 | 643.5 | **Communication Wait on IMS** | 1965d? | 2007-06-22 A | 2014-12-09 | 93% | 132.85d? | 2007-06-22 | 2014-12-05 | 1960d? | 657d |  | C1; C3; IETF | 61880h | 57696.4h | CW_IMS | Rel-8 | SP-38 | Frederic | CW_IMS | Deutsche Telekom | martin.huelsemann@telekom.de | PCG-21 |
| 2450 | 643.5.1 | CT1 part of Stage 3 CW-IMS | 331d? | 2007-11-30 A | 2009-03-06 A | 100% |  | 2007-11-30 | 2009-03-06 | 331d? |  | finish no earlier than 2009-03-06 | C1 | 2648h | 2648h | CW_IMS | Rel-8 | CP-38 | Frederic |  | Deutsche Telekom | martin.huelsemann@telekom.de | PCG-21 |
| 2451 | 643.5.2 | (IETF) Stage 3 CW-IMS (salud-alert-info-urns) | 1244d? | 2007-06-22 A | 2014-12-09 | 90% | 124.4d? | 2007-06-22 | 2014-12-05 | 1242d? | 657d | finish no earlier than 2014-12-09 | C1-IETF | 9952h | 8956.8h | CW_IMS | Rel-8 | CP-52 | Frederic |  | Roland Jesske | Roland Jesske | PCG-27 |
| 2452 | 643.5.3 | CT3 part of Stage 3 CW-IMS | 265d? | 2007-11-30 A | 2008-12-04 A | 100% |  | 2007-11-30 | 2008-12-04 | 265d? |  | finish no earlier than 2008-12-05 | C3 | 2120h | 2120h | CW_IMS | Rel-8 | CP-38 | Adrian |  | Deutsche Telekom | martin.huelsemann@telekom.de | PCG-21 |
| 2453 | 643.6 | **IMS Charging** | 389d? | 2007-09-17 A | 2009-03-12 A | 100% |  | 2007-09-17 | 2009-03-12 | 389d? |  |  | S5 | 6608h | 6608h | CH8 | Rel-8 | SP-37 | Mirko | CH8 | Alcatel-Lucent | maryse.gardella@alcatel-lucent.com |  |
| 2454 | 643.6.1 | Add Interconnection Border Control Function (IBCF) to IMS Charging | 128d? | 2007-09-17 A | 2008-03-12 A | 100% |  | 2007-09-17 | 2008-03-12 | 128d? |  | finish no earlier than 2008-03-12 | S5 | 1024h | 1024h | CH8 | Rel-8 | SP-37 | Mirko |  | Alcatel-Lucent | maryse.gardella@alcatel-lucent.com |  |
| 2455 | 643.6.2 | Advice of Charge (AoC) support in IMS Charging | 309d? | 2008-01-07 A | 2009-03-12 A | 100% |  | 2008-01-07 | 2009-03-12 | 309d? |  | finish no earlier than 2009-03-12 | S5 | 2472h | 2472h | CH8 | Rel-8 | SP-38 | Mirko |  | Nokia Siemens Networks | Gerald.Goermer@nsn.com | PCG-21 |
| 2456 | 644 | **3GPP2 Input to Common IMS** | 200d? | 2008-03-07 A | 2008-12-11 A | 100% |  | 2008-03-07 | 2008-12-11 | 200d? |  |  | S1; S2; S3; C1; C3; C4 | 21453.2h | 21453.2h | CIMS_3GPP2, IMS_Common | Rel-8 | SP-39 | Alain | CIMS_3GPP2, IMS_Common | Nortel | Amar Deol (deola@nortelnetworks.com) | PCG-21 |
| 2457 | 644.1 | Stage 1 CIMS_3GPP2 | 30.65d? | 2008-03-12 A | 2008-06-05 A | 100% |  | 2008-03-12 | 2008-06-05 | 30.65d? |  | finish no earlier than 2008-06-12 | S1 | 245.2h | 245.2h | CIMS_3GPP2, IMS_Common | Rel-8 | SP-39 | Alain |  | Nortel | Amar Deol (deola@nortelnetworks.com) | PCG-21 |
| 2458 | 644.2 | Stage 2 CIMS_3GPP2 | 62d? | 2008-03-12 A | 2008-06-05 A | 100% |  | 2008-03-12 | 2008-06-05 | 62d? |  | finish no earlier than 2008-09-11 | S2 | 496h | 496h | CIMS_3GPP2, IMS_Common | Rel-8 | SP-39 | Maurice |  | Nortel | Amar Deol (deola@nortelnetworks.com) | PCG-21 |
| 2459 | 644.3 | Security CIMS_3GPP2 | 197d? | 2008-03-12 A | 2008-12-11 A | 100% |  | 2008-03-12 | 2008-12-11 | 197d? |  | finish no earlier than 2008-12-11 | S3 | 1576h | 1576h | CIMS_3GPP2, IMS_Common | Rel-8 | SP-39 | Mirko |  | Nortel | Amar Deol (deola@nortelnetworks.com) | PCG-21 |

Notes:
- 2433: SP#43 completed
- 2434: CP#43 completed
- 2435: SP#39 completed / Impacted TSs and TRs: 22.228, 22.115, 22.101
- 2436: CP#41 completed / Impacted TSs and TRs: 24.141, 24.147, 24.173, 24.229, 24.247, 24.341, 24.604, 24.605, 24.606, 24.607, 24.608, 24.610, 24.611, 24.616, 24.623, 24.628, 24.629, 24.647, 24.654
- 2437: CP#43 completed / Impacted TSs and TRs: 29.162, 29.163, 29.658
- 2438: CP#41 completed / Impacted TSs and TRs: 29.228, 29.229
- 2439: SP#43 completed
- 2440: SP#38 completed / Impacted TSs and TRs: 22.173
- 2441: CP#43 completed / Impacted TSs and TRs: 32.275, 32.298/299
- 2442: CP#43 completed
- 2443: CP#43 completed / Impacted TSs and TRs: 24.642, 24.229, 24.173
- 2444: CP#42 completed / Impacted TSs and TRs: 29.163
- 2445: CP#60 completed / Impacted TSs and TRs: RFC 6910 (was draft-ietf-bliss-call-completion)
- 2446: CP#43 completed
- 2447: SP#40 completed / Impacted TSs and TRs: 22.173
- 2448: CP#43 completed / Impacted TSs and TRs: 24.239, 24.173
- 2449: CP#43 completed
- 2450: CP#43 completed / Impacted TSs and TRs: 24.615, 24.229, 24.173
- 2451: In RFC Editors Queue. LM: 75->90 / Impacted TSs and TRs: draft-ietf-salud-alert-info-urns
- 2452: CP#42 completed / Impacted TSs and TRs: 29.163
- 2453: SP#39 completed / Impacted TSs and TRs: 32.260, 32.298
- 2454: SP#39 completed / Impacted TSs and TRs: 32.260, 32.298
- 2455: SP#43 completed / Impacted TSs and TRs: 32.240, 32.260, 32.296, 32.298, 32.299, new 32.280
- 2456: TSG#42 completed
- 2457: SP#40 completed / Impacted TSs and TRs: 22.228, 22.173, 22.101, 22.153
- 2458: SP#40 completed / Impacted TSs and TRs: 23.002, 23.141, 23.203, 23.167, 23.228
- 2459: SP#42 completed [issues addressed under UID_370078 (IMS-Sec)] / Impacted TSs and TRs: 33.141, 33.203, 33.210

| ID | WBS | Task | Duration | Start | Finish | Complete | Baseline start | Baseline finish | Baseline duration | Constraint | Resources | Work | Actual work | Acronym | PCG approved | WI rapporteur name | WI rapporteur e-mail | Release | TSG approved | MCC resp | Acronym_3GU_Export |
| --- | --- | --- | --- | --- | --- | --- | --- | --- | --- | --- | --- | --- | --- | --- | --- | --- | --- | --- | --- | --- | --- |
| 2460 | 644.4 | **Stage 3 CIMS_3GPP2** | 200d? | 2008-03-07 A | 2008-12-11 A | 100% | 2008-03-07 | 2008-12-11 | 200d? |  | C1; C3; C4 | 9536h | 9536h | REDOC_3GPP2 | PCG-21 | Alcatel-Lucent | orsic@alcatel-lucent.com | Rel-8 | CP-39 | Frederic | REDOC_3GPP2 |
| 2461 | 644.4.1 | Stage 3 CIMS_3GPP2 (CT1) | 196d? | 2008-03-07 A | 2008-12-05 A | 100% | 2008-03-07 | 2008-12-05 | 196d? | finish no earlier than 2008-12-11 | C1 | 1568h | 1568h | REDOC_3GPP2 | PCG-21 | Alcatel-Lucent | orsic@alcatel-lucent.com | Rel-8 | CP-39 | Frederic |  |
| 2462 | 644.4.2 | Stage 3 CIMS_3GPP2 (CT3) | 196d? | 2008-03-07 A | 2008-12-05 A | 100% | 2008-03-07 | 2008-12-05 | 196d? | finish no earlier than 2008-12-05 | C3 | 1568h | 1568h | REDOC_3GPP2 | PCG-21 | Alcatel-Lucent | orsic@alcatel-lucent.com | Rel-8 | CP-39 | Adrian |  |
| 2463 | 644.4.3 | Stage 3 CIMS_3GPP2 (CT4) | 200d? | 2008-03-07 A | 2008-12-11 A | 100% | 2008-03-07 | 2008-12-11 | 200d? | finish no earlier than 2008-12-11 | C4 | 1600h | 1600h | REDOC_3GPP2 | PCG-21 | Alcatel-Lucent | orsic@alcatel-lucent.com | Rel-8 | CP-39 | Kimmo |  |
| 2464 | 645 | **IMS Enhancements for support of Packet Cable access** | 388d? | 2006-12-06 A | 2008-05-30 A | 100% | 2006-12-06 | 2008-05-30 | 388d? |  | S2; S3; C1; C3; C4 | 58616h | 58616h | PktCbl |  | Cablelabs | Bernie McKibben (b.mckibben@cablelabs.com) | Rel-8 |  | Maurice | PktCbl |
| 2465 | 645.1 | **IMS Enhancements for Cable Client Types and Deployment Models** | 345d? | 2007-02-05 A | 2008-05-30 A | 100% | 2007-02-05 | 2008-05-30 | 345d? |  | S2; C1 | 9752h | 9752h | PktCbl-Deploy |  | Cablelabs | Bernie McKibben (b.mckibben@cablelabs.com) | Rel-8 |  | Maurice | PktCbl-Deploy |
| 2466 | 645.1.1 | Architecture aspects of PktCbl-Deploy | 219d? | 2007-02-05 A | 2007-12-06 A | 100% | 2007-02-05 | 2007-12-06 | 219d? | finish no earlier than 2007-12-03 | S2 | 1752h | 1752h | PktCbl-Deploy |  | Cablelabs | Bernie McKibben (b.mckibben@cablelabs.com) | Rel-8 |  | Maurice |  |
| 2467 | 645.1.2 | CT1 aspects of PktCbl-Deploy | 310d? | 2007-03-26 A | 2008-05-30 A | 100% | 2007-03-26 | 2008-05-30 | 310d? | finish no earlier than 2008-06-15 | C1 | 2480h | 2480h | PktCbl-Deploy |  | Cablelabs | D.Hancock@CableLabs.com | Rel-8 |  | Frederic |  |
| 2468 | 645.2 | **IMS Inter-working aspects in Support of Cable Regulatory requirements** | 290d? | 2007-02-05 A | 2008-03-14 A | 100% | 2007-02-05 | 2008-03-14 | 290d? |  | S2; C1; C3 | 12320h | 12320h | PktCbl-Intw |  | Cablelabs | B.McKibben@CableLabs.com | Rel-8 |  | Maurice | PktCbl-Intw |
| 2469 | 645.2.1 | Architecture aspects of PktCbl-Interwork | 160d? | 2007-02-05 A | 2007-09-14 A | 100% | 2007-02-05 | 2007-09-14 | 160d? | start no earlier than 2007-02-05 | S2 | 1280h | 1280h | PktCbl-Intw |  | Cablelabs | B.McKibben@CableLabs.com | Rel-8 |  | Maurice |  |
| 2470 | 645.2.2 | CT1,CT3 aspects of PktCbl-Interwork | 255d? | 2007-03-26 A | 2008-03-14 A | 100% | 2007-03-26 | 2008-03-14 | 255d? | finish no earlier than 2008-03-15 | C1; C3 | 4080h | 4080h | PktCbl-Intw |  | Cablelabs | D.Hancock@CableLabs.com | Rel-8 |  | Frederic |  |
| 2471 | 645.3 | **IMS Enhancements for Security Requirements in Support of Cable Deployments** | 388d? | 2006-12-06 A | 2008-05-30 A | 100% | 2006-12-06 | 2008-05-30 | 388d? |  | S3; C1; C3; C4 | 21024h | 21024h | PktCbl-Sec |  | Cablelabs | s.dotson@cablelabs.com | Rel-8 |  | Mirko | PktCbl-Sec |
| 2472 | 645.3.1 | SA3 aspects of PktCbl-Sec | 331d? | 2006-12-06 A | 2008-03-12 A | 100% | 2006-12-06 | 2008-03-12 | 331d? | finish no earlier than 2007-12-20 | S3 | 2648h | 2648h | PktCbl-Sec |  | Cablelabs | s.dotson@cablelabs.com | Rel-8 |  | Mirko |  |
| 2473 | 645.3.2 | CT1 aspects of PktCbl-Sec | 310d? | 2007-03-26 A | 2008-05-30 A | 100% | 2007-03-26 | 2008-05-30 | 310d? | finish no earlier than 2008-06-06 | C1 | 2480h | 2480h | PktCbl-Sec |  | Cablelabs | D.Hancock@CableLabs.com | Rel-8 |  | Frederic |  |
| 2474 | 645.3.3 | CT3 aspects of PktCbl-Sec | 180d? | 2007-03-26 A | 2007-11-30 A | 100% | 2007-03-26 | 2007-11-30 | 180d? | finish no earlier than 2008-03-15 | C3 | 1440h | 1440h | PktCbl-Sec | PCG-21 | Cablelabs | D.Hancock@CableLabs.com | Rel-8 | CP-38 | Adrian |  |
| 2475 | 645.3.4 | CT4 aspects of PktCbl-Sec | 255d? | 2007-03-26 A | 2008-03-14 A | 100% | 2007-03-26 | 2008-03-14 | 255d? | finish no earlier than 2008-03-14 | C4 | 2040h | 2040h | PktCbl-Sec |  | Cablelabs | D.Hancock@CableLabs.com | Rel-8 |  | Kimmo |  |
| 2476 | 646 | **IMS System enhancements for corporate network access** | 1901d? | 2007-06-22 A | 2014-09-12 A | 100% | 2007-06-22 | 2014-12-05 | 1960d? |  | S2; S1; C1; C4; IETF | 91240.9h | 91240.9h | IMS_Corp |  | Orange | Delphin Barankanira | Rel-8 |  | Maurice | IMS_Corp |
| 2477 | 646.1 | SA1 aspects of IMS_Corp | 23.6d? | 2008-03-12 A | 2008-06-05 A | 100% | 2008-03-12 | 2008-06-05 | 23.6d? | finish no earlier than 2008-06-05 | S1 | 188.8h | 188.8h | IMS_Corp | PCG-21 | Telecom Italia |  | Rel-8 | SP-39 | Alain |  |
| 2478 | 646.2 | SA2 aspects of IMS_Corp | 325d? | 2007-06-22 A | 2008-09-18 A | 100% | 2007-06-22 | 2008-09-18 | 325d? | finish no earlier than 2008-12-25 | S2 | 2600h | 2600h | IMS_Corp |  | Orange | Delphin Barankanira | Rel-8 |  | Maurice |  |
| 2479 | 646.3 | CT1 aspects of IMS_Corp | 532d? | 2008-03-07 A | 2010-03-19 A | 100% | 2008-03-07 | 2010-03-19 | 532d? | finish no earlier than 2010-03-19 | C1 | 4244.09h | 4244.09h | IMS_Corp | PCG-21 | Alcatel-Lucent | Keith Drage (drage@alcatel-lucent.com) | Rel-8 | CP-39 | Frederic |  |
| 2480 | 646.4 | (IETF) CT1 aspects of IMS_Corp (RFC 7316) | 825d? | 2011-06-29 A | 2014-09-12 A | 100% | 2011-06-29 | 2014-12-05 | 885d? | finish no earlier than 2014-09-12 | C1-IETF | 6600h | 6600h | IMS_Corp | PCG-27 | Keith Drage | Keith Drage (drage@alcatel-lucent.com) | Rel-8 | CP-53 | Frederic |  |
| 2481 | 646.5 | CT4 aspects of IMS_Corp | 196d? | 2008-02-26 A | 2008-12-05 A | 100% | 2008-02-26 | 2008-12-05 | 196d? | finish no earlier than 2008-12-11 | C4 | 1568h | 1568h | IMS_Corp | PCG-21 | Alcatel-Lucent | Keith Drage (drage@alcatel-lucent.com) | Rel-8 | CP-39 | Kimmo |  |
| 2482 | 647 | **Maintenance of TISPAN documentation** | 1829d? | 2007-07-02 A | 2014-06-13 A | 100% | 2007-07-02 | 2014-06-13 | 1829d? |  | S2; C1; C3; C4; IETF | 85904h | 85904h | MAINTISP | PCG-21 |  |  | Rel-8 | SP-38 | Maurice | MAINTISP |
| 2483 | 647.1 | Maintenance of TISPAN R2 | 86d? | 2007-11-09 A | 2008-03-07 A | 100% | 2007-11-09 | 2008-03-07 | 86d? | start no earlier than 2007-11-09 | C1; C3; C4 | 2064h | 2064h | MAINT_R2 | PCG-21 | Alcatel-Lucent | Keith Drage (drage@alcatel-lucent.com) | Rel-8 | CP-38 | Frederic | MAINT_R2 |
| 2484 | 647.2 | Deleted - (IETF) Maintenance of TISPAN R2 (avasarala-dispatch-comm-div-notification) | 1117d? | 2007-11-09 A | 2014-06-13 A | 100% | 2007-11-09 | 2014-06-13 | 1117d? | finish no earlier than 2014-06-13 | C1-IETF | 8936h | 8936h | MAINT_R2_IETF | PCG-27 | Andrew Allen |  | Rel-8 | CP-52 | Frederic | MAINT_R2_IETF |
| 2485 | 647.3 | Documentation of TISPAN NGN R1 and R2 in 3GPP SA2 | 104d? | 2008-01-14 A | 2008-06-05 A | 100% | 2008-01-14 | 2008-06-05 | 104d? | finish no earlier than 2008-06-20 | S2 | 832h | 832h | IMS_Comm_Doc | PCG-21 | Nokia Siemens Networks | jozsef.varga@nsn.com | Rel-8 | SP-38 | Maurice | IMS_Comm_Doc |
| 2486 | 647.4 | Maintenance of TISPAN release 2 common IMS | 114d? | 2007-07-02 A | 2007-12-06 A | 100% | 2007-07-02 | 2007-12-06 | 114d? | finish no earlier than 2007-12-06 | S2 | 912h | 912h | IMS_Comm_Mtce8 | PCG-21 | Telecom Italia | antonio.ascolese@telecomitalia.it | Rel-8 | SP-38 | Maurice | IMS_Comm_Mtce8 |

Notes:
- 2460: -
- 2461: CP#42 completed / Impacted TSs and TRs: 23.218, 24.141, 24.147, 24.173, 24.229, 24.238, 24.247, 24.604, 24.605, 24.606, 24.607, 24.608, 24.610, 24.611, 24.629, 24.930
- 2462: CP#42 completed / Impacted TSs and TRs: 29.163, 29.212, 29.213, 29.214
- 2463: CP#42 completed / Impacted TSs and TRs: 29.228, 29.229, 29.328, 29.329
- 2464: CP#40 completed
- 2465: CP#40 completed
- 2466: SP#38 completed / Impacted TSs and TRs: 23.228
- 2467: CP#40 completed
- 2468: CP#39 completed
- 2469: SP#37 completed / Impacted TSs and TRs: 23.228
- 2470: CP#39 completed / Impacted TSs and TRs: 24.229
- 2471: CP#40 completed
- 2472: SP#39 completed / Impacted TSs and TRs: 33.203, 33.210, 33.220
- 2473: CP#40 completed / Impacted TSs and TRs: 24.229
- 2474: CP#38 completed / Impacted TSs and TRs: 29.163
- 2475: CP#39 completed / Impacted TSs and TRs: 29.228, 29.229, 23.008
- 2476: CP#47 completed
- 2477: SP#40 completed
- 2478: no Stage 2 impacts / Impacted TSs and TRs: 23.228
- 2479: CP#47 completed / Impacted TSs and TRs: 24.229, 24.503
- 2480: CP#65 completed / Impacted TSs and TRs: RFC 7316 (was draft-vanelburg-dispatch-private-network-ind)
- 2481: CP#42 completed / Impacted TSs and TRs: 29.228, 29.229, 23.003, 23.008, 29.433
- 2482: SP#40 completed
- 2483: CP#39 completed / Impacted TSs and TRs: 24.406, 24.407, 24.410, 24.411, 24.423, 24.430, 24.447, 24.451, 24.454, 24.503, 24.505, 24.508, 24.516, 24.528, 24.529, 29.412, 29.421, 29.433, 29.458, 29.527, 29.624
- 2484: CP#64 Draft removed from 3GPP documentation / Impacted TSs and TRs: draft-avasarala-dispatch-comm-div-notification
- 2485: SP#40 completed / Impacted TSs and TRs: 23.228, 23.204, 23.167
- 2486: SP#38 completed / Impacted TSs and TRs: 23.506, 23.507,23.517, 23.521

| ID | WBS | Task | Type | Duration | Start | Finish | Complete | Remaining | Baseline start | Baseline finish | Baseline duration | Total slack | Constraint | Resources | Work | Actual work | Acronym | PCG approved | WI rapporteur name | WI rapporteur e-mail | Release | TSG approved | MCC resp | Acronym_3GU_Export | Impacted TSs and TRs |
| --- | --- | --- | --- | --- | --- | --- | --- | --- | --- | --- | --- | --- | --- | --- | --- | --- | --- | --- | --- | --- | --- | --- | --- | --- | --- |
| 2487 | 648 | **IMS Service Continuity** |  | 318d? | 2008-03-12 A | 2009-05-29 A | 100% |  | 2008-03-12 | 2009-05-29 | 318d? |  |  | S2; S1; C1 | 10712h | 10712h | IMS-Cont | PCG-21 | LG Electronics | JaeSeung SONG (anthonys@lge.com) | Rel-8 | SP-39 | Maurice | IMS-Cont |  |
| 2488 | 648.1 | Stage 1 IMS Service Continuity |  | 62d? | 2008-03-12 A | 2008-06-05 A | 100% |  | 2008-03-12 | 2008-06-05 | 62d? |  | start no earlier than 2008-03-12 | S1 | 496h | 496h | IMS-Cont | PCG-21 | LG Electronics | JaeSeung SONG (anthonys@lge.com) | Rel-8 | SP-39 | Alain |  |  |
| 2489 | 648.2 | Stage 2 IMS Service Continuity |  | 62d? | 2008-03-12 A | 2008-06-05 A | 100% |  | 2008-03-12 | 2008-06-05 | 62d? |  | finish no earlier than 2008-06-05 | S2 | 496h | 496h | IMS-Cont | PCG-21 | LG Electronics | JaeSeung SONG (anthonys@lge.com) | Rel-8 | SP-39 | Maurice |  | 23.237, 23.292 |
| 2490 | 648.3 | Stage 3 IMS Service Continuity |  | 261d? | 2008-05-30 A | 2009-05-29 A | 100% |  | 2008-05-30 | 2009-05-29 | 261d? |  | finish no earlier than 2009-05-29 | C1 | 2088h | 2088h | IMS-Cont | PCG-21 | Huawei | Lili Yang (kadyyang@huawei.com) | Rel-8 | CP-40 | Frederic |  | 24.237, 24.229, 24.216 |
| 2491 | 649 | **Security Enhancements for IMS** |  | 643.3d? | 2006-09-19 A | 2009-03-06 A | 100% |  | 2006-09-19 | 2009-03-06 | 643.3d? |  |  | S3; C1; C4 | 29847.2h | 29847.2h | IMS-Sec |  | Ericsson | Bengt.Sahlin@ericsson.com | Rel-8 | SP-37 | Mirko | IMS-Sec |  |
| 2492 | 649.1 | Stage 2 for IMS-Sec |  | 466d? | 2007-03-01 A | 2008-12-11 A | 100% |  | 2007-03-01 | 2008-12-11 | 466d? |  | finish no earlier than 2008-12-11 | S3 | 3728h | 3728h | IMS-Sec |  | Ericsson | Bengt.Sahlin@ericsson.com | Rel-8 |  | Mirko |  | 33.203, 33.141, 33.803 |
| 2493 | 649.2 | CT1 part of Stage 3 for IMS-Sec |  | 392d? | 2006-09-19 A | 2008-12-05 A | 100% |  | 2006-09-19 | 2008-12-05 | 392d? |  | finish no earlier than 2008-12-05 | C1 | 3136h | 3136h | IMS-Sec | PCG-21 | Ericsson |  | Rel-8 | CP-39 | Frederic |  |  |
| 2494 | 649.3 | CT4 part of Stage 3 for IMS-Sec |  | 457d? | 2007-06-07 A | 2009-03-06 A | 100% |  | 2007-06-07 | 2009-03-06 | 457d? |  | finish no earlier than 2009-03-06 | C4 | 3656h | 3656h | IMS-Sec | PCG-21 | Ericsson |  | Rel-8 | CP-39 | Kimmo |  |  |
| 2495 | 649.4 | CT1 part of Network Attachment Subsystem (NASS) Bundled Authentication |  | 343d? | 2007-11-14 A | 2009-03-06 A | 100% |  | 2007-11-14 | 2009-03-06 | 343d? |  | finish no earlier than 2009-03-06 | C1 | 2744h | 2744h | NBA | PCG-21 | Alcatel-Lucent | Keith Drage (drage@alcatel-lucent.com) | Rel-8 | CP-39 | Frederic | NBA | 24.229 |
| 2496 | 649.5 | CT4 part of Network Attachment Subsystem (NASS) Bundled Authentication |  | 143d? | 2007-11-14 A | 2008-05-30 A | 100% |  | 2007-11-14 | 2008-05-30 | 143d? |  | start no earlier than 2007-11-14 | C4 | 1144h | 1144h | NBA-CT4 | PCG-21 | Alcatel-Lucent |  | Rel-8 | CP-39 | Kimmo | NBA-CT4 | 29.229, 29.228, 23.008 |
| 2497 | 650 | **IMS initiated and controlled PSS and MBMS User Service** |  | 924d? | 2008-03-12 A | 2011-09-21 A | 100% |  | 2008-03-12 | 2011-09-21 | 924d? |  |  | S4; S3; IETF | 28108.8h | 28108.8h | IMS_PSS_MBMS_US |  | FT, Ericsson | olle.franceschi@ericsson.com | Rel-8 |  | Paolo | IMS_PSS_MBMS_US |  |
| 2498 | 650.1 | SA4, SA3 part of IMS initiated and controlled PSS and MBMS User Service | milestone | 0d? | 2008-03-12 A | 2008-03-12 A | 100% |  | 2008-03-12 | 2008-03-12 | 0d? |  | finish no earlier than 2009-03-12 | S4; S3 |  |  | IMS_PSS_MBMS_US |  | FT, Ericsson | olle.franceschi@ericsson.com | Rel-8 |  | Paolo |  | 26.234, 26.346, 33.246, New 26.237 |
| 2499 | 650.2 | (IETF) IMS initiated and controlled PSS and MBMS User Service (RFC 6080) |  | 743.6d? | 2008-03-12 A | 2011-09-21 A | 100% |  | 2008-03-12 | 2011-09-21 | 743.6d? |  | finish no earlier than 2011-09-21 | S4-IETF | 5932.8h | 5932.8h | IMS_PSS_MBMS_US | PCG-27 | Ericsson |  | Rel-8 | SP-52 | Paolo |  | RFC 6080 (was draft-ietf-sipping-config-framework) |
| 2500 | 651 | **Multimedia interworking between IMS and CS networks** |  | 836d? | 2005-09-23 A | 2008-12-05 A | 100% |  | 2005-09-23 | 2008-12-05 | 836d? |  |  | C3; C4 | 22800h | 22800h | MIW-IMS |  | Vodafone | nico.gabriele@vodafone.com | Rel-8 |  | Adrian | MIW-IMS |  |
| 2501 | 651.1 | Stage 1 and 2 defined in earlier Releases |  | 49d? | 2005-09-23 A | 2005-11-30 A | 100% |  | 2005-09-23 | 2005-11-30 | 49d? |  | start no earlier than 2005-09-23 | S2 | 392h | 392h | MIW-IMS |  | Vodafone | nico.gabriele@vodafone.com | Rel-8 |  | Maurice |  |  |
| 2502 | 651.2 | Stage 3 of MW-IMS |  | 571d? | 2005-09-23 A | 2007-11-30 A | 100% |  | 2005-09-23 | 2007-11-30 | 571d? |  | finish no earlier than 2007-09-14 | C3 | 4568h | 4568h | MIW-IMS-St3 |  | Vodafone | nico.gabriele@vodafone.com | Rel-8 |  | Adrian | MIW-IMS-St3 | 29.863, 29.163 |
| 2503 | 651.3 | Stage 3 for MW-IMS, MONA extension |  | 285d? | 2007-11-05 A | 2008-12-05 A | 100% |  | 2007-11-05 | 2008-12-05 | 285d? |  | finish no earlier than 2008-12-05 | C3 | 2280h | 2280h | MIW-IMS-St3 | PCG-21 | Vodafone | Christer.Holmberg@ericsson.com | Rel-8 | CP-38 | Adrian |  | 29.863, 29.163 |
| 2504 | 651.4 | Mn interface (MGCF – IM MGW) |  | 273d? | 2007-11-21 A | 2008-12-05 A | 100% |  | 2007-11-21 | 2008-12-05 | 273d? |  | finish no earlier than 2008-12-19 | C4 | 2184h | 2184h | MIW-IMS-St3 | PCG-21 | Vodafone | Christer.Holmberg@ericsson.com | Rel-8 | CP-38 | Kimmo |  | 29.332 |
| 2505 | 652 | **IMS Stage 3 IETF Protocol Alignment - phase 2** |  | 1965d? | 2007-06-22 A | 2014-12-09 | 96% | 81.7d? | 2007-06-22 | 2014-12-05 | 1960d? | 657d |  | C1; IETF | 55368h | 30068.8h | IMSProtoc2 |  | Alcatel-Lucent | Keith Drage (drage@alcatel-lucent.com) | Rel-8 |  | Frederic | IMSProtoc2 |  |
| 2506 | 652.1 | CT1 aspects of IMS Stage 3 IETF Protocol Alignment - phase 2 |  | 446d? | 2007-06-22 A | 2009-03-06 A | 100% |  | 2007-06-22 | 2009-03-06 | 446d? |  | finish no earlier than 2009-03-06 | C1 | 3568h | 3568h | IMSProtoc2 |  | Alcatel-Lucent | Keith Drage (drage@alcatel-lucent.com) | Rel-8 |  | Frederic |  | 23.218, 24.229, 24.930 |
| 2507 | 652.2 | (IETF) IMS Stage 3 IETF Protocol Alignment (draft-bakker-sipping-3gpp-ims-xml-body-handling) |  | 715d? | 2007-06-22 A | 2012-12-07 A | 100% |  | 2007-06-22 | 2012-12-07 | 715d? |  | finish no earlier than 2012-12-07 | C1-IETF | 5720h | 5720h | IMSProtoc2 | PCG-27 | Andrew Allen |  | Rel-8 | CP-52 | Frederic |  | draft-bakker-sipping-3gpp-ims-xml-body-handling |
| 2508 | 652.3 | (IETF) IMS Stage 3 IETF Protocol Alignment (RFC 6544) |  | 587d? | 2007-06-22 A | 2012-06-15 A | 100% |  | 2007-06-22 | 2012-06-15 | 587d? |  | finish no earlier than 2012-04-20 | C1-IETF | 4688h | 4688h | IMSProtoc2 | PCG-27 | Keith Drage |  | Rel-8 | CP-52 | Frederic |  | RFC 6544 (was draft-ietf-mmusic-ice-tcp) |
| 2509 | 652.4 | (IETF) IMS Stage 3 IETF Protocol Alignment (draft-ietf-salud-alert-info-urns) |  | 1244d? | 2007-06-22 A | 2014-12-09 | 90% | 124.4d? | 2007-06-22 | 2014-12-05 | 1242d? | 657d | finish no earlier than 2014-12-09 | C1-IETF | 9952h | 8956.8h | IMSProtoc2 | PCG-27 | Roland Jesske | Roland Jesske | Rel-8 | CP-52 | Frederic |  | draft-ietf-salud-alert-info-urns |
| 2510 | 653 | **Interworking between User-to-User Signalling (UUS) and SIP** |  | 1850d? | 2007-11-30 A | 2014-12-09 | 93% | 123.72d? | 2007-11-30 | 2014-12-05 | 1845d? | 657d |  | C1; C3; IETF | 68624.4h | 22306.8h | UUSIW | PCG-21 | Huawei | Lili Yang (kadyyang@huawei.com) | Rel-8 | CP-38 | Kimmo | UUSIW |  |
| 2511 | 653.1 | CT1 part of Stage 3 MGCF UUSIW |  | 266d? | 2007-11-30 A | 2008-12-05 A | 100% |  | 2007-11-30 | 2008-12-05 | 266d? |  | finish no earlier than 2008-12-05 | C1 | 2128h | 2128h | UUSIW | PCG-21 | Huawei | Lili Yang (kadyyang@huawei.com) | Rel-8 | CP-38 | Frederic |  | 24.279, 24.229 |
| 2512 | 653.2 | (IETF) Stage 3 MGCF UUSIW (cuss-sip-uui) |  | 227.03d? | 2007-11-30 A | 2014-12-09 | 90% | 22.7d? | 2007-11-30 | 2014-12-05 | 225.03d? | 657d | finish no earlier than 2014-12-09 | C1-IETF; C3-IETF | 3632.4h | 3269.16h | UUSIW | PCG-27 | Roland Jesske | Roland Jesske | Rel-8 | CP-52 | Frederic |  | draft-ietf-cuss-sip-uui |
| 2513 | 653.3 | (IETF) Stage 3 MGCF UUSIW (cuss-sip-uui-isdn) |  | 986.5d? | 2011-03-17 A | 2014-12-09 | 90% | 98.65d? | 2011-03-17 | 2014-12-05 | 984.5d? | 657d | finish no earlier than 2014-12-09 | C1-IETF; C3-IETF | 15784h | 14205.6h | UUSIW | PCG-28 | Keith Drage | Keith Drage (drage@alcatel-lucent.com) | Rel-8 | CP-55 | Frederic |  | draft-ietf-cuss-sip-uui-isdn |
| 2514 | 653.4 | CT3 part of Stage 3 MGCF UUSIW |  | 335d? | 2007-11-30 A | 2009-03-12 A | 100% |  | 2007-11-30 | 2009-03-12 | 335d? |  | finish no earlier than 2009-03-12 | C3 | 2680h | 2680h | UUSIW | PCG-21 | Huawei | Lili Yang (kadyyang@huawei.com) | Rel-8 | CP-38 | Adrian |  | 29.163 |

Notes:
- 2487: CP#44 completed
- 2488: SP#40 completed
- 2489: SP#40 completed
- 2490: CP#44 completed
- 2491: CP#43 completed
- 2492: SP#42 completed. SP#46 withdrawn draft 33.178-100 and 33.978 from Rel-8 onwards
- 2493: CP#42 completed
- 2494: CP#43 completed
- 2495: CP#43 completed
- 2496: CP#40 completed
- 2497: SP#39 WID approved
- 2498: SP#43 completed
- 2499: SP#53/IETF#81 completed
- 2500: CP#42 completed
- 2501: SP#31 Moved from FS section Feb 2006
- 2502: Moved from Rel-7. Feature extended in Rel-8 by including Stage 3 covering MONA UID_380021
- 2503: CP#42 completed
- 2504: CP#42 completed
- 2505: CP#43 completed
- 2506: CP#43 completed
- 2507: CP#58 completed. ietf-draft discontinued. Documented within 3GPP
- 2508: CP#56 completed
- 2509: In RFC Editors Queue. LM: 75->90
- 2510: CP#43 completed
- 2511: CP#42 completed
- 2512: In RFC Editors Queue.
- 2513: In RFC Editors Queue. LM: 75->90
- 2514: CP#43 completed

| ID | WBS | Task | Type | Duration | Start | Finish | Complete | Baseline start | Baseline finish | Baseline duration | Constraint | Resources | Work | Actual work | Acronym | PCG approved | WI rapporteur name | WI rapporteur e-mail | Release | TSG approved | MCC resp | Acronym_3GU_Export | Impacted TSs and TRs | Special Focus Doc | Status Report |
| --- | --- | --- | --- | --- | --- | --- | --- | --- | --- | --- | --- | --- | --- | --- | --- | --- | --- | --- | --- | --- | --- | --- | --- | --- | --- |
| 2515 | 654 | **Support of Overlap signalling** |  | 331d? | 2007-11-30 A | 2009-03-06 A | 100% | 2007-11-30 | 2009-03-06 | 331d? |  | C3; C1; C4 | 15304.2h | 15304.2h | Overlap | PCG-21 | Deutsche Telekom | r.jesske@telekom.de | Rel-8 | CP-38 | Adrian | Overlap |  |  |  |
| 2516 | 654.1 | Stage 3 Overlap (CT1) |  | 331d? | 2007-11-30 A | 2009-03-06 A | 100% | 2007-11-30 | 2009-03-06 | 331d? | finish no earlier than 2009-03-06 | C1 | 2648h | 2648h | Overlap | PCG-21 | Deutsche Telekom | r.jesske@telekom.de | Rel-8 | CP-38 | Frederic |  | 24.229 |  |  |
| 2517 | 654.2 | Stage 3 Overlap (CT3) |  | 331d? | 2007-11-30 A | 2009-03-06 A | 100% | 2007-11-30 | 2009-03-06 | 331d? | finish no earlier than 2009-03-06 | C3 | 2648h | 2648h | Overlap | PCG-21 | Deutsche Telekom | r.jesske@telekom.de | Rel-8 | CP-38 | Adrian |  | 29.163 |  |  |
| 2518 | 654.3 | Stage 3 Overlap (CT4) |  | 258.02d? | 2007-11-30 A | 2008-12-05 A | 100% | 2007-11-30 | 2008-12-05 | 258.02d? | start no earlier than 2007-11-30 | C4 | 2064.16h | 2064.16h | Overlap | PCG-21 | Deutsche Telekom | r.jesske@telekom.de | Rel-8 | CP-38 | Kimmo |  | 29.228, 29.229 |  |  |
| 2519 | 655 | **AS/MRFC Stage 2 and 3** |  | 1203d? | 2007-11-14 A | 2012-06-15 A | 100% | 2007-11-14 | 2012-06-15 | 1203d? |  | C1; IETF | 28384h | 28384h | MRFC_TS | PCG-21 | Hewlett-Packard | mark.syrett@hp.com | Rel-8 | CP-38 | Frederic | MRFC_TS |  |  |  |
| 2520 | 655.1 | AS/MRFC Stage 2 |  | 278d? | 2007-11-14 A | 2008-12-05 A | 100% | 2007-11-14 | 2008-12-05 | 278d? | finish no earlier than 2008-12-05 | C1 | 2224h | 2224h | MRFC_TS | PCG-21 | Hewlett-Packard | mark.syrett@hp.com | Rel-8 | CP-38 | Frederic |  | 23.218 |  |  |
| 2521 | 655.2 | AS/MRFC Stage 3 |  | 278d? | 2007-11-14 A | 2008-12-05 A | 100% | 2007-11-14 | 2008-12-05 | 278d? | finish no earlier than 2008-12-05 | C1 | 2224h | 2224h | MRFC_TS | PCG-21 | Hewlett-Packard | mark.syrett@hp.com | Rel-8 | CP-38 | Frederic |  | 24.229, 24.147, 24.247 |  |  |
| 2522 | 655.3 | (IETF) AS/MRFC Stage 2 and 3 (RFC 6505) |  | 590d? | 2007-11-14 A | 2012-06-15 A | 100% | 2007-11-14 | 2012-06-15 | 590d? | finish no earlier than 2012-06-15 | C1-IETF | 4688h | 4688h | MRFC_TS | PCG-27 | Keith Drage |  | Rel-8 | CP-52 | Frederic |  | RFC 6505 (was draft-ietf-mediactrl-mixer-control-package) |  |  |
| 2523 | 656 | **IMS Restoration Procedures** |  | 201d? | 2008-05-30 A | 2009-03-06 A | 100% | 2008-05-30 | 2009-03-06 | 201d? |  | C4; C1 | 6432h | 6432h | IMS_RP | PCG-21 | Ericsson | german.blanco@ericsson.com | Rel-8 | SP-40 | Kimmo | IMS_RP |  |  |  |
| 2524 | 656.1 | IMS Restoration Procedures (CT4) |  | 201d? | 2008-05-30 A | 2009-03-06 A | 100% | 2008-05-30 | 2009-03-06 | 201d? | finish no earlier than 2009-03-06 | C4 | 1608h | 1608h | IMS_RP | PCG-21 | Ericsson | german.blanco@ericsson.com | Rel-8 | SP-40 | Kimmo |  | 23.380, 29.228, 29.229, 29.230, 23.008 |  |  |
| 2525 | 656.2 | IMS Restoration Procedures (CT1) |  | 201d? | 2008-05-30 A | 2009-03-06 A | 100% | 2008-05-30 | 2009-03-06 | 201d? | finish no earlier than 2009-03-06 | C1 | 1608h | 1608h | IMS_RP | PCG-21 | Ericsson | german.blanco@ericsson.com | Rel-8 | SP-40 | Frederic |  | 24.229 |  |  |
| 2526 | 657 | IMS Application Server Service Data Descriptions for AS interoperability |  | 125d? | 2008-09-12 A | 2009-03-06 A | 100% | 2008-09-12 | 2009-03-06 | 125d? | finish no earlier than 2009-03-06 | C4 | 1000h | 1000h | IMS_ASIO | PCG-21 | Alcatel-Lucent | nhberry@alcatel-lucent.com | Rel-8 | CP-41 | Kimmo | IMS_ASIO | 29.328, 29.329, 29.364 |  |  |
| 2527 | 658 | **I-WLAN Network Selection Principle (NSP)** |  | 451d? | 2007-06-14 A | 2009-03-06 A | 100% | 2007-06-14 | 2009-03-06 | 451d? |  | S1; C1; C6 | 13859.2h | 13859.2h | IWLANNSP |  | Telefónica O2 | chris.friel@O2.com | Rel-8 |  | Alain | IWLANNSP |  | WLAN |  |
| 2528 | 658.1 | Stage 1 for I-WLAN NSP | milestone | 0d? | 2007-06-14 A | 2007-06-14 A | 100% | 2007-06-14 | 2007-06-14 | 0d? |  | S1 |  |  | IWLANNSP | PCG-21 | Telefónica O2 | chris.friel@O2.com | Rel-8 | SP-39 | Alain |  | 22.234 | WLAN |  |
| 2529 | 658.2 | CT1 part of Stage 3 for I-WLAN NSP |  | 261d? | 2008-03-07 A | 2009-03-06 A | 100% | 2008-03-07 | 2009-03-06 | 261d? | finish no earlier than 2008-12-05 | C1 | 2088h | 2088h | IWLANNSP | PCG-21 | Research In Motion | Adrian Buckley (abuckley@rim.com) | Rel-8 | CP-39 | Frederic |  | 24.234 | WLAN |  |
| 2530 | 658.3 | CT6 part of Stage 3 for I-WLAN NSP |  | 118.4d? | 2008-03-07 A | 2008-12-11 A | 100% | 2008-03-07 | 2008-12-11 | 118.4d? | finish no earlier than 2008-12-11 | C6 | 947.2h | 947.2h | IWLANNSP | PCG-21 | Research In Motion | Adrian Buckley (abuckley@rim.com) | Rel-8 | CP-39 | Xavier |  | 31.102, 31.111 | WLAN |  |
| 2531 | 659 | **Mobility between 3GPP-WLAN Interworking and 3GPP Systems** |  | 386d? | 2007-09-14 A | 2009-03-06 A | 100% | 2007-09-14 | 2009-03-06 | 386d? |  | S2; C1 | 9304h | 9304h | IWLAN_Mob |  | Orange | xiaobao.chen@orange-ftgroup.com | Rel-8 | SP-37 | Maurice | IWLAN_Mob |  | WLAN |  |
| 2532 | 659.1 | Stage 2 for Mobility between 3GPP-WLAN Interworking and 3GPP Systems |  | 190d? | 2007-09-14 A | 2008-06-05 A | 100% | 2007-09-14 | 2008-06-05 | 190d? | finish no earlier than 2008-09-08 | S2 | 1520h | 1520h | IWLAN_Mob | PCG-21 | Orange | xiaobao.chen@orange-ftgroup.com | Rel-8 | SP-38 | Maurice |  | new 23.327 | WLAN |  |
| 2533 | 659.2 | CT1 aspects of Mobility between 3GPP-WLAN Interworking and 3GPP Systems |  | 201d? | 2008-05-30 A | 2009-03-06 A | 100% | 2008-05-30 | 2009-03-06 | 201d? | finish no earlier than 2009-03-06 | C1 | 1608h | 1608h | IWLAN_Mob | PCG-21 | Orange | reina.nader@orange-ftgroup.com | Rel-8 | CP-40 | Frederic |  | 24.303, new 24.327 | WLAN |  |
| 2534 | 660 | Conformance Test Aspects – Mobility between 3GPP WLAN Interworking and 3GPP Systems |  | 206d? | 2009-12-04 A | 2010-09-17 A | 100% | 2009-12-04 | 2010-09-17 | 206d? | finish no earlier than 2010-09-17 | R5 | 1648h | 1648h | IWLAN_Mob_UEConTest | PCG-24 | Qualcomm | Patrick Stupar (pstupar@qualcomm.com) | Rel-8 | RP-46 | Ingbert | IWLAN_Mob_UEConTest | 34.108, 34.123-1, 34.123-2, 34.123-3 | WLAN | RP-100740 |
| 2535 | 661 | **Enhancements for Voice Group Call Service (VGCS) Applications (EVA)** |  | 919d? | 2006-03-15 A | 2009-09-18 A | 100% | 2006-03-15 | 2009-09-18 | 919d? |  | S1; C1; C4; G2 | 45559.5h | 45559.5h | EVA |  | Nortel | Amar Deol (deola@nortelnetworks.com) | Rel-8 |  | Alain | EVA |  |  |  |
| 2536 | 661.1 | SA1 aspects of EVA |  | 191d? | 2006-03-15 A | 2006-12-06 A | 100% | 2006-03-15 | 2006-12-06 | 191d? | finish no earlier than 2006-12-06 | S1 | 1528h | 1528h | EVA |  | Nortel | Amar Deol (deola@nortelnetworks.com) | Rel-8 |  | Alain |  | 42.068 |  |  |
| 2537 | 661.2 | VGCS/VBS and GPRS Interactions |  | 145d? | 2007-09-03 A | 2008-03-21 A | 100% | 2007-09-03 | 2008-03-21 | 145d? | finish no earlier than 2008-03-21 | S1 | 1160h | 1160h | EVA |  | Huawei | Ling Liu | Rel-8 | SP-37 | Alain |  | 42.068, 42.069 |  |  |
| 2538 | 661.3 | CT1 aspects of EVA |  | 862d? | 2006-06-02 A | 2009-09-18 A | 100% | 2006-06-02 | 2009-09-18 | 862d? | finish no earlier than 2009-12-04 | C1 | 6887.53h | 6887.53h | EVA |  | Nortel | milanpa@nortel.com | Rel-8 |  | Frederic |  | 43.068, 44.068 |  |  |
| 2539 | 661.4 | CT4 aspects of EVA |  | 391d? | 2006-06-02 A | 2007-11-30 A | 100% | 2006-06-02 | 2007-11-30 | 391d? | finish no earlier than 2007-06-01 | C4 | 3128h | 3128h | EVA |  | Nortel |  | Rel-8 |  | Kimmo |  | 29.002 |  |  |
| 2540 | 661.5 | GERAN2 aspects of EVA |  | 431d? | 2006-06-30 A | 2008-02-22 A | 100% | 2006-06-30 | 2008-02-22 | 431d? | finish no earlier than 2008-02-22 | G2 | 3448h | 3448h | EVA |  | Nortel | frank.billenkamp@nortel.com | Rel-8 |  | Gert |  | 44.018, 48.008 |  |  |

Notes:
- 2515: CP#43 completed
- 2516: CP#43 completed
- 2517: CP#43 completed
- 2518: CP#42 completed
- 2519: Triggered by Study UID_7048 (MRFC)
- 2520: CP#42 completed
- 2521: CP#42 completed
- 2522: CP#56 completed
- 2523: CP#43 completed. Triggered by Study TR 23.820 (FS_IMS_RP) UID_350018
- 2524: CP#43 completed
- 2525: CP#43 completed
- 2526: CP#43 completed. Triggered by UID_360030 (FS_IMS_ASIO)
- 2527: CP#43 completed
- 2528: SP#36 completed
- 2529: CP#43 completed
- 2530: CP#42 completed
- 2531: CP#43 completed
- 2532: SP#40 completed
- 2533: CP#43 completed
- 2534: RP#49 completed. Testing for Rel-8 UID_400013 CT1 aspects of mobility between 3GPP WLAN Interworking and 3GPP Systems (24.327)
- 2535: CP#45 completed
- 2536: SP#38 completed
- 2537: SP#39 completed
- 2538: CP#45 completed
- 2539: CP#38 completed
- 2540: GP#37 completed

| ID | WBS | Task | Type | Duration | Start | Finish | Complete | Baseline start | Baseline finish | Baseline duration | Constraint | Resources | Work | Actual work | Acronym | WI rapporteur name | WI rapporteur e-mail | Release | MCC resp | Acronym_3GU_Export | Impacted TSs and TRs | TSG stopped | Special Focus Doc | TSG approved | PCG approved | Status Report |
| --- | --- | --- | --- | --- | --- | --- | --- | --- | --- | --- | --- | --- | --- | --- | --- | --- | --- | --- | --- | --- | --- | --- | --- | --- | --- | --- |
| 2541 | 662 | **Personal Network Management** |  | 955d? | 2005-07-11 A | 2009-03-06 A | 100% | 2005-07-11 | 2009-03-06 | 955d? |  | S1; C1; S3 | 46368h | 46368h | PNM | Vodafone | armin.toepfer@vodafone.com | Rel-8 | Alain | PNM |  |  |  |  |  |  |
| 2542 | 662.1 | Stage 1 for PNM |  | 276d? | 2005-07-11 A | 2006-07-31 A | 100% | 2005-07-11 | 2006-07-31 | 276d? | start no earlier than 2005-07-11 | S1 | 2208h | 2208h | PNM | Vodafone | armin.toepfer@vodafone.com | Rel-8 | Alain |  | 22.259 |  |  |  |  |  |
| 2543 | 662.2 | Stage 2 for PNM |  | 445d? | 2007-03-26 A | 2008-12-05 A | 100% | 2007-03-26 | 2008-12-05 | 445d? | finish no earlier than 2008-12-05 | C1 | 3560h | 3560h | PNM | Vodafone | yang.lu@vodafone.com | Rel-8 | Frederic |  | 23.259 |  |  |  |  |  |
| 2544 | 662.3 | **Stage 3 for PNM** |  | 510d? | 2007-03-26 A | 2009-03-06 A | 100% | 2007-03-26 | 2009-03-06 | 510d? |  | C1; C4 | 15800h | 15800h | PNM | Vodafone | yang.lu@vodafone.com | Rel-8 | Frederic |  |  |  |  |  |  |  |
| 2545 | 662.3.1 | CT1 aspects of Stage 3 PNM |  | 510d? | 2007-03-26 A | 2009-03-06 A | 100% | 2007-03-26 | 2009-03-06 | 510d? | finish no earlier than 2008-12-05 | C1 | 4080h | 4080h | PNM | Vodafone | yang.lu@vodafone.com | Rel-8 | Frederic |  | 24.259, 24.229 |  |  |  |  |  |
| 2546 | 662.3.2 | Deleted - CT4 aspects of Stage 3 PNM |  | 445d? | 2007-03-26 A | 2008-12-05 A | 100% | 2007-03-26 | 2008-12-05 | 445d? | finish no earlier than 2008-12-11 | C4 | 3560h | 3560h | PNM | Vodafone | yang.lu@vodafone.com | Rel-8 | Kimmo |  |  | CP-42 |  |  |  |  |
| 2547 | 662.4 | Key establishment between a UICC hosting device and a remote device |  | 235d? | 2006-12-06 A | 2007-10-30 A | 100% | 2006-12-06 | 2007-10-30 | 235d? | finish no earlier than 2007-10-30 | S3 | 1880h | 1880h | PNM | Ericsson | Vesa.Lehtovirta@ericsson.com | Rel-8 | Mirko |  | 33.259 |  |  |  |  |  |
| 2548 | 662.5 | Deleted - Actual Requirements of PNM | milestone | 0d? | 2007-03-26 A | 2007-03-26 A | 100% | 2007-03-26 | 2007-03-26 | 0d? | finish no earlier than 2007-03-26 | C1 |  |  | PNM | Ericsson |  | Rel-8 | Frederic |  |  | SP-37 |  |  |  |  |
| 2549 | 663 | **eCall Data Transfer** |  | 637d? | 2006-09-28 A | 2009-03-06 A | 100% | 2006-09-28 | 2009-03-06 | 637d? |  | S1; C1 | 14840h | 14840h | EData | Airbiquity | rrobinson@airbiquity.com | Rel-8 | Alain | EData |  |  | Public Safety (I-A) |  |  |  |
| 2550 | 663.1 | eData Requirements |  | 380d? | 2006-09-28 A | 2008-03-12 A | 100% | 2006-09-28 | 2008-03-12 | 380d? | finish no earlier than 2006-12-07 | S1 | 3040h | 3040h | EData | Airbiquity | rrobinson@airbiquity.com | Rel-8 | Alain |  | 22.101, 22.105 |  | Public Safety (I-A) | SP-37 |  |  |
| 2551 | 663.2 | Transfer of data during an emergency call |  | 201d? | 2008-05-30 A | 2009-03-06 A | 100% | 2008-05-30 | 2009-03-06 | 201d? | finish no earlier than 2009-03-06 | C1 | 1608h | 1608h | EData | T-Mobile | Dieter Jacobsohn | Rel-8 | Frederic |  | 24.008 |  | Public Safety (I-A) | SP-40 | PCG-21 |  |
| 2552 | 664 | eCall data transfer Phase 2: Comparison of alternative in-band modem solutions and standardization of one in-band modem solution |  | 472d? | 2007-12-06 A | 2009-09-24 A | 100% | 2007-12-06 | 2009-09-24 | 472d? | finish no earlier than 2009-09-24 | S4 | 3768.09h | 3768.09h | eCall_Phase2 | Airbiquity | lhong@airbiquity.com & rrobinson@airbiquity.com | Rel-8 | Paolo | eCall_Phase2 | 26.267, 26.268, 26.269, 26.967, 26.969 |  | Public Safety (I-A) |  |  |  |
| 2553 | 665 | eCall Conformance Testing |  | 261d? | 2009-09-04 A | 2010-09-03 A | 100% | 2009-09-04 | 2010-09-03 | 261d? | finish no earlier than 2010-09-03 | G3new | 2088h | 2088h | eCall_MSTest | Ericsson, Qualcomm | Vikrant Jain (vikrantj@qualcomm.com) | Rel-8 | Ingbert | eCall_MSTest | 51.010-1, 51.010-2 |  | Public Safety (I-A) | GP-45 | PCG-23 |  |
| 2554 | 666 | Conformance Test Aspects – non-modem procedures of eCall sessions in UTRA |  | 186d? | 2009-09-18 A | 2010-06-04 A | 100% | 2009-09-18 | 2010-06-04 | 186d? | finish no earlier than 2010-06-04 | R5 | 1488h | 1488h | UMTS_eCall_UEConTest | Ericsson, Qualcomm | Shubhang Vora (svora@qualcomm.com) | Rel-8 | Ingbert | UMTS_eCall_UEConTest | 34.108, 34.123-1, 34.123-2, 34.123-3 |  | Public Safety (I-A) | RP-45 | PCG-23 | RP-100489 |
| 2555 | 667 | **IP Interconnection of Services** |  | 668d? | 2006-08-16 A | 2009-03-06 A | 100% | 2006-08-16 | 2009-03-06 | 668d? |  | S1; S2; S5; C3 | 44240h | 44240h | IPinterc | Telefónica O2 | chris.friel@O2.com | Rel-8 | Alain | IPinterc |  |  |  | SP-38 | PCG-21 |  |
| 2556 | 667.1 | Stage 1 for IPinterc |  | 70d? | 2007-12-06 A | 2008-03-12 A | 100% | 2007-12-06 | 2008-03-12 | 70d? | start no earlier than 2007-12-06 | S1 | 560h | 560h | IPinterc | Telefónica O2 | chris.friel@O2.com | Rel-8 | Alain |  | 22.101, 22.228 |  |  | SP-38 | PCG-21 |  |
| 2557 | 667.2 | **System enhancements for interconnection interfaces between two IMSs** |  | 668d? | 2006-08-16 A | 2009-03-06 A | 100% | 2006-08-16 | 2009-03-06 | 668d? |  | S2; S5; C3 | 22304h | 22304h | IMS_NNI | Telecom Italia | Mario Madella (mario.madella@telecomitalia.it) | Rel-8 | Maurice | IMS_NNI |  |  |  |  |  |  |
| 2558 | 667.2.1 | Stage 2 for IMS_NNI |  | 120d? | 2007-06-22 A | 2007-12-06 A | 100% | 2007-06-22 | 2007-12-06 | 120d? | finish no earlier than 2007-12-21 | S2 | 960h | 960h | IMS_NNI | Telecom Italia | Mario Madella (mario.madella@telecomitalia.it) | Rel-8 | Maurice |  | 23.002, 23.228 |  |  |  |  |  |
| 2559 | 667.2.2 | IMS inter-operator service interconnection interface |  | 461d? | 2007-06-01 A | 2009-03-06 A | 100% | 2007-06-01 | 2009-03-06 | 461d? | finish no earlier than 2009-03-06 | C3 | 3688h | 3688h | FBI2-IOPSI | Telecom Italia | antonio.ascolese@telecomitalia.it | Rel-8 | Adrian | FBI2-IOPSI | 29.865, 29.165 |  |  |  |  |  |
| 2560 | 667.2.3 | Charging harmonization for NGN between 3GPP and ATIS-TMOC |  | 51d? | 2006-09-28 A | 2006-12-07 A | 100% | 2006-09-28 | 2006-12-07 | 51d? | finish no earlier than 2006-12-07 | S5 | 408h | 408h | FBI2-TISP2-CH | Amdocs | yishai.brown@amdocs.com | Rel-8 | Mirko | FBI2-TISP2-CH | 32.297 |  |  |  |  |  |
| 2561 | 667.2.4 | Deleted - Protocol impact of FBI for TISPAN R2 |  | 152d? | 2006-08-16 A | 2007-03-15 A | 100% | 2006-08-16 | 2007-03-15 | 152d? | finish no earlier than 2007-03-15 | C1 | 1216h | 1216h | FBI2-TISP2-c1 | Ericsson |  | Rel-8 | Frederic | FBI2-TISP2-c1 |  | SP-38 |  |  |  |  |
| 2562 | 667.2.5 | Deleted (never approved) - Stage 2 of FBI for TISPAN R2 - Rel 8 | milestone | 0d? | 2007-11-30 A | 2007-11-30 A | 100% | 2007-11-30 | 2007-11-30 | 0d? | finish no earlier than 2007-11-30 | S2 |  |  | FBI2-TISP2-s2 | Nokia Siemens Networks |  | Rel-8 | Maurice | FBI2-TISP2-s2 |  | SP-36 |  |  |  |  |
| 2563 | 668 | **Support of (G)MSC-S – (G)MSC-S Nc Interface based on the SIP-I protocol** |  | 386d? | 2007-09-14 A | 2009-03-06 A | 100% | 2007-09-14 | 2009-03-06 | 386d? |  | C4; C3 | 14960h | 14960h | SIP_Nc | Vodafone | David.Hutton@vodafone.com | Rel-8 | Kimmo | SIP_Nc |  |  |  |  |  |  |
| 2564 | 668.1 | Stage 1 for SIP_Nc (covered by Feature IPinterc) |  | 70d? | 2007-12-06 A | 2008-03-12 A | 100% | 2007-12-06 | 2008-03-12 | 70d? | start no earlier than 2007-12-06 | S1 | 560h | 560h | SIP_Nc | Telefónica O2 | chris.friel@O2.com | Rel-8 | Alain |  | 22.101, 22.228 |  |  | CP-41 | PCG-21 |  |
| 2565 | 668.2 | SIP-I based circuit-switched core network; Stage 2 |  | 321d? | 2007-09-14 A | 2008-12-05 A | 100% | 2007-09-14 | 2008-12-05 | 321d? | finish no earlier than 2008-12-11 | C4 | 2568h | 2568h | SIP_Nc-St2 | Vodafone | David.Hutton@vodafone.com | Rel-8 | Kimmo | SIP_Nc-St2 | 23.231, 23.153, 23.205 |  |  |  |  |  |
| 2566 | 668.3 | Application of SIP-I Protocols to Circuit Switched (CS) core network architecture; Stage 3 |  | 321d? | 2007-09-14 A | 2008-12-05 A | 100% | 2007-09-14 | 2008-12-05 | 321d? | finish no earlier than 2008-12-11 | C4 | 2568h | 2568h | SIP_Nc-St3 | Vodafone | David.Hutton@vodafone.com | Rel-8 | Kimmo | SIP_Nc-St3 | 29.231, 29.232, 29.332 |  |  |  |  |  |
| 2567 | 668.4 | Interworking between the 3GPP CS domain with SIP-I as signalling protocol and other networks |  | 386d? | 2007-09-14 A | 2009-03-06 A | 100% | 2007-09-14 | 2009-03-06 | 386d? | finish no earlier than 2009-03-06 | C3 | 3088h | 3088h | SIP_Nc-St3 | Nokia Siemens Networks | Thomas.Belling@nsn.com | Rel-8 | Adrian |  | 29.235, 23.172, 23.202, 29.007, 29.163, 29.414 |  |  |  |  |  |

Notes:
- 2541: CP#43 completed
- 2542: SP#31 completed
- 2543: CP#42 completed
- 2544: CP#43 completed
- 2545: CP#43 completed
- 2546: CP#42 no impact on CT4 specs
- 2547: SP#37 completed
- 2548: SP#37 stopped
- 2549: SP#39 completed. Linked to SA4 Feature UID_34042 (eCall_Phase2)
- 2550: SP#39 completed
- 2551: CP#43 completed
- 2552: SP#45 completed. Triggered by Study UID_360015 (eCALLIBMS). Linked to SA1 Feature UID_330005 (EData)
- 2553: GP#47 completed. GP#43 WID approved. Testing for Rel-8 eCall_Phase2 (UID_34042) and EData (UID_330005)
- 2554: RP#48 completed. Testing for Rel-8 eCall_Phase2 (UID_34042) and Edata (UID_330005)
- 2555: SP#43 completed
- 2556: SP#39 completed.
- 2557: CP#43 completed
- 2558: SP#38 completed
- 2559: CP#43 completed
- 2560: SP#34 completed
- 2561: SP#38 stopped
- 2562: SP#36 stopped
- 2563: CP#43 completed. Stage 1 in Feature UID_380060 (IPinterc). CP#40 updated WID CP-070517=>CP-080282
- 2564: 22/07/08 Created. Stage 1 for SIP_Nc (covered by SA1 Feature UID_380060 Ipinterc)
- 2565: CP#42 completed
- 2566: CP#42 completed
- 2567: CP#43 completed. CP#42 target 12/08=>03/09

| ID | WBS | Task | Type | Duration | Start | Finish | Complete | Baseline start | Baseline finish | Baseline duration | Constraint | Resources | Work | Actual work | Acronym | WI rapporteur name | WI rapporteur e-mail | Release | TSG approved | MCC resp | Special Focus Doc | Acronym_3GU_Export | Impacted TSs and TRs | PCG approved | Status Report |
| --- | --- | --- | --- | --- | --- | --- | --- | --- | --- | --- | --- | --- | --- | --- | --- | --- | --- | --- | --- | --- | --- | --- | --- | --- | --- |
| 2568 | 669 | **Earthquake and Tsunami Warning System** |  | 440d? | 2007-09-10 A | 2009-05-15 A | 100% | 2007-09-10 | 2009-05-15 | 440d? |  | S1; S2; C1; C4; G2 | 21280h | 21280h | ETWS | NTT DoCoMo | kitaharar@nttdocomo.co.jp | Rel-8 | SP-37 | Alain | Public Safety (I-A) | ETWS |  |  |  |
| 2569 | 669.1 | Stage 1 for ETWS |  | 133d? | 2007-09-10 A | 2008-03-12 A | 100% | 2007-09-10 | 2008-03-12 | 133d? | finish no earlier than 2008-03-12 | S1 | 1064h | 1064h | ETWS | NTT DoCoMo | kitaharar@nttdocomo.co.jp | Rel-8 | SP-37 | Alain | Public Safety (I-A) |  | 22.168 |  |  |
| 2570 | 669.2 | SA2 aspects of ETWS |  | 179d? | 2008-01-14 A | 2008-09-18 A | 100% | 2008-01-14 | 2008-09-18 | 179d? | finish no earlier than 2008-09-08 | S2 | 1432h | 1432h | ETWS | NTT DoCoMo | tanakai@nttdocomo.co.jp | Rel-8 | SP-38 | Maurice | Public Safety (I-A) |  | 23.828, 23.401 | PCG-21 |  |
| 2571 | 669.3 | CT1 aspects of ETWS |  | 50.5d? | 2008-05-30 A | 2008-12-05 A | 100% | 2008-05-30 | 2008-12-05 | 50.5d? | finish no earlier than 2008-12-05 | C1 | 404h | 404h | ETWS | NTT DoCoMo | yamashitahi@s1.nttdocomo.co.jp | Rel-8 | CP-40 | Frederic | Public Safety (I-A) |  | 23.041 | PCG-21 |  |
| 2572 | 669.4 | CT4 aspects of ETWS |  | 50.5d? | 2008-09-26 A | 2008-12-05 A | 100% | 2008-09-26 | 2008-12-05 | 50.5d? | finish no earlier than 2008-12-05 | C4 | 404h | 404h | ETWS | NTT DoCoMo | yamashitahi@s1.nttdocomo.co.jp | Rel-8 | CP-40 | Kimmo | Public Safety (I-A) |  | 29.168 | PCG-21 |  |
| 2573 | 669.5 | ETWS primary notification message definition in GERAN |  | 47d? | 2009-03-12 A | 2009-05-15 A | 100% | 2009-03-12 | 2009-05-15 | 47d? | finish no earlier than 2009-05-15 | G2 | 376h | 376h | ETWS | Ericsson | claes-goran.persson@ericsson.com | Rel-8 | SP-43 | Gert | Public Safety (I-A) |  | 44.018, 44.060 | PCG-22 |  |
| 2574 | 670 | Conformance Test Aspects – UMTS Earthquake and Tsunami Warning System (ETWS) FDD |  | 207d? | 2009-05-29 A | 2010-03-12 A | 100% | 2009-05-29 | 2010-03-12 | 207d? | finish no earlier than 2010-03-12 | R5 | 1656h | 1656h | ETWS_UMTS_UEConTestFDD | NTT DoCoMo | Makoto Ito (itohm@nttdocomo.co.jp) | Rel-8 | RP-44 | Ingbert | Public Safety (I-A) | ETWS_UMTS_UEConTestFDD | 34.108, 34.123-1, 34.123-2 | PCG-23 | RP-100068 |
| 2575 | 671 | **In Case of Emergency numbers storage and easy access on UICC** |  | 519d? | 2007-03-13 A | 2009-03-06 A | 100% | 2007-03-13 | 2009-03-06 | 519d? |  | S1; C6 | 14552h | 14552h | ICE | Vodafone | armin.toepfer@vodafone.com | Rel-8 | SP-38 | Alain |  | ICE |  | PCG-21 |  |
| 2576 | 671.1 | Stage 1 for ICE |  | 262d? | 2007-03-13 A | 2008-03-12 A | 100% | 2007-03-13 | 2008-03-12 | 262d? | finish no earlier than 2008-03-12 | S1 | 2096h | 2096h | ICE | Vodafone | armin.toepfer@vodafone.com | Rel-8 | SP-38 | Alain |  |  | 22.030, 22.101 | PCG-21 |  |
| 2577 | 671.2 | CT6 aspects of ICE |  | 519d? | 2007-03-13 A | 2009-03-06 A | 100% | 2007-03-13 | 2009-03-06 | 519d? | finish no earlier than 2009-03-06 | C6 | 4152h | 4152h | ICE | Vodafone | armin.toepfer@vodafone.com | Rel-8 | SP-38 | Xavier |  |  | 31.102 | PCG-21 |  |
| 2578 | 672 | Local Charging Zone Requirements |  | 380d? | 2006-09-28 A | 2008-03-12 A | 100% | 2006-09-28 | 2008-03-12 | 380d? | finish no earlier than 2006-12-07 | S1 | 3040h | 3040h | LCZR | China Mobile | liuhongyfw@chinamobile.com | Rel-8 |  | Alain |  | LCZR | 22.115 |  |  |
| 2579 | 673 | **Customized Alerting Tone (CAT) service** |  | 729d? | 2006-12-06 A | 2009-09-18 A | 100% | 2006-12-06 | 2009-09-18 | 729d? |  | S1; C1; C3; C4 | 39854h | 39854h | CAT | China Mobile | fenglingjuan@chinamobile.com | Rel-8 |  | Alain |  | CAT |  |  |  |
| 2580 | 673.1 | Stage 1 for CAT |  | 207d? | 2006-12-06 A | 2007-09-20 A | 100% | 2006-12-06 | 2007-09-20 | 207d? | start no earlier than 2006-12-06 | S1 | 1656h | 1656h | CAT | China Mobile | fenglingjuan@chinamobile.com | Rel-8 | SP-37 | Alain |  |  | 22.182 |  |  |
| 2581 | 673.2 | TISPAN requirements for customized multimedia information services |  | 71d? | 2007-09-03 A | 2007-12-10 A | 100% | 2007-09-03 | 2007-12-10 | 71d? | finish no earlier than 2007-12-10 | S1 | 568h | 568h | TISCMI | China Mobile | fenglingjuan@chinamobile.com | Rel-8 | SP-37 | Alain |  | TISCMI | 22.182 |  |  |
| 2582 | 673.3 | **IMS CAT Supplementary Service** |  | 399d? | 2008-03-12 A | 2009-09-18 A | 100% | 2008-03-12 | 2009-09-18 | 399d? |  | C1; C3 | 10814.4h | 10814.4h | CAT-SS | Nortel | milanpa@nortel.com | Rel-8 | CP-39 | Frederic |  | CAT-SS |  | PCG-21 |  |
| 2583 | 673.3.1 | IMS CAT SS |  | 164d? | 2008-04-21 A | 2008-12-04 A | 100% | 2008-04-21 | 2008-12-04 | 164d? | finish no earlier than 2008-12-05 | C1 | 1312h | 1312h | CAT-SS | Nortel | milanpa@nortel.com | Rel-8 | CP-39 | Frederic |  |  | 24.182 | PCG-21 |  |
| 2584 | 673.3.2 | CAT solution for voice and video call in CS domain |  | 389.8d? | 2008-03-12 A | 2009-09-18 A | 100% | 2008-03-12 | 2009-09-18 | 389.8d? | finish no earlier than 2009-09-11 | C3 | 3118.4h | 3118.4h | CAT-SS | Nortel | milanpa@nortel.com | Rel-8 | CP-39 | Adrian |  |  | 29.163 | PCG-21 |  |
| 2585 | 673.4 | **CAT Service in 3GPP CS domain** |  | 126d? | 2008-09-12 A | 2009-03-06 A | 100% | 2008-09-12 | 2009-03-06 | 126d? |  | C4; C1 | 3487.6h | 3487.6h | CAT-3G_CS | China Mobile | zhaoyuyi@chinamobile.com | Rel-8 | CP-41 | Kimmo |  | CAT-3G_CS | 23.205, 23.231, 29.002 | PCG-21 |  |
| 2586 | 673.4.1 | CT4 part of CAT Service in 3GPP CS domain |  | 126d? | 2008-09-12 A | 2009-03-06 A | 100% | 2008-09-12 | 2009-03-06 | 126d? | finish no earlier than 2009-03-06 | C4 | 1008h | 1008h | CAT-3G_CS | China Mobile | zhaoyuyi@chinamobile.com | Rel-8 | CP-41 | Kimmo |  |  | 23.205, 23.231, 29.002 | PCG-21 |  |
| 2587 | 673.4.2 | CT1 part of CAT Service in 3GPP CS domain |  | 57.95d? | 2008-09-12 A | 2008-12-05 A | 100% | 2008-09-12 | 2008-12-05 | 57.95d? | start no earlier than 2008-09-12 | C1 | 463.6h | 463.6h | CAT-3G_CS | China Mobile | zhaoyuyi@chinamobile.com | Rel-8 | CP-41 | Frederic |  |  | 24.008, 23.014 | PCG-21 |  |
| 2588 | 674 | **Service-Level Interworking for Messaging Services** |  | 509d? | 2007-03-26 A | 2009-03-06 A | 100% | 2007-03-26 | 2009-03-06 | 509d? |  | S1; S2; C3; C1 | 20800h | 20800h | MESSIW | Huawei | ling.liu@huawei.com; duanxiaoqin@huawei.com | Rel-8 |  | Alain |  | MESSIW |  |  |  |
| 2589 | 674.1 | Stage 1 for MESSIW | milestone | 0d? | 2007-03-26 A | 2007-03-26 A | 100% | 2007-03-26 | 2007-03-26 | 0d? | finish no earlier than 2007-12-01 | S1 |  |  | MESSIW | Huawei | ling.liu@huawei.com | Rel-8 |  | Alain |  |  | 22.105, 22.340 |  |  |
| 2590 | 674.2 | Stage 2 for MESSIW |  | 227d? | 2007-04-26 A | 2008-03-07 A | 100% | 2007-04-26 | 2008-03-07 | 227d? | finish no earlier than 2008-03-07 | S2 | 1816h | 1816h | MESSIW | Huawei | patrice.hede@huawei.com | Rel-8 |  | Maurice |  |  | 23.811, 23.204 |  |  |
| 2591 | 674.3 | CT3 part of Stage 3 for MESSIW |  | 201d? | 2008-05-30 A | 2009-03-06 A | 100% | 2008-05-30 | 2009-03-06 | 201d? | finish no earlier than 2008-12-05 | C3 | 1608h | 1608h | MESSIW | Huawei | xupeili@huawei.com | Rel-8 | CP-40 | Adrian |  |  | 29.311 | PCG-21 |  |
| 2592 | 674.4 | CT1 part of Stage 3 for MESSIW |  | 136d? | 2008-05-30 A | 2008-12-05 A | 100% | 2008-05-30 | 2008-12-05 | 136d? | finish no earlier than 2008-12-12 | C1 | 1088h | 1088h | MESSIW | Huawei | xupeili@huawei.com | Rel-8 | CP-40 | Frederic |  |  | 24.229 | PCG-21 |  |

Notes:
- 2568: SP#43 Larger scope Feature UID_380057 (PWS) moved to Rel-9
- 2569: SP#39 completed
- 2570: SP#41 completed
- 2571: CP#42 completed
- 2572: CP#42 completed
- 2573: SP#44 completed with CT1 help (GERAN2 LS_in SP-090154)
- 2574: RP#47 completed. Testing for Rel-8 ETWS UID_370051
- 2575: CP#43 completed (ICE Graphics not included in Rel-8)
- 2576: SP#39 Stage 1 completed
- 2577: CP#43 completed (ICE Graphics not in Rel-8 / not explicitly in SA1 WID either)
- 2578: SP#39 Stage 1 completed
- 2579: CP#45 completed
- 2580: -
- 2581: SP#38 completed
- 2582: -
- 2583: CP#42 completed
- 2584: CP#45 completed. Triggered by Study UID_360031 (TR 29.882)
- 2585: -
- 2586: CP#43 completed. Triggered by Study UID_360031 (TR 29.882)
- 2587: CP#42 completed. Triggered by Study UID_360031 (TR 29.882)
- 2588: CP#43 completed
- 2589: SP#35 completed
- 2590: SP#39 completed
- 2591: CP#43 completed
- 2592: CP#42 completed

| ID | WBS | Task | Duration | Start | Finish | Complete | Baseline start | Baseline finish | Baseline duration | Constraint | Resources | Work | Actual work | Acronym | WI rapporteur name | WI rapporteur e-mail | Release | TSG approved | MCC resp | Special Focus Doc | Acronym_3GU_Export | Impacted TSs and TRs | PCG stopped | TSG stopped | PCG approved |
| --- | --- | --- | --- | --- | --- | --- | --- | --- | --- | --- | --- | --- | --- | --- | --- | --- | --- | --- | --- | --- | --- | --- | --- | --- | --- |
| 2593 | 675 | **Multimedia Priority Service** | 858d? | 2006-06-08 A | 2009-09-18 A | 100% | 2006-06-08 | 2009-09-18 | 858d? |  | S1; C1; C3; C4 | 43016h | 43016h | PRIOR | Telcordia | jgarraha@telcordia.com | Rel-8 | SP-34 | Alain | Public Safety (I-A) | PRIOR |  |  |  |  |
| 2594 | 675.1 | Service Requirements for PRIOR | 391d? | 2006-06-08 A | 2007-12-06 A | 100% | 2006-06-08 | 2007-12-06 | 391d? | finish no earlier than 2007-11-30 | S1 | 3128h | 3128h | PRIOR-EMR | Telcordia | jgarraha@telcordia.com | Rel-8 | SP-32 | Alain | Public Safety (I-A) | PRIOR-EMR | New 22.153 |  |  |  |
| 2595 | 675.2 | CT1 part of Stage 3 for PRIOR | 732d? | 2006-12-01 A | 2009-09-18 A | 100% | 2006-12-01 | 2009-09-18 | 732d? | finish no earlier than 2009-09-18 | C1 | 5856h | 5856h | PRIOR-EMR | Alcatel-Lucent | Keith Drage (drage@alcatel-lucent.com) | Rel-8 | CP-34 | Frederic | Public Safety (I-A) |  | 24.229 |  |  |  |
| 2596 | 675.3 | CT4 part of Stage 3 for PRIOR | 381d? | 2007-09-21 A | 2009-03-06 A | 100% | 2007-09-21 | 2009-03-06 | 381d? | finish no earlier than 2009-03-06 | C4 | 3048h | 3048h | PRIOR-EMR | Alcatel-Lucent | Keith Drage (drage@alcatel-lucent.com) | Rel-8 | CP-37 | Kimmo | Public Safety (I-A) |  | 23.008, 29.228, 29.229 |  |  |  |
| 2597 | 675.4 | Deleted - Stage 3 for PRIOR | 441d? | 2007-09-21 A | 2009-05-29 A | 100% | 2007-09-21 | 2009-05-29 | 441d? | finish no earlier than 2009-05-29 | C3 | 3528h | 3528h | PRIOR-EMR | Alcatel-Lucent | Keith Drage (drage@alcatel-lucent.com) | Rel-8 | CP-37 | Adrian | Public Safety (I-A) |  | 29.212, 29.213, 29.214, 29.163 | PCG-23 | CP-44 |  |
| 2598 | 676 | **Open Service Access (OSA) Rel-8** | 202d? | 2007-08-23 A | 2008-05-30 A | 100% | 2007-08-23 | 2008-05-30 | 202d? |  | S1; C5 | 25528h | 25528h | OSA8 | Orange | Song Dong | Rel-8 |  | Alain |  | OSA8 |  |  |  |  |
| 2599 | 676.1 | OSA Stage 1 - Service Requirements | 145d? | 2007-08-23 A | 2008-03-12 A | 100% | 2007-08-23 | 2008-03-12 | 145d? | finish no earlier than 2007-12-04 | S1 | 1160h | 1160h | OSA8 | Orange, AePONA | Song Dong | Rel-8 |  | Alain |  |  | 22.127 |  |  |  |
| 2600 | 676.2 | OSA Stage 1 - NGN Service Requirement | 140d? | 2007-09-03 A | 2008-03-14 A | 100% | 2007-09-03 | 2008-03-14 | 140d? | finish no earlier than 2008-03-14 | S1 | 1120h | 1120h | OSA8-IMS | Orange | Song Dong | Rel-8 | SP-37 | Alain |  | OSA8-IMS | 22.127 |  |  |  |
| 2601 | 676.3 | **Rel-8 OSA Stage 2/3 enhancements** | 157d? | 2007-10-25 A | 2008-05-30 A | 100% | 2007-10-25 | 2008-05-30 | 157d? |  | C5 | 20016h | 20016h | OSA8-IMS | Alcatel-Lucent | unmehopa@alcatel-lucent.com | Rel-8 |  | Kimmo |  |  | 23.198, 29.198, 29.199 |  |  |  |
| 2602 | 676.3.1 | Deleted - Ensure Parlay-X composable with identity management frameworks, in particular Liberty Alliance | 157d? | 2007-10-25 A | 2008-05-30 A | 100% | 2007-10-25 | 2008-05-30 | 157d? | finish no earlier than 2008-12-25 | C5 | 1256h | 1256h | OSA8-IMS | Ericsson | catherine.mulligan@ericsson.com | Rel-8 | CP-37 | Kimmo |  |  | existing 29.199-xy | PCG-21 | CP-40 | PCG-21 |
| 2603 | 676.3.2 | Parlay-X Content Management web service (store/manage meta-data) | 157d? | 2007-10-25 A | 2008-05-30 A | 100% | 2007-10-25 | 2008-05-30 | 157d? | finish no earlier than 2008-12-04 | C5 | 1256h | 1256h | OSA8-IMS | Alcatel-Lucent | unmehopa@alcatel-lucent.com | Rel-8 | CP-37 | Kimmo |  |  | 29.199-21 |  |  |  |
| 2604 | 676.3.3 | Parlay-X Policy web service | 157d? | 2007-10-25 A | 2008-05-30 A | 100% | 2007-10-25 | 2008-05-30 | 157d? | finish no earlier than 2008-12-04 | C5 | 1256h | 1256h | OSA8-IMS | Alcatel-Lucent | unmehopa@alcatel-lucent.com | Rel-8 | CP-37 | Kimmo |  |  | 29.199-22 |  |  |  |
| 2605 | 676.3.4 | Parlay-X Terminal status web service | 157d? | 2007-10-25 A | 2008-05-30 A | 100% | 2007-10-25 | 2008-05-30 | 157d? | finish no earlier than 2008-05-30 | C5 | 1256h | 1256h | OSA8-IMS | Alcatel-Lucent | unmehopa@alcatel-lucent.com | Rel-8 | CP-37 | Kimmo |  |  | 29.199-08 |  |  |  |
| 2606 | 676.3.5 | Deleted - Identify communication format used by a particular application | 157d? | 2007-10-25 A | 2008-05-30 A | 100% | 2007-10-25 | 2008-05-30 | 157d? | finish no earlier than 2008-05-30 | C5 | 1256h | 1256h | OSA8-IMS | Ericsson | catherine.mulligan@ericsson.com | Rel-8 | CP-37 | Kimmo |  |  | existing 29.199-xy | PCG-21 | CP-40 | PCG-21 |
| 2607 | 676.3.6 | Deleted - Security on User Profile Management - reuse GUP API (22.127 CR 0084 S1-071794) | 128d? | 2007-12-05 A | 2008-05-30 A | 100% | 2007-12-05 | 2008-05-30 | 128d? | finish no earlier than 2008-12-25 | C5 | 1024h | 1024h | OSA8-IMS | Telecom Italia | vincenzo.amorino@telecomitalia.it | Rel-8 | CP-38 | Kimmo |  |  | PXWS Framework | PCG-21 | CP-40 | PCG-21 |
| 2608 | 676.3.7 | Deleted - Privacy on Subscriber Identity (Liberty Alliance, OASIS) (22.127 CR 0085 S1-071835) | 128d? | 2007-12-05 A | 2008-05-30 A | 100% | 2007-12-05 | 2008-05-30 | 128d? | finish no earlier than 2008-12-25 | C5 | 1024h | 1024h | OSA8-IMS | Telecom Italia | vincenzo.amorino@telecomitalia.it | Rel-8 | CP-38 | Kimmo |  |  | PXWS Framework | PCG-21 | CP-40 | PCG-21 |
| 2609 | 676.3.8 | Deleted - Topology Hiding (22.127 CR 0086 S1-071838) | 128d? | 2007-12-05 A | 2008-05-30 A | 100% | 2007-12-05 | 2008-05-30 | 128d? | finish no earlier than 2008-12-25 | C5 | 1024h | 1024h | OSA8-IMS | Telecom Italia | vincenzo.amorino@telecomitalia.it | Rel-8 | CP-38 | Kimmo |  |  | PXWS Framework | PCG-21 | CP-40 | PCG-21 |
| 2610 | 676.3.9 | Deleted - Subscriber event notification (22.127 CR 0087 S1-071836) | 128d? | 2007-12-05 A | 2008-05-30 A | 100% | 2007-12-05 | 2008-05-30 | 128d? | finish no earlier than 2008-12-25 | C5 | 1024h | 1024h | OSA8-IMS | Telecom Italia | vincenzo.amorino@telecomitalia.it | Rel-8 | CP-38 | Kimmo |  |  | PXWS Framework | PCG-21 | CP-40 | PCG-21 |
| 2611 | 676.3.10 | Deleted - Event notification (22.127 CR 0088 S1-071762) | 128d? | 2007-12-05 A | 2008-05-30 A | 100% | 2007-12-05 | 2008-05-30 | 128d? | finish no earlier than 2008-12-25 | C5 | 1024h | 1024h | OSA8-IMS | Telecom Italia | vincenzo.amorino@telecomitalia.it | Rel-8 | CP-38 | Kimmo |  |  | PXWS Framework | PCG-21 | CP-40 | PCG-21 |
| 2612 | 676.3.11 | Deleted - Access policy (22.127 CR 0089 S1-071763) | 128d? | 2007-12-05 A | 2008-05-30 A | 100% | 2007-12-05 | 2008-05-30 | 128d? | finish no earlier than 2008-12-25 | C5 | 1024h | 1024h | OSA8-IMS | Telecom Italia | vincenzo.amorino@telecomitalia.it | Rel-8 | CP-38 | Kimmo |  |  | PXWS Framework | PCG-21 | CP-40 | PCG-21 |
| 2613 | 676.3.12 | Deleted - API usage accounting (22.127 CR 0090 S1-071792) | 128d? | 2007-12-05 A | 2008-05-30 A | 100% | 2007-12-05 | 2008-05-30 | 128d? | finish no earlier than 2008-12-25 | C5 | 1024h | 1024h | OSA8-IMS | Telecom Italia | vincenzo.amorino@telecomitalia.it | Rel-8 | CP-38 | Kimmo |  |  | PXWS Framework | PCG-21 | CP-40 | PCG-21 |
| 2614 | 676.3.13 | Presence alignment with OMA and IETF (22.127 CR 0092 S1-071764) | 128d? | 2007-12-05 A | 2008-05-30 A | 100% | 2007-12-05 | 2008-05-30 | 128d? | finish no earlier than 2008-05-30 | C5 | 1024h | 1024h | OSA8-IMS | Alcatel-Lucent | unmehopa@alcatel-lucent.com | Rel-8 | CP-38 | Kimmo |  |  | 29.199-14/13 |  |  | PCG-21 |
| 2615 | 676.3.14 | Deleted - Service identification (22.127 CR 0095 S1-071837) | 128d? | 2007-12-05 A | 2008-05-30 A | 100% | 2007-12-05 | 2008-05-30 | 128d? | finish no earlier than 2008-05-30 | C5 | 1024h | 1024h | OSA8-IMS | Ericsson | catherine.mulligan@ericsson.com | Rel-8 | CP-38 | Kimmo |  |  | existing 29.199-xy | PCG-21 | CP-40 | PCG-21 |
| 2616 | 676.3.15 | Framework Enterprise Operator (Service Subscription function) | 102d? | 2008-01-10 A | 2008-05-30 A | 100% | 2008-01-10 | 2008-05-30 | 102d? | finish no earlier than 2008-05-30 | C5 | 816h | 816h | OSA8-IMS | Alcatel-Lucent | unmehopa@alcatel-lucent.com | Rel-8 | CP-39 | Kimmo |  |  | 29.198-03 |  |  | PCG-21 |
| 2617 | 676.3.16 | Mobility Emergency Location | 102d? | 2008-01-10 A | 2008-05-30 A | 100% | 2008-01-10 | 2008-05-30 | 102d? | finish no earlier than 2008-05-30 | C5 | 816h | 816h | OSA8-IMS | Alcatel-Lucent | unmehopa@alcatel-lucent.com | Rel-8 | CP-39 | Kimmo |  |  | 29.198-06 |  |  | PCG-21 |
| 2618 | 676.3.17 | Connectivity Manager SCF | 102d? | 2008-01-10 A | 2008-05-30 A | 100% | 2008-01-10 | 2008-05-30 | 102d? |  | C5 | 816h | 816h | OSA8-IMS | Alcatel-Lucent | unmehopa@alcatel-lucent.com | Rel-8 | CP-39 | Kimmo |  |  | 29.198-10 |  |  | PCG-21 |
| 2619 | 676.3.18 | PAM Presence Agent | 102d? | 2008-01-10 A | 2008-05-30 A | 100% | 2008-01-10 | 2008-05-30 | 102d? | finish no earlier than 2008-05-30 | C5 | 816h | 816h | OSA8-IMS | Alcatel-Lucent | unmehopa@alcatel-lucent.com | Rel-8 | CP-39 | Kimmo |  |  | 29.198-14 |  |  | PCG-21 |

Notes:
- 2593: CP#45 completed
- 2594: SP#38 completed
- 2595: CP#45 completed
- 2596: CP#43 completed
- 2597: CP#44 stopped (Reason: No Rel-8 solution expected (LS sent to SA2, but not prioritized in SA2)
- 2598: SP#40 maintenance & new OSA work moved to OMA. Rel-9 onwards 3GPP references to 22.127 changed to OMA Parlay Service Access Requirements (OMA-RD-Parlay_Service_Access-V1_0-20100427-A).
- 2599: SP#40 maintenance & new OSA work moved to OMA. Rel-9 onwards 3GPP references to 22.127 changed to OMA Parlay Service Access Requirements (OMA-RD-Parlay_Service_Access-V1_0-20100427-A).
- 2600: SP#40 maintenance & new OSA work moved to OMA
- 2601: SP#40 maintenance & new OSA work moved to OMA
- 2602: CP#40: Work moved to OMA
- 2603: CP#40 completed
- 2604: CP#40 completed
- 2605: CP#40 completed
- 2606: CP#40: Work moved to OMA
- 2607: SP#38 SP-070853 R8 CRs 22.127 OSA Stage 1. CP#40: Work moved to OMA
- 2608: SP#38 SP-070853 R8 CRs 22.127 OSA Stage 1. CP#40: Work moved to OMA
- 2609: SP#38 SP-070853 R8 CRs 22.127 OSA Stage 1. CP#40: Work moved to OMA
- 2610: SP#38 SP-070853 R8 CRs 22.127 OSA Stage 1. CP#40: Work moved to OMA
- 2611: SP#38 SP-070853 R8 CRs 22.127 OSA Stage 1. CP#40: Work moved to OMA
- 2612: SP#38 SP-070853 R8 CRs 22.127 OSA Stage 1. CP#40: Work moved to OMA
- 2613: SP#38 SP-070853 R8 CRs 22.127 OSA Stage 1. CP#40: Work moved to OMA
- 2614: CP#40 completed
- 2615: SP#38 SP-070853 R8 CRs 22.127 OSA Stage 1. CP#40: Work moved to OMA
- 2616: CP#40 completed
- 2617: CP#40 completed
- 2618: CP#40 completed
- 2619: CP#40 completed

| ID | WBS | Task | Duration | Start | Finish | Complete | Remaining | Baseline start | Baseline finish | Baseline duration | Total slack | Constraint | Resources | Work | Actual work | Acronym | WI rapporteur name | Release | MCC resp | Acronym_3GU_Export | TSG approved | PCG approved | Status Report | Special Focus Doc |
| --- | --- | --- | --- | --- | --- | --- | --- | --- | --- | --- | --- | --- | --- | --- | --- | --- | --- | --- | --- | --- | --- | --- | --- | --- |
| 2620 | 677 | **Paging Permission with Access Control (PPACR)** | 389d? | 2007-06-12 A | 2008-12-05 A | 100% |  | 2007-06-12 | 2008-12-05 | 389d? |  |  | S1; C1 | 9000h | 9000h | PPACR | NTT DoCoMo | Rel-8 | Alain | PPACR |  |  |  |  |
| 2621 | 677.1 | Stage 1 for PPACR | 69d? | 2007-06-12 A | 2007-09-14 A | 100% |  | 2007-06-12 | 2007-09-14 | 69d? |  | finish no earlier than 2007-09-14 | S1 | 552h | 552h | PPACR-S1 | NTT DoCoMo | Rel-8 | Alain | PPACR-S1 | SP-37 |  |  |  |
| 2622 | 677.2 | Stage 3 for PPACR (CT1) | 278d? | 2007-11-14 A | 2008-12-05 A | 100% |  | 2007-11-14 | 2008-12-05 | 278d? |  | finish no earlier than 2008-12-05 | C1 | 2224h | 2224h | PPACR-CT1 | NTT DoCoMo | Rel-8 | Frederic | PPACR-CT1 | CP-38 | PCG-21 |  |  |
| 2623 | 678 | Conformance Test Aspects – Paging Permission with Access Control (PPAC) | 61d? | 2010-09-17 A | 2010-12-10 A | 100% |  | 2010-09-17 | 2010-12-10 | 61d? |  | finish no earlier than 2010-12-10 | R5 | 488h | 488h | PPAC_UEConTest | NTT DoCoMo | Rel-8 | Ingbert | PPAC_UEConTest | RP-49 | PCG-25 | RP-101074 |  |
| 2624 | 679 | **Charging for multi-phases services** | 70d? | 2007-12-06 A | 2008-03-12 | 99% | 0d? | 2007-12-06 | 2008-03-12 | 70d? | 0d |  | S1 | 560h | 560h | CHRGMPH | Telecom Italia | Rel-8 | Alain | CHRGMPH | SP-38 | PCG-21 |  |  |
| 2625 | 679.1 | Stage 1 for CHRGMPH | 70d? | 2007-12-06 A | 2008-03-12 A | 100% |  | 2007-12-06 | 2008-03-12 | 70d? |  | start no earlier than 2007-12-06 | S1 | 560h | 560h | CHRGMPH-s1 | Telecom Italia | Rel-8 | Alain | CHRGMPH-s1 | SP-38 | PCG-21 |  |  |
| 2626 | 680 | **Home NodeB / eNodeB** | 327d? | 2007-12-06 A | 2009-03-06 A | 100% |  | 2007-12-06 | 2009-03-06 | 327d? |  |  | S1; C1; C4 | 10952h | 10952h | HomeNB | Vodafone | Rel-8 | Alain | HomeNB | SP-38 | PCG-21 |  | HNB |
| 2627 | 680.1 | Stage 1 for Home NodeB / eNodeB | 70d? | 2007-12-06 A | 2008-03-12 A | 100% |  | 2007-12-06 | 2008-03-12 | 70d? |  | start no earlier than 2007-12-06 | S1 | 560h | 560h | HomeNB-S1 | Vodafone | Rel-8 | Alain | HomeNB-S1 | SP-38 | PCG-21 |  | HNB |
| 2628 | 680.2 | Support of Closed Subscriber Group (CSG) | 66d? | 2008-12-05 A | 2009-03-06 A | 100% |  | 2008-12-05 | 2009-03-06 | 66d? |  | finish no earlier than 2009-03-06 | C4 | 528h | 528h |  | CT#42 | Rel-8 | Kimmo |  | CP-42 | PCG-22 |  | HNB |
| 2629 | 680.3 | CSG and Idle Mode Mobility for LTE Home eNodeB | 126d? | 2008-09-12 A | 2009-03-06 A | 100% |  | 2008-09-12 | 2009-03-06 | 126d? |  | finish no earlier than 2009-03-06 | C1 | 1008h | 1008h | HomeNB-LTE | Huawei | Rel-8 | Frederic | HomeNB-LTE | CP-41 | PCG-21 |  | HNB |
| 2630 | 680.4 | CSG and Idle Mode Mobility for 3G Home NodeB | 126d? | 2008-09-12 A | 2009-03-06 A | 100% |  | 2008-09-12 | 2009-03-06 | 126d? |  | finish no earlier than 2009-03-06 | C1 | 1008h | 1008h | HomeNB-3G | Qualcomm | Rel-8 | Frederic | HomeNB-3G | CP-41 | PCG-21 |  | HNB |
| 2631 | 681 | **UTRA HNB** | 326d? | 2008-03-07 A | 2009-06-04 A | 100% |  | 2008-03-07 | 2009-06-04 | 326d? |  |  | RP; S5 | 11008h | 11008h | HNB |  | Rel-8 | Issam | HNB | SP-39 | PCG-21 |  | HNB |
| 2632 | 681.1 | Support of UTRA HNB | 201d? | 2008-05-30 A | 2009-03-06 A | 100% |  | 2008-05-30 | 2009-03-06 | 201d? |  | finish no earlier than 2009-03-06 | R2 | 1608h | 1608h | HNB-supp | Huawei | Rel-8 | Yong-Jun | HNB-supp | SP-40 | PCG-21 | RP-090040 | HNB |
| 2633 | 681.2 | UTRAN Architecture for 3G HNB | 136d? | 2008-05-30 A | 2008-12-05 A | 100% |  | 2008-05-30 | 2008-12-05 | 136d? |  | finish no earlier than 2008-12-05 | R3 | 1088h | 1088h | HNB-arch | Alcatel-Lucent | Rel-8 | Juha | HNB-arch | SP-40 | PCG-21 | RP-090042 | HNB |
| 2634 | 681.3 | FDD Home NodeB RF requirements | 261d? | 2008-03-07 A | 2009-03-06 A | 100% |  | 2008-03-07 | 2009-03-06 | 261d? |  | finish no earlier than 2009-03-06 | R4 | 2088h | 2088h | HNB-RF | Motorola | Rel-8 | Issam | HNB-RF | SP-39 | PCG-21 | RP-090041 | HNB |
| 2635 | 681.4 | 3G Home NodeB OAM&P Type 1 Management Interface | 127d? | 2008-12-11 A | 2009-06-04 A | 100% |  | 2008-12-11 | 2009-06-04 | 127d? |  | finish no earlier than 2009-06-04 | S5 | 1008h | 1008h | HNB-3G_OAM | Huawei | Rel-8 | Mirko | HNB-3G_OAM | SP-42 | PCG-22 |  | HNB |
| 2636 | 682 | **UTRA HNB – UE Conformance Testing** | 327d? | 2009-03-06 A | 2010-06-04 A | 100% |  | 2009-03-06 | 2010-06-04 | 327d? |  |  | R5 | 5224h | 5224h | HNB-UEConTest |  | Rel-8 | Ingbert | HNB-UEConTest | RP-43 | PCG-22 |  | HNB |
| 2637 | 682.1 | Conformance Test Aspects – UTRA HNB (FDD) | 326d? | 2009-03-06 A | 2010-06-04 A | 100% |  | 2009-03-06 | 2010-06-04 | 326d? |  | finish no earlier than 2010-06-04 | R5 | 2608h | 2608h | HNB-UEConTestFDD | Huawei | Rel-8 | Ingbert | HNB-UEConTestFDD | RP-43 | PCG-22 | RP-100482 | HNB |
| 2638 | 683 | Lawful Interception in the 3GPP Rel-8 | 524d? | 2007-03-12 A | 2009-03-12 A | 100% |  | 2007-03-12 | 2009-03-12 | 524d? |  | finish no earlier than 2009-03-12 | S3 | 4192h | 4192h | LI8 | BMWI, Verizon | Rel-8 | Mirko | LI8 |  |  |  |  |
| 2639 | 684 | **Generic Bootstrapping Architecture Push Function** | 258d? | 2008-03-12 A | 2009-03-06 A | 100% |  | 2008-03-12 | 2009-03-06 | 258d? |  |  | S3; C1; C4 | 10596.8h | 10596.8h | GBAPush | Ericsson | Rel-8 | Mirko | GBAPush | SP-39 | PCG-21 |  |  |
| 2640 | 684.1 | SA3 part of GBAPush (33.223) | 193d? | 2008-03-12 A | 2008-12-05 A | 100% |  | 2008-03-12 | 2008-12-05 | 193d? |  | finish no earlier than 2008-12-05 | S3 | 1544h | 1544h | GBAPush | Ericsson | Rel-8 | Mirko |  | SP-39 | PCG-21 |  |  |
| 2641 | 684.2 | CT1 part of GBAPush | 178.8d? | 2008-03-12 A | 2009-03-06 A | 100% |  | 2008-03-12 | 2009-03-06 | 178.8d? |  | finish no earlier than 2009-03-06 | C1 | 1430.4h | 1430.4h | GBAPush | Ericsson | Rel-8 | Frederic |  | SP-39 | PCG-21 |  |  |
| 2642 | 684.3 | CT4 part of GBAPush | 178.8d? | 2008-03-12 A | 2009-03-06 A | 100% |  | 2008-03-12 | 2009-03-06 | 178.8d? |  | finish no earlier than 2009-03-06 | C4 | 1430.4h | 1430.4h | GBAPush | Ericsson | Rel-8 | Kimmo |  | SP-39 | PCG-21 |  |  |
| 2643 | 685 | Requirements and Test methods for Wideband Terminals | 197d? | 2008-03-12 A | 2008-12-11 A | 100% |  | 2008-03-12 | 2008-12-11 | 197d? |  | start no earlier than 2008-03-12 | S4 | 1576h | 1576h | RETEM_WB_T | FT, Ericsson | Rel-8 | Paolo | RETEM_WB_T |  |  |  |  |
| 2644 | 686 | Extending PSS and MBMS User Services for optimized Mobile TV | 266d? | 2007-12-06 A | 2008-12-11 A | 100% |  | 2007-12-06 | 2008-12-11 | 266d? |  | finish no earlier than 2008-12-11 | S4 | 2128h | 2128h | PSS_MBMS_OMTV | Ericsson | Rel-8 | Paolo | PSS_MBMS_OMTV |  |  |  |  |

Notes:
- 2620: CP#42 completed. Triggered by Study UID_330016 (PPAC). / WI rapporteur e-mail: Morita Takashi
- 2621: SP#37 completed / Impacted TSs and TRs: 22.011 / WI rapporteur e-mail: Morita Takashi
- 2622: CP#42 completed / Impacted TSs and TRs: 24.008, 23.122, 24.301
- 2623: RP#50 completed / Impacted TSs and TRs: UTRA 34.108, 34.123-1, 34.123-2, 34.123-3 / WI rapporteur e-mail: Takao.Shimizu.rp@nttdocomo.com
- 2624: SP#39 Stage 1 completed / Impacted TSs and TRs: 22.115 / WI rapporteur e-mail: Marco.DeLuca1@telecomitalia.it
- 2625: SP#39 completed / Impacted TSs and TRs: 22.115 / WI rapporteur e-mail: Marco.DeLuca1@telecomitalia.it
- 2626: CP#43 completed / WI rapporteur e-mail: John Watson
- 2627: SP#39 completed / Impacted TSs and TRs: 22.011, 22.115 / WI rapporteur e-mail: John Watson
- 2628: CP#43 completed. SP#42 SP-080874 22.011CR0141 confirmed Requirement to support roaming subscribers with CSG home network subscription but did NOT confirmed requirement for home network independent support of roamers in CSG / Impacted TSs and TRs: 29.002, 29.272, 23.008, 23.003 / WI rapporteur e-mail: Hannu Hietalahti
- 2629: CP#43 completed / Impacted TSs and TRs: 23.122, new (24.285, 24.301, 24.801) / WI rapporteur e-mail: zhang.peng@huawei.com
- 2630: CP#43 completed / Impacted TSs and TRs: 23.122, 24.008, new 24.285 / WI rapporteur e-mail: Osok Song
- 2631: SP#44 completed
- 2632: RP#43 completed / Impacted TSs and TRs: 25.304, 25.306, 25.331, new 25.367 / WI rapporteur e-mail: Yang Xudong (yangxudong@huawei.com)
- 2633: RP#42 completed / Impacted TSs and TRs: 25.401, 25.410, 25.412, 25.413, 25.414, 25.415, new (25.467, 25.468, 25.469) / WI rapporteur e-mail: Martin Warner (mw15@alcatel-lucent.com)
- 2634: RP#43 completed / Impacted TSs and TRs: 25.104, 25.141, new 25.967 / WI rapporteur e-mail: Ying Cai (yingcai@motorola.com)
- 2635: SP#44 completed. Complements work in BroadBand Forum / Impacted TSs and TRs: new (32.581, 32.582, 32.583, 32.584) / WI rapporteur e-mail: Zou Lan (zlan@huawei.com)
- 2636: RP#48 FDD completed. Testing for Feature UID_390033 UTRA HNB
- 2637: RP#48 completed / Impacted TSs and TRs: 34.108, 34.123-1, 34.123-2, 34.123-3 / WI rapporteur e-mail: Trica Li (trica_li@huawei.com)
- 2638: SP#43 completed / Impacted TSs and TRs: 33.106, 33.107, 33.108 / WI rapporteur e-mail: berthold.wilhelm@bnetza.de, ron_ryan@verizon.net
- 2639: CP#43 completed / WI rapporteur e-mail: Rolf Blom
- 2640: SP#42 completed 33.223 as Rel-8. TS 33.224 moved to Rel-9 under new UID_420039 / Impacted TSs and TRs: 33.223 / WI rapporteur e-mail: Rolf Blom
- 2641: CP#43 completed / Impacted TSs and TRs: 24.109 / WI rapporteur e-mail: Rolf Blom
- 2642: CP#43 completed / Impacted TSs and TRs: 29.109 / WI rapporteur e-mail: Rolf Blom
- 2643: SP#42 completed. SP#39 WID approved. / Impacted TSs and TRs: 26.131, 26.132 / WI rapporteur e-mail: stephane.ragot@orange-ftgroup.com, wanqing.shi@sonyericsson.com
- 2644: SP#42 completed. SP#38 WID approved. / Impacted TSs and TRs: 26.234, 26.346, 26.946 / WI rapporteur e-mail: thorsten.lohmar@ericsson.com

| ID | WBS | Task | Duration | Start | Finish | Complete | Baseline start | Baseline finish | Baseline duration | Constraint | Resources | Work | Actual work | Acronym | PCG approved | WI rapporteur name | Release | TSG approved | MCC resp | Acronym_3GU_Export | TSG stopped | PCG stopped |
| --- | --- | --- | --- | --- | --- | --- | --- | --- | --- | --- | --- | --- | --- | --- | --- | --- | --- | --- | --- | --- | --- | --- |
| 2645 | 687 | **Encoding formats, transport formats and media description signalling for interworking, QoE, and other enhancements to MTSI-MHI** | 331d? | 2007-12-06 A | 2009-03-12 A | 100% | 2007-12-06 | 2009-03-12 | 331d? |  | S4; C3; C4 | 14936h | 14936h | MTSI_eMHI | PCG-21 | Ericsson, Qualcomm | Rel-8 | SP-40 | Paolo | MTSI_eMHI |  |  |
| 2646 | 687.1 | MTSI Video - Dynamic Rate Adaptation/Signalling of Image Size | 331d? | 2007-12-06 A | 2009-03-12 A | 100% | 2007-12-06 | 2009-03-12 | 331d? | finish no earlier than 2009-03-12 | S4 | 2648h | 2648h | MTSI_eMHI-DRASIS |  | Qualcomm, Samsung | Rel-8 |  | Paolo | MTSI_eMHI-DRASIS |  |  |
| 2647 | 687.2 | CT3 part of Enhancement of interworking between MTSI and CS networks | 201d? | 2008-05-30 A | 2009-03-06 A | 100% | 2008-05-30 | 2009-03-06 | 201d? | finish no earlier than 2009-03-06 | C3 | 1608h | 1608h | MTSI_eMHI | PCG-21 | Huawei | Rel-8 | CP-40 | Adrian |  |  |  |
| 2648 | 687.3 | CT4 part of Enhancement of interworking between MTSI and CS networks | 201d? | 2008-05-30 A | 2009-03-06 A | 100% | 2008-05-30 | 2009-03-06 | 201d? | finish no earlier than 2009-03-06 | C4 | 1608h | 1608h | MTSI_eMHI | PCG-21 | Huawei | Rel-8 | CP-40 | Kimmo |  |  |  |
| 2649 | 687.4 | Deleted - CT1 part of Enhancement of interworking between MTSI and CS networks | 141d? | 2008-05-30 A | 2008-12-12 A | 100% | 2008-05-30 | 2008-12-12 | 141d? | start no earlier than 2008-05-30 | C1 | 1128h | 1128h | MTSI_eMHI | PCG-21 | Huawei | Rel-8 | CP-40 | Frederic |  | CP-42 |  |
| 2650 | 688 | **Rel-8 Operations, Administration, Maintenance and Provisioning (OAM&P)** | 1445d? | 2007-06-07 A | 2012-12-07 A | 100% | 2007-06-07 | 2012-12-07 | 1445d? |  | S5; C1; C4; IETF | 120270h | 120270h | OAM8 |  |  | Rel-8 |  | Mirko | OAM8 |  |  |
| 2651 | 688.1 | **Rel-8 Network Infrastructure Management** | 653d? | 2007-06-07 A | 2009-12-04 A | 100% | 2007-06-07 | 2009-12-04 | 653d? |  | S5 | 19464h | 19464h | OAM8-NIM |  |  | Rel-8 |  | Mirko | OAM8-NIM |  |  |
| 2652 | 688.1.1 | Telecom Management Methodology | 461d? | 2007-06-07 A | 2009-03-12 A | 100% | 2007-06-07 | 2009-03-12 | 461d? | finish no earlier than 2009-03-12 | S5 | 3688h | 3688h | OAM8-NIM |  | Ericsson | Rel-8 |  | Mirko |  |  |  |
| 2653 | 688.1.2 | Advanced Alarming on Itf-N | 266d? | 2007-06-07 A | 2008-06-12 A | 100% | 2007-06-07 | 2008-06-12 | 266d? | finish no earlier than 2008-12-11 | S5 | 2128h | 2128h | OAM8-NIM |  | Nokia Siemens Networks | Rel-8 |  | Mirko |  |  |  |
| 2654 | 688.1.3 | CN CS Bearer Transport Network (BTN) relative NRM | 266d? | 2007-06-07 A | 2008-06-12 A | 100% | 2007-06-07 | 2008-06-12 | 266d? | finish no earlier than 2008-12-11 | S5 | 2128h | 2128h | OAM8-NIM |  | China Mobile | Rel-8 |  | Mirko |  |  |  |
| 2655 | 688.1.4 | Alignment with eTOM and M.3060 architectural concepts | 210d? | 2008-02-22 A | 2008-12-11 A | 100% | 2008-02-22 | 2008-12-11 | 210d? | start no earlier than 2008-02-22 | S5 | 1680h | 1680h | OAM8-NIM | PCG-21 | TeliaSonera | Rel-8 | SP-39 | Mirko |  |  |  |
| 2656 | 688.1.5 | IRP SOAP Solution Sets | 201d? | 2008-06-05 A | 2009-03-12 A | 100% | 2008-06-05 | 2009-03-12 | 201d? | finish no earlier than 2009-03-12 | S5 | 1608h | 1608h | OAM8-NIM | PCG-21 | Ericsson | Rel-8 | SP-40 | Mirko |  |  |  |
| 2657 | 688.1.6 | Create missing specifications for IRP XML definitions | 52d? | 2009-09-24 A | 2009-12-04 A | 100% | 2009-09-24 | 2009-12-04 | 52d? | finish no earlier than 2010-03-12 | S5 | 416h | 416h | OAM8-NIM | PCG-23 | ZTE | Rel-8 | SP-45 | Mirko |  |  |  |
| 2658 | 688.1.7 | Deleted - End point modelling for reference point | 324d? | 2007-09-17 A | 2008-12-11 A | 100% | 2007-09-17 | 2008-12-11 | 324d? | finish no earlier than 2008-12-11 | S5 | 2592h | 2592h | OAM8-NIM |  | Motorola | Rel-8 | SP-37 | Mirko |  | SP-41 | PCG-21 |
| 2659 | 688.2 | **Rel-8 Performance Management** | 461d? | 2007-06-07 A | 2009-03-12 A | 100% | 2007-06-07 | 2009-03-12 | 461d? |  | S5 | 13712h | 13712h | OAM8-PM |  |  | Rel-8 |  | Mirko | OAM8-PM |  |  |
| 2660 | 688.2.1 | IP bearer network Performance measurement definitions | 396d? | 2007-06-07 A | 2008-12-11 A | 100% | 2007-06-07 | 2008-12-11 | 396d? | finish no earlier than 2008-12-11 | S5 | 3168h | 3168h | OAM8-PM |  | China Mobile | Rel-8 |  | Mirko |  |  |  |
| 2661 | 688.2.2 | HSUPA performance measurements | 396d? | 2007-06-07 A | 2008-12-11 A | 100% | 2007-06-07 | 2008-12-11 | 396d? | finish no earlier than 2008-12-11 | S5 | 3168h | 3168h | OAM8-PM |  | China Mobile | Rel-8 |  | Mirko |  |  |  |
| 2662 | 688.2.3 | Key Performance Indicators (KPIs) for UMTS and GSM | 461d? | 2007-06-07 A | 2009-03-12 A | 100% | 2007-06-07 | 2009-03-12 | 461d? | finish no earlier than 2009-03-12 | S5 | 3688h | 3688h | OAM8-PM |  | China Mobile | Rel-8 |  | Mirko |  |  |  |
| 2663 | 688.3 | **Rel-8 Trace Management** | 1249d? | 2008-03-07 A | 2012-12-07 A | 100% | 2008-03-07 | 2012-12-07 | 1249d? |  | C1; C4; IETF | 40854.4h | 40854.4h | OAM8-Trace |  |  | Rel-8 |  | Mirko | OAM8-Trace |  |  |
| 2664 | 688.3.1 | CT1 part of Service Level Tracing in IMS | 196d? | 2008-03-07 A | 2008-12-05 A | 100% | 2008-03-07 | 2008-12-05 | 196d? | finish no earlier than 2008-12-05 | C1 | 1568h | 1568h | OAM8-Trace |  | Vodafone | Rel-8 |  | Frederic |  |  |  |
| 2665 | 688.3.2 | (IETF) Service Level Tracing in IMS (draft-dawes-sipping-debug) | 717d? | 2008-03-07 A | 2012-12-07 A | 100% | 2008-03-07 | 2012-12-07 | 717d? | finish no earlier than 2012-12-07 | C1-IETF | 5736h | 5736h | OAM8-Trace | PCG-27 | Peter Dawes | Rel-8 | CP-52 | Frederic |  |  |  |
| 2666 | 688.3.3 | (IETF) Service Level Tracing in IMS (draft-dawes-sipping-debug-event) | 98d? | 2008-03-07 A | 2011-12-09 A | 100% | 2008-03-07 | 2011-12-09 | 98d? | finish no earlier than 2011-12-09 | C1-IETF | 768.04h | 768.04h | OAM8-Trace | PCG-27 | Peter Dawes | Rel-8 | CP-53 | Frederic |  |  |  |
| 2667 | 688.3.4 | CT4 part of Service Level Tracing in IMS | 175.4d? | 2008-03-07 A | 2008-12-05 A | 100% | 2008-03-07 | 2008-12-05 | 175.4d? | finish no earlier than 2008-12-05 | C4 | 1403.2h | 1403.2h | OAM8-Trace | PCG-21 | Vodafone | Rel-8 | CP-40 | Frederic |  |  |  |
| 2668 | 688.3.5 | Deleted - CT3 part of Service Level Tracing in IMS | 175.4d? | 2008-03-07 A | 2008-12-05 A | 100% | 2008-03-07 | 2008-12-05 | 175.4d? | finish no earlier than 2008-12-05 | C3 | 1403.2h | 1403.2h | OAM8-Trace | PCG-21 | Vodafone | Rel-8 | CP-40 | Adrian |  | CP-42 | PCG-22 |

Notes:
- 2645: TSG#43 completed / WI rapporteur e-mail: olle.franceschi@ericsson.com, nleung@qualcomm.com
- 2646: SP#43 completed / Impacted TSs and TRs: 26.114 / WI rapporteur e-mail: nleung@qualcomm.com & kyunghun.jung@samsung.com
- 2647: CP#43 completed / Impacted TSs and TRs: 29.163 / WI rapporteur e-mail: Tingfang Tang (tagna_online@huawei.com)
- 2648: CP#43 completed / Impacted TSs and TRs: 29.332 / WI rapporteur e-mail: Tingfang Tang (tagna_online@huawei.com)
- 2649: CP#42 stopped (No CT1-impact). WID updated CP-080422=>CP-080774 / WI rapporteur e-mail: Tingfang Tang (tagna_online@huawei.com)
- 2650: OAM8 is an umbrella Feature also for OAM&P related TEI8 type of changes that are not part of any other dedicated feature/WI / Impacted TSs and TRs: TR 30.818
- 2651: -
- 2652: SP#43 completed / Impacted TSs and TRs: 32.155, 32.153 / WI rapporteur e-mail: thomas.tovinger@ericsson.com
- 2653: SP#40 completed / Impacted TSs and TRs: 32.121, 32.122, 32.123 / WI rapporteur e-mail: SUERBAUM, Clemens
- 2654: SP#40 completed / Impacted TSs and TRs: 32.632, 32.633, 32.635 / WI rapporteur e-mail: Li Jian (lijian@chinamobile.com)
- 2655: SP#42 completed / Impacted TSs and TRs: 32.101/2, 32-series / WI rapporteur e-mail: tommy.berggren@teliasonera.com
- 2656: SP#43 completed / Impacted TSs and TRs: 32.111-7, 32.617, 32.417, 32.367, 32.347, 32.111-1, 32.111-2, 32.111-3, 32.111-5, 32.307, 32.317, 32.341, 32.342, 32.343, 32.345, 32.361, 32.362, 32.363, 32.365, 32.411, 32.412, 32.413, 32.415, 32.611, 32.612, 32.613, 32.615, 32.625 / WI rapporteur e-mail: edwin.tse@ericsson.com
- 2657: SP#46 completed. Create missing XML definitions specs for IRPs (Advanced Alarm Management, Communication Surveillance, Self-Configuration of Network Elements, Software Management) needed for implementation of Rel-8 Notification Log IRP (TS 32.33x) / Impacted TSs and TRs: new (32.125, 32.355, 32.505, 32.535), 32.150, 32.153, 32.335 / WI rapporteur e-mail: Shuqiang Huang (huangsq@zte.com.cn)
- 2658: SP#41 Work stopped. Contributions related to E-UTRAN/EPC to be submitted to UID_380036 E-UTRAN NRM IRP/ UID_380037 EPC NRM IRP / Impacted TSs and TRs: 32.152, 32.62/3/4x, 32.73x / WI rapporteur e-mail: Yizhi Yao (yzyao@motorola.com)
- 2659: - / WI rapporteur e-mail: Li Jian (lijian@chinamobile.com)
- 2660: SP#42 completed / Impacted TSs and TRs: 32.321, 32.322, 32.323, 32.325 / WI rapporteur e-mail: lilianyuan@chinamobile.com
- 2661: SP#42 completed / Impacted TSs and TRs: 32.405 / WI rapporteur e-mail: Li Jian (lijian@chinamobile.com)
- 2662: SP#43 completed / Impacted TSs and TRs: 32.410 / WI rapporteur e-mail: Li Jian (lijian@chinamobile.com), Liang Shuangchun (liangshuangchun@cmdi.chinamobile.com)
- 2663: -
- 2664: CP#42 completed / Impacted TSs and TRs: 24.323, 24.229 / WI rapporteur e-mail: peter.dawes@vodafone.com
- 2665: CP#58 Removed from Rel-8, Rel-9 and Rel-10 (Not completed internet-draft) / Impacted TSs and TRs: Rel-11 remains draft-dawes-dispatch-debug / WI rapporteur e-mail: peter.dawes@vodafone.com
- 2666: CP#54 Draft removed from 3GPP documentation, covered by draft-dawes-sipping-debug / Impacted TSs and TRs: draft-dawes-sipping-debug-event / WI rapporteur e-mail: peter.dawes@vodafone.com
- 2667: CP#42 completed / Impacted TSs and TRs: 29.228, 29.229 / WI rapporteur e-mail: peter.dawes@vodafone.com
- 2668: CP#42 stopped (No CT3-impact) / WI rapporteur e-mail: peter.dawes@vodafone.com

| ID | WBS | Task | Type | Duration | Start | Finish | Complete | Baseline start | Baseline finish | Baseline duration | Constraint | Resources | Work | Actual work | Acronym | Release | MCC resp | Acronym_3GU_Export | WI rapporteur name | WI rapporteur e-mail | PCG approved | TSG approved | PCG stopped | TSG stopped | Status Report |
| --- | --- | --- | --- | --- | --- | --- | --- | --- | --- | --- | --- | --- | --- | --- | --- | --- | --- | --- | --- | --- | --- | --- | --- | --- | --- |
| 2669 | 689 | **Rel-8 Charging Management small Enhancements** |  | 716d? | 2006-03-16 A | 2008-12-11 A | 100% | 2006-03-16 | 2008-12-11 | 716d? |  | S5 | 12544h | 12544h | CH8 | Rel-8 | Mirko | CH8 |  |  |  |  |  |  |  |
| 2670 | 689.1 | Online charging correlation |  | 457d? | 2006-03-16 A | 2007-12-14 A | 100% | 2006-03-16 | 2007-12-14 | 457d? | start no earlier than 2006-03-16 | S5 | 3656h | 3656h | CH8 | Rel-8 | Mirko |  | Orange | Chahine, Rony |  |  |  |  |  |
| 2671 | 689.2 | SMS online charging |  | 137d? | 2007-06-07 A | 2007-12-14 A | 100% | 2007-06-07 | 2007-12-14 | 137d? | finish no earlier than 2007-12-14 | S5 | 1096h | 1096h | CH8 | Rel-8 | Mirko |  | Vodafone | Gavin.Wong@vodafone.com |  |  |  |  |  |
| 2672 | 689.3 | Introduce Online Charging from SMS-SC into the SMS Charging Specifications |  | 61d? | 2008-09-18 A | 2008-12-11 A | 100% | 2008-09-18 | 2008-12-11 | 61d? | finish no earlier than 2008-12-11 | S5 | 488h | 488h | CH8 | Rel-8 | Mirko |  | Acision | erik.gebler@acision.com | PCG-21 | SP-41 |  |  |  |
| 2673 | 689.4 | Deleted - WLAN Offline Charging |  | 244d? | 2008-01-07 A | 2008-12-11 A | 100% | 2008-01-07 | 2008-12-11 | 244d? | finish no earlier than 2008-12-11 | S5 | 1952h | 1952h | CH8 | Rel-8 | Mirko |  | Alcatel-Lucent | maryse.gardella@alcatel-lucent.com | PCG-21 | SP-38 | PCG-22 | SP-42 |  |
| 2674 | 690 | **Conferencing enhancements for Mp interface** |  | 266d? | 2007-11-30 A | 2008-12-05 A | 100% | 2007-11-30 | 2008-12-05 | 266d? |  | C4 | 6384h | 6384h | eMp | Rel-8 | Kimmo | eMp | Huawei | Chencheng@huawei.com | PCG-21 |  |  |  |  |
| 2675 | 690.1 | Stage 2 for eMp |  | 266d? | 2007-11-30 A | 2008-12-05 A | 100% | 2007-11-30 | 2008-12-05 | 266d? | finish no earlier than 2008-12-11 | C4 | 2128h | 2128h | eMp | Rel-8 | Kimmo |  | Huawei | Chencheng@huawei.com | PCG-21 | CP-38 |  |  |  |
| 2676 | 690.2 | Stage 3 for eMp |  | 266d? | 2007-11-30 A | 2008-12-05 A | 100% | 2007-11-30 | 2008-12-05 | 266d? | finish no earlier than 2008-12-05 | C4 | 2128h | 2128h | eMp | Rel-8 | Kimmo |  | Huawei | Chencheng@huawei.com | PCG-21 | CP-38 |  |  |  |
| 2677 | 691 | **Contact Manager for 3GPP UICC applications** |  | 642d? | 2006-06-22 A | 2008-12-05 A | 100% | 2006-06-22 | 2008-12-05 | 642d? |  | C6 | 13352h | 13352h | eUPHBOOK | Rel-8 | Xavier | eUPHBOOK | Gemalto | Jacques.seif@gemalto.com |  |  |  |  |  |
| 2678 | 691.1 | Requirements for Contact Manager |  | 392d? | 2006-06-22 A | 2007-12-21 A | 100% | 2006-06-22 | 2007-12-21 | 392d? | finish no earlier than 2007-12-21 | C6 | 3136h | 3136h | eUPHBOOK-St1 | Rel-8 | Xavier | eUPHBOOK-St1 | Gemalto | Jacques.seif@gemalto.com |  |  |  |  |  |
| 2679 | 691.2 | External interface for eUPHBOOK |  | 220d? | 2007-05-07 A | 2008-03-07 A | 100% | 2007-05-07 | 2008-03-07 | 220d? | finish no earlier than 2008-03-07 | C6 | 1760h | 1760h | eUPHBOOK-Ext_Spec | Rel-8 | Xavier | eUPHBOOK-Ext_Spec | Gemalto | Jacques.seif@gemalto.com |  |  |  |  |  |
| 2680 | 691.3 | Internal interface for eUPHBOOK |  | 415d? | 2007-05-07 A | 2008-12-05 A | 100% | 2007-05-07 | 2008-12-05 | 415d? | finish no earlier than 2008-12-05 | C6 | 3320h | 3320h | eUPHBOOK-Int_Spec | Rel-8 | Xavier | eUPHBOOK-Int_Spec | Gemalto | Jacques.seif@gemalto.com |  | CP-37 |  |  |  |
| 2681 | 691.4 | Deleted - Implementation of eUPHBOOK | milestone | 0d? | 2007-06-21 A | 2007-06-21 A | 100% | 2007-06-21 | 2007-06-21 | 0d? | start no earlier than 2007-06-21 | C6 |  |  | eUPHBOOK-St23 | Rel-8 | Xavier | eUPHBOOK-St23 | Giesecke & Devrient | Claus Dietze |  |  |  | SP-33 |  |
| 2682 | 692 | **Rel-8 LTE – 3G Long Term Evolution - Evolved Packet System RAN part** |  | 644d? | 2006-09-25 A | 2009-03-12 A | 100% | 2006-09-25 | 2009-03-12 | 644d? |  | RP; S5 | 50048h | 50048h | LTE | Rel-8 |  | LTE | NTT DoCoMo | Takehiro Nakamura (nakamurata@nttdocomo.co.jp) |  |  |  |  | RP-080741 |
| 2683 | 692.1 | LTE – Physical Layer |  | 380d? | 2006-09-25 A | 2008-03-07 A | 100% | 2006-09-25 | 2008-03-07 | 380d? | finish no earlier than 2007-09-14 | R1 | 3040h | 3040h | LTE-Phys | Rel-8 | Patrick | LTE-Phys | NTT DoCoMo | Sadayuki Abeta |  |  |  |  | RP-080741 |
| 2684 | 692.2 | LTE – Radio Interface Layer 2 and 3 Protocol Aspect |  | 575d? | 2006-09-25 A | 2008-12-05 A | 100% | 2006-09-25 | 2008-12-05 | 575d? | finish no earlier than 2008-12-11 | R2 | 4600h | 4600h | LTE-L23 | Rel-8 | Yong-Jun | LTE-L23 | Nokia Siemens Networks | benoist.sebire@nokia.com |  |  |  |  | RP-080741 |
| 2685 | 692.3 | LTE – eUTRAN Interfaces |  | 575d? | 2006-09-25 A | 2008-12-05 A | 100% | 2006-09-25 | 2008-12-05 | 575d? | finish no earlier than 2008-12-11 | R3 | 4600h | 4600h | LTE-interfaces | Rel-8 | Juha | LTE-interfaces | Ericsson | Martin Israelsson |  |  |  |  | RP-080741 |
| 2686 | 692.4 | LTE – Evolved UTRA and UTRAN RF Radio Transmission/Reception, System Performance Requirements and Conformance Testing |  | 575d? | 2006-09-25 A | 2008-12-05 A | 100% | 2006-09-25 | 2008-12-05 | 575d? | finish no earlier than 2008-12-11 | R4 | 4600h | 4600h | LTE-RF | Rel-8 | Issam | LTE-RF | Nokia Siemens Networks | Tuomo Saynajakangas |  |  |  |  | RP-080741 |
| 2687 | 692.5 | LTE – FDD repeaters |  | 386d? | 2007-09-14 A | 2009-03-06 A | 100% | 2007-09-14 | 2009-03-06 | 386d? | finish no earlier than 2009-03-06 | R4 | 3088h | 3088h | LTE-Repeaters | Rel-8 | Issam | LTE-Repeaters | Powerwave Technologies, Andrew Wireless | ralf.michanikl@andrew.com, Alf.Ahlstrom@pwav.com |  | RP-37 |  |  | RP-090037 |
| 2688 | 692.6 | **E-UTRAN Data Definitions** |  | 389d? | 2007-09-17 A | 2009-03-12 A | 100% | 2007-09-17 | 2009-03-12 | 389d? |  | S5 | 13096h | 13096h | E-UTRAN-OAM | Rel-8 | Mirko | E-UTRAN-OAM |  |  | PCG-21 | SP-39 |  |  |  |
| 2689 | 692.6.1 | Subscriber and Equipment Trace for E-UTRAN and EPC |  | 389d? | 2007-09-17 A | 2009-03-12 A | 100% | 2007-09-17 | 2009-03-12 | 389d? | finish no earlier than 2009-03-12 | S5 | 3112h | 3112h | E-UTRAN-OAM | Rel-8 | Mirko |  | Ericsson | robert.petersen@ericsson.com |  | SP-37 |  |  |  |
| 2690 | 692.6.2 | E-UTRAN Network Resource Model (NRM) Integration Reference Point (IRP) |  | 309d? | 2008-01-07 A | 2009-03-12 A | 100% | 2008-01-07 | 2009-03-12 | 309d? | finish no earlier than 2009-03-12 | S5 | 2472h | 2472h | E-UTRAN-OAM | Rel-8 | Mirko |  | Ericsson | ELMDAHL, Per | PCG-21 | SP-38 |  |  |  |
| 2691 | 692.6.3 | Performance measurements for E-UTRAN |  | 275d? | 2008-02-22 A | 2009-03-12 A | 100% | 2008-02-22 | 2009-03-12 | 275d? | finish no earlier than 2009-03-12 | S5 | 2200h | 2200h | E-UTRAN-OAM | Rel-8 | Mirko |  | Motorola, Huawei | Yizhi Yao (yzyao@motorola.com) | PCG-21 | SP-39 |  |  |  |
| 2692 | 692.6.4 | Key Performance Indicators (KPIs) for E-UTRAN |  | 275d? | 2008-02-22 A | 2009-03-12 A | 100% | 2008-02-22 | 2009-03-12 | 275d? | finish no earlier than 2009-03-12 | S5 | 2200h | 2200h | E-UTRAN-OAM | Rel-8 | Mirko |  | Ericsson | ulf.hubinette@ericsson.com | PCG-21 | SP-39 |  |  |  |

Notes:
- 2669: CH8 is an umbrella Feature also for OAM&P related TEI8 type of changes that are not part of any other dedicated feature/WI / Impacted TSs and TRs: TR 30.818
- 2670: SP#38 completed / Impacted TSs and TRs: 32.296
- 2671: SP#38 completed / Impacted TSs and TRs: 32.240, 32.299, new 32.274
- 2672: SP#42 completed. Linked to SA2 UID 32081 (Support of SMS over IP networks) and CT4 UID 340016 (Routeing of MT-SMS via the HPLMN). / Impacted TSs and TRs: 32.274, 32.299
- 2673: SP#42 stopped / Impacted TSs and TRs: 32.252, 32.298, 32.299
- 2674: CP#42 completed
- 2675: CP#42 completed / Impacted TSs and TRs: 23.333
- 2676: CP#42 completed / Impacted TSs and TRs: 29.333
- 2677: CP#42 completed. CP#40: WID updated CP-070622=>CP-080382. aka Enhanced USIM phonebook
- 2678: CP#38 completed / Impacted TSs and TRs: 21.111
- 2679: CP#39 completed / Impacted TSs and TRs: new 31.220
- 2680: CP#42 completed / Impacted TSs and TRs: new 31.221
- 2681: SP#33 stopped / Impacted TSs and TRs: 31.102
- 2682: RP#43 completed. Role model for SAE/LTE system wide project management by SA2 in SP-060166 / Impacted TSs and TRs: LTE 36.300, 36.938
- 2683: RP#39 completed / Impacted TSs and TRs: 36.201, 36.211, 36.212, 36.213, 36.214, 25.215, 25.225
- 2684: RP#42 completed / Impacted TSs and TRs: 36.302, 36.304, 36.306, 36.314, 36.321, 36.322, 36.323, 36.331, 25.302, 25.304, 25.331
- 2685: RP#42 completed / Impacted TSs and TRs: 36.401, 36.410, 36.411, 36.412, 36.413, 36.414, 36.420, 36.421, 36.422, 36.423, 36.424, 25.413
- 2686: RP#42 completed. RP#47 abandoned draft 36.801, 36.803, 36.804 / Impacted TSs and TRs: 36.101, 36.104, 36.113, 36.124, 36.133, 36.141, 36.942, 25.123, 25.133
- 2687: RP#43 completed. RP#47 create Rel-9 TR 36.956 (see R4-100386, RP-100320_RAN4 Report) / Impacted TSs and TRs: 36.106, 36.143, 25.113
- 2688: SP#43 completed
- 2689: SP#43 completed / Impacted TSs and TRs: 32.421, 2.422, 32.423, 2.441, 32.442, 32.443, 32.445
- 2690: SP#43 completed / Impacted TSs and TRs: new (32.761, 32.762, 32.763, 32.765)
- 2691: SP#43 completed / Impacted TSs and TRs: new 32.425
- 2692: SP#43 completed / Impacted TSs and TRs: new (32.450, 32.451)

| ID | WBS | Task | Duration | Start | Finish | Complete | Baseline start | Baseline finish | Baseline duration | Constraint | Resources | Work | Actual work | Acronym | PCG approved | WI rapporteur name | WI rapporteur e-mail | Release | TSG approved | MCC resp | Special Focus Doc | Acronym_3GU_Export | Status Report | PCG stopped | TSG stopped |
| --- | --- | --- | --- | --- | --- | --- | --- | --- | --- | --- | --- | --- | --- | --- | --- | --- | --- | --- | --- | --- | --- | --- | --- | --- | --- |
| 2693 | 692.7 | **Self-Organizing Networks (SON)** | 210d? | 2008-02-22 A | 2008-12-11 A | 100% | 2008-02-22 | 2008-12-11 | 210d? |  | S5 | 6720h | 6720h | LTE_SON-OAM | PCG-21 | Vodafone | GOMPAKIS, Panagiotis | Rel-8 | SP-39 | Mirko | SON | LTE_SON-OAM |  |  |  |
| 2694 | 692.7.1 | SON Concepts and requirements | 210d? | 2008-02-22 A | 2008-12-11 A | 100% | 2008-02-22 | 2008-12-11 | 210d? |  | S5 | 1680h | 1680h | LTE_SON-OAM | PCG-21 | Vodafone | GOMPAKIS, Panagiotis | Rel-8 | SP-39 | Mirko |  |  |  |  |  |
| 2695 | 692.7.2 | Self-Establishment of eNBs, including automated Software Management | 210d? | 2008-02-22 A | 2008-12-11 A | 100% | 2008-02-22 | 2008-12-11 | 210d? | start no earlier than 2008-02-22 | S5 | 1680h | 1680h | LTE_SON-OAM | PCG-21 | Nokia Siemens Networks | SUERBAUM, Clemens | Rel-8 | SP-39 | Mirko |  |  |  |  |  |
| 2696 | 692.7.3 | SON Automatic Neighbour Relations (ANR) List Management | 210d? | 2008-02-22 A | 2008-12-11 A | 100% | 2008-02-22 | 2008-12-11 | 210d? | finish no earlier than 2008-12-11 | S5 | 1680h | 1680h | LTE_SON-OAM | PCG-21 | Ericsson | edwin.tse@ericsson.com | Rel-8 | SP-39 | Mirko |  |  |  |  |  |
| 2697 | 693 | **Rel-8 LTE – Terminal Conformance Test Specification** | 657d? | 2007-06-01 A | 2009-12-04 A | 100% | 2007-06-01 | 2009-12-04 | 657d? |  | R5 | 14336h | 14336h | LTE-UEConTest |  |  |  | Rel-8 |  | Ingbert |  | LTE-UEConTest |  |  |  |
| 2698 | 693.1 | 3G LTE – Terminal Protocol Conformance Test Specifications | 657d? | 2007-06-01 A | 2009-12-04 A | 100% | 2007-06-01 | 2009-12-04 | 657d? | finish no earlier than 2009-12-04 | R5 | 5256h | 5256h | LTE-UEConTest_SIG |  | NEC, Motorola | david.lecompte@nectech.fr, Jacob.John@motorola.com | Rel-8 |  | Ingbert |  | LTE-UEConTest_SIG | RP-091060 |  |  |
| 2699 | 693.2 | LTE – Terminal Radio Transmission and Reception Conformance Test Specifications | 657d? | 2007-06-01 A | 2009-12-04 A | 100% | 2007-06-01 | 2009-12-04 | 657d? |  | R5 | 5256h | 5256h | LTE-UEConTest_RF |  | Agilent | andrea_leonardi@agilent.com | Rel-8 |  | Ingbert |  | LTE-UEConTest_RF | RP-091059 |  |  |
| 2700 | 694 | **Rel-8 Improvements of the Radio Interface** | 525d? | 2007-03-05 A | 2009-03-06 A | 100% | 2007-03-05 | 2009-03-06 | 525d? |  | RP | 18152h | 18152h | RInImp8 |  |  |  | Rel-8 |  | Issam |  | RInImp8 |  |  |  |
| 2701 | 694.1 | UMTS 1500 MHz | 140d? | 2007-03-05 A | 2007-09-14 A | 100% | 2007-03-05 | 2007-09-14 | 140d? | finish no earlier than 2007-09-14 | R4 | 1120h | 1120h | RInImp8-UMTS1500 |  | NTT DoCoMo | Takehiro Nakamura (nakamurata@nttdocomo.co.jp) | Rel-8 |  | Issam |  | RInImp8-UMTS1500 | RP-070526 |  |  |
| 2702 | 694.2 | UMTS 700 MHz FDD | 325d? | 2007-03-05 A | 2008-05-30 A | 100% | 2007-03-05 | 2008-05-30 | 325d? | finish no earlier than 2008-06-12 | R4 | 2600h | 2600h | RInImp8-UMTS700 |  | Nokia | Tuomo Saynajakangas | Rel-8 |  | Issam |  | RInImp8-UMTS700 | RP-080260 |  |  |
| 2703 | 694.3 | UMTS 1880 MHz TDD | 126d? | 2008-09-12 A | 2009-03-06 A | 100% | 2008-09-12 | 2009-03-06 | 126d? | finish no earlier than 2009-03-09 | R4 | 1008h | 1008h | RInImp9-UMTS1880TDD | PCG-21 | CATT | Yuexia Song (songyuexia@catt.cn) | Rel-8 | RP-41 | Issam |  | RInImp9-UMTS1880TDD | RP-090044 |  |  |
| 2704 | 694.4 | UMTS 2300 MHz TDD LCR | 195d? | 2007-12-17 A | 2008-09-12 A | 100% | 2007-12-17 | 2008-09-12 | 195d? | finish no earlier than 2008-09-12 | R4 | 1560h | 1560h | RInImp8-UMTS2300TDD | PCG-21 | CATT | Yuexia Song (songyuexia@catt.cn) | Rel-8 | RP-38 | Issam |  | RInImp8-UMTS2300TDD | RP-080517 |  |  |
| 2705 | 694.5 | Further Improved Minimum Performance Requirements for HSDPA UE (FDD) - Two-Branch Interference Cancellation | 265d? | 2007-03-05 A | 2008-03-07 A | 100% | 2007-03-05 | 2008-03-07 | 265d? | finish no earlier than 2008-03-12 | R4 | 2120h | 2120h | RInImp8-2BIC |  | AT&T | Marc Grant | Rel-8 |  | Issam |  | RInImp8-2BIC | RP-080041 |  |  |
| 2706 | 694.6 | CS Voice Service over HSPA | 167d? | 2007-07-19 A | 2008-03-07 A | 100% | 2007-07-19 | 2008-03-07 | 167d? |  | R2 | 1336h | 1336h | RInImp8-CsHspa |  | Nokia Siemens Networks | woonhee.hwang@nsn.com | Rel-8 | RP-37 | Yong-Jun |  | RInImp8-CsHspa | RP-080042 |  |  |
| 2707 | 694.7 | Performance requirements for 15 code reception with 16QAM/QPSK (FDD) | 126d? | 2007-06-11 A | 2008-03-07 A | 100% | 2007-06-11 | 2008-03-07 | 126d? | finish no earlier than 2008-06-12 | R4 | 1008h | 1008h | RInImp8-Hsdpa15codes |  | Vodafone | tim.frost@vodafone.com | Rel-8 | RP-37 | Issam |  | RInImp8-Hsdpa15codes | RP-080043 |  |  |
| 2708 | 694.8 | Deleted - UMTS 2300 MHz FDD/TDD | 400d? | 2007-03-05 A | 2008-09-12 A | 100% | 2007-03-05 | 2008-09-12 | 400d? | finish no earlier than 2008-12-11 | R4 | 3200h | 3200h | RInImp8-UMTS2300 |  | AT&T | Marc Grant | Rel-8 |  | Issam |  | RInImp8-UMTS2300 | RP-080515 | PCG-21 | RP-41 |
| 2709 | 695 | **Rel-8 Improvements of the Radio Interface - UE Conformance Testing** | 396d? | 2007-06-01 A | 2008-12-05 A | 100% | 2007-06-01 | 2008-12-05 | 396d? |  | R5 | 6256h | 6256h |  |  |  |  | Rel-8 |  | Ingbert |  |  |  |  |  |
| 2710 | 695.1 | Conformance Test Aspects – CS Voice Service over HSPA | 336d? | 2007-06-01 A | 2008-09-12 A | 100% | 2007-06-01 | 2008-09-12 | 336d? | finish no earlier than 2008-09-12 | R5 | 2688h | 2688h | RInImp8-CsHspa_UEConTest |  | Huawei | baoyi@huawei.com | Rel-8 |  | Ingbert |  | RInImp8-CsHspa_UEConTest | RP-080542 |  |  |
| 2711 | 695.2 | Conformance Test Aspects – Performance requirements for 15 code reception with 16QAM/QPSK (FDD) | 195d? | 2008-03-07 A | 2008-12-05 A | 100% | 2008-03-07 | 2008-12-05 | 195d? | finish no earlier than 2008-12-05 | R5 | 1560h | 1560h | RInImp8-UEConTest_ Hsdpa15codes | PCG-21 | Ericsson | Mikael.Ziren@Ericsson.com | Rel-8 | RP-40 | Ingbert |  | RInImp8-UEConTest_ Hsdpa15codes | RP-080818 |  |  |
| 2712 | 696 | **Rel-8 RAN improvements** | 520d? | 2007-06-04 A | 2009-05-29 A | 100% | 2007-06-04 | 2009-05-29 | 520d? |  | RP | 37481.6h | 37481.6h |  |  |  |  | Rel-8 |  |  |  |  |  |  |  |
| 2713 | 696.1 | Combination of 64QAM and MIMO for HSDPA (FDD) | 205d? | 2007-06-04 A | 2008-09-12 A | 100% | 2007-06-04 | 2008-09-12 | 205d? | finish no earlier than 2008-09-12 | R1 | 1640h | 1640h | RANimp-64QamMimoHsdpa |  | Ericsson | Johan.Bergman@ericsson.com | Rel-8 |  | Patrick |  | RANimp-64QamMimoHsdpa | RP-080518 |  |  |
| 2714 | 696.2 | Improved L2 for uplink | 186d? | 2007-09-14 A | 2008-05-30 A | 100% | 2007-09-14 | 2008-05-30 | 186d? | finish no earlier than 2008-05-30 | R2 | 1488h | 1488h | RANimp-UplinkL2dataRates |  | Ericsson | Janne.Peisa@ericsson.com | Rel-8 | RP-37 | Yong-Jun |  | RANimp-UplinkL2dataRates | RP-080265 |  |  |
| 2715 | 696.3 | Enhanced Uplink for CELL_FACH State in FDD | 321d? | 2007-09-14 A | 2008-12-05 A | 100% | 2007-09-14 | 2008-12-05 | 321d? | finish no earlier than 2008-12-12 | R2 | 2568h | 2568h | RANimp-UplinkEnhState |  | Nokia Siemens Networks | markus.wimmer@nsn.com | Rel-8 | RP-37 | Yong-Jun |  | RANimp-UplinkEnhState | RP-080804 |  |  |
| 2716 | 696.4 | Enhanced UE Discontinuous Reception (DRX) for FDD | 261d? | 2007-09-14 A | 2008-09-12 A | 100% | 2007-09-14 | 2008-09-12 | 261d? | finish no earlier than 2008-09-12 | R2 | 2088h | 2088h | RANimp-DRX |  | Nokia | luis.barreto@nokia.com | Rel-8 | RP-37 | Yong-Jun |  | RANimp-DRX | RP-080520 |  |  |
| 2717 | 696.5 | Enhancements for Serving Radio Network Subsystem (SRNS) Relocation Procedure | 261d? | 2007-09-14 A | 2008-09-12 A | 100% | 2007-09-14 | 2008-09-12 | 261d? | finish no earlier than 2008-09-12 | R3 | 2088h | 2088h | RANimp-SrnsReloc |  | Nokia Siemens Networks | masatoshi.nakamata@nsn.com | Rel-8 | RP-37 | Juha |  | RANimp-SrnsReloc | RP-080521 |  |  |
| 2718 | 696.6 | Enhancements for FDD HSPA Evolution | 321d? | 2007-09-14 A | 2008-12-05 A | 100% | 2007-09-14 | 2008-12-05 | 321d? | finish no earlier than 2008-12-05 | R3; R2 | 5136h | 5136h | RANimp-HSPAEvo |  | Nokia Siemens Networks | masatoshi.nakamata@nsn.com | Rel-8 | RP-37 | Juha |  | RANimp-HSPAEvo | RP-080805 |  |  |
| 2719 | 696.7 | 64QAM for 1.28 Mcps TDD HSDPA | 264d? | 2007-12-04 A | 2008-12-05 A | 100% | 2007-12-04 | 2008-12-05 | 264d? | finish no earlier than 2008-12-05 | R1 | 2112h | 2112h | RANimp-64Qam1.28TDD | PCG-21 | ZTE | zfmail@zte.com.cn | Rel-8 | RP-38 | Patrick |  | RANimp-64Qam1.28TDD | RP-080806 |  |  |
| 2720 | 696.8 | Enhanced CELL_FACH state in 1.28 Mcps TDD | 264d? | 2007-12-04 A | 2008-12-05 A | 100% | 2007-12-04 | 2008-12-05 | 264d? | finish no earlier than 2008-12-12 | R2 | 2112h | 2112h | RANimp-EnhState1.28TDD | PCG-21 | ZTE | zhang.yincheng@zte.com.cn | Rel-8 | RP-38 | Yong-Jun |  | RANimp-EnhState1.28TDD | RP-080807 |  |  |
| 2721 | 696.9 | Continuous Connectivity for packet data users for 1.28 Mcps TDD | 321d? | 2008-03-07 A | 2009-05-29 A | 100% | 2008-03-07 | 2009-05-29 | 321d? | finish no earlier than 2009-05-29 | R1 | 2568h | 2568h | RANimp-LCRCPC | PCG-21 | TD Tech | chenying@td-tech.com | Rel-8 | RP-39 | Patrick |  | RANimp-LCRCPC | RP-090394 |  |  |
| 2722 | 696.10 | HSPA VoIP to WCDMA/GSM CS continuity | 261d? | 2008-03-07 A | 2009-03-06 A | 100% | 2008-03-07 | 2009-03-06 | 261d? | finish no earlier than 2009-03-06 | R2 | 2088h | 2088h | RANimp-HSPAVoIP | PCG-21 | Nokia | Simone.Provvedi@nokia.com | Rel-8 | RP-39 | Yong-Jun |  | RANimp-HSPAVoIP | RP-090050 |  |  |
| 2723 | 696.11 | HS-DSCH Serving Cell Change Enhancements | 196d? | 2008-03-07 A | 2008-12-05 A | 100% | 2008-03-07 | 2008-12-05 | 196d? | finish no earlier than 2008-12-12 | R2 | 1568h | 1568h | RANimp-HSDSCH | PCG-21 | Ericsson | henrik.enbuske@ericsson.com | Rel-8 | RP-39 | Yong-Jun |  | RANimp-HSDSCH | RP-080811 |  |  |
| 2724 | 696.12 | MIMO for 1.28 Mcps TDD. Linked to Rel-8 Study on Scope of future HSPA Evolution for 1.28 Mcps TDD (UID_370041) TR 25.824 | 351.6d? | 2008-01-24 A | 2009-05-29 A | 100% | 2008-01-24 | 2009-05-29 | 351.6d? | finish no earlier than 2009-05-29 | R1; R4 | 5625.6h | 5625.6h | RANimp-MIMOLCR | PCG-21 | CATT | wangke@datangmobile.cn | Rel-8 | RP-40 | Patrick |  | RANimp-MIMOLCR | RP-090313 |  |  |
| 2725 | 696.13 | Dual-Cell HSDPA operation on adjacent carriers | 140d? | 2008-11-17 A | 2009-05-29 A | 100% | 2008-11-17 | 2009-05-29 | 140d? | finish no earlier than 2009-05-29 | R1; R4 | 2240h | 2240h | RANimp-DCHSDPA | PCG-21 | Ericsson | johan.bergman@ericsson.com | Rel-8 | RP-40 | Patrick |  | RANimp-DCHSDPA | RP-080814 |  |  |

Notes:
- 2693: SP#42 completed (WT UID_390007 moved to Rel-9)
- 2694: SP#42 completed / Impacted TSs and TRs: new 32.500
- 2695: SP#42 completed / Impacted TSs and TRs: new (32.501, 32.502, 32.503, 32.531, 32.532, 32.533)
- 2696: SP#42 completed / Impacted TSs and TRs: 32.761, 32.762, 32.763, 32.765, new 32.511
- 2697: Testing for Feature UID_20068 (LTE)
- 2698: RP#46 completed / Impacted TSs and TRs: 36.521-1, 36.521-2, 36.508, 36.509, 36.523-1, 36.523-2, 36.523-3
- 2699: RP#46 completed. RP#50 TR 36.903 v100 for Approval / Impacted TSs and TRs: 36.521-1, 36.521-2, 36.521-3, new TR 36.903
- 2700: -
- 2701: RP#37 completed / Impacted TSs and TRs: 25.101, 25.104, 25.133, 25.141, 25.331, 25.942, 25.306, 25.307, 34.121
- 2702: RP#40 completed / Impacted TSs and TRs: 25.101, 25.104, 25.133, 25.141, 25.331, 25.942, 25.306, 25.307, 34.121
- 2703: RP#43 completed / Impacted TSs and TRs: 25.102, 25.105, 25.113, 25.123, 25.142, 34.124, 25.307
- 2704: RP#41 completed. RP#47 abandoned draft 25.828 / Impacted TSs and TRs: 25.102, 25.105, 25.113, 25.123, 25.142, 34.124, 25.306, 25.331, 34.122
- 2705: RP#39 completed / Impacted TSs and TRs: 25.101
- 2706: RP#39 completed / Impacted TSs and TRs: 25.323, 25.331, 25.322
- 2707: RP#39 completed / Impacted TSs and TRs: 25.101
- 2708: RP#41 stopped / Impacted TSs and TRs: 25.101, 25.104, 25.133, 25.141, 25.331, 25.942, 25.306, 25.307, 34.121
- 2709: 05/08: Linked to Feature UID_20028 (RInImp)
- 2710: RP#41 completed / Impacted TSs and TRs: 34.108, 34.123-1, 34.123-2, 34.123-3
- 2711: RP#42 completed / Impacted TSs and TRs: 34.121-1, 34.121-2
- 2712: -
- 2713: RP#41 completed / Impacted TSs and TRs: 25.308, 25.211, 25.212, 25.213, 25.306, 25.331, 25.433, 25.435, 25.423, 25.425, 25.101, 25.104, 25.141
- 2714: RP#40 completed. Linked to UID_370037 Enhanced Uplink for CELL_FACH State in FDD / Impacted TSs and TRs: 25.319, 25.301, 25.306, 25.321, 25.331, 25.433, 25.435, 25.423, 25.425, 25.427
- 2715: RP#42 completed. Linked to UID_370036 Improved L2 for uplink / Impacted TSs and TRs: 25.309, 25.211, 25.214, 25.321, 25.331, 25.423, 25.433
- 2716: RP#41 completed. Continuation of Rel-7 work item "Continuous connectivity for packet data users" UID_20046. / Impacted TSs and TRs: 25.306, 25.308, 25.321, 25.331, 25.423
- 2717: RP#41 completed. Linked to UID_370040 Enhancements for FDD HSPA Evolution / Impacted TSs and TRs: 25.306, 25.308, 25.321, 25.331, 25.423, 25.433, 25.214, 25.133
- 2718: RP#42 completed. Triggered by Rel-7 Study on Scope of future FDD HSPA Evolution (UID_20065) TR 25.999 / Impacted TSs and TRs: 25.401, 25.413, 25.420, 25.423, 25.427, 25.433, 25.446, 25.301, 25.346
- 2719: RP#42 completed. Linked to Rel-8 Study on Scope of future HSPA Evolution for 1.28 Mcps TDD (UID_370041) TR 25.824 / Impacted TSs and TRs: 25.102, 25.105, 25.123, 25.142, 25.201, 25.221, 25.222, 25.223, 25.224, 25.306, 25.308, 25.321, 25.331, 25.423, 25.433
- 2720: RP#42 completed. Linked to Rel-8 Study on Scope of future HSPA Evolution for 1.28 Mcps TDD (UID_370041) TR 25.824 / Impacted TSs and TRs: 25.123, 25.221, 25.222, 25.224, 25.301, 25.302, 25.304, 25.306, 25.308, 25.319, 25.321, 25.331, 25.401, 25.423, 25.425, 25.433, 25.435
- 2721: RP#44 completed. Linked to Rel-8 Study on Scope of future HSPA Evolution for 1.28 Mcps TDD (UID_370041) TR 25.824 / Impacted TSs and TRs: 25.929, 25.308, 25.319
- 2722: RP#43 completed / Impacted TSs and TRs: 25.331, 25.413
- 2723: RP#42 completed / Impacted TSs and TRs: 25.101, 25.104, 25.133, 25.212, 25.214, 25.308, 25.321, 25.331, 25.423, 25.433
- 2724: RP#43 completed / Impacted TSs and TRs: 25.201, 25.221, 25.222, 25.223, 25.224, 25.306, 25.308, 25.321, 25.331, 25.423, 25.433, 25.102, 25.105, 25.142
- 2725: RP#42 completed. Triggered by UID_390032 Study on Dual-Cell HSDPA (withdrawn TR 25.825 v100). / Impacted TSs and TRs: 25.101, 25.104, 25.133, 25.141, 25.211, 25.212, 25.213, 25.214, 25.215, 25.306, 25.308, 25.321, 25.331, 25.423, 25.433

| ID | WBS | Task | Duration | Start | Finish | Complete | Baseline start | Baseline finish | Baseline duration | Constraint | Resources | Work | Actual work | Release | MCC resp | Acronym | PCG approved | WI rapporteur name | TSG approved | Status Report | Acronym_3GU_Export |
| --- | --- | --- | --- | --- | --- | --- | --- | --- | --- | --- | --- | --- | --- | --- | --- | --- | --- | --- | --- | --- | --- |
| 2726 | 697 | **Rel-8 RAN improvements - UE Conformance Testing** | 602d? | 2008-05-30 A | 2010-09-17 A | 100% | 2008-05-30 | 2010-09-17 | 602d? |  | R5 | 29391.2h | 29391.2h | Rel-8 | Ingbert |  |  |  |  |  |  |
| 2727 | 697.1 | Conformance Test Aspects – Combination of 64QAM and MIMO for HSDPA (FDD) | 322d? | 2008-09-12 A | 2009-12-04 A | 100% | 2008-09-12 | 2009-12-04 | 322d? | finish no earlier than 2009-12-04 | R5 | 2576h | 2576h | Rel-8 | Ingbert | RANimp-UEConTest_64QamMimoHsdpa | PCG-21 | Ericsson | RP-41 | RP-091058 | RANimp-UEConTest_64QamMimoHsdpa |
| 2728 | 697.2 | Conformance Test Aspects – Improved L2 for uplink | 341d? | 2008-05-30 A | 2009-09-18 A | 100% | 2008-05-30 | 2009-09-18 | 341d? | finish no earlier than 2009-09-18 | R5 | 2728h | 2728h | Rel-8 | Ingbert | RANimp-UEConTest_UplinkL2dataRates | PCG-21 | Ericsson | RP-40 | RP-090712 | RANimp-UEConTest_UplinkL2dataRates |
| 2729 | 697.3 | Conformance Test Aspects – 1.28 Mcps TDD Improved L2 support for high data rates | 342d? | 2009-05-29 A | 2010-09-17 A | 100% | 2009-05-29 | 2010-09-17 | 342d? | finish no earlier than 2010-09-17 | R5 | 2736h | 2736h | Rel-8 | Ingbert | RANimp-UEConTest_ImprovedL2LCRTDD | PCG-23 | CATT | RP-44 | RP-100737 | RANimp-UEConTest_ImprovedL2LCRTDD |
| 2730 | 697.4 | Conformance Test Aspects – 64QAM for 1.28 Mcps TDD HSDPA | 261d? | 2008-05-30 A | 2009-05-29 A | 100% | 2008-05-30 | 2009-05-29 | 261d? | finish no earlier than 2009-05-29 | R5 | 2088h | 2088h | Rel-8 | Ingbert | RANimp-UEConTest_64Qam1.28TDD | PCG-21 | ZTE | RP-40 | RP-090415 | RANimp-UEConTest_64Qam1.28TDD |
| 2731 | 697.5 | Conformance Test Aspects – Dual-Cell HSDPA operation on adjacent carriers | 391d? | 2008-12-05 A | 2010-06-04 A | 100% | 2008-12-05 | 2010-06-04 | 391d? | finish no earlier than 2010-06-04 | R5 | 3128h | 3128h | Rel-8 | Ingbert | RANimp-UEConTest_DCHSDPA | PCG-22 | Qualcomm | RP-42 | RP-100479 | RANimp-UEConTest_DCHSDPA |
| 2732 | 697.6 | Conformance Test Aspects – Enhanced Uplink for CELL_FACH State in FDD | 326d? | 2009-03-06 A | 2010-06-04 A | 100% | 2009-03-06 | 2010-06-04 | 326d? | finish no earlier than 2010-06-04 | R5 | 2608h | 2608h | Rel-8 | Ingbert | RANimp-UEConTest_EnhancedRACHCellFACHState | PCG-22 | Nokia | RP-43 | RP-100483 | RANimp-UEConTest_EnhancedRACHCellFACHState |
| 2733 | 697.7 | Conformance Test Aspects – Receiver Type3i | 196d? | 2009-03-06 A | 2009-12-04 A | 100% | 2009-03-06 | 2009-12-04 | 196d? | finish no earlier than 2009-12-04 | R5 | 1568h | 1568h | Rel-8 | Ingbert | RANimp-UEConTest_ReceiverType3i | PCG-22 | Qualcomm | RP-43 | RP-091066 | RANimp-UEConTest_ReceiverType3i |
| 2734 | 697.8 | Conformance Test Aspects – Enhanced CELL_FACH State in LCR TDD | 341d? | 2009-05-30 A | 2010-09-17 A | 100% | 2009-05-30 | 2010-09-17 | 341d? | finish no earlier than 2010-09-17 | R5 | 2728h | 2728h | Rel-8 | Ingbert | RANimp-UEConTest_EnhancedCellFACHStateLCRTDD | PCG-23 | CATT | RP-44 | RP-100735 | RANimp-UEConTest_EnhancedCellFACHStateLCRTDD |
| 2735 | 697.9 | Conformance Test Aspects – Continuous Connectivity for packet data users for 1.28 Mcps TDD | 261d? | 2009-09-18 A | 2010-09-17 A | 100% | 2009-09-18 | 2010-09-17 | 261d? | finish no earlier than 2010-09-17 | R5 | 2088h | 2088h | Rel-8 | Ingbert | RANimp-UEConTest_CPCLCRTDD | PCG-23 | ZTE | RP-45 | RP-100739 | RANimp-UEConTest_CPCLCRTDD |
| 2736 | 697.10 | Conformance Test Aspects – MIMO for 1.28 Mcps TDD | 186d? | 2009-09-18 A | 2010-06-04 A | 100% | 2009-09-18 | 2010-06-04 | 186d? | finish no earlier than 2010-06-04 | R5 | 1488h | 1488h | Rel-8 | Ingbert | RANimp-UEConTest_MIMOLCRTDD | PCG-23 | ZTE | RP-45 | RP-100660 | RANimp-UEConTest_MIMOLCRTDD |
| 2737 | 697.11 | Conformance Test Aspects – HS-DSCH Serving Cell Change Enhancements | 131d? | 2009-09-18 A | 2010-03-19 A | 100% | 2009-09-18 | 2010-03-19 | 131d? | finish no earlier than 2010-03-12 | R5 | 1048h | 1048h | Rel-8 | Ingbert | HSDSCH_UEConTest | PCG-23 | Qualcomm | RP-45 | RP-100077 | HSDSCH_UEConTest |
| 2738 | 698 | 3.84 Mcps TDD MBMS over a Single Frequency Network (MBSFN) Integrated Mobile Broadcast | 395d? | 2007-06-04 A | 2008-12-05 A | 100% | 2007-06-04 | 2008-12-05 | 395d? |  | R1 | 3160h | 3160h | Rel-8 | Patrick | MBSFN-DOB |  | Ericsson |  | RP-080218 | MBSFN-DOB |
| 2739 | 699 | Conformance Test Aspects – 3.84 Mcps TDD MBMS over a Single Frequency Network (MBSFN) Integrated Mobile Broadcast | 211d? | 2009-05-30 A | 2010-03-19 A | 100% | 2009-05-30 | 2010-03-19 | 211d? | finish no earlier than 2010-03-19 | R5 | 1688h | 1688h | Rel-8 | Ingbert | MBSFN_IMB_UEConTest | PCG-23 | IPwireless | RP-44 | RP-100070 | MBSFN_IMB_UEConTest |
| 2740 | 700 | **GERAN support for GERAN - 3G Long Term Evolution interworking** | 1365d? | 2006-09-08 A | 2011-11-25 A | 100% | 2006-09-08 | 2011-11-25 | 1365d? |  | GP; G1; C1; G3new | 69960h | 69960h | Rel-8 | Paolo | GELTE |  | Nokia, Nokia Siemens Networks |  |  | GELTE |
| 2741 | 700.1 | G1 part of GERAN support for GERAN - 3G Long Term Evolution interworking | 641d? | 2006-09-08 A | 2009-02-20 A | 100% | 2006-09-08 | 2009-02-20 | 641d? | finish no earlier than 2009-02-20 | G1 | 5128h | 5128h | Rel-8 | Paolo | GELTE |  | Nokia, Nokia Siemens Networks |  |  |  |
| 2742 | 700.2 | G2 part of GERAN support for GERAN - 3G Long Term Evolution interworking | 641d? | 2006-09-08 A | 2009-02-20 A | 100% | 2006-09-08 | 2009-02-20 | 641d? | finish no earlier than 2009-02-20 | G2 | 5128h | 5128h | Rel-8 | Paolo | GELTE |  | Nokia, Nokia Siemens Networks |  |  |  |
| 2743 | 700.3 | CT1 part of GERAN support for GERAN - 3G Long Term Evolution interworking | 641d? | 2006-09-08 A | 2009-02-20 A | 100% | 2006-09-08 | 2009-02-20 | 641d? | finish no earlier than 2009-02-20 | C1 | 5128h | 5128h | Rel-8 | Paolo | GELTE |  | Nokia, Nokia Siemens Networks |  |  |  |
| 2744 | 700.4 | Testing for GERAN support for GERAN - 3G Long Term Evolution interworking | 1363d? | 2006-09-08 A | 2011-11-25 A | 100% | 2006-09-08 | 2011-11-25 | 1363d? | finish no earlier than 2011-11-25 | G3new | 10896h | 10896h | Rel-8 | Ingbert | GELTE |  | Renesas Mobile |  |  |  |
| 2745 | 701 | U-TDOA Enhancement | 131d? | 2007-05-18 A | 2007-11-16 A | 100% | 2007-05-18 | 2007-11-16 | 131d? | finish no earlier than 2007-05-18 | GP | 1048h | 1048h | Rel-8 | Paolo | GUTEN |  | TruePosition |  |  | GUTEN |
| 2746 | 702 | **GAN Enhancements** | 604.2d? | 2007-05-15 A | 2009-09-04 A | 100% | 2007-05-15 | 2009-09-04 | 604.2d? |  | GP | 9432h | 9432h | Rel-8 | Paolo | GANENH |  | T-Mobile |  |  | GANENH |
| 2747 | 702.1 | Update to GAN specifications | 126d? | 2007-08-31 A | 2008-02-22 A | 100% | 2007-08-31 | 2008-02-22 | 126d? | finish no earlier than 2008-02-22 | GP | 1008h | 1008h | Rel-8 | Paolo | GANENH-SPEC |  | T-Mobile |  |  | GANENH-SPEC |
| 2748 | 702.2 | Update TS 51.010 Mobile Station (MS) Conformance Specification for GAN Enhancements | 526d? | 2007-05-15 A | 2009-09-04 A | 100% | 2007-05-15 | 2009-09-04 | 526d? | finish no earlier than 2009-09-04 | G3new | 4208h | 4208h | Rel-8 | Ingbert | GANENH-MStest |  | T-Mobile |  |  | GANENH-MStest |
| 2749 | 703 | **AoIP (A-interface over IP)** | 2335d? | 2000-01-03 A | 2008-12-11 A | 100% | 2000-01-03 | 2008-12-11 | 2335d? |  | GP; S4; C4; C1; C3 | 119396h | 119396h | Rel-8 | Paolo | AoIP | PCG-21 | China Mobile, Ericsson |  |  | AoIP |
| 2750 | 703.1 | GERAN aspects of AoIP | 2321d? | 2000-01-03 A | 2008-11-21 A | 100% | 2000-01-03 | 2008-11-21 | 2321d? | finish no earlier than 2008-11-21 | GP | 18560h | 18560h | Rel-8 | Paolo | AoIP | PCG-21 | China Mobile, Ericsson | SP-40 |  |  |
| 2751 | 703.2 | Media Requirements for CS over IP based User Plane | 267d? | 2007-12-05 A | 2008-12-11 A | 100% | 2007-12-05 | 2008-12-11 | 267d? | finish no earlier than 2008-12-11 | S4 | 1996.09h | 1996.09h | Rel-8 | Paolo | AoIP-CSoIP | PCG-21 | China Mobile, Ericsson | SP-40 |  | AoIP-CSoIP |

Notes:
- 2726: Linked to Feature UID_20029 (RANimp)
- 2727: RP#46 completed. Testing for UID_360013 / Impacted TSs and TRs: 34.108, 34.121-1, 34.121-2, 34.123-1, 34.123-2 / WI rapporteur e-mail: leif.mattisson@ericsson.com
- 2728: RP#45 completed. Testing for UID_370036 / Impacted TSs and TRs: 34.108, 34.123-1, 34.123-2, 34.123-3 / WI rapporteur e-mail: leif.mattisson@ericsson.com
- 2729: RP#49 completed. Testing for Rel-7 UID_340039 Improved L2 support for high data rates and Rel-8 UID_370036 Improved L2 for uplink / Impacted TSs and TRs: 34.108, 34.123-1, 34.123-2, 34.123-3 / WI rapporteur e-mail: Xiaozhong Chen (chenxiaozhong@datangmobile.cn)
- 2730: RP#44 completed. Testing for UID_380075 / Impacted TSs and TRs: 34.108, 34.122, 34.123-1, 34.123-2, 34.123-3 / WI rapporteur e-mail: ma.zijiang@zte.com.cn
- 2731: RP#48 completed. Testing for UID_400052 / Impacted TSs and TRs: 34.108, 34.121-1, 34.121-2, 34.123-1, 34.123-2, 34.123-3 / WI rapporteur e-mail: Shubhang Vora (svora@qualcomm.com)
- 2732: RP#48 completed. Testing for UID_370037 / Impacted TSs and TRs: 34.108, 34.121-1, 34.121-2, 34.123-1, 34.123-2, 34.123-3 / WI rapporteur e-mail: jarkko.hellsten@nokia.com
- 2733: RP#46 completed. Testing for Receiver Type3i in 25.101 UE radio Tx and Rx FDD / Impacted TSs and TRs: 34.108, 34.121-1, 34.121-2 / WI rapporteur e-mail: Ashok Kumar Narayanaswamy (anarayan@qualcomm.com)
- 2734: RP#49 completed. Testing for UID_380076 / Impacted TSs and TRs: 34.108, 34.123-1, 34.123-2, 34.123-3 / WI rapporteur e-mail: Xiaozhong Chen (chenxiaozhong@datangmobile.cn)
- 2735: RP#49 completed. Testing for UID_390028 / Impacted TSs and TRs: 34.108, 34.123-1, 34.123-2, 34.123-3 / WI rapporteur e-mail: huang.he4@zte.com.cn
- 2736: PR#48 completed. Testing for UID_400050 / Impacted TSs and TRs: 34.108, 34.122, 34.123-1, 34.123-2, 34.123-3 / WI rapporteur e-mail: huang.chun2@zte.com.cn
- 2737: RP#47 completed. Testing for UID_390030 / Impacted TSs and TRs: 34.108, 34.121-1, 34.121-2, 34.123-1, 34.123-2, 34.123-3 / WI rapporteur e-mail: Shubhang Vora (svora@qualcomm.com)
- 2738: RP#42 completed. WID updated RP-070493=>RP-081124 (changed WI title "MBSFN Downlink Optimized Broadcast (DOB) 3.84 Mcps TDD" => "3.84Mcps TDD MBSFN Integrated Mobile Broadcast"). / Impacted TSs and TRs: 25.102, 25.105, 25.123, 25.201, 25.221, 25.222, 25.223, 25.224, 25.304, 25.306, 25.331, 25.346, 25.402, 25.433 / WI rapporteur e-mail: Lars.Lindbom@ericsson.com
- 2739: RP#47 completed. Testing for Rel-8 MBSFN-DOB UID_360008 / Impacted TSs and TRs: 34.108, 34.122, 34.123-1, 34.123-2, 34.123-3 / WI rapporteur e-mail: Phil Young (pyoung@ipwireless.com)
- 2740: GP#41 completed. GP#52 completed MS conformance testing / Impacted TSs and TRs: 44.018, 44.060, 45.002, 45.008, 45.010, 48.008, 48.018, 51.010 / WI rapporteur e-mail: sergio.parolari@nsn.com, vlora.rexhepi@nokia.com
- 2741: GP#41 completed / Impacted TSs and TRs: 43.055, 43.129, 43.246, 45.002, 45.008, 45.010 / WI rapporteur e-mail: sergio.parolari@nsn.com, vlora.rexhepi@nokia.com
- 2742: GP#41 completed / Impacted TSs and TRs: 44.018, 44.060, 48.008, 48.018 / WI rapporteur e-mail: sergio.parolari@nsn.com, vlora.rexhepi@nokia.com
- 2743: - / Impacted TSs and TRs: 24.008 / WI rapporteur e-mail: sergio.parolari@nsn.com, vlora.rexhepi@nokia.com
- 2744: GP#52 completed / Impacted TSs and TRs: 51.010 / WI rapporteur e-mail: deepa.kamath@renesasmobile.com
- 2745: GP#36 completed U-TDOA (Uplink Time Difference of Arrival) / Impacted TSs and TRs: 43.059, 45.008, 48.071 / WI rapporteur e-mail: Terry Brooks (terri.brooks@trueposition.com)
- 2746: GP#37 completed. GP#43 completed Testing / WI rapporteur e-mail: mohammed.versi@t-mobile.com
- 2747: GP#37 completed / Impacted TSs and TRs: 43.318, 44.318 / WI rapporteur e-mail: mohammed.versi@t-mobile.com
- 2748: GP#43 completed / Impacted TSs and TRs: 51.010 / WI rapporteur e-mail: mohammed.versi@t-mobile.com
- 2749: GP#40/TSG#42 completed . Triggered by TR 43.903 Study on A-interface over IP (AINTIP) UID_50589. / WI rapporteur e-mail: wangshuaiyu@chinamobile.com, paul.schliwa-bertling@ericsson.com
- 2750: GP#40 completed. GP#39 updated WID GP-080901=>GP-081362. / Impacted TSs and TRs: 48.001, 48.002, 48.008, 48.020, 49.008, 48.103 / WI rapporteur e-mail: wangshuaiyu@chinamobile.com, paul.schliwa-bertling@ericsson.com
- 2751: SP#42 completed / Impacted TSs and TRs: 26.102, 26.103, 26.202 / WI rapporteur e-mail: Karl.Hellwig@Ericsson.com

| ID | WBS | Task | Type | Duration | Start | Finish | Complete | Baseline start | Baseline finish | Baseline duration | Constraint | Resources | Work | Actual work | Acronym | PCG approved | WI rapporteur name | Release | TSG approved | MCC resp | Acronym_3GU_Export | Impacted TSs and TRs | Status Report | TSG stopped | Special Focus Doc | PCG stopped |
| --- | --- | --- | --- | --- | --- | --- | --- | --- | --- | --- | --- | --- | --- | --- | --- | --- | --- | --- | --- | --- | --- | --- | --- | --- | --- | --- |
| 2752 | 703.3 | **Core Network Impacts for A-Interface User Plane over IP** |  | 136d? | 2008-05-30 A | 2008-12-05 A | 100% | 2008-05-30 | 2008-12-05 | 136d? |  | C4; C1; C3 | 5440h | 5440h | AoIP-CN | PCG-21 | Ericsson | Rel-8 | CP-40 | Kimmo | AoIP-CN |  |  |  |  |  |
| 2753 | 703.3.1 | CT4 part of Core Network Impacts for A-Interface User Plane over IP |  | 136d? | 2008-05-30 A | 2008-12-05 A | 100% | 2008-05-30 | 2008-12-05 | 136d? | start no earlier than 2008-05-30 | C4 | 1088h | 1088h | AoIP-CN | PCG-21 | Ericsson | Rel-8 | CP-40 | Kimmo |  | 23.205, 23.153, 23.231, 29.232 |  |  |  |  |
| 2754 | 703.3.2 | CT1 part of Core Network Impacts for A-Interface User Plane over IP |  | 68d? | 2008-05-30 A | 2008-12-05 A | 100% | 2008-05-30 | 2008-12-05 | 68d? | finish no earlier than 2008-12-05 | C1 | 544h | 544h | AoIP-CN | PCG-21 | Ericsson | Rel-8 | CP-40 | Frederic |  | 23.009 |  |  |  |  |
| 2755 | 703.3.3 | CT3 part of Core Network Impacts for A-Interface User Plane over IP |  | 68d? | 2008-05-30 A | 2008-12-05 A | 100% | 2008-05-30 | 2008-12-05 | 68d? | finish no earlier than 2008-12-05 | C3 | 544h | 544h | AoIP-CN | PCG-21 | Ericsson | Rel-8 | CP-40 | Adrian |  | 29.007 |  |  |  |  |
| 2756 | 704 | New multicarrier BTS class |  | 261d? | 2007-08-31 A | 2008-08-29 A | 100% | 2007-08-31 | 2008-08-29 | 261d? | finish no earlier than 2008-08-29 | G1 | 2088h | 2088h | MCBTS |  | Alcatel-Lucent | Rel-8 |  | Paolo | MCBTS | 45.005, 45.050, 51.021 |  |  |  |  |
| 2757 | 705 | **Support for Additional Navigation Satellite Systems (ANSS) for LCS** |  | 150d? | 2008-05-16 A | 2008-12-11 A | 100% | 2008-05-16 | 2008-12-11 | 150d? |  | S1; G2; R2 | 5784h | 5784h | ANSS |  | Qualcomm | Rel-8 |  | Paolo | ANSS |  |  |  |  |  |
| 2758 | 705.1 | Stage 1 for ANSS for LCS |  | 1d? | 2008-12-11 A | 2008-12-11 A | 100% | 2008-12-11 | 2008-12-11 | 1d? | start no earlier than 2008-12-11 | S1 | 8h | 8h | ANSS | PCG-22 |  | Rel-8 | SP-42 | Alain |  | 22.071 |  |  |  |  |
| 2759 | 705.2 | GERAN2 part of Support for Additional Navigation Satellite Systems (ANSS) for LCS |  | 136d? | 2008-05-16 A | 2008-11-21 A | 100% | 2008-05-16 | 2008-11-21 | 136d? | start no earlier than 2008-05-16 | G2 | 1088h | 1088h | ANSS |  | Qualcomm | Rel-8 |  | Paolo |  | 43.059, 44.031, 49.031, 44.071, 48.031, 51.010 |  |  |  |  |
| 2760 | 705.3 | RAN2 part of Support for Additional Navigation Satellite Systems (ANSS) for LCS |  | 136d? | 2008-05-30 A | 2008-12-05 A | 100% | 2008-05-30 | 2008-12-05 | 136d? | finish no earlier than 2008-12-08 | R2 | 1088h | 1088h | RANimp-ANSS | PCG-21 | Qualcomm | Rel-8 | RP-40 | Yong-Jun | RANimp-ANSS | 25.305, 25.306, 25.331, 25.413, 25.423, 25.433, 25.453 | RP-080813 |  |  |  |
| 2761 | 706 | **Conformance testing for the Latency Reductions feature** |  | 532d? | 2008-02-22 A | 2010-03-05 A | 100% | 2008-02-22 | 2010-03-05 | 532d? |  | G1; G3new | 14848h | 14848h | CTLATRED | PCG-21 | Ericsson | Rel-8 |  | Paolo | CTLATRED |  |  |  |  |  |
| 2762 | 706.1 | MS conformance testing for the Latency Reductions feature |  | 532d? | 2008-02-22 A | 2010-03-05 A | 100% | 2008-02-22 | 2010-03-05 | 532d? | finish no earlier than 2010-03-05 | G3new | 4248h | 4248h | CTLATRED-MStest | PCG-21 | Ericsson | Rel-8 |  | Ingbert | CTLATRED-MStest | 51.010 |  |  |  |  |
| 2763 | 706.2 | BTS conformance testing for the Latency Reductions feature |  | 261d? | 2008-02-22 A | 2009-02-20 A | 100% | 2008-02-22 | 2009-02-20 | 261d? | finish no earlier than 2009-02-20 | G1 | 2088h | 2088h | CTLATRED-BTStest | PCG-21 | Ericsson | Rel-8 |  | Paolo | CTLATRED-BTStest | 51.021 |  |  |  |  |
| 2764 | 707 | MS conformance testing of changes introduced by WI "Support of Packet-switched Handover for GERAN A/Gb mode" |  | 196d? | 2008-02-22 A | 2008-11-21 A | 100% | 2008-02-22 | 2008-11-21 | 196d? | finish no earlier than 2008-11-21 | G3new | 1568h | 1568h | PSHCT-MStest | PCG-21 | Rohde & Schwarz | Rel-8 |  | Ingbert | PSHCT-MStest | 51.010 |  |  |  |  |
| 2765 | 708 | (Small) Technical Enhancements and Improvements for Rel-8 |  | 509d? | 2007-01-01 A | 2008-12-11 A | 100% | 2007-01-01 | 2008-12-11 | 509d? | finish no earlier than 2008-12-11 | SP; CP; RP; GP | 16288h | 16288h | TEI8 |  |  | Rel-8 |  | All | TEI8 |  |  |  |  |  |
| 2766 | 709 | (IETF) (Small) Technical Enhancements and Improvements for Rel-8 |  | 650d? | 2007-01-01 A | 2012-09-07 A | 100% | 2007-01-01 | 2012-09-07 | 650d? | finish no earlier than 2012-09-07 | C1-IETF | 5200h | 5200h | TEI8_IETF | PCG-27 | christer.holmberg@ericsson.com | Rel-8 | CP-52 | Frederic | TEI8_IETF | RFC 6714 (was draft-ietf-simple-msrp-cema) |  |  |  |  |
| 2767 | 710 | Test - (Small) Technical Enhancements and Improvements for Rel-8 |  | 993.6d? | 2007-03-07 A | 2010-12-24 A | 100% | 2007-03-07 | 2010-12-24 | 993.6d? | finish no earlier than 2010-12-24 | R5; G3new | 15897.6h | 15897.6h | TEI8_Test | PCG-21 |  | Rel-8 | RP-40 | Ingbert | TEI8_Test |  |  |  |  |  |
| 2768 | 711 | **Deleted - All-IP Network** |  | 448d? | 2004-06-28 A | 2006-03-15 A | 100% | 2004-06-28 | 2006-03-15 | 448d? |  | S1 | 7168h | 7168h | AIPN |  | NTT DoCoMo | Rel-8 |  | Alain | AIPN |  |  | SP-38 |  |  |
| 2769 | 711.1 | Deleted - Stage 1 |  | 448d? | 2004-06-28 A | 2006-03-15 A | 100% | 2004-06-28 | 2006-03-15 | 448d? | finish no earlier than 2006-03-15 | S1 | 3584h | 3584h | AIPN |  | NTT DoCoMo | Rel-8 |  | Alain |  | 22.258 |  | SP-38 |  |  |
| 2770 | 712 | Deleted - was Rel-7 - LCS for 3GPP Interworking WLAN | milestone | 0d? | 2007-09-28 A | 2007-09-28 A | 100% | 2007-09-28 | 2007-09-28 | 0d? | start no earlier than 2007-09-28 | S2 |  |  | LCS4_IWLAN |  | LG Electronics | Rel-8 |  | Maurice | LCS4_IWLAN | 23.234, 23.271, 23.167 |  | SP-35 | WLAN |  |
| 2771 | 713 | Deleted - never approved- FBI Phase 2 | milestone | 0d | 2007-09-28 A | 2007-09-28 A | 100% | 2007-09-28 | 2007-09-28 | 0d | start no earlier than 2007-09-28 | S2 |  |  | FBI2 |  | Nokia Siemens Networks | Rel-8 |  | Maurice | FBI2 |  |  | SP-38 |  |  |
| 2772 | 714 | Deleted -Enhancements to BS30 Bearer service for Videotelephony | milestone | 0d? | 2007-03-15 A | 2007-03-15 A | 100% | 2007-03-15 | 2007-03-15 | 0d? | finish no earlier than 2007-03-15 | S1 |  |  | BS30 |  |  | Rel-8 |  | Alain | BS30 | 22.002, 22.004, 22.101, 22.105, 24.008 |  | SP-38 |  |  |
| 2773 | 715 | Deleted - IMS Enhancements Rel-8 |  | 75d? | 2007-09-03 A | 2007-12-14 A | 100% | 2007-09-03 | 2007-12-14 | 75d? |  | S1 | 600h | 600h | IMS8 |  | Telecom Italia | Rel-8 | SP-37 | Alain | IMS8 |  |  | SP-38 |  |  |
| 2774 | 716 | **Deleted - Contact Manager Conformance Test specifications** |  | 471d? | 2008-06-02 A | 2010-03-19 A | 100% | 2008-06-02 | 2010-03-19 | 471d? |  | C6 | 11304h | 11304h | eUPHBOOK-Test | PCG-21 | Comprion, Gemalto | Rel-8 | CP-40 | Xavier | eUPHBOOK-Test |  |  | CP-47 |  | PCG-24 |
| 2775 | 716.1 | Deleted - Contact Manager for 3GPP UICC applications test specifications |  | 471d? | 2008-06-02 A | 2010-03-19 A | 100% | 2008-06-02 | 2010-03-19 | 471d? | finish no earlier than 2010-03-19 | C6 | 3768h | 3768h | eUPHBOOK-Test | PCG-21 | Comprion | Rel-8 | CP-40 | Xavier |  | 31.320 (external interface for communication with the ME) |  | CP-47 |  | PCG-24 |
| 2776 | 716.2 | Deleted - Contact Manager API for Java™ Card test specification |  | 471d? | 2008-06-02 A | 2010-03-19 A | 100% | 2008-06-02 | 2010-03-19 | 471d? | finish no earlier than 2010-03-19 | C6 | 3768h | 3768h | eUPHBOOK-Test | PCG-21 | Gemalto | Rel-8 | CP-40 | Xavier |  | 31.321 (internal interface (API)) |  | CP-47 |  | PCG-24 |
| 2777 | 717 | Deleted - MS conformance testing of Support of Conversational Services in A/Gb mode via the PS domain |  | 401d? | 2008-02-25 A | 2009-09-04 A | 100% | 2008-02-25 | 2009-09-04 | 401d? | finish no earlier than 2009-09-04 | G3new | 3208h | 3208h | SCSAGBCT-MStest | PCG-21 | Nokia | Rel-8 |  | Ingbert | SCSAGBCT-MStest | 51.010 |  | GP-43 |  | PCG-23 |
| 2778 | 718 | Release 8 Studies | milestone | 0d? | 2005-10-07 A | 2005-10-07 A | 100% | 2005-10-07 | 2010-11-12 | 1332d? | start no earlier than 2000-01-03 | CP; GP; RP; SP |  |  |  |  |  | Rel-8 |  | All |  |  |  |  |  |  |
| 2779 | 719 | Study on Customised Alerting Tone (CAT) Requirements |  | 245d? | 2005-10-07 A | 2006-09-14 A | 100% | 2005-10-07 | 2006-09-14 | 245d? | start no earlier than 2005-10-07 | S1 | 1960h | 1960h | FS_CAT |  | China Mobile | Rel-8 |  | Alain | FS_CAT | 22.982 |  |  |  |  |
| 2780 | 720 | Study on Facilitating Machine to Machine Communication in GSM and UMTS (M2M) |  | 350d? | 2005-11-04 A | 2007-03-08 A | 100% | 2005-11-04 | 2007-03-08 | 350d? | finish no earlier than 2006-06-16 | S1 | 2800h | 2800h | FS_M2M |  | Siemens | Rel-8 |  | Alain | FS_M2M | 22.868 |  |  | MTC, M2M |  |
| 2781 | 721 | Study on Network Composition |  | 526d? | 2005-12-07 A | 2007-12-12 A | 100% | 2005-12-07 | 2007-12-12 | 526d? | finish no earlier than 2006-09-27 | S1 | 4208h | 4208h | FS_NetComp |  | Nokia Siemens Networks | Rel-8 |  | Alain | FS_NetComp | 22.980 |  |  |  |  |
| 2782 | 722 | Study on Requirements of IMS Multimedia Conferencing |  | 330d? | 2006-06-08 A | 2007-09-12 A | 100% | 2006-06-08 | 2007-09-12 | 330d? | finish no earlier than 2007-03-21 | S1 | 2640h | 2640h | FS_IMSconf |  | China Mobile | Rel-8 |  | Alain | FS_IMSconf | 22.948 |  |  |  |  |
| 2783 | 723 | Study on support of a Public Warning System |  | 140d? | 2007-09-03 A | 2008-03-14 A | 100% | 2007-09-03 | 2008-03-14 | 140d? |  | S1 | 1120h | 1120h | FS_PWS |  | T-Mobile | Rel-8 |  | Alain | FS_PWS | 22.968 |  |  | Public Safety (I-A) |  |
| 2784 | 724 | Study on Paging Permission with Access Control |  | 256d? | 2006-09-28 A | 2007-09-20 A | 100% | 2006-09-28 | 2007-09-20 | 256d? | finish no earlier than 2007-09-20 | S1 | 2048h | 2048h | FS_PPAC |  | NTT DoCoMo | Rel-8 |  | Alain | FS_PPAC | 22.908 |  |  |  |  |
| 2785 | 725 | Study on Non-3GPP access Network Selection Principles (NSP) |  | 392d? | 2006-12-06 A | 2008-06-05 A | 100% | 2006-12-06 | 2008-06-05 | 392d? | finish no earlier than 2007-11-19 | S1 | 3136h | 3136h | FS_N3GtoNSP |  | Telefónica O2 | Rel-8 |  | Alain | FS_N3GtoNSP | 22.912 |  |  |  |  |
| 2786 | 726 | Study on Value Added Services for Short Message Service |  | 263d? | 2006-12-06 A | 2007-12-07 A | 100% | 2006-12-06 | 2007-12-07 | 263d? | finish no earlier than 2007-12-07 | S1 | 2104h | 2104h | FS_VAS4SMS |  | China Mobile | Rel-8 |  | Alain | FS_VAS4SMS | 22.942 |  |  |  |  |
| 2787 | 727 | Study on Service continuity between mobile and WLAN networks |  | 262d? | 2006-12-06 A | 2007-12-06 A | 100% | 2006-12-06 | 2007-12-06 | 262d? | finish no earlier than 2008-12-25 | S1 | 2096h | 2096h | FS_SMLSWLAN |  | NEC | Rel-8 |  | Alain | FS_SMLSWLAN | 22.937 |  |  | WLAN |  |
| 2788 | 728 | Study on Services Alignment and Migration |  | 331d? | 2006-12-06 A | 2008-03-12 A | 100% | 2006-12-06 | 2008-03-12 | 331d? | finish no earlier than 2007-09-20 | S1 | 2648h | 2648h | FS_ServAl |  | Telefónica O2 | Rel-8 | SP-37 | Alain | FS_ServAl | 22.983 |  |  |  |  |

Notes:
- 2752: CP#42 completed. Updated WID CP-080278=>CP-080722 / WI rapporteur e-mail: philip.hodges@ericsson.com
- 2753: CP#42 completed. Updated WID CP-080278=>CP-080722 / WI rapporteur e-mail: philip.hodges@ericsson.com
- 2754: CP#42 completed. Updated WID CP-080278=>CP-080722 / WI rapporteur e-mail: philip.hodges@ericsson.com
- 2755: CP#42 completed. Updated WID CP-080278=>CP-080722 / WI rapporteur e-mail: philip.hodges@ericsson.com
- 2756: GP#39 completed / WI rapporteur e-mail: thomas.bitzer@alcatel-lucent.de
- 2757: GP#40 completed / WI rapporteur e-mail: Mungal Dhanda
- 2758: SP#42 completed by 22.071 CR0077
- 2759: GP#40 completed / WI rapporteur e-mail: Mungal Dhanda
- 2760: RP#42 WI closed at 95%. Considers Rel-9 performance requirements / WI rapporteur e-mail: Etienne Chaponniere (echaponn@qualcomm.com)
- 2761: GP#45 completed / WI rapporteur e-mail: mats.y.samuelsson@ericsson.com, hakan.e.grunditz@ericsson.com
- 2762: GP#45 completed / WI rapporteur e-mail: hakan.e.grunditz@ericsson.com
- 2763: GP#41 completed / WI rapporteur e-mail: mats.y.samuelsson@ericsson.com
- 2764: GP#40 completed / WI rapporteur e-mail: Franz.Segerer@ROHDE-SCHWARZ.COM
- 2765: SP#42 completed
- 2766: CP#57 completed / WI rapporteur e-mail: christer.holmberg@ericsson.com
- 2767: -
- 2768: SP#38 stopped. 25/07/08 Moved UID_31059 Study on All-IP Network (FS_AIPN/was AIPFS) to Rel-7 out of the stopped Rel-8 Feature UID_31067 Deleted - All-IP Network (AIPN) / WI rapporteur e-mail: c.masyu@nttdocomo.co.jp
- 2769: 22.258 withdrawn, superseded by 22.278 (UID 320022). SP#38 stopped / WI rapporteur e-mail: c.masyu@nttdocomo.co.jp
- 2770: SP#35 stopped / WI rapporteur e-mail: dhshim@lge.com
- 2771: SP#38 stopped
- 2772: SP#38 stopped (no support) / WI rapporteur e-mail: andre.jarvis@three.co.uk
- 2773: SP#38 stopped
- 2774: CP#47 work stopped/abandoned / WI rapporteur e-mail: Udo Willenbrink, Jacques Seif
- 2775: CP#47 work stopped/abandoned / WI rapporteur e-mail: Udo Willenbrink (uwillenbrink@comprion.com )
- 2776: CP#47 work stopped/abandoned / WI rapporteur e-mail: jacques.seif@gemalto.com
- 2777: GP#43 work stopped/abandoned (completion 0%) / WI rapporteur e-mail: arsi.heino@nokia.com
- 2778: -
- 2779: Spin-off Rel-8 Feature Customized Alerting Tone (CAT) Service UID_340029 / WI rapporteur e-mail: Qing Huang (huangqing@chinamobile.com)
- 2780: SP#35 completed. Spin-off SA3 Study on Security Aspects of Remote Provisioning and Change of Subscription for M2M (UID_370053). SP#40 Spin-off new Feature UID_410030 (NIMTC) / WI rapporteur e-mail: Juergen Merkel
- 2781: SP#38 completed / WI rapporteur e-mail: joerg.swetina@neclab.eu
- 2782: SP#37 completed. Spin-off New Feature UID_370026 Value-Added Services for Short Message Service (VAS4SMS) / WI rapporteur e-mail: Qing Huang (huangqing@chinamobile.com)
- 2783: SP#39 completed. Spin-off Rel-9 Feature UID_380057 (PWS) / WI rapporteur e-mail: mark.younge@t-mobile.com
- 2784: SP#37 completed. Spin-off new Feature UID_370084 (PPACR) / WI rapporteur e-mail: Katsuhiro NOGUCHI (noguchi@nttdocomo.co.jp)
- 2785: SP#38 completed. Spin-off New Feature UID_380062 (N3GTONSP). SP#40 WID updated SP-060930=>SP-080318. TR re-approved with new # 22.812=>22.912 / WI rapporteur e-mail: chris.friel@O2.com
- 2786: SP#38 completed. Spin-off New Feature UID_370026 (VAS4SM) / WI rapporteur e-mail: Qing Huang (huangqing@chinamobile.com)
- 2787: SP#38 completed / WI rapporteur e-mail: joerg.swetina@neclab.eu
- 2788: SP#39 completed. Spin-off Rel-9 Feature UID_330017 Services Alignment and Migration (ServAl) / WI rapporteur e-mail: chris.friel@O2.com

| ID | WBS | Task | Duration | Start | Finish | Complete | Baseline start | Baseline finish | Baseline duration | Constraint | Resources | Work | Actual work | Acronym | WI rapporteur name | WI rapporteur e-mail | Release | MCC resp | Acronym_3GU_Export | Impacted TSs and TRs | PCG approved | TSG approved | Special Focus Doc | Status Report | PCG stopped | TSG stopped |
| --- | --- | --- | --- | --- | --- | --- | --- | --- | --- | --- | --- | --- | --- | --- | --- | --- | --- | --- | --- | --- | --- | --- | --- | --- | --- | --- |
| 2789 | 729 | **Study on 3GPP System Architecture Evolution** | 1115d? | 2004-12-03 A | 2009-03-12 A | 100% | 2004-12-03 | 2009-03-12 | 1115d? |  | S2; S3 | 34064h | 34064h | FS_SAE | Vodafone | chris.pudney@vodafone.com | Rel-8 | Maurice | FS_SAE |  |  |  |  |  |  |  |
| 2790 | 729.1 | Stage 2 Interim conclusion for RAN Work to start | 990d? | 2004-12-03 A | 2008-09-18 A | 100% | 2004-12-03 | 2008-09-18 | 990d? | finish no earlier than 2005-09-23 | S2 | 7920h | 7920h | FS_SAE | Vodafone | chris.pudney@vodafone.com | Rel-8 | Maurice |  | 23.882 |  |  |  |  |  |  |
| 2791 | 729.2 | Stage 2 study on 3GPP architectural development | 704d? | 2006-01-09 A | 2008-09-18 A | 100% | 2006-01-09 | 2008-09-18 | 704d? | finish no earlier than 2007-09-28 | S2 | 5632h | 5632h | FS_SAE | Vodafone | chris.pudney@vodafone.com | Rel-8 | Maurice |  | 23.882 |  |  |  |  |  |  |
| 2792 | 729.3 | Security study for Inter-access mobility between non-3GPP and 3GPP system | 334d? | 2007-09-03 A | 2009-03-12 A | 100% | 2007-09-03 | 2009-03-12 | 334d? | finish no earlier than 2009-03-12 | S3 | 2672h | 2672h | FS_SAE | Nokia | dajiang.zhang@nokia.com | Rel-8 | Mirko |  | 33.821, 33.822 |  |  |  |  |  |  |
| 2793 | 730 | Study on Stage 2 aspects of IMS Service Brokering | 589d? | 2006-06-19 A | 2008-09-18 A | 100% | 2006-06-19 | 2008-09-18 | 589d? | finish no earlier than 2008-09-18 | S2 | 4712h | 4712h | FS_ISB_ST2 | Telcordia | raquel@research.telcordia.com | Rel-8 | Maurice | FS_ISB_ST2 | 23.810 |  |  |  |  |  |  |
| 2794 | 731 | Study on IMS utilizing multicast bearer services | 447d? | 2006-03-22 A | 2007-12-06 A | 100% | 2006-03-22 | 2007-12-06 | 447d? | finish no earlier than 2007-12-03 | S2 | 3576h | 3576h | FS_MLTICAST-IMS | Nokia Siemens Networks |  | Rel-8 | Maurice | FS_MLTICAST-IMS | 23.847 |  |  |  |  |  |  |
| 2795 | 732 | Study on Multimedia Session Continuity | 291d? | 2007-04-26 A | 2008-06-05 A | 100% | 2007-04-26 | 2008-06-05 | 291d? | finish no earlier than 2008-06-05 | S2 | 2328h | 2328h | FS_MMSC | LG Electronics |  | Rel-8 | Maurice | FS_MMSC | 23.893 |  |  |  |  |  |  |
| 2796 | 733 | **Study on centralized IMS service control** | 363d? | 2006-10-23 A | 2008-03-12 A | 100% | 2006-10-23 | 2008-03-12 | 363d? |  | S2; S1 | 10856h | 10856h | FS_ICS | Ericsson | peter.bleckert@ericsson.com | Rel-8 | Alain | FS_ICS |  | PCG-21 | SP-38 |  |  |  |  |
| 2797 | 733.1 | Study on centralized IMS services requirements | 268d? | 2007-03-05 A | 2008-03-12 A | 100% | 2007-03-05 | 2008-03-12 | 268d? | start no earlier than 2007-03-05 | S1 | 2144h | 2144h | FS_ICS-S1 | NEC | joerg.swetina@neclab.eu | Rel-8 | Alain | FS_ICS-S1 | 22.892 |  | SP-37 |  |  |  |  |
| 2798 | 733.2 | Study on centralized IMS services control | 363d? | 2006-10-23 A | 2008-03-12 A | 100% | 2006-10-23 | 2008-03-12 | 363d? | finish no earlier than 2008-02-21 | S2 | 2904h | 2904h | FS_IMS_CSC | Alcatel-Lucent | andy.bennett@alcatel-lucent.com | Rel-8 | Maurice | FS_IMS_CSC | 23.892 |  |  |  |  |  |  |
| 2799 | 734 | Study on Architecture of IMS based Customized Alerting Tone (CAT) | 208d? | 2007-12-04 A | 2008-09-18 A | 100% | 2007-12-04 | 2008-09-18 | 208d? | finish no earlier than 2008-09-08 | S2 | 1664h | 1664h | FS_CAT-St2 | China Mobile | WANG, Jing (wangjing@chinamobilecom) | Rel-8 | Maurice | FS_CAT-St2 | 23.872 | PCG-21 | SP-38 |  |  |  |  |
| 2800 | 735 | Study on Home (e)NodeB Security | 321d? | 2007-12-20 A | 2009-03-12 A | 100% | 2007-12-20 | 2009-03-12 | 321d? | finish no earlier than 2009-03-10 | S3 | 2568h | 2568h | FS_HNB_Sec | Huawei | yangyanmei@huawei.com | Rel-8 | Mirko | FS_HNB_Sec | 33.820 | PCG-21 | SP-38 | HNB |  |  |  |
| 2801 | 736 | Study on Transferring of emergency call data – in-band modem solution | 265d? | 2006-12-07 A | 2007-12-12 A | 100% | 2006-12-07 | 2007-12-12 | 265d? | finish no earlier than 2008-09-18 | S4 | 2120h | 2120h | eCALLIBMS | Airbiquity | lhong@airbiquity.com | Rel-8 | Paolo | eCALLIBMS | 26.967 |  |  | Public Safety (I-A) |  |  |  |
| 2802 | 737 | Study on Element Operations Systems Function (EOSF) definition | 266d? | 2007-06-07 A | 2008-06-12 A | 100% | 2007-06-07 | 2008-06-12 | 266d? | finish no earlier than 2008-12-11 | S5 | 2128h | 2128h | OAM7-NIM-EOSF | China Mobile | Li Jian (lijian@chinamobile.com) | Rel-8 | Mirko | OAM7-NIM-EOSF | 32.819 |  |  |  |  |  |  |
| 2803 | 738 | Study on SA5 MTOSI XML Harmonization | 351d? | 2006-05-10 A | 2007-09-12 A | 100% | 2006-05-10 | 2007-09-12 | 351d? | finish no earlier than 2007-12-14 | S5 | 2808h | 2808h | OAM8-NIM-XML | Nortel | jduguay@nortel.com | Rel-8 | Mirko | OAM8-NIM-XML | 32.818 |  |  |  |  |  |  |
| 2804 | 739 | Study on Common Profile Storage (CPS) Framework of User Data for network services and management | 244d? | 2006-07-03 A | 2007-06-07 A | 100% | 2006-07-03 | 2007-06-07 | 244d? | finish no earlier than 2007-06-07 | S5 | 1952h | 1952h | OAM7-CPS | T-Mobile | istvan.aba@t-mobile.at | Rel-8 | Mirko | OAM7-CPS | 32.808 |  |  |  |  |  |  |
| 2805 | 740 | Study on Management for LTE and SAE | 526d? | 2006-12-07 A | 2008-12-11 A | 100% | 2006-12-07 | 2008-12-11 | 526d? | finish no earlier than 2008-12-11 | S5 | 4208h | 4208h | FS_OAM_LTE_SAE | Ericsson | robert.petersen@ericsson.com | Rel-8 | Mirko | FS_OAM_LTE_SAE | 32.816 |  |  |  |  |  |  |
| 2806 | 741 | Study on Charging Aspects of 3GPP System Evolution | 179d? | 2007-04-02 A | 2007-12-06 A | 100% | 2007-04-02 | 2007-12-06 | 179d? | finish no earlier than 2007-12-06 | S5 | 1432h | 1432h | FS_SAEcharg | Nokia Siemens Networks | Gerald.Goermer@nsn.com | Rel-8 | Mirko | FS_SAEcharg | 32.820 |  |  |  |  |  |  |
| 2807 | 742 | Study on AS-MRFC media server control protocol | 583d? | 2006-03-22 A | 2008-06-13 A | 100% | 2006-03-22 | 2008-06-13 | 583d? | finish no earlier than 2008-06-13 | C1 | 4664h | 4664h | MRFC | Hewlett-Packard | mark.syrett@hp.com | Rel-8 | Frederic | MRFC | 24.880 |  |  |  |  |  |  |
| 2808 | 743 | Study on IMS Restoration Procedures | 310d? | 2007-03-26 A | 2008-05-30 A | 100% | 2007-03-26 | 2008-05-30 | 310d? | finish no earlier than 2008-05-30 | C4 | 2480h | 2480h | FS_IMS_RP | Ericsson | german.blanco@ericsson.com | Rel-8 | Kimmo | FS_IMS_RP | 23.820 |  |  |  |  |  |  |
| 2809 | 744 | Study on IMS Application Server Service Data Descriptions for AS interoperability | 261d? | 2007-09-14 A | 2008-09-12 A | 100% | 2007-09-14 | 2008-09-12 | 261d? | finish no earlier than 2008-09-12 | C4 | 2088h | 2088h | FS_IMS_ASIO | Alcatel-Lucent | Jean-Jacques Trottin | Rel-8 | Kimmo | FS_IMS_ASIO | 29.864 |  |  |  |  |  |  |
| 2810 | 745 | Study on Customized Alerting Tone (CAT) solution for voice and video call in CS domain | 261d? | 2007-09-14 A | 2008-09-12 A | 100% | 2007-09-14 | 2008-09-12 | 261d? |  | C4 | 626.4h | 626.4h | FS_CAT_VVC_CS | China Mobile | zhanghao@chinamobile.com | Rel-8 | Kimmo | FS_CAT_VVC_CS | 29.882 |  |  |  |  |  |  |
| 2811 | 746 | Study on InterWorking Function between MAP based and Diameter based interfaces | 266d? | 2007-11-30 A | 2008-12-05 A | 100% | 2007-11-30 | 2008-12-05 | 266d? | finish no earlier than 2008-12-05 | C4 | 2128h | 2128h | FS_MAP2Diam | Huawei | liming49985@huawei.com | Rel-8 | Kimmo | FS_MAP2Diam | 29.805 | PCG-21 | CP-38 |  |  |  |  |
| 2812 | 747 | Study on Scope of future HSPA Evolution for 1.28 Mcps TDD | 186d? | 2007-09-14 A | 2008-05-30 A | 100% | 2007-09-14 | 2008-05-30 | 186d? | finish no earlier than 2008-05-30 | R1 | 1488h | 1488h | FS_RAN-LCRTDDHSPAEvo | RITT | Xu Fei | Rel-8 | Patrick | FS_RAN-LCRTDDHSPAEvo | 25.824 |  | RP-37 |  | RP-080290 |  |  |
| 2813 | 748 | Study on Synchronized E-DCH for UTRA FDD | 126d? | 2007-09-14 A | 2008-03-07 A | 100% | 2007-09-14 | 2008-03-07 | 126d? | finish no earlier than 2008-03-14 | R1 | 1008h | 1008h | FS_RAN-UplinkSync | Nokia Siemens Networks | Karri.Ranta-aho@nsn.com | Rel-8 | Patrick | FS_RAN-UplinkSync | 25.823 |  | RP-37 |  | RP-080068 |  |  |
| 2814 | 749 | Study on Improved network controlled mobility between LTE and 3GPP2/mobile WiMAX radio technologies | 131d? | 2007-06-04 A | 2007-12-03 A | 100% | 2007-06-04 | 2007-12-03 | 131d? | finish no earlier than 2007-12-03 | R4 | 1048h | 1048h | FS_RAN-LTEmob | Motorola | hao.bi@Motorola.com | Rel-8 | Issam | FS_RAN-LTEmob | 36.938 |  |  |  | RP-070827 |  |  |
| 2815 | 750 | Study on 3G Home NodeB/eNodeB | 325d? | 2007-03-05 A | 2008-05-30 A | 100% | 2007-03-05 | 2008-05-30 | 325d? | finish no earlier than 2008-05-30 | R4 | 2600h | 2600h | FS_RAN-HNBeNB | Motorola | howard.thomas@motorola.com | Rel-8 | Issam | FS_RAN-HNBeNB | 25.820 |  |  | HNB | RP-080289 |  |  |
| 2816 | 751 | Study on A-interface over IP | 126d? | 2007-08-31 A | 2008-02-22 A | 100% | 2007-08-31 | 2008-02-22 | 126d? | finish no earlier than 2008-02-22 | GP | 1008h | 1008h | AINTIP | China Mobile, Ericsson | paul.schliwa-bertling@ericsson.com | Rel-8 | Paolo | AINTIP | 43.903 |  |  |  |  |  |  |
| 2817 | 752 | Study on Multi-User Reusing-One-Slot | 782d? | 2007-11-16 A | 2010-11-12 A | 100% | 2007-11-16 | 2010-11-12 | 782d? | finish no earlier than 2010-11-12 | GP | 6248h | 6248h | MUROS | Nokia Siemens Networks | juergen.hofmann@nsn.com | Rel-8 | Paolo | MUROS | 45.914 |  |  |  |  |  |  |
| 2818 | 753 | Study on Optimized Transmit Pulse Shape for Downlink EGPRS2-B | 657d? | 2007-11-16 A | 2010-05-21 A | 100% | 2007-11-16 | 2010-05-21 | 657d? | finish no earlier than 2010-05-27 | G1 | 5248.44h | 5248.44h | WIDER | Research In Motion, Nokia Siemens Networks | jdwyer@RIM.COM and eddie.riddington@nsn.com | Rel-8 | Paolo | WIDER | 45.913 |  |  |  |  |  |  |
| 2819 | 754 | Deleted - Study on Mobility between 3GPP-WLAN Interworking and 3GPP Systems | 393d? | 2007-03-20 A | 2008-09-18 A | 100% | 2007-03-20 | 2008-09-18 | 393d? | finish no earlier than 2008-09-18 | S2 | 3144h | 3144h | FS_SM3GWLAN | Orange |  | Rel-8 | Maurice | FS_SM3GWLAN | withdrawn 23.827 |  |  | WLAN |  | PCG-21 | SP-41 |
| 2820 | 755 | Deleted - equals 340035 -FS on Service continuity between mobile and WLAN networks | 75d? | 2007-09-03 A | 2007-12-14 A | 100% | 2007-09-03 | 2007-12-14 | 75d? | finish no earlier than 2007-12-14 | S1 | 600h | 600h | FSSCMobToW | BT | mike.meyerstein@bt.com | Rel-8 | Alain | FSSCMobToW | 22.937 |  | SP-37 |  |  | PCG-21 | SP-39 |
| 2821 | 756 | Deleted - Study on Evaluation of LCS Control Plane Solution for EPS | 100d? | 2008-01-14 A | 2008-05-30 A | 100% | 2008-01-14 | 2008-05-30 | 100d? | finish no earlier than 2009-03-20 | S2 | 800h | 800h | FS_LCS_EPS | SiRF |  | Rel-8 | Maurice | FS_LCS_EPS | 23.891 |  | SP-38 |  |  | PCG-21 | SP-40 |
| 2822 | 757 | Deleted - Study on HS-PDSCH serving cell change enhancements | 60d? | 2007-12-17 A | 2008-03-07 A | 100% | 2007-12-17 | 2008-03-07 | 60d? | finish no earlier than 2008-06-12 | R4 | 480h | 480h | FS_RAN-HSPDSCH | Qualcomm |  | Rel-8 | Issam | FS_RAN-HSPDSCH | none | PCG-21 | RP-38 |  | RP-080070 | PCG-21 | RP-39 |
| 2823 | 758 | Deleted - Study on Dual-Cell HSDPA operation | 261d? | 2007-08-15 A | 2009-03-06 A | 100% | 2007-08-15 | 2009-03-06 | 261d? | finish no earlier than 2009-03-06 | R1 | 2088h | 2088h | FS_RAN-DCHS | Qualcomm | Josef Blanz | Rel-8 | Patrick | FS_RAN-DCHS | withdrawn 25.825 v100 | PCG-21 | RP-39 |  | RP-090066 | PCG-22 | RP-43 |
| 2824 | 759 | Release 7 Features | 679d? | 2005-05-02 A | 2007-12-06 A | 100% | 2005-05-02 | 2007-12-06 | 679d? | start no earlier than 2000-01-01 | CP; GP; RP; SP | 21728h | 21728h |  |  |  | Rel-7 | All |  |  |  |  |  |  |  |  |

Notes:
- 2789: SP#43 completed
- 2790: SP#41 completed
- 2791: SP#41 completed
- 2792: SP#43 completed
- 2793: SP#41 completed. No spin-off activity proposed. [Note: IMS Service Brokering enhancements UID_31088 moved back from R8 to R7 to give a home to 22228CR0036_(Rel-7)_S1-051232. Hence, Rel-7 ISB has Stage 1 only (and is misaligned with Rel-7 Stages 2/3.]
- 2794: SP#38 completed
- 2795: SP#40 completed
- 2796: SP#39 completed
- 2797: SP#39 completed
- 2798: SP#39 completed
- 2799: SP#41 completed as Rel-8
- 2800: SP#43 completed. Linked to RAN4 Study on 3G Home NodeB/eNodeB (UID_350039) and to SA5 Study on Self-Organizing Networks (SON) related OAM interfaces for Home NodeB (UID_360007)
- 2801: SP#38 completed. Spin-off WID UID_34042 (eCall_Phase2)
- 2802: SP#40 completed. WID updated SP-050608=>SP-070307
- 2803: SP#37 completed. WID updated SP-050295=>SP-070305
- 2804: SP#36 completed. Spin-off New Feature UID_400034 User Data Convergence (UDC)
- 2805: SP#42 completed
- 2806: SP#38 completed
- 2807: CP#40 completed. Spin-off New Feature UID_380035 (MRFC_TS)
- 2808: CP#40 completed. Spin-off WID UID_400012 (IMS_RP)
- 2809: CP#41 completed. Linked to SA5 Study on Common Profile Storage framework UID_320006. Spin-off WID UID_410003 (IMS_ASIO)
- 2810: CP#41 completed. Spin-off WID under Feature CAT UID_340029
- 2811: CP#42 completed. Spin-off implementation Building Block UID_410007 (MAP2Diam) under the SAES Feature UID_320005
- 2812: RP#40 completed
- 2813: RP#39 completed
- 2814: RP#38 completed
- 2815: RP#40 completed
- 2816: GP#37 completed. Spin-off implementation Feature AoIP (A-interface over IP) UID_50591
- 2817: GP#48 completed as Rel-8. Spin-off implementation WI UID_420002 VAMOS (Voice services over Adaptive Multi-user channels on One Slot)
- 2818: GP#46 completed
- 2819: SP#41 stopped. Draft TR 23.827 content implemented in TS 23.327.
- 2820: SP#39 stopped
- 2821: SP#40 spin-off Feature UID_400038 (LCS_CPS_EPS). SP#40 FS stopped
- 2822: RP#39 stopped (no TR produced). Spin-off HS-DSCH Serving Cell Change Enhancements (UID_39003)
- 2823: RP#43 stopped (draft TR 25.825 v100 withdrawn). Conclusions in RP-090318 (RAN1 findings of the UTRA Multi-Carrier Evolution study). RP#42 New WI approved on Dual-Cell HSDPA operation on adjacent carriers (UID_400052)
- 2824: -

| ID | WBS | Task | Type | Duration | Start | Finish | Complete | Baseline start | Baseline finish | Baseline duration | Constraint | Resources | Work | Actual work | Acronym | WI rapporteur name | WI rapporteur e-mail | Release | MCC resp | Acronym_3GU_Export | TSG stopped | Status Report | TSG approved | PCG approved | Special Focus Doc |
| --- | --- | --- | --- | --- | --- | --- | --- | --- | --- | --- | --- | --- | --- | --- | --- | --- | --- | --- | --- | --- | --- | --- | --- | --- | --- |
| 2825 | 760 | **Identification of Communication Services in IMS** |  | 620d? | 2005-05-02 A | 2007-09-14 A | 100% | 2005-05-02 | 2007-09-14 | 620d? |  | S2; S1; C1; S5 | 29048h | 29048h | ServID | Ericsson | stephen.terrill@ericsson.com | Rel-7 | Maurice | ServID |  |  |  |  |  |
| 2826 | 760.1 | TR on ServID |  | 232d? | 2005-05-02 A | 2006-03-21 A | 100% | 2005-05-02 | 2006-03-21 | 232d? | finish no earlier than 2006-03-20 | S2 | 1856h | 1856h | ServID | Ericsson | stephen.terrill@ericsson.com | Rel-7 | Maurice |  |  |  |  |  |  |
| 2827 | 760.2 | Stage 1,2 of ServID |  | 144d? | 2005-11-11 A | 2006-05-31 A | 100% | 2005-11-11 | 2006-05-31 | 144d? | start no earlier than 2005-11-11 | S1; S2 | 2304h | 2304h | ServID | Ericsson | stephen.terrill@ericsson.com | Rel-7 | Maurice |  |  |  |  |  |  |
| 2828 | 760.3 | Stage 3 of ServID |  | 250d? | 2006-03-31 A | 2007-03-15 A | 100% | 2006-03-31 | 2007-03-15 | 250d? | finish no earlier than 2007-03-15 | C1 | 2000h | 2000h | ServID | Ericsson | christer.holmberg@ericsson.com | Rel-7 | Frederic |  |  |  |  |  |  |
| 2829 | 760.4 | Charging of ServID |  | 381d? | 2006-03-31 A | 2007-09-14 A | 100% | 2006-03-31 | 2007-09-14 | 381d? | finish no earlier than 2007-09-14 | S5 | 3048h | 3048h | ServID | Orange | alain.bibas@orange-ft.com | Rel-7 | Mirko |  |  |  |  |  |  |
| 2830 | 761 | **Supporting Globally Routable User Agent URIs in IMS** |  | 415d? | 2005-11-14 A | 2007-06-15 A | 100% | 2005-11-14 | 2007-06-15 | 415d? |  | S2; S1; C1 | 14920h | 14920h | GRUU | Research In Motion | Adrian Buckley (abuckley@rim.com) | Rel-7 | Maurice | GRUU |  |  |  |  |  |
| 2831 | 761.1 | Deleted - TR on GRUU |  | 219d? | 2005-11-14 A | 2006-09-14 A | 100% | 2005-11-14 | 2006-09-14 | 219d? | finish no earlier than 2006-09-14 | S2 | 1752h | 1752h | GRUU | Research In Motion | Adrian Buckley (abuckley@rim.com) | Rel-7 | Maurice |  | SP-32 |  |  |  |  |
| 2832 | 761.2 | Stage 1,2 of GRUU |  | 65d? | 2006-07-03 A | 2006-09-29 A | 100% | 2006-07-03 | 2006-09-29 | 65d? | start no earlier than 2006-07-03 | S1; S2 | 1040h | 1040h | GRUU | Research In Motion | Adrian Buckley (abuckley@rim.com) | Rel-7 | Maurice |  |  |  |  |  |  |
| 2833 | 761.3 | Stage 3 of GRUU |  | 271d? | 2006-06-02 A | 2007-06-15 A | 100% | 2006-06-02 | 2007-06-15 | 271d? | finish no earlier than 2007-06-15 | C1 | 2168h | 2168h | GRUU | CableLabs | Bernie McKibben (b.mckibben@cablelabs.com) | Rel-7 | Frederic |  |  |  |  |  |  |
| 2834 | 762 | **Multimedia Telephony Service for IMS** |  | 357d? | 2006-02-01 A | 2007-06-15 A | 100% | 2006-02-01 | 2007-06-15 | 357d? |  | S1; C1; S4 | 14688h | 14688h | MTSI | Ericsson | peter.bleckert@ericsson.com | Rel-7 | Alain | MTSI |  |  |  |  |  |
| 2835 | 762.1 | Stage 1 of MTSI |  | 173d? | 2006-02-01 A | 2006-09-29 A | 100% | 2006-02-01 | 2006-09-29 | 173d? | start no earlier than 2006-02-01 | S1 | 1384h | 1384h | MTSI-REQ | Ericsson | peter.bleckert@ericsson.com | Rel-7 | Alain | MTSI-REQ |  |  |  |  |  |
| 2836 | 762.2 | Stage 3 of MTSI |  | 330d? | 2006-03-10 A | 2007-06-14 A | 100% | 2006-03-10 | 2007-06-14 | 330d? | finish no earlier than 2007-06-15 | C1 | 2640h | 2640h | MTSI | Ericsson | christer.holmberg@ericsson.com | Rel-7 | Frederic | MTSI |  |  |  |  |  |
| 2837 | 762.3 | Media handling and interaction in MTSI |  | 262d? | 2006-03-15 A | 2007-03-15 A | 100% | 2006-03-15 | 2007-03-15 | 262d? | finish no earlier than 2007-03-15 | S4 | 2096h | 2096h | MTSI-MHI | Ericsson | olle.franceschi@ericsson.com | Rel-7 | Paolo | MTSI-MHI |  |  |  |  |  |
| 2838 | 762.4 | Deleted - duplicates UID7039 - IMS Multimedia Telephony Service | milestone | 0d? | 2007-06-15 A | 2007-06-15 A | 100% | 2007-06-15 | 2007-06-15 | 0d? | start no earlier than 2007-06-15 | S1 |  |  | MMTEL | Ericsson | peter.bleckert@ericsson.com | Rel-7 | Alain | MMTEL | SP-32 |  |  |  |  |
| 2839 | 763 | Multimedia Telephony Service for IMS (MTSI) - UE Conformance Testing |  | 387d | 2007-09-19 A | 2009-03-12 A | 100% | 2007-09-19 | 2009-03-12 | 387d | finish no earlier than 2009-03-13 | R5 | 1664h | 1664h | MTSI-UEConTest | Ericsson, Motorola | Leif.Mattisson@ericsson.com, Jacob.John@motorola.com | Rel-7 | Ingbert | MTSI-UEConTest |  | RP-090056 |  |  |  |
| 2840 | 764 | TISPAN requirements for Multimedia Telephony with PSTN/ISDN simulation services |  | 58d? | 2007-09-18 A | 2007-12-06 A | 100% | 2007-09-18 | 2007-12-06 | 58d? | start no earlier than 2007-09-18 | S1 | 464h | 464h | TMMTEL7 |  |  | Rel-7 | Alain | TMMTEL7 |  |  | SP-37 |  |  |
| 2841 | 765 | **Maintenance of TISPAN release 1 common IMS** |  | 180d? | 2007-07-02 A | 2008-03-07 A | 100% | 2007-07-02 | 2008-03-07 | 180d? |  | S2 | 5808h | 5808h | MCIMSTR1 | Ericsson | Raymond Forbes | Rel-7 | Maurice | MCIMSTR1 |  |  | SP-38 | PCG-21 |  |
| 2842 | 765.1 | SA1 aspects of MCIMSTR1 |  | 58d? | 2007-09-18 A | 2007-12-06 A | 100% | 2007-09-18 | 2007-12-06 | 58d? | finish no earlier than 2007-12-06 | S1 | 464h | 464h | MCIMSTR1-S1 | Telecom Italia | Marco.DeLuca1@telecomitalia.it | Rel-7 | Alain | MCIMSTR1-S1 |  |  | SP-38 | PCG-21 |  |
| 2843 | 765.2 | SA2 aspects of MCIMSTR1 |  | 58d? | 2007-09-18 A | 2007-12-06 A | 100% | 2007-09-18 | 2007-12-06 | 58d? | finish no earlier than 2007-12-06 | S2 | 464h | 464h | MCIMSTR1-S2 | Ericsson | Raymond Forbes | Rel-7 | Maurice | MCIMSTR1-S2 |  |  | SP-38 | PCG-21 |  |
| 2844 | 765.3 | SA1,SA2 part of Maintenance of TISPAN release 1 common IMS |  | 114d? | 2007-07-02 A | 2007-12-06 A | 100% | 2007-07-02 | 2007-12-06 | 114d? | finish no earlier than 2007-12-06 | S2; S1 | 1824h | 1824h | IMS_Comm_Mtce7 | BT, Ericsson | Dick Knight, Raymond Forbes | Rel-7 | Maurice | IMS_Comm_Mtce7 |  |  | SP-38 | PCG-21 |  |
| 2845 | 765.4 | Maintenance of TISPAN R1 |  | 86d? | 2007-11-09 A | 2008-03-07 A | 100% | 2007-11-09 | 2008-03-07 | 86d? | start no earlier than 2007-11-09 | C1; C3; C4 | 2064h | 2064h | MAINT_R1 | Alcatel-Lucent | Keith Drage (drage@alcatel-lucent.com) | Rel-7 | Frederic | MAINT_R1 |  |  | CP-38 | PCG-21 |  |
| 2846 | 766 | **PS domain and IMS impacts for supporting IMS Emergency calls (EMC1)** |  | 2934d? | 2000-09-18 A | 2011-12-09 A | 100% | 2000-09-18 | 2011-12-09 | 2934d? |  | S2; S1; C1; C4; IETF | 185422h | 185422h | EMC1 | Siemens | Rainer Liebhart | Rel-7 | Maurice | EMC1 |  |  |  |  | Public Safety (I-A) |
| 2847 | 10.1.1 | Service Requirements for IP-based emergency calls |  | 985d | 2000-09-18 A | 2004-06-25 A | 100% | 2000-09-18 | 2004-06-25 | 985d | finish no earlier than 2004-06-25 | S1 | 7880h | 7880h | EMC1 | Siemens | Rainer Liebhart | Rel-7 | Alain |  |  |  |  |  | Public Safety (I-A) |
| 2848 | 766.2 | Study on Stage 2 for IMS-level solution |  | 668d? | 2003-02-26 A | 2005-09-16 A | 100% | 2003-02-26 | 2005-09-16 | 668d? | finish no earlier than 2005-09-16 | S2 | 5344h | 5344h | EMC1 | Siemens | Rainer Liebhart | Rel-7 | Maurice |  |  |  |  |  | Public Safety (I-A) |
| 2849 | 766.3 | Study on Stage 2 for GPRS-level solution |  | 301d? | 2004-10-14 A | 2005-12-08 A | 100% | 2004-10-14 | 2005-12-08 | 301d? | finish no earlier than 2005-12-08 | S2 | 2408h | 2408h | EMC1 | Siemens | Rainer Liebhart | Rel-7 | Maurice |  |  |  |  |  | Public Safety (I-A) |
| 2850 | 766.4 | Stage 2 Specification Phase - IMS-level |  | 200d? | 2005-09-05 A | 2006-06-09 A | 100% | 2005-09-05 | 2006-06-09 | 200d? | finish no earlier than 2006-06-09 | S2 | 1600h | 1600h | EMC1 | Siemens | Rainer Liebhart | Rel-7 | Maurice |  |  |  |  |  | Public Safety (I-A) |
| 2851 | 766.5 | Deleted - Stage 2 Specification Phase - GPRS-level | milestone | 0d? | 2007-03-02 A | 2007-03-02 A | 100% | 2007-03-02 | 2007-03-02 | 0d? | start no earlier than 2007-03-02 | S2 |  |  | EMC1 | Siemens | Rainer Liebhart | Rel-7 | Maurice |  | SP-32 |  |  |  | Public Safety (I-A) |

Notes:
- 2825: WID approved SP#28. WID updated SP#32
- 2826: - / Impacted TSs and TRs: 23.816
- 2827: - / Impacted TSs and TRs: 22.228, 23.228, 23.203
- 2828: CP#32 approved WID / Impacted TSs and TRs: 23.218, 24.229
- 2829: - / Impacted TSs and TRs: 32.260, 32.298, 32.299
- 2830: SP#29 approved WID
- 2831: Abandoned
- 2832: SP#29 approved WID / Impacted TSs and TRs: 22.228, 23.228, 23.218, 24.229
- 2833: CP#32 approved WID / Impacted TSs and TRs: 24.229
- 2834: -
- 2835: - / Impacted TSs and TRs: 22.173
- 2836: - / Impacted TSs and TRs: 24.173
- 2837: - / Impacted TSs and TRs: 26.114
- 2838: - / Impacted TSs and TRs: 22.173
- 2839: RP#43 completed. Linked UID_7038 (MTSI) / Impacted TSs and TRs: 34.123-1, 34.123-2, 34.123-3, 34.229-1, 34.229-2
- 2840: - / Impacted TSs and TRs: 22.273 (EI 181 002 maintenance)
- 2841: - / Impacted TSs and TRs: http://www.3gpp.org/specs/TISPAN-IMS-ansfer.htm
- 2842: - / Impacted TSs and TRs: 22.173, 22.273
- 2843: - / Impacted TSs and TRs: 23.406, 23.417, 23.508,23.509, 23.511
- 2844: SP#38 completed / Impacted TSs and TRs: 22.173, 22.273, 22.401, 23.406, 23.417, 23.508, 23.509, 23.511
- 2845: CP#39 completed / Impacted TSs and TRs: 24.404, 24.405, 24.406, 24.407, 24.408, 24.410, 24.411, 24.416, 29.421, 24.423, 24.428, 24.429, 29.433, 24.441, 24.403, 29.427, 24.430, 29.412
- 2846: - / Impacted TSs and TRs: EMC1
- 2847: - / Impacted TSs and TRs: 22.101
- 2848: - / Impacted TSs and TRs: 23.867
- 2849: - / Impacted TSs and TRs: 23.867
- 2850: - / Impacted TSs and TRs: 23.060, 23.167, 23.203, 23.221, 23.228, 23.234, 23.271, 23.406
- 2851: -

| ID | WBS | Task | Type | Duration | Start | Finish | Complete | Baseline start | Baseline finish | Baseline duration | Constraint | Resources | Work | Actual work | Acronym | WI rapporteur name | WI rapporteur e-mail | Release | MCC resp | Special Focus Doc | Impacted TSs and TRs | PCG approved | TSG approved | TSG stopped | Acronym_3GU_Export | Created at | Status Report |
| --- | --- | --- | --- | --- | --- | --- | --- | --- | --- | --- | --- | --- | --- | --- | --- | --- | --- | --- | --- | --- | --- | --- | --- | --- | --- | --- | --- |
| 2852 | 10.1 | **Emergency Call Enhancements for IP& PS Based Calls – stage 3** |  | 1549d? | 2006-01-09 A | 2011-12-09 A | 100% | 2006-01-09 | 2011-12-09 | 1549d? |  | C1; C4; IETF | 50829.8h | 50829.8h | EMC1 | Ericsson | alf.heidermark@ericsson.com | Rel-7 | Frederic | Public Safety (I-A) |  |  |  |  |  |  |  |
| 2853 | 10.1.2 | CT1 IMS aspects to support IMS Emergency sessions |  | 350.82d | 2006-01-09 A | 2007-06-15 A | 100% | 2006-01-09 | 2007-06-15 | 350.82d | finish no earlier than 2007-06-15 | C1 | 2806.57h | 2806.57h | EMC1 | Ericsson | alf.heidermark@ericsson.com | Rel-7 | Frederic | Public Safety (I-A) | 24.229 |  |  |  |  |  |  |
| 2854 | 766.6.2 | (IETF) CT1 IMS aspects to support IMS Emergency sessions |  | 452d? | 2006-01-09 A | 2011-12-09 A | 100% | 2006-01-09 | 2011-12-09 | 452d? | finish no earlier than 2011-12-09 | C1-IETF | 3608h | 3608h | EMC1 | Keith Drage |  | Rel-7 | Frederic | Public Safety (I-A) | RFC 6442 (was draft-ietf-sipcore-location-conveyance) | PCG-27 | CP-52 |  |  |  |  |
| 2855 | 10.1.2 | Deleted - CT3 IMS aspects to support IMS Emergency sessions |  | 95d | 2006-05-08 A | 2006-09-15 A | 100% | 2006-05-08 | 2006-09-15 | 95d | finish no earlier than 2006-09-15 | C3 | 760h | 760h | EMC1 | Ericsson | alf.heidermark@ericsson.com | Rel-7 | Adrian | Public Safety (I-A) | 29.163 |  |  | CP-33 |  |  |  |
| 2856 | 10.1.5 | Deleted - CT3 PS domain aspects to support IMS Emergency sessions |  | 95d | 2006-05-08 A | 2006-09-15 A | 100% | 2006-05-08 | 2006-09-15 | 95d | start no earlier than 2006-05-08 | C3 | 760h | 760h | EMC1 | Ericsson | alf.heidermark@ericsson.com | Rel-7 | Adrian | Public Safety (I-A) | 29.061 |  |  | CP-33 |  |  |  |
| 2857 | 10.1.5 | CT1 PS domain aspects to support IMS Emergency sessions |  | 349.9d | 2006-01-09 A | 2007-06-15 A | 100% | 2006-01-09 | 2007-06-15 | 349.9d | finish no earlier than 2007-06-15 | C1 | 2799.2h | 2799.2h | EMC1 | Ericsson | alf.heidermark@ericsson.com | Rel-7 | Frederic | Public Safety (I-A) | 24.008, 24.234 |  |  |  |  |  |  |
| 2858 | 10.1.5 | CT4 PS domain aspects to support IMS Emergency sessions |  | 365d | 2006-01-09 A | 2007-06-01 A | 100% | 2006-01-09 | 2007-06-01 | 365d | finish no earlier than 2007-06-01 | C4 | 2920h | 2920h | EMC1-GPRSc4 | Ericsson | alf.heidermark@ericsson.com | Rel-7 | Kimmo | Public Safety (I-A) | 29.060 |  |  |  | EMC1-GPRSc4 |  |  |
| 2859 | 767 | IMS Support of Conferencing |  | 355d? | 2005-11-04 A | 2007-03-15 A | 100% | 2005-11-04 | 2007-03-15 | 355d? | finish no earlier than 2007-03-15 | C1 | 2840h | 2840h | IMSconf | Alcatel-Lucent | Keith Drage (drage@alcatel-lucent.com) | Rel-7 | Frederic |  | 24.147, 24.229 |  |  |  | IMSconf |  |  |
| 2860 | 768 | Performance Characterization of VoIMS over HSDPA\EUL channels |  | 713d? | 2005-03-15 A | 2007-12-06 A | 100% | 2005-03-15 | 2007-12-06 | 713d? | finish no earlier than 2007-12-06 | S4 | 5704h | 5704h | VoIMS-PCVoIMS | Alcatel-Lucent | mcgowan@alcatel-lucent.com | Rel-7 | Paolo |  | 26.935 |  |  |  | VoIMS-PCVoIMS |  |  |
| 2861 | 769 | **WLAN-UMTS Interworking Phase 2** |  | 371d? | 2004-01-05 A | 2005-06-07 A | 100% | 2004-01-05 | 2005-06-07 | 371d? |  | S1; S2 | 6856h | 6856h | WLAN2, WLAN-SC | Telenor | frederic.paint@telenor.com | Rel-7 | Alain | WLAN | 33.234 (SP-36 SA3 CRs approved) |  |  |  | WLAN2, WLAN-SC |  |  |
| 2862 | 769.1 | Stage 1 on Session Continuity |  | 115d? | 2004-01-05 A | 2004-06-11 A | 100% | 2004-01-05 | 2004-06-11 | 115d? | start no earlier than 2004-01-05 | S1 | 920h | 920h | WLAN2, WLAN-SC |  |  | Rel-7 | Alain | WLAN | 22.234 |  |  |  |  | SP-24 |  |
| 2863 | 769.2 | Stage 2 on Session Continuity: covered by SAE | milestone | 0d? | 2005-06-07 A | 2005-06-07 A | 100% | 2005-06-07 | 2005-06-07 | 0d? | finish no earlier than 2005-06-07 | S2 |  |  | WLAN2, WLAN-SC |  |  | Rel-7 | Maurice | WLAN |  |  |  |  |  |  |  |
| 2864 | 770 | **WLAN Interworking – Private Network access from WLAN 3GPP IP Access** |  | 252d? | 2005-10-10 A | 2006-09-26 A | 100% | 2005-10-10 | 2006-09-26 | 252d? |  | S2; C1; C3; C4 | 17704h | 17704h | WLANPNA | NEC | Toshiyuki Tamura (tamurato@aj.jp.nec.com) | Rel-7 | Maurice | WLAN |  |  |  |  | WLANPNA |  |  |
| 2865 | 770.1 | WLAN-PNA - Stage 2 |  | 185d? | 2005-10-10 A | 2006-06-23 A | 100% | 2005-10-10 | 2006-06-23 | 185d? | start no earlier than 2005-10-10 | S2 | 1480h | 1480h | WLANPNA-st2 | NEC | Toshiyuki Tamura (tamurato@aj.jp.nec.com) | Rel-7 | Maurice | WLAN | 23.234, 33.234 |  |  |  | WLANPNA-st2 |  |  |
| 2866 | 770.2 | **WLAN-PNA - Stage 3** |  | 170d? | 2006-02-01 A | 2006-09-26 A | 100% | 2006-02-01 | 2006-09-26 | 170d? |  | C1; C3; C4 | 8160h | 8160h | WLANPNA-st3 | NEC |  | Rel-7 | Frederic | WLAN |  |  |  |  | WLANPNA-st3 |  |  |
| 2867 | 770.2.1 | CT1 aspets for WLAN-PNA |  | 170d? | 2006-02-01 A | 2006-09-26 A | 100% | 2006-02-01 | 2006-09-26 | 170d? | start no earlier than 2006-02-01 | C1 | 1360h | 1360h | WLANPNA-st3 | NEC |  | Rel-7 | Frederic | WLAN | 24.234 |  |  |  |  |  |  |
| 2868 | 770.2.2 | CT3 aspets for WLAN-PNA |  | 170d? | 2006-02-01 A | 2006-09-26 A | 100% | 2006-02-01 | 2006-09-26 | 170d? | start no earlier than 2006-02-01 | C3 | 1360h | 1360h | WLANPNA-st3 | NEC |  | Rel-7 | Adrian | WLAN | 29.161 |  |  |  |  |  |  |
| 2869 | 770.2.3 | Deleted - CT4 aspets for WLAN-PNA |  | 170d? | 2006-02-01 A | 2006-09-26 A | 100% | 2006-02-01 | 2006-09-26 | 170d? | start no earlier than 2006-02-01 | C4 | 1360h | 1360h | WLANPNA-st3 | NEC |  | Rel-7 | Kimmo | WLAN | 29.234 |  |  | CP-32 |  |  |  |
| 2870 | 771 | **Enhancements to support QoS provisioning over 3GPP/WLAN Interworking** |  | 520d? | 2005-03-14 A | 2007-03-09 A | 100% | 2005-03-14 | 2007-03-09 | 520d? |  | S2; C4; C1 | 16680h | 16680h | WLANQOS | Samsung |  | Rel-7 | Maurice | WLAN |  |  |  |  | WLANQOS |  |  |
| 2871 | 771.1 | Deleted - TR on support of QoS on WLAN |  | 232d? | 2005-03-14 A | 2006-01-31 A | 100% | 2005-03-14 | 2006-01-31 | 232d? | start no earlier than 2005-03-14 | S2 | 1856h | 1856h | WLANQOS | Samsung |  | Rel-7 | Maurice | WLAN | 23.836 |  |  | SP-32 |  |  |  |
| 2872 | 771.2 | Stage 2 on support of QoS over 3GPP/WLAN interworking |  | 108d? | 2006-02-01 A | 2006-06-30 A | 100% | 2006-02-01 | 2006-06-30 | 108d? | start no earlier than 2006-02-01 | S2 | 864h | 864h | WLANQOS | Samsung |  | Rel-7 | Maurice | WLAN | 23.234 |  |  |  |  |  |  |
| 2873 | 771.3 | Stage 3 CT4 on support of QoS over 3GPP/WLAN Interworking |  | 121d? | 2006-09-22 A | 2007-03-09 A | 100% | 2006-09-22 | 2007-03-09 | 121d? | finish no earlier than 2007-03-09 | C4 | 968h | 968h | WLANQOS | Huawei | zhang.peng@huawei.com | Rel-7 | Kimmo | WLAN | 29.234, 23.008 |  |  |  |  |  |  |
| 2874 | 771.4 | Stage 3 CT1 on support of QoS over 3GPP/WLAN Interworking |  | 64d? | 2006-09-04 A | 2006-11-30 A | 100% | 2006-09-04 | 2006-11-30 | 64d? | finish no earlier than 2006-11-30 | C1 | 512h | 512h | WLANQOS | Huawei | zhang.peng@huawei.com | Rel-7 | Frederic | WLAN | 24.234 |  |  |  |  |  |  |
| 2875 | 772 | **Location Services enhancements** |  | 906d? | 2004-06-28 A | 2007-12-17 A | 100% | 2004-06-28 | 2007-12-17 | 906d? |  | S1; S2; GP; C4; R2 | 81525.6h | 81525.6h | LCS3 |  |  | Rel-7 | Alain |  |  |  |  |  | LCS3 |  |  |
| 2876 | 772.1 | Stage 2 for LCS3 (including IMS emergency location aspects) |  | 446d? | 2004-12-31 A | 2006-09-15 A | 100% | 2004-12-31 | 2006-09-15 | 446d? | finish no earlier than 2006-09-15 | S2 | 3568h | 3568h | LCS3 | SiRF | brodilitz@sirf.com | Rel-7 | Maurice |  | 23.271 |  |  |  |  |  |  |
| 2877 | 772.2 | LCS Enhancements related to Location-Based Services |  | 695d? | 2005-01-03 A | 2007-08-31 A | 100% | 2005-01-03 | 2007-08-31 | 695d? | finish no earlier than 2007-08-31 | GP | 5560h | 5560h | LCS3-LBS | SiRF | kjudge@sirf.com | Rel-7 | Paolo |  | 43.059, 44.031, 48.008, 49.031 |  |  |  | LCS3-LBS |  |  |
| 2878 | 772.3 | CT4 aspects for LCS UEPos-LBS |  | 240d? | 2006-01-02 A | 2006-12-01 A | 100% | 2006-01-02 | 2006-12-01 | 240d? | finish no earlier than 2006-12-01 | C4 | 1920h | 1920h | LCS3-UEPos-LBS | SiRF | brodilitz@sirf.com | Rel-7 | Kimmo |  | 24.030, 24.080, 29.002 |  |  |  | LCS3-UEPos-LBS |  |  |
| 2879 | 772.4 | UE positioning - Velocity |  | 394d? | 2005-03-15 A | 2006-09-15 A | 100% | 2005-03-15 | 2006-09-15 | 394d? | finish no earlier than 2006-09-15 | R2 | 3152h | 3152h | LCS3-UEPos-Velocity | SiRF | BRodilitz@SiRF.com | Rel-7 | Yong-Jun |  | 25.305, 25.331, 25.410, 25.413, 25.453 |  |  |  | LCS3-UEPos-Velocity |  | RP-060459 |
| 2880 | 772.5 | Inclusion of Uplink TDOA UE positioning method in the UTRAN specifications |  | 849d? | 2004-09-15 A | 2007-12-17 A | 100% | 2004-09-15 | 2007-12-17 | 849d? | finish no earlier than 2007-12-17 | R2 | 6792h | 6792h | LCS3-UEPos-UTDOA | TruePosition | Robert Gross (rgross@polariswireless.com) | Rel-7 | Yong-Jun |  | 25.305, 25.453, new TS 25.111 |  |  |  | LCS3-UEPos-UTDOA |  | RP-070797 |

Notes:
- 2852: -
- 2853: -
- 2854: CP#54 completed
- 2855: Cancelled for Rel-7 and there is no corresponding Rel-8 WI
- 2856: Cancelled for Rel-7 and there is no corresponding Rel-8 WI
- 2857: -
- 2858: -
- 2859: CP#35 revised WID
- 2860: -
- 2861: Created at SP#27 because of WLAN items belonging to Rel-7
- 2862: -
- 2863: -
- 2864: -
- 2865: Approved at SP#29
- 2866: Approved at CP#29
- 2867: Approved at CP#29
- 2868: Approved at CP#29
- 2869: CT4#31; no impacts identified, therefore completed. CP-32 stopped
- 2870: Moved from FS section Feb 06. SP-30 updated WID
- 2871: SP#32 stopped
- 2872: SP#30 updated WID
- 2873: CP#33 approved WID
- 2874: CP#33 approved WID
- 2875: -
- 2876: SP#27 approved WID
- 2877: -
- 2878: -
- 2879: -
- 2880: -

| ID | WBS | Task | Duration | Start | Finish | Complete | Baseline start | Baseline finish | Baseline duration | Constraint | Resources | Work | Actual work | Acronym | WI rapporteur name | WI rapporteur e-mail | Release | MCC resp | Special Focus Doc | Acronym_3GU_Export | TSG stopped | Status Report | PCG approved | TSG approved |
| --- | --- | --- | --- | --- | --- | --- | --- | --- | --- | --- | --- | --- | --- | --- | --- | --- | --- | --- | --- | --- | --- | --- | --- | --- |
| 2881 | 772.6 | **LCS for 3GPP Interworking WLAN** | 700d? | 2004-06-28 A | 2007-03-02 A | 100% | 2004-06-28 | 2007-03-02 | 700d? |  | S1; S2 | 17501.6h | 17501.6h | LCS3-IWLAN | Telcordia | Mike Loushine | Rel-7 | Alain | WLAN | LCS3-IWLAN |  |  |  |  |
| 2882 | 772.6.1 | FS on 3GPP system to WLAN Interworking with LCS | 512.7d? | 2004-06-28 A | 2006-06-30 A | 100% | 2004-06-28 | 2006-06-30 | 512.7d? | finish no earlier than 2005-09-29 | S1 | 4101.6h | 4101.6h | LCS3-IWLAN-FSs1 | Telcordia | Mike Loushine | Rel-7 | Alain |  | LCS3-IWLAN-FSs1 |  |  |  |  |
| 2883 | 772.6.2 | Deleted - Study of work on an LCS architecture for I-WLAN. | 180d? | 2006-06-26 A | 2007-03-02 A | 100% | 2006-06-26 | 2007-03-02 | 180d? | finish no earlier than 2007-03-02 | S2 | 1440h | 1440h | LCS3-IWLAN-FSs2 | LG Electronics | dhshim@lge.com ; phede@lge.com | Rel-7 | Maurice |  | LCS3-IWLAN-FSs2 | SP-35 |  |  |  |
| 2884 | 772.6.3 | Stage 2 for LCS architecture for I-WLAN | 95d? | 2006-10-23 A | 2007-03-02 A | 100% | 2006-10-23 | 2007-03-02 | 95d? | finish no earlier than 2007-03-02 | S2 | 760h | 760h | LCS3-IWLAN | LG Electronics | dhshim@lge.com ; phede@lge.com | Rel-7 | Maurice |  | LCS3-IWLAN |  |  |  |  |
| 2885 | 772.7 | Deleted - UE positioning Rel-7 | 849d? | 2004-09-15 A | 2007-12-17 A | 100% | 2004-09-15 | 2007-12-17 | 849d? |  | RP | 6792h | 6792h | LCS3-UEpos |  |  | Rel-7 | Yong-Jun |  | LCS3-UEpos | RP-38 |  |  |  |
| 2886 | 773 | **MBMS Enhancements** | 625d? | 2005-07-11 A | 2007-11-30 A | 100% | 2005-07-11 | 2007-11-30 | 625d? |  | S1; R1; C3 | 20844.6h | 20844.6h | MBMSE | China Mobile | liuhongyfw@chinamobile.com | Rel-7 | Alain |  | MBMSE |  |  |  |  |
| 2887 | 773.1 | Stage 1 of MBMSE | 109d? | 2005-07-11 A | 2005-12-08 A | 100% | 2005-07-11 | 2005-12-08 | 109d? | finish no earlier than 2005-12-08 | S1 | 872h | 872h | MBMSE | China Mobile | liuhongyfw@chinamobile.com | Rel-7 | Alain |  |  |  |  |  |  |
| 2888 | 773.2 | MBMS FDD Physical layer Enhancements | 117.29d? | 2006-12-15 A | 2007-06-04 A | 100% | 2006-12-15 | 2007-06-04 | 117.29d? | finish no earlier than 2007-06-04 | R1 | 938.32h | 938.32h | MBMSE-RANPhysFDD | Ericsson | Lars.Lindbom@ericsson.com | Rel-7 | Patrick |  | MBMSE-RANPhysFDD |  | RP-070290 |  |  |
| 2889 | 773.3 | MBMS TDD Physical layer Enhancements | 117.29d? | 2006-12-15 A | 2007-06-04 A | 100% | 2006-12-15 | 2007-06-04 | 117.29d? | finish no earlier than 2007-06-04 | R1 | 938.32h | 938.32h | MBMSE-RANPhysTDD | IPWireless | Nicholas Anderson | Rel-7 | Patrick |  | MBMSE-RANPhysTDD |  | RP-070291 |  |  |
| 2890 | 773.4 | MBMS Low Chip Rate TDD Physical Layer Enhancement | 127d? | 2007-03-16 A | 2007-09-10 A | 100% | 2007-03-16 | 2007-09-10 | 127d? | finish no earlier than 2007-09-10 | R1 | 1016h | 1016h | MBMSE-RANPhysLCRTDD | RITT | Lin Hui | Rel-7 | Patrick |  | MBMSE-RANPhysLCRTDD |  | RP-070292 |  |  |
| 2891 | 773.5 | MBMS Mz interface | 260d? | 2006-12-04 A | 2007-11-30 A | 100% | 2006-12-04 | 2007-11-30 | 260d? | finish no earlier than 2007-05-11 | C3 | 2080h | 2080h | MBMSMz | Huawei | Deng Tingting (ttdeng@huawei.com) | Rel-7 | Adrian |  | MBMSMz |  |  |  |  |
| 2892 | 774 | **MBMS - UE Conformance Testing** | 657d? | 2007-06-01 A | 2009-12-04 A | 100% | 2007-06-01 | 2009-12-04 | 657d? |  | R5 | 13848h | 13848h | MBMSE_UEConTest |  |  | Rel-7 | Ingbert |  | MBMSE_UEConTest |  |  | PCG-21 | SP-40 |
| 2893 | 774.1 | Conformance Test Aspects – MBMS TDD Physical layer Enhancements – MBSFN for HCR and VHCR TDD | 336d? | 2007-06-01 A | 2008-09-12 A | 100% | 2007-06-01 | 2008-09-12 | 336d? | start no earlier than 2007-06-01 | R5 | 2688h | 2688h | MBMSE-RANPhysTDD_UEConTest | IPWireless | tspeight@ipwireless.com | Rel-7 | Ingbert |  | MBMSE-RANPhysTDD_UEConTest |  | RP-080541 |  |  |
| 2894 | 774.2 | Conformance Test Aspects – MBMS LCR TDD Physical Layer Enhancement | 342d? | 2008-05-30 A | 2009-09-18 A | 100% | 2008-05-30 | 2009-09-18 | 342d? | finish no earlier than 2009-09-18 | R5 | 2728h | 2728h | MBMSE-RANPhysLCRTDD_UEConTest | CATT | chenxiaozhong@datangmobile.cn | Rel-7 | Ingbert |  | MBMSE-RANPhysLCRTDD_UEConTest |  | RP-090715 | PCG-21 | RP-40 |
| 2895 | 774.3 | Conformance Test Aspects – MBSFN for FDD | 397d? | 2008-05-30 A | 2009-12-04 A | 100% | 2008-05-30 | 2009-12-04 | 397d? | finish no earlier than 2009-12-04 | R5 | 3176h | 3176h | MBMSE-UEConTest_RANPhysFDD | Huawei | Xiang Li (trica_li@huawei.com) | Rel-7 | Ingbert |  | MBMSE-UEConTest_RANPhysFDD |  | RP-091214 | PCG-21 | RP-40 |
| 2896 | 775 | MBMS User Service Extensions | 392d? | 2005-12-07 A | 2007-06-07 A | 100% | 2005-12-07 | 2007-06-07 | 392d? | finish no earlier than 2007-06-07 | S4 | 3136h | 3136h | MBMSUSE | Ericsson | Thorsten.Lohmar@ericsson.com | Rel-7 | Paolo |  | MBMSUSE |  |  |  |  |
| 2897 | 776 | **Advanced Global Navigation Satellite System (AGNSS) concept** | 830d? | 2004-06-28 A | 2007-08-31 A | 100% | 2004-06-28 | 2007-08-31 | 830d? |  | S1; S2; GP; R2 | 36129.6h | 36129.6h | LCS3-AGNSS | Alcatel | Michel.monnerat@thalesaleniaspace.com | Rel-7 | Alain |  | LCS3-AGNSS |  |  |  |  |
| 2898 | 776.1 | Stage 1/2 for Towards AGNSS Concept | 1d? | 2007-02-16 A | 2007-02-16 A | 100% | 2007-02-16 | 2007-02-16 | 1d? | start no earlier than 2007-02-16 | S1; S2 | 16h | 16h | AGNSS | Alcatel | richard.couty@space.alcatel.fr | Rel-7 | Alain |  | AGNSS |  |  |  |  |
| 2899 | 776.2 | Towards AGNSS Concept | 811.2d? | 2004-06-28 A | 2007-08-31 A | 100% | 2004-06-28 | 2007-08-31 | 811.2d? | finish no earlier than 2007-08-31 | GP | 6489.6h | 6489.6h | AGNSS-GP | Alcatel | richard.couty@space.alcatel.fr | Rel-7 | Paolo |  | AGNSS-GP |  |  |  |  |
| 2900 | 776.3 | Global Navigation Satellite System (GNSS) in UTRAN | 383d? | 2005-12-15 A | 2007-06-04 A | 100% | 2005-12-15 | 2007-06-04 | 383d? | finish no earlier than 2007-06-04 | R2 | 3064h | 3064h | LCS3-GNSS-UTRAN | France Telecom | alain.abinakhoul@francetelecom.com | Rel-7 | Yong-Jun |  | LCS3-GNSS-UTRAN |  | RP-070482 |  |  |
| 2901 | 777 | A-GPS Minimum Performance | 351d? | 2006-04-28 A | 2007-08-31 A | 100% | 2006-04-28 | 2007-08-31 | 351d? | finish no earlier than 2007-08-31 | G1; G3 | 5616h | 5616h | GAGR | Spirent | richard.catmur@spirentcom.com | Rel-7 | Paolo |  | GAGR |  |  |  |  |
| 2902 | 778 | **Unstructured Supplementary Service Data (USSD) message delivery and transfer to USIM** | 376d? | 2004-03-05 A | 2005-08-12 A | 100% | 2004-03-05 | 2005-08-12 | 376d? |  | S1; C6 | 8778.4h | 8778.4h | USSD-USIM | Axalto | Christophe Dubois (cdubois@axalto.com) | Rel-7 | Alain |  | USSD-USIM |  |  |  |  |
| 2903 | 778.1 | Stage 1 for USSD message delivery and transfer to USIM | 152d? | 2004-03-18 A | 2004-10-15 A | 100% | 2004-03-18 | 2004-10-15 | 152d? | start no earlier than 2004-03-18 | S1 | 1216h | 1216h | USSD-USIM | Axalto | Christophe Dubois (cdubois@axalto.com) | Rel-7 | Alain |  |  |  |  |  |  |
| 2904 | 778.2 | Alignment with requirements regarding USSD usage | 193.3d? | 2004-03-05 A | 2005-08-12 A | 100% | 2004-03-05 | 2005-08-12 | 193.3d? | finish no earlier than 2005-08-12 | C6 | 1546.4h | 1546.4h | USSD-USIM | Axalto | Christophe Dubois (cdubois@axalto.com) | Rel-7 | Xavier |  |  |  |  |  |  |

Notes:
- 2881: -
- 2882: - / Impacted TSs and TRs: new TR 22.935
- 2883: SP#41 TR withdrawn. All work transferred to specs / Impacted TSs and TRs: 23.837
- 2884: - / Impacted TSs and TRs: 23.234, 23.271, 23.167
- 2885: -
- 2886: -
- 2887: - / Impacted TSs and TRs: 22.146, 22.246, 22.228
- 2888: - / Impacted TSs and TRs: 25.211, 25.212, 25.213, 25.101, 25.104, 25.331, 25.433, 25.346, 25.306
- 2889: - / Impacted TSs and TRs: 25.346, 25.221, 25.222, 25.223, 25.224, 25.306, 25.331, 25.402, 25.433, 25.102, 25.105, 25.123
- 2890: - / Impacted TSs and TRs: 25.346, 25.221, 25.222, 25.223, 25.224, 25.306, 25.331, 25.402, 25.433, 25.102, 25.105, 25.123
- 2891: - / Impacted TSs and TRs: 29.061
- 2892: Linked to Rel-7 Feature UID_31084 (MBMSE)
- 2893: RP#41 completed / Impacted TSs and TRs: 34.108, 34.122, 34.123-1/2/3
- 2894: RP#45 completed / Impacted TSs and TRs: 34.108, 34.123-1
- 2895: RP#46 completed / Impacted TSs and TRs: 34.108, 34.109, 34.121-1, 34.121-2, 34.123-1, 34.123-2, 34.123-3
- 2896: - / Impacted TSs and TRs: 26.346, 26.946
- 2897: -
- 2898: - / Impacted TSs and TRs: 22.071, 23.271
- 2899: GP#36 completed / Impacted TSs and TRs: 43.030, 43.059, 44.031, 44.035, 44.071, 48.008, 48.018, 48.031, 49.031
- 2900: - / Impacted TSs and TRs: 25.305, 25.331, 25.306, 25.413, 25.423, 25.433, 25.453, 25.302, 25.215, 25.401, 25.402, 25.450, 25.452
- 2901: - / Impacted TSs and TRs: 45.005, 51.010
- 2902: -
- 2903: - / Impacted TSs and TRs: 22.090
- 2904: - / Impacted TSs and TRs: 31.111, 31.115, 31.130

| ID | WBS | Task | Type | Duration | Start | Finish | Complete | Baseline start | Baseline finish | Baseline duration | Constraint | Resources | Work | Actual work | Acronym | WI rapporteur name | WI rapporteur e-mail | Release | MCC resp | Acronym_3GU_Export | Impacted TSs and TRs | TSG stopped |
| --- | --- | --- | --- | --- | --- | --- | --- | --- | --- | --- | --- | --- | --- | --- | --- | --- | --- | --- | --- | --- | --- | --- |
| 2905 | 779 | **Combinational Services** |  | 296d? | 2005-01-17 A | 2006-03-06 A | 100% | 2005-01-17 | 2006-03-06 | 296d? |  | S1; S2; C1; S4 | 14648h | 14648h | CSICS | TeliaSonera | Robert.Frank@teliasonera.com | Rel-7 | Alain | CSICS |  |  |
| 2906 | 779.1 | Stage 1 for CSICS |  | 104d? | 2005-01-17 A | 2005-06-09 A | 100% | 2005-01-17 | 2005-06-09 | 104d? | start no earlier than 2005-01-17 | S1 | 832h | 832h | CSICS | TeliaSonera | Robert.Frank@teliasonera.com | Rel-7 | Alain |  | 22.279 |  |
| 2907 | 779.2 | Stage 2 for CSICS |  | 130d? | 2005-01-17 A | 2005-07-15 A | 100% | 2005-01-17 | 2005-07-15 | 130d? | start no earlier than 2005-01-17 | S2 | 1040h | 1040h | CSICS | TeliaSonera | Robert.Frank@teliasonera.com | Rel-7 | Maurice |  | 23.279 |  |
| 2908 | 779.3 | Stage 3 for CSICS CN aspects |  | 221d? | 2005-05-02 A | 2006-03-06 A | 100% | 2005-05-02 | 2006-03-06 | 221d? | finish no earlier than 2006-03-06 | C1 | 1768h | 1768h | CSICS | Vodafone | peter.dawes@vodafone.com | Rel-7 | Frederic |  | 24.879, 24.279, 24.229, 24.008 |  |
| 2909 | 779.4 | Stage 3 for codec aspects |  | 192d? | 2005-03-15 A | 2005-12-07 A | 100% | 2005-03-15 | 2005-12-07 | 192d? | finish no earlier than 2005-12-07 | S4 | 1536h | 1536h | CSICS-Codec | Ericsson | Per.Frojdh@ericsson.com | Rel-7 | Paolo | CSICS-Codec | 26.141, 26.235 |  |
| 2910 | 780 | **CAMEL Trunk Triggers** |  | 251d? | 2004-12-17 A | 2005-12-05 A | 100% | 2004-12-17 | 2005-12-05 | 251d? |  | S1; C4 | 8032h | 8032h | TTCAMEL | Nortel | Amar Deol (deola@nortelnetworks.com) | Rel-7 | Alain | TTCAMEL |  |  |
| 2911 | 780.1 | Stage 1 for CAMEL Trunk Triggers |  | 251d? | 2004-12-17 A | 2005-12-05 A | 100% | 2004-12-17 | 2005-12-05 | 251d? |  | S1 | 2008h | 2008h | TTCAMEL | Nortel | Amar Deol (deola@nortelnetworks.com) | Rel-7 | Alain |  | 22.078 |  |
| 2912 | 780.2 | CAMEL Trunk Originated Trigger Detection Points |  | 251d? | 2004-12-17 A | 2005-12-05 A | 100% | 2004-12-17 | 2005-12-05 | 251d? | start no earlier than 2004-12-17 | C4 | 2008h | 2008h | CamelR7 | Nortel | David Hutton (dhutton@nortel.com) | Rel-7 | Kimmo | CamelR7 |  |  |
| 2913 | 781 | **IMS Service Brokering enhancements** |  | 69d? | 2005-12-07 A | 2006-03-13 A | 100% | 2005-12-07 | 2006-03-13 | 69d? |  | S1 | 1104h | 1104h | ISB | Telcordia | jbakker@telcordia.com | Rel-7 | Alain | ISB | 22.228 |  |
| 2914 | 781.1 | Stage 1 for ISB |  | 69d? | 2005-12-07 A | 2006-03-13 A | 100% | 2005-12-07 | 2006-03-13 | 69d? | finish no earlier than 2006-03-13 | S1 | 552h | 552h | ISB-s1 | Telcordia | jbakker@telcordia.com | Rel-7 | Alain | ISB-s1 | 22.228 |  |
| 2915 | 782 | **Enhancements of VGCS for public authority officials** |  | 731d? | 2004-08-27 A | 2007-06-15 A | 100% | 2004-08-27 | 2007-06-15 | 731d? |  | S1; C1; C4; G2 | 49312h | 49312h | EVGCS |  |  | Rel-7 | Alain | EVGCS | 43.068, 44.068, 24.008, 29.002 |  |
| 2916 | 782.1 | Stage 1 for Enhancements of VGCS for public authority officials | milestone | 0d? | 2004-08-27 A | 2004-08-27 A | 100% | 2004-08-27 | 2004-08-27 | 0d? | finish no earlier than 2004-08-27 | S1 |  |  | EVGCS | Siemens | joerg.swetina@neclab.eu | Rel-7 | Alain |  | 42.068, 43.068 |  |
| 2917 | 782.2 | **Architecture and protocol aspects** |  | 731d? | 2004-08-27 A | 2007-06-15 A | 100% | 2004-08-27 | 2007-06-15 | 731d? |  | C1; C4 | 20752h | 20752h | EVGCS | Siemens | robert.zaus@nsn.com | Rel-7 | Frederic |  | 43.068, 44.068 |  |
| 2918 | 782.2.1 | CT1 aspects of EVGCS |  | 731d? | 2004-08-27 A | 2007-06-15 A | 100% | 2004-08-27 | 2007-06-15 | 731d? | finish no earlier than 2006-09-15 | C1 | 5848h | 5848h | EVGCS | Siemens | robert.zaus@nsn.com | Rel-7 | Frederic |  | 43.068, 44.068, 24.008 |  |
| 2919 | 782.2.2 | CT4 aspects of EVGCS |  | 401d? | 2004-08-27 A | 2006-03-10 A | 100% | 2004-08-27 | 2006-03-10 | 401d? | finish no earlier than 2006-03-10 | C4 | 3208h | 3208h | EVGCS | Siemens | robert.zaus@nsn.com | Rel-7 | Kimmo |  | 29.002 |  |
| 2920 | 782.3 | GERAN2 aspects of EVGCS |  | 646d? | 2004-08-27 A | 2007-02-16 A | 100% | 2004-08-27 | 2007-02-16 | 646d? | finish no earlier than 2007-02-16 | G2 | 5168h | 5168h | EVGCS | Siemens | kenneth.isaacs@roke.co.uk | Rel-7 | Gert |  |  |  |
| 2921 | 783 | **Improvements of VGCS for parallel use of services** |  | 523d? | 2005-03-15 A | 2007-03-15 A | 100% | 2005-03-15 | 2007-03-15 | 523d? |  | S1 | 12230.2h | 12230.2h | IVGCS |  |  | Rel-7 | Alain | IVGCS |  |  |
| 2922 | 783.1 | Service Requirements for VGCS improvements |  | 62d? | 2005-03-15 A | 2005-06-08 A | 100% | 2005-03-15 | 2005-06-08 | 62d? | finish no earlier than 2005-06-08 | S1 | 496h | 496h | IVGCS | T-Mobile | kurt.bischinger@t-mobile.at | Rel-7 | Alain |  | 42.068 |  |
| 2923 | 783.2 | Stage 2 modifications for VGCS improvements |  | 335d? | 2005-12-01 A | 2007-03-14 A | 100% | 2005-12-01 | 2007-03-14 | 335d? | start no earlier than 2005-12-01 | C1 | 2680h | 2680h | IVGCS | T-Mobile | kurt.bischinger@t-mobile.at | Rel-7 | Frederic |  | 43.068 |  |
| 2924 | 783.3 | **Protocol aspects** |  | 336d? | 2005-12-01 A | 2007-03-15 A | 100% | 2005-12-01 | 2007-03-15 | 336d? |  | C1 | 5376h | 5376h | IVGCS | T-Mobile | Dieter Jacobsohn | Rel-7 | Frederic |  | 44.068 |  |
| 2925 | 783.3.1 | CT1 aspects of IVGCS |  | 336d? | 2005-12-01 A | 2007-03-15 A | 100% | 2005-12-01 | 2007-03-15 | 336d? | finish no earlier than 2007-03-15 | C1 | 2688h | 2688h | IVGCS | T-Mobile |  | Rel-7 | Frederic |  | 43.068, 44.068 |  |
| 2926 | 783.3.2 | Deleted - CT4 aspects of IVGCS | milestone | 0d? | 2007-03-09 A | 2007-03-09 A | 100% | 2007-03-09 | 2007-03-09 | 0d? | finish no earlier than 2007-03-09 | C4 |  |  | IVGCS-St3-c4 | T-mobile |  | Rel-7 | Kimmo | IVGCS-St3-c4 | 29.002 | CP-35 |
| 2927 | 784 | **Open Service Access (OSA) Rel-7** |  | 584d? | 2005-03-15 A | 2007-06-08 A | 100% | 2005-03-15 | 2007-06-08 | 584d? |  | S1; C5 | 29776h | 29776h | OSA7 | AePONA | eamonn.murray@aepona.com | Rel-7 | Alain | OSA7 |  |  |
| 2928 | 784.1 | **OSA Service Broker** |  | 449d? | 2005-03-15 A | 2006-12-01 A | 100% | 2005-03-15 | 2006-12-01 | 449d? |  | S1; C5 | 10176h | 10176h | OSA7-SB | AePONA | eamonn.murray@aepona.com | Rel-7 | Alain | OSA7-SB |  |  |
| 2929 | 784.1.1 | Service Requirements for OSA Service Broker |  | 62d? | 2005-03-15 A | 2005-06-08 A | 100% | 2005-03-15 | 2005-06-08 | 62d? | finish no earlier than 2005-06-08 | S1 | 496h | 496h | OSA7 | AePONA | eamonn.murray@aepona.com | Rel-7 | Alain |  | 22.127 |  |
| 2930 | 784.1.2 | Stage 2 OSA API Service Brokering |  | 156d? | 2006-04-28 A | 2006-12-01 A | 100% | 2006-04-28 | 2006-12-01 | 156d? |  | C5 | 1248h | 1248h | OSA7 | AePONA | damian.oneill@aepona.com | Rel-7 | Kimmo |  | 23.198 |  |
| 2931 | 784.1.3 | Stage 3 OSA API Service Brokering |  | 156d? | 2006-04-28 A | 2006-12-01 A | 100% | 2006-04-28 | 2006-12-01 | 156d? | finish no earlier than 2006-12-01 | C5 | 1248h | 1248h | OSA7 | AePONA | damian.oneill@aepona.com | Rel-7 | Kimmo |  | 29.198-16 |  |

Notes:
- 2905: -
- 2906: -
- 2907: -
- 2908: -
- 2909: -
- 2910: -
- 2911: -
- 2912: -
- 2913: No CR submitted in rel-8 (according to CR database).
- 2914: No Rel-8 changes
- 2915: Moved from Rel-6 UID_50563 Enhancements of VGCS in public networks for communication of public authority officials
- 2916: Voice Group Call Service
- 2917: -
- 2918: -
- 2919: -
- 2920: -
- 2921: Voice Group Call Service
- 2922: -
- 2923: -
- 2924: Previous name (before CT32) was Architecture and protocol aspects
- 2925: -
- 2926: CT4#33 stage 2 solution is still open. ...
- 2927: -
- 2928: -
- 2929: -
- 2930: -
- 2931: -

| ID | WBS | Task | Type | Duration | Start | Finish | Complete | Baseline start | Baseline finish | Baseline duration | Constraint | Resources | Work | Actual work | Acronym | Impacted TSs and TRs | WI rapporteur name | WI rapporteur e-mail | Release | MCC resp | Acronym_3GU_Export | TSG stopped | Status Report |
| --- | --- | --- | --- | --- | --- | --- | --- | --- | --- | --- | --- | --- | --- | --- | --- | --- | --- | --- | --- | --- | --- | --- | --- |
| 2932 | 784.2 | **Rel-7 OSA Stage 2/3 enhancements** |  | 291d? | 2006-04-28 A | 2007-06-08 A | 100% | 2006-04-28 | 2007-06-08 | 291d? |  | C5 | 10256h | 10256h | OSA7 | 29.198/9, 23.198 | AePONA | damian.oneill@aepona.com | Rel-7 | Kimmo |  |  |  |
| 2933 | 784.2.1 | Parlay X Message Broadcast Web Service |  | 156d? | 2006-04-28 A | 2006-12-01 A | 100% | 2006-04-28 | 2006-12-01 | 156d? | finish no earlier than 2006-12-01 | C5 | 1248h | 1248h | OSA7 | 29.199-15, 23.198 | ETRI |  | Rel-7 | Kimmo |  |  |  |
| 2934 | 784.2.2 | Parlay X Geocoding Web Service |  | 156d? | 2006-04-28 A | 2006-12-01 A | 100% | 2006-04-28 | 2006-12-01 | 156d? | finish no earlier than 2006-12-01 | C5 | 1248h | 1248h | OSA7 | 29.199-16, 23.198 | ETRI |  | Rel-7 | Kimmo |  |  |  |
| 2935 | 784.2.3 | Parlay X Application driven QoS Web Service |  | 226d? | 2006-04-28 A | 2007-03-09 A | 100% | 2006-04-28 | 2007-03-09 | 226d? | finish no earlier than 2007-03-09 | C5 | 1808h | 1808h | OSA7 | 29.199-17, 23.198 | BT |  | Rel-7 | Kimmo |  |  |  |
| 2936 | 784.2.4 | Parlay-X Device Capabilities and Configuration |  | 162d? | 2006-10-26 A | 2007-06-08 A | 100% | 2006-10-26 | 2007-06-08 | 162d? | finish no earlier than 2007-06-09 | C5 | 1296h | 1296h | OSA7 | 29.199-18, 23.198 | Telenor |  | Rel-7 | Kimmo |  |  |  |
| 2937 | 784.2.5 | Parlay-X Multimedia Streaming Session Management Web Service |  | 97d? | 2006-10-26 A | 2007-03-09 A | 100% | 2006-10-26 | 2007-03-09 | 97d? | start no earlier than 2006-10-26 | C5 | 776h | 776h | OSA7 | 29.199-19, 23.198 | Telenor |  | Rel-7 | Kimmo |  |  |  |
| 2938 | 784.2.6 | Parlay-X Multimedia Multicast Control Web Service |  | 97d? | 2006-10-26 A | 2007-03-09 A | 100% | 2006-10-26 | 2007-03-09 | 97d? | start no earlier than 2006-10-26 | C5 | 776h | 776h | OSA7 | 29.199-20, 23.198 | ETRI |  | Rel-7 | Kimmo |  |  |  |
| 2939 | 784.2.7 | OSA API Conference Call Control SCF |  | 97d? | 2006-10-26 A | 2007-03-09 A | 100% | 2006-10-26 | 2007-03-09 | 97d? | start no earlier than 2006-10-26 | C5 | 776h | 776h | OSA7 | 29.198-04-5, 23.198 | Ericsson |  | Rel-7 | Kimmo |  |  |  |
| 2940 | 785 | **Selective Disabling of UE Capabilities** |  | 624.36d? | 2005-01-24 A | 2007-06-15 A | 100% | 2005-01-24 | 2007-06-15 | 624.36d? |  | S1; S2; C1 | 22341.5h | 22341.5h | SDoUE |  | Motorola |  | Rel-7 | Alain | SDoUE |  |  |
| 2941 | 785.1 | Stage 1 of SDoUE |  | 393.6d? | 2005-01-24 A | 2006-12-08 A | 100% | 2005-01-24 | 2006-12-08 | 393.6d? | finish no earlier than 2006-12-08 | S1 | 3148.8h | 3148.8h | SDoUE-CR | 22.011 | Motorola |  | Rel-7 | Alain | SDoUE-CR |  |  |
| 2942 | 785.2 | Deleted - TR on different possible architectures |  | 195d? | 2005-03-21 A | 2005-12-16 A | 100% | 2005-03-21 | 2005-12-16 | 195d? | finish no earlier than 2005-12-16 | S2 | 1560h | 1560h | SDoUE-FS | 23.805 abandonned at SP-30; descendant C1 24.305 | Vodafone | Gavin.Wong@vodafone.com | Rel-7 | Maurice | SDoUE-FS | SP-30 |  |
| 2943 | 785.3 | Stage 3 of SDoUE |  | 331d? | 2006-03-10 A | 2007-06-15 A | 100% | 2006-03-10 | 2007-06-15 | 331d? | finish no earlier than 2007-06-15 | C1 | 2648h | 2648h | SDoUE | 24.305 | Ericsson | christian.herrero@ericsson.com | Rel-7 | Frederic |  |  |  |
| 2944 | 786 | **Network selection enhancements (NSP)** |  | 328d? | 2006-03-15 A | 2007-06-15 A | 100% | 2006-03-15 | 2007-06-15 | 328d? |  | S1 | 6320h | 6320h | NSP |  | O2 | chris.friel@O2.com | Rel-7 | Alain | NSP |  |  |
| 2945 | 786.1 | Stage 1 of NSP |  | 191d? | 2006-03-15 A | 2006-12-06 A | 100% | 2006-03-15 | 2006-12-06 | 191d? | start no earlier than 2006-03-15 | S1 | 1528h | 1528h | NSP-TS | 22.101, 22.011, 23.122, 24.008, 25.304, 31.102, 45.008 | O2 | chris.friel@O2.com | Rel-7 | Alain | NSP-TS |  |  |
| 2946 | 786.2 | Procedural aspects of NSP |  | 271d? | 2006-06-02 A | 2007-06-15 A | 100% | 2006-06-02 | 2007-06-15 | 271d? | finish no earlier than 2007-06-15 | C1 | 2168h | 2168h | NSP-CR | 23.122, 24.008, 31.102 | Motorola | Andrew Howell | Rel-7 | Frederic | NSP-CR |  |  |
| 2947 | 787 | Network selection enhancements (NSP) - UE Conformance Testing |  | 396d? | 2007-06-01 A | 2008-12-05 A | 100% | 2007-06-01 | 2008-12-05 | 396d? | finish no earlier than 2008-12-05 | R5 | 3168h | 3168h | NSP-CR_UEConTest | 34.108, 34.123-1, 34.123-2, 34.123-3 | Nokia | jarkko.hellsten@nokia.com | Rel-7 | Ingbert | NSP-CR_UEConTest |  | RP-080819 |
| 2948 | 788 | **Access Class Barring and Overload Protection** |  | 650d? | 2004-03-15 A | 2006-09-08 A | 100% | 2004-03-15 | 2006-09-08 | 650d? |  | S2; C1 | 13968h | 13968h | ACBOP | 23.898 | Vodafone | chris.pudney@vodafone.com | Rel-7 | Maurice | ACBOP |  |  |
| 2949 | 788.1 | TR on Stage 2 |  | 274d? | 2004-03-15 A | 2005-03-31 A | 100% | 2004-03-15 | 2005-03-31 | 274d? | finish no earlier than 2005-03-31 | S2 | 2192h | 2192h | ACBOP | 23.898 | NTT DoCoMo | Jean-Jacques Davidian (davidian@docomo.fr) | Rel-7 | Maurice |  |  |  |
| 2950 | 788.2 | Stage 3 CN aspects of ACBOP |  | 172d? | 2005-06-06 A | 2006-01-31 A | 100% | 2005-06-06 | 2006-01-31 | 172d? | start no earlier than 2005-06-06 | C1 | 1376h | 1376h | ACBOP | 24.008 |  |  | Rel-7 | Frederic |  |  |  |
| 2951 | 788.3 | Deleted - Potential impact on Iu interface Overload functionality | milestone | 0d? | 2004-03-15 A | 2004-03-15 A | 100% | 2004-03-15 | 2004-03-15 | 0d? | finish no earlier than 2004-03-15 | RP |  |  | ACBOP | 25.413 |  |  | Rel-7 | Issam |  | RP-25 |  |
| 2952 | 788.4 | Deleted - Extra ACBOP information in RAN | milestone | 0d? | 2004-03-15 A | 2004-03-15 A | 100% | 2004-03-15 | 2004-03-15 | 0d? | finish no earlier than 2004-03-15 | RP |  |  | ACBOP | 25.331 |  |  | Rel-7 | Issam |  | RP-25 |  |
| 2953 | 788.5 | Deleted - Extra ACBOP information in GERAN | milestone | 0d? | 2006-09-08 A | 2006-09-08 A | 100% | 2006-09-08 | 2006-09-08 | 0d? | start no earlier than 2006-09-08 | GP |  |  | ACBOP | 44.018 |  |  | Rel-7 | Paolo |  | RP-33 |  |
| 2954 | 789 | **System enhancements for Fixed Broadband access to IMS** |  | 2117d? | 2003-11-05 A | 2011-12-09 A | 100% | 2003-11-05 | 2011-12-09 | 2117d? |  | S2; S3; S5; C1; C3; C4; IETF | 369944h | 369944h | FBI |  |  |  | Rel-7 | Maurice | FBI |  |  |
| 2955 | 789.1 | **TISPAN Rel 1 related aspects** |  | 2117d? | 2003-11-05 A | 2011-12-09 A | 100% | 2003-11-05 | 2011-12-09 | 2117d? |  | S2; S3; C1; C3; C4; IETF | 239320h | 239320h | FBI-TIS1 |  |  |  | Rel-7 | Maurice | FBI-TIS1 |  |  |
| 2956 | 789.1.1 | Stage 2 of FBI for TISPAN R1 |  | 365d? | 2004-10-14 A | 2006-03-08 A | 100% | 2004-10-14 | 2006-03-08 | 365d? | start no earlier than 2004-10-14 | S2 | 2920h | 2920h |  |  |  |  | Rel-7 | Maurice |  |  |  |

Notes:
- 2932: CP#34 updated WID CP-060607=>CP-070200
- 2933: -
- 2934: -
- 2935: -
- 2936: -
- 2937: -
- 2938: -
- 2939: -
- 2940: Moved from FS section Feb 06
- 2941: Moved from FS section Feb 06
- 2942: Moved from FS section Feb 06. Abandoned at SP-30
- 2943: -
- 2944: -
- 2945: -
- 2946: -
- 2947: RP#42 completed. Testing for Feature UID_7041 (NSP-CR)
- 2948: -
- 2949: -
- 2950: -
- 2951: -
- 2952: -
- 2953: -
- 2954: -
- 2955: -
- 2956: -

| ID | WBS | Task | Duration | Start | Finish | Complete | Baseline start | Baseline finish | Baseline duration | Constraint | Resources | Work | Actual work | WI rapporteur name | WI rapporteur e-mail | Release | MCC resp | PCG approved | TSG approved | Acronym | Acronym_3GU_Export | Special Focus Doc | TSG stopped |
| --- | --- | --- | --- | --- | --- | --- | --- | --- | --- | --- | --- | --- | --- | --- | --- | --- | --- | --- | --- | --- | --- | --- | --- |
| 2957 | 789.1.2 | **Protocol impact of FBI for TISPAN R1** | 2117d? | 2003-11-05 A | 2011-12-09 A | 100% | 2003-11-05 | 2011-12-09 | 2117d? |  | S3; C1; C3; C4; IETF | 133840h | 133840h | Siemens | peter.leis@nsn.com | Rel-7 | Frederic |  |  |  |  |  |  |
| 2958 | 789.1.2.1 | (IETF) CT aspects of FBI for TISPAN R1 | 2117d? | 2003-11-05 A | 2011-12-09 A | 100% | 2003-11-05 | 2011-12-09 | 2117d? | start no earlier than 2003-11-05 | C1-IETF; C3-IETF | 33872h | 33872h | Roland Jesske |  | Rel-7 | Frederic | PCG-27 | CP-52 |  |  |  |  |
| 2959 | 789.1.2.2 | CT1 aspects of FBI for TISPAN R1 | 802d? | 2003-11-05 A | 2006-11-30 A | 100% | 2003-11-05 | 2006-11-30 | 802d? | finish no earlier than 2006-11-30 | C1 | 6416h | 6416h | Siemens | peter.leis@nsn.com | Rel-7 | Frederic |  |  |  |  |  |  |
| 2960 | 789.1.2.3 | CT3 aspects of FBI for TISPAN R1 | 808d? | 2003-11-05 A | 2006-12-08 A | 100% | 2003-11-05 | 2006-12-08 | 808d? | finish no earlier than 2006-12-08 | C3 | 6464h | 6464h | Siemens | peter.leis@nsn.com | Rel-7 | Adrian |  |  |  |  |  |  |
| 2961 | 789.1.2.4 | CT4 aspects of FBI for TISPAN R1 | 301d? | 2006-01-13 A | 2007-03-09 A | 100% | 2006-01-13 | 2007-03-09 | 301d? | finish no earlier than 2007-03-09 | C4 | 2408h | 2408h | Siemens | peter.leis@nsn.com | Rel-7 | Kimmo |  |  | FBI-TIS1-st3-c4 | FBI-TIS1-st3-c4 |  |  |
| 2962 | 789.1.3 | Security Enhancements for FBI | 118d? | 2005-06-28 A | 2005-12-08 A | 100% | 2005-06-28 | 2005-12-08 | 118d? | start no earlier than 2005-06-28 | S3 | 944h | 944h | Ericsson | Bengt.Sahlin@ericsson.com | Rel-7 | Mirko |  |  | FBI-ISE | FBI-ISE |  |  |
| 2963 | 789.2 | **PacketCable Related aspects** | 291d? | 2006-02-01 A | 2007-03-14 A | 100% | 2006-02-01 | 2007-03-14 | 291d? |  | S2; S5; C1 | 12072h | 12072h | CableLabs | Bernie McKibben (b.mckibben@cablelabs.com) | Rel-7 | Maurice |  |  | FBI-PCBL | FBI-PCBL |  |  |
| 2964 | 789.2.1 | Stage 1,2 of FBI for PacketCable | 228d? | 2006-02-01 A | 2006-12-15 A | 100% | 2006-02-01 | 2006-12-15 | 228d? | finish no earlier than 2006-12-15 | S2 | 1824h | 1824h | CableLabs | Bernie McKibben (b.mckibben@cablelabs.com) | Rel-7 | Maurice |  |  |  |  |  |  |
| 2965 | 789.2.2 | Protocol impact of FBI for PacketCable | 228d? | 2006-05-01 A | 2007-03-14 A | 100% | 2006-05-01 | 2007-03-14 | 228d? | finish no earlier than 2007-03-15 | C1 | 1824h | 1824h |  |  | Rel-7 | Frederic |  |  |  |  |  |  |
| 2966 | 789.2.3 | SA5 Charging aspects of FBI for PacketCable | 180d? | 2006-03-31 A | 2006-12-07 A | 100% | 2006-03-31 | 2006-12-07 | 180d? | finish no earlier than 2006-12-07 | S5 | 1440h | 1440h | CableLabs | Bernie McKibben (b.mckibben@cablelabs.com) | Rel-7 | Mirko |  |  | FBI-PCBL-CH | FBI-PCBL-CH |  |  |
| 2967 | 790 | **Support of SMS over generic 3GPP IP access** | 696d? | 2004-10-14 A | 2007-06-14 A | 100% | 2004-10-14 | 2007-06-14 | 696d? |  | S2; C4; C1 | 37544h | 37544h | Huawei | zhangwenlin@huawei.com | Rel-7 | Maurice |  |  | SMSIP | SMSIP | WLAN |  |
| 2968 | 790.1 | FS on SMSIP | 173d? | 2004-10-14 A | 2005-06-13 A | 100% | 2004-10-14 | 2005-06-13 | 173d? | start no earlier than 2004-10-14 | S2 | 1384h | 1384h | Huawei | zhangwenlin@huawei.com | Rel-7 | Maurice |  |  |  |  | WLAN |  |
| 2969 | 790.2 | Stage 2 for SMSIP | 333d? | 2005-06-08 A | 2006-09-15 A | 100% | 2005-06-08 | 2006-09-15 | 333d? | finish no earlier than 2006-09-15 | S2 | 2664h | 2664h | Huawei | zhangwenlin@huawei.com | Rel-7 | Maurice |  |  |  |  | WLAN |  |
| 2970 | 790.3 | **Stage 3 for SMSIP** | 527d? | 2005-06-08 A | 2007-06-14 A | 100% | 2005-06-08 | 2007-06-14 | 527d? |  | C4; C1 | 16792h | 16792h | Nokia | jari.jansson@nokia.com | Rel-7 | Kimmo |  |  | SMSIP-St3 | SMSIP-St3 | WLAN |  |
| 2971 | 790.3.1 | CT1 aspects for SMSIP | 527d? | 2005-06-08 A | 2007-06-14 A | 100% | 2005-06-08 | 2007-06-14 | 527d? | finish no earlier than 2007-06-15 | C1 | 4216h | 4216h | Nokia | jari.jansson@nokia.com | Rel-7 | Frederic |  |  |  |  | WLAN |  |
| 2972 | 790.3.2 | CT4 aspects for SMSIP | 518d? | 2005-06-08 A | 2007-06-01 A | 100% | 2005-06-08 | 2007-06-01 | 518d? | finish no earlier than 2007-06-01 | C4 | 4144h | 4144h | Nokia | jari.jansson@nokia.com | Rel-7 | Kimmo |  |  | SMSIP-St3-c4 | SMSIP-St3-c4 | WLAN |  |
| 2973 | 791 | **Evolution of Policy Control and Charging** | 817d? | 2004-10-14 A | 2007-11-30 A | 100% | 2004-10-14 | 2007-11-30 | 817d? |  | S2; S5; C3; C1 | 54112h | 54112h | Nokia | balazs.bertenyi@nsn.com | Rel-7 | Maurice |  |  | PCC | PCC |  |  |
| 2974 | 791.1 | Deleted - TR for PCC | 315d? | 2004-10-14 A | 2005-12-29 A | 100% | 2004-10-14 | 2005-12-29 | 315d? | finish no earlier than 2005-12-28 | S2 | 2520h | 2520h | Nokia | balazs.bertenyi@nsn.com | Rel-7 | Maurice |  |  |  |  |  | SP-33 |
| 2975 | 791.2 | Stage 2 for PCC | 315d? | 2005-07-04 A | 2006-09-15 A | 100% | 2005-07-04 | 2006-09-15 | 315d? | finish no earlier than 2006-09-15 | S2 | 2520h | 2520h | Nokia | balazs.bertenyi@nsn.com | Rel-7 | Maurice |  |  |  |  |  |  |
| 2976 | 791.3 | Evolution of policy control and flow based bearer level charging | 109d? | 2006-08-01 A | 2006-12-29 A | 100% | 2006-08-01 | 2006-12-29 | 109d? | start no earlier than 2006-08-01 | S2 | 872h | 872h | Nokia | balazs.bertenyi@nsn.com | Rel-7 | Maurice |  |  |  |  |  |  |
| 2977 | 791.4 | SA5 Charging aspects of PCC | 316d? | 2006-03-31 A | 2007-06-15 A | 100% | 2006-03-31 | 2007-06-15 | 316d? | finish no earlier than 2007-06-15 | S5 | 2528h | 2528h | Orange | alain.bibas@orange-ft.com | Rel-7 | Mirko |  |  | PCC-CH | PCC-CH |  |  |
| 2978 | 791.5 | Gx reference point for Policy and Charging Control | 521d? | 2005-12-02 A | 2007-11-30 A | 100% | 2005-12-02 | 2007-11-30 | 521d? | finish no earlier than 2007-09-14 | C3 | 4168h | 4168h | Siemens | Thomas.Belling@nsn.com | Rel-7 | Adrian |  |  | PCC-Gx | PCC-Gx |  |  |
| 2979 | 791.6 | **Rx reference point for PCC CT3 aspects** | 521d? | 2005-12-02 A | 2007-11-30 A | 100% | 2005-12-02 | 2007-11-30 | 521d? |  | C3; C1 | 15360h | 15360h | Ericsson | j.javier.pastor@ericsson.com | Rel-7 | Adrian |  |  | PCC-Rx | PCC-Rx |  |  |
| 2980 | 791.6.1 | PCC-Rx CT3 aspects | 521d? | 2005-12-02 A | 2007-11-30 A | 100% | 2005-12-02 | 2007-11-30 | 521d? | finish no earlier than 2007-09-14 | C3 | 4168h | 4168h | Ericsson | j.javier.pastor@ericsson.com | Rel-7 | Adrian |  |  | PCC-Rx-c3 | PCC-Rx-c3 |  |  |
| 2981 | 791.6.2 | PCC-Rx CT1 aspects | 357d? | 2005-12-02 A | 2007-06-15 A | 100% | 2005-12-02 | 2007-06-15 | 357d? | finish no earlier than 2007-06-15 | C1 | 2856h | 2856h | Ericsson | j.javier.pastor@ericsson.com | Rel-7 | Frederic |  |  | PCC-Rx-Gx-c1 | PCC-Rx-Gx-c1 |  |  |

Notes:
- 2957: -
- 2958: CP#54 completed / Impacted TSs and TRs: RFC 6432 (was draft-jesske-dispatch-update3326-reason-responses)
- 2959: - / Impacted TSs and TRs: 24.819, 24.229
- 2960: - / Impacted TSs and TRs: 29.163, 29.209
- 2961: CT4#32: a set of CRs on FBI for cable labs / Impacted TSs and TRs: 29.229
- 2962: Duplicated entry ("ACCSEC2", "Access Security Enhancements", SP-040865) deleted by A.Sultan / Impacted TSs and TRs: 33.203
- 2963: -
- 2964: - / Impacted TSs and TRs: 22.228, 23.228
- 2965: -
- 2966: 03/2006 SP#31 WID approved / Impacted TSs and TRs: 32.240, 32.260, 32.298, 32.299
- 2967: SP#33 updated WID (removed MMS)
- 2968: SP#33 updated WID / Impacted TSs and TRs: 23.804
- 2969: SP#33 updated WID / Impacted TSs and TRs: 23.204
- 2970: CP#34 updated WID
- 2971: CP#34 updated WID / Impacted TSs and TRs: 23.040, 24.229
- 2972: CP#34 updated WID / Impacted TSs and TRs: 23.008, 29.002
- 2973: SP-29 approved WID. SP-31 updated WID adding SA5 charging. 23.125 will be discontinued from Rel-7.
- 2974: SP-30: S2 has no intention for TR completion / Impacted TSs and TRs: 23.803
- 2975: SP-29 approved WID. SP-31 updated WID. 23.125 will be discontinued from Rel-7. / Impacted TSs and TRs: 23.203
- 2976: SP-29 approved WID. SP-31 updated WID. 23.125 will be discontinued from Rel-7. / Impacted TSs and TRs: 23.207, 23.002, 23.228
- 2977: SP-31 updated WID with SA5 charging. / Impacted TSs and TRs: 32.250, 32.251, 32.298, 32.299
- 2978: - / Impacted TSs and TRs: 29.212 (not progressed to Rel-7: 29.210, 29.207, 29.208)
- 2979: WID approved at CP#30, Revised at CP#31, Revised at CP#33
- 2980: - / Impacted TSs and TRs: 29.213, 29.214 (not progressed to Rel-7: 29.209, 29.211)
- 2981: - / Impacted TSs and TRs: 24.229

| ID | WBS | Task | Type | Duration | Start | Finish | Complete | Baseline start | Baseline finish | Baseline duration | Constraint | Resources | Work | Actual work | Acronym | WI rapporteur name | WI rapporteur e-mail | Release | MCC resp | Special Focus Doc | Acronym_3GU_Export | Impacted TSs and TRs | TSG stopped |
| --- | --- | --- | --- | --- | --- | --- | --- | --- | --- | --- | --- | --- | --- | --- | --- | --- | --- | --- | --- | --- | --- | --- | --- |
| 2982 | 792 | **Voice Call Continuity between CS and IMS (incl. I-WLAN)** |  | 641d? | 2004-12-31 A | 2007-06-15 A | 100% | 2004-12-31 | 2007-06-15 | 641d? |  | S2; S1; S5; C1; C4 | 43592h | 43592h | VCC | Alcatel-Lucent | Keith Drage (drage@alcatel-lucent.com) | Rel-7 | Maurice | WLAN | VCC |  |  |
| 2983 | 792.1 | TR for Voice Call Continuity between CS and IMS (incl. I-WLAN) |  | 245d? | 2004-12-31 A | 2005-12-08 A | 100% | 2004-12-31 | 2005-12-08 | 245d? | finish no earlier than 2005-12-08 | S2 | 1960h | 1960h |  | Alcatel-Lucent | andy.bennett@alcatel-lucent.com | Rel-7 | Maurice | WLAN |  | 23.806 |  |
| 2984 | 792.2 | Stage 1 for Voice Call Continuity between CS and IMS (incl. I-WLAN) |  | 140d? | 2005-03-17 A | 2005-09-28 A | 100% | 2005-03-17 | 2005-09-28 | 140d? | finish no earlier than 2005-09-28 | S1 | 1120h | 1120h |  | Alcatel-Lucent | andy.bennett@alcatel-lucent.com | Rel-7 | Alain | WLAN |  | 22.101 |  |
| 2985 | 792.3 | Stage 2 for Voice Call Continuity between CS and IMS (incl. I-WLAN) |  | 264d? | 2005-09-06 A | 2006-09-08 A | 100% | 2005-09-06 | 2006-09-08 | 264d? | finish no earlier than 2006-09-08 | S2 | 2112h | 2112h |  | Alcatel-Lucent | andy.bennett@alcatel-lucent.com | Rel-7 | Maurice | WLAN |  | 23.206 |  |
| 2986 | 792.4 | SA5 Charging for Voice Call Continuity between CS and IMS (incl. I-WLAN) |  | 325d? | 2006-03-17 A | 2007-06-14 A | 100% | 2006-03-17 | 2007-06-14 | 325d? | finish no earlier than 2007-06-14 | S5 | 2600h | 2600h | VCC-CH | Orange | alain.bibas@orange-ft.com | Rel-7 | Mirko | WLAN | VCC-CH | 32.250, 32.260 |  |
| 2987 | 792.5 | **Stage 3 for Voice Call Continuity between CS and IMS (incl. I-WLAN)** |  | 358d? | 2006-02-01 A | 2007-06-15 A | 100% | 2006-02-01 | 2007-06-15 | 358d? |  | C1; C4 | 10160h | 10160h |  | Alcatel-Lucent | Keith Drage (drage@alcatel-lucent.com) | Rel-7 | Frederic | WLAN |  |  |  |
| 2988 | 792.5.1 | CT1 aspects of Stage 3 for Voice Call Continuity between CS and IMS (incl. I-WLAN) |  | 358d? | 2006-02-01 A | 2007-06-15 A | 100% | 2006-02-01 | 2007-06-15 | 358d? | finish no earlier than 2007-06-15 | C1 | 2864h | 2864h |  | Alcatel-Lucent | Keith Drage (drage@alcatel-lucent.com) | Rel-7 | Frederic | WLAN |  | 24.206, 24.216 |  |
| 2989 | 792.5.2 | CT4 aspects of Stage 3 for Voice Call Continuity between CS and IMS (incl. I-WLAN) |  | 196d? | 2006-06-09 A | 2007-03-09 A | 100% | 2006-06-09 | 2007-03-09 | 196d? | start no earlier than 2006-06-09 | C4 | 1568h | 1568h | VCC-St3-c4 | Alcatel-Lucent | Keith Drage (drage@alcatel-lucent.com) | Rel-7 | Kimmo | WLAN | VCC-St3-c4 | 23.003 |  |
| 2990 | 792.5.3 | Deleted - CT3 aspects of Stage 3 for Voice Call Continuity between CS and IMS (incl. I-WLAN) | milestone | 0d? | 2006-11-02 A | 2006-11-02 A | 100% | 2006-11-02 | 2006-11-02 | 0d? | finish no earlier than 2006-11-02 | C3 |  |  |  | Alcatel-Lucent | Keith Drage (drage@alcatel-lucent.com) | Rel-7 | Adrian | WLAN |  | 29.163 | CP-33 |
| 2991 | 793 | **One Tunnel solution for optimization of Packet Data Traffic** |  | 418d? | 2006-03-27 A | 2007-10-31 A | 100% | 2006-03-27 | 2007-10-31 | 418d? |  | S2 | 7048h | 7048h | OPTUNEL | Nokia | antti.j.pasanen@nokia.com | Rel-7 | Maurice |  | OPTUNEL |  |  |
| 2992 | 793.1 | Deleted - Study on Stage 2 for One Tunnel solution |  | 125d? | 2006-03-27 A | 2006-09-15 A | 100% | 2006-03-27 | 2006-09-15 | 125d? | finish no earlier than 2005-09-12 | S2 | 1000h | 1000h | OPTUNEL-Study | Nokia | antti.j.pasanen@nokia.com | Rel-7 | Maurice |  | OPTUNEL-Study | 23.809 | SP-34 |
| 2993 | 793.2 | One Tunnel Deployment Guideline |  | 268d? | 2006-10-23 A | 2007-10-31 A | 100% | 2006-10-23 | 2007-10-31 | 268d? | finish no earlier than 2007-10-31 | S2 | 2144h | 2144h | OPTUNEL-Guide | Huawei | lan.liu@huawei.com | Rel-7 | Maurice |  | OPTUNEL-Guide | 23.919 |  |
| 2994 | 793.3 | Stage 2 specification for One Tunnel solution |  | 70d? | 2006-09-11 A | 2006-12-15 A | 100% | 2006-09-11 | 2006-12-15 | 70d? | finish no earlier than 2006-12-15 | S2 | 560h | 560h | OPTUNEL-Stage2 | Nokia | antti.j.pasanen@nokia.com | Rel-7 | Maurice |  | OPTUNEL-Stage2 | 23.060 |  |
| 2995 | 794 | **CSI Terminating Session handling** |  | 267d? | 2006-06-08 A | 2007-06-15 A | 100% | 2006-06-08 | 2007-06-15 | 267d? |  | S2; C1 | 6864h | 6864h | CSItermS | Samsung | Osok Song | Rel-7 | Maurice |  | CSItermS |  |  |
| 2996 | 794.1 | Stage 2 of CStermS |  | 192d? | 2006-06-08 A | 2007-03-02 A | 100% | 2006-06-08 | 2007-03-02 | 192d? | start no earlier than 2006-06-08 | S2 | 1536h | 1536h |  | Samsung | Osok Song | Rel-7 | Maurice |  |  | 23.279 |  |
| 2997 | 794.2 | Stage 3 of CStermS |  | 132d? | 2006-12-14 A | 2007-06-15 A | 100% | 2006-12-14 | 2007-06-15 | 132d? | finish no earlier than 2007-06-15 | C1 | 1056h | 1056h |  | Samsung | chenho.chin@samsung.com | Rel-7 | Frederic |  |  | 24.229, 24.279 |  |
| 2998 | 794.3 | Deleted - duplicated with UID 340015 -Stage 3 CSI Terminating Session handling | milestone | 0d? | 2007-03-09 A | 2007-03-09 A | 100% | 2007-03-09 | 2007-03-09 | 0d? | start no earlier than 2007-03-09 | C1 |  |  |  | Samsung | chenho.chin@samsung.com | Rel-7 | Frederic |  |  | 24.229, 24.179, 24.279 | CP-34 |
| 2999 | 795 | Liberty Alliance and 3GPP Security Interworking |  | 451d? | 2005-03-10 A | 2006-11-30 A | 100% | 2005-03-10 | 2006-11-30 | 451d? | finish no earlier than 2006-11-30 | S3 | 3608h | 3608h | LibSec | Nokia | Silke.Holtmanns@nokia.com | Rel-7 | Mirko |  | LibSec | 33.980 |  |
| 3000 | 796 | Trust Requirements for Open Platforms in 3GPP |  | 499d? | 2005-01-03 A | 2006-11-30 A | 100% | 2005-01-03 | 2006-11-30 | 499d? | finish no earlier than 2006-11-30 | S3 | 3992h | 3992h | TrustOP | Nokia | Silke.Holtmanns@nokia.com | Rel-7 | Mirko |  | TrustOP | 33.905 |  |
| 3001 | 797 | Development of UEA2 and UIA2 |  | 268d? | 2004-12-01 A | 2005-12-09 A | 100% | 2004-12-01 | 2005-12-09 | 268d? | finish no earlier than 2005-12-09 | S3 | 2144h | 2144h | AlgUEA2 | TeliaSonera | per.christoffersson@teliasonera.com | Rel-7 | Mirko |  | AlgUEA2 | 35.919, 35.215, 35.216, 35.217, 35.218 |  |
| 3002 | 798 | Lawful Interception in the 3GPP Rel-7 architecture |  | 118d? | 2005-06-28 A | 2005-12-08 A | 100% | 2005-06-28 | 2005-12-08 | 118d? | start no earlier than 2005-06-28 | S3 | 944h | 944h | LI-7A | BMWI | berthold.wilhelm@regtp.de | Rel-7 | Mirko |  | LI-7A | 33.106, 33.107, 33.108 |  |
| 3003 | 799 | Key establishment between a UICC and a terminal |  | 201.45d? | 2005-12-07 A | 2006-09-28 A | 100% | 2005-12-07 | 2006-09-28 | 201.45d? | finish no earlier than 2006-09-28 | S3 | 1611.6h | 1611.6h | KeyEstUTerm | Gemalto | mireille.pauliac@gemplus.com | Rel-7 | Mirko |  | KeyEstUTerm | 33.110 |  |
| 3004 | 800 | NDS Authentication Framework Extension for Transport Layer Security |  | 50d? | 2006-09-28 A | 2006-12-06 A | 100% | 2006-09-28 | 2006-12-06 | 50d? | finish no earlier than 2006-09-28 | S3 | 400h | 400h | NDSAFTLS | Nokia | tiina.s.koskinen@nokia.com | Rel-7 | Mirko |  | NDSAFTLS | 33.310 |  |
| 3005 | 801 | **Security enhancements** |  | 319d? | 2005-09-12 A | 2006-11-30 A | 100% | 2005-09-12 | 2006-11-30 | 319d? |  | S3; C1; C4 | 16376h | 16376h | SEC7 |  |  | Rel-7 | Mirko |  | SEC7 |  |  |
| 3006 | 801.1 | HTTPS connection between a UICC and a NAF |  | 1d? | 2005-09-12 A | 2005-09-12 A | 100% | 2005-09-12 | 2005-09-12 | 1d? | start no earlier than 2005-09-12 | S3; C1 | 16h | 16h | SEC7-HSUN | Gemalto | JSeif@axalto.com, mireille.pauliac@gemplus.com | Rel-7 | Mirko |  | SEC7-HSUN | 33.918, 33.222, 24.109 |  |
| 3007 | 801.2 | 2G GBA: 2G SIM usage in 3GPP GAA framework |  | 61d? | 2005-09-12 A | 2005-12-05 A | 100% | 2005-09-12 | 2005-12-05 | 61d? | finish no earlier than 2005-12-05 | S3 | 488h | 488h | SEC7-2GGBA | Nokia | Silke.Holtmanns@nokia.com | Rel-7 | Mirko |  | SEC7-2GGBA | 33.920, 33.220 |  |
| 3008 | 801.3 | Generic Authentication Architecture usage extensions and optimizations |  | 319d? | 2005-09-12 A | 2006-11-30 A | 100% | 2005-09-12 | 2006-11-30 | 319d? | finish no earlier than 2006-11-30 | S3 | 2552h | 2552h | SEC7-GAA2 | Nokia | Silke.Holtmanns@nokia.com | Rel-7 | Mirko |  | SEC7-GAA2 | 33.220, 29.109, 24.109, (33.223 goes to R8) |  |

Notes:
- 2982: WID approved SP#27; updated SP#28; updated SP#32
- 2983: -
- 2984: -
- 2985: -
- 2986: 03/2006 SP#31 WID approved
- 2987: -
- 2988: -
- 2989: -
- 2990: -
- 2991: -
- 2992: TR for Info SP-33. SP-34: S2 Report intention to discontinue TR
- 2993: -
- 2994: -
- 2995: Triggered by the abandoned Study UID_32117
- 2996: -
- 2997: CP-34 approved WID. CP-35 updated WID
- 2998: CP-34 approved WID
- 2999: WID approved SP#27.
- 3000: WID approved SP#26.
- 3001: WID approved SP#26, Dependant on Funding Availability.
- 3002: -
- 3003: -
- 3004: TLS profile is moved to Rel-8
- 3005: -
- 3006: -
- 3007: -
- 3008: 33.223 goes to R8

| ID | WBS | Task | Duration | Start | Finish | Complete | Baseline start | Baseline finish | Baseline duration | Constraint | Resources | Work | Actual work | Acronym | WI rapporteur name | WI rapporteur e-mail | Release | MCC resp | Acronym_3GU_Export | Impacted TSs and TRs | TSG stopped | PCG approved | TSG approved |
| --- | --- | --- | --- | --- | --- | --- | --- | --- | --- | --- | --- | --- | --- | --- | --- | --- | --- | --- | --- | --- | --- | --- | --- |
| 3009 | 801.4 | **SS7 TCAP security Gateway** | 241d? | 2005-09-12 A | 2006-08-14 A | 100% | 2005-09-12 | 2006-08-14 | 241d? |  | S3; C4 | 5664h | 5664h | SEC7-NDS-TCAPsec | Siemens | marc.blommaert.ext@nsn.com | Rel-7 | Mirko | SEC7-NDS-TCAPsec |  |  |  |  |
| 3010 | 801.4.1 | SA3 aspects of SEC7-NDS-TCAPsec | 130d? | 2005-09-12 A | 2006-03-10 A | 100% | 2005-09-12 | 2006-03-10 | 130d? | finish no earlier than 2006-03-10 | S3 | 1040h | 1040h | SEC7-NDS-TCAPsec-SA3 | Siemens | marc.blommaert.ext@nsn.com | Rel-7 | Mirko | SEC7-NDS-TCAPsec-SA3 | 33.204 |  |  |  |
| 3011 | 801.4.2 | TCAPsec Gateway | 96d? | 2006-04-03 A | 2006-08-14 A | 100% | 2006-04-03 | 2006-08-14 | 96d? | start no earlier than 2006-04-01 | C4 | 768h | 768h | SEC7-TCAP | Siemens | Ulrich.wiehe@gksag.de | Rel-7 | Kimmo | SEC7-TCAP | 29.204, 29.002 |  |  |  |
| 3012 | 802 | IMS Stage 3 IETF Protocol Alignment | 589d? | 2004-12-10 A | 2007-03-14 A | 100% | 2004-12-10 | 2007-03-14 | 589d? | finish no earlier than 2007-03-15 | C1 | 4712h | 4712h | IMSProtoc |  |  | Rel-7 | Frederic | IMSProtoc | 24.930 |  |  |  |
| 3013 | 803 | **Interoperability between VGCS/VBS and A/Gb flexibility** | 253d? | 2006-03-22 A | 2007-03-09 A | 100% | 2006-03-22 | 2007-03-09 | 253d? |  | C1; C4 | 7344h | 7344h | VGCSFlex | Siemens | robert.zaus@nsn.com | Rel-7 | Frederic | VGCSFlex |  |  |  |  |
| 3014 | 803.1 | CT1 aspects of VGCSFlex | 159d? | 2006-03-22 A | 2006-10-30 A | 100% | 2006-03-22 | 2006-10-30 | 159d? | finish no earlier than 2006-10-30 | C1 | 1272h | 1272h |  | Siemens | robert.zaus@nsn.com | Rel-7 | Frederic |  | 43.068, 43.069 |  |  |  |
| 3015 | 803.2 | CT4 aspects of VGCSFlex | 253d? | 2006-03-22 A | 2007-03-09 A | 100% | 2006-03-22 | 2007-03-09 | 253d? | finish no earlier than 2007-03-09 | C4 | 2024h | 2024h | VGCSFlex-c4 | Siemens | robert.zaus@nsn.com | Rel-7 | Kimmo | VGCSFlex-c4 | 29.002 |  |  |  |
| 3016 | 804 | DIAMETER on the GGSN Gi interface | 586d? | 2004-09-10 A | 2006-12-08 A | 100% | 2004-09-10 | 2006-12-08 | 586d? | finish no earlier than 2006-12-08 | C3 | 4688h | 4688h | DIAMGi | Vodafone | Nico.Gabriele@vodafone.com | Rel-7 | Adrian | DIAMGi | 29.061 |  |  |  |
| 3017 | 805 | DIAMETER on the PDG Wi interface | 586d? | 2004-09-10 A | 2006-12-08 A | 100% | 2004-09-10 | 2006-12-08 | 586d? | finish no earlier than 2006-12-08 | C3 | 4688h | 4688h | DIAMWi | Vodafone | Nico.Gabriele@vodafone.com | Rel-7 | Adrian | DIAMWi | 29.161 |  |  |  |
| 3018 | 806 | Interworking between the 3GPP CS domain with BICC or ISUP as signalling protocol and external SIP-I networks | 478d? | 2006-09-22 A | 2008-07-22 A | 100% | 2006-09-22 | 2008-07-22 | 478d? | finish no earlier than 2007-09-14 | C3 | 3824h | 3824h | ExtSIPI | Siemens | Thomas.Belling@nsn.com | Rel-7 | Adrian | ExtSIPI | 29.164 |  |  |  |
| 3019 | 807 | PDU multiplexing at Nb Interface with IP transport | 427d? | 2006-12-04 A | 2008-07-22 A | 100% | 2006-12-04 | 2008-07-22 | 427d? | start no earlier than 2006-12-04 | C3 | 3416h | 3416h | NbIPMux | Alcatel-Lucent | Jean.Rzeznik@alcatel-lucent.fr | Rel-7 | Adrian | NbIPMux | 29.414 |  |  |  |
| 3020 | 808 | **Mp (MRFC - MRFP) interface** | 345d? | 2006-02-13 A | 2007-06-08 A | 100% | 2006-02-13 | 2007-06-08 | 345d? |  | C4; C1 | 9904h | 9904h | Mp | Ericsson | philip.hodges@ericsson.com | Rel-7 | Kimmo | Mp |  |  |  |  |
| 3021 | 808.1 | CT1 aspects of Mp | 1d | 2006-02-13 A | 2006-02-13 A | 100% | 2006-02-13 | 2006-02-13 | 1d | finish no earlier than 2006-02-13 | C1 | 8h | 8h |  | Ericsson | philip.hodges@ericsson.com | Rel-7 | Frederic |  | 24.229 |  |  |  |
| 3022 | 808.2 | Deleted - CT3 aspects of Mp | 1d | 2006-09-22 A | 2006-09-22 A | 100% | 2006-09-22 | 2006-09-22 | 1d | start no earlier than 2006-09-22 | C3 | 8h | 8h |  | Ericsson | philip.hodges@ericsson.com | Rel-7 | Adrian |  | 29.162 | CP-33 |  |  |
| 3023 | 808.3 | Procedures description | 201d? | 2006-06-02 A | 2007-03-09 A | 100% | 2006-06-02 | 2007-03-09 | 201d? | finish no earlier than 2007-03-09 | C4 | 1608h | 1608h | Mp-PROCc4 | Huawei | Chencheng@huawei.com | Rel-7 | Kimmo | Mp-PROCc4 | 23.333 |  |  |  |
| 3024 | 808.4 | Stage 3 for Mp (MRFC - MRFP) interface | 345d | 2006-02-13 A | 2007-06-08 A | 100% | 2006-02-13 | 2007-06-08 | 345d | finish no earlier than 2007-06-08 | C4 | 2760h | 2760h | Mp-St3c4 | Ericsson | philip.hodges@ericsson.com | Rel-7 | Kimmo | Mp-St3c4 | 29.333 |  |  |  |
| 3025 | 809 | Routeing of MT-SMS via the HPLMN | 71d? | 2006-12-01 A | 2007-03-09 A | 100% | 2006-12-01 | 2007-03-09 | 71d? | finish no earlier than 2007-03-09 | C4; C1 | 1136h | 1136h | SMSviaH | Vodafone | Nick.Russell@vodafone.com | Rel-7 | Kimmo | SMSviaH | 23.040, 29.002 |  |  |  |
| 3026 | 810 | Mobile Termination whilst the MS is moving to another MSC | 60d? | 2007-03-09 A | 2007-05-31 A | 100% | 2007-03-09 | 2007-05-31 | 60d? | start no earlier than 2007-03-09 | C4 | 480h | 480h | MTmovMS | Alcatel-Lucent | bruno.landais@alcatel-lucent.fr | Rel-7 | Kimmo | MTmovMS | 23.008, 23.012, 23.018, 23.078, 23.079, 29.002 |  |  |  |
| 3027 | 811 | ISIM API for Java Card | 620d? | 2005-03-14 A | 2007-07-27 A | 100% | 2005-03-14 | 2007-07-27 | 620d? | finish no earlier than 2007-07-27 | C6 | 4960h | 4960h | APIJAVA | Sun | Sebastian Hans | Rel-7 | Xavier | APIJAVA | 31.103, 102 241 |  |  |  |
| 3028 | 812 | Rel-7 (U)SIM API Testing (TS 31.213) | 211d? | 2009-05-30 A | 2010-03-19 A | 100% | 2009-05-30 | 2010-03-19 | 211d? | finish no earlier than 2010-03-12 | C6 | 1688h | 1688h | USIM_API_Test | Sagem Orga | gerrit.hartbrod@sagem-orga.com | Rel-7 | Xavier | USIM_API_Test | 31.213 |  | PCG-23 | CP-44 |
| 3029 | 813 | High speed interface between the UICC and the ME | 311d? | 2006-09-22 A | 2007-11-30 A | 100% | 2006-09-22 | 2007-11-30 | 311d? | finish no earlier than 2007-11-30 | C6 | 2488h | 2488h | HSI | Gemalto | jacques.seif@GEMALTO.COM | Rel-7 | Xavier | HSI | 31.101 |  |  |  |
| 3030 | 814 | Video Codec Performance Requirements | 634d? | 2005-01-03 A | 2007-06-07 A | 100% | 2005-01-03 | 2007-06-07 | 634d? | finish no earlier than 2007-06-07 | S4 | 5072h | 5072h | VICPer | Siemens | juergen.pandel@siemens.com | Rel-7 | Paolo | VICPer | 26.234, 26.235, 26.346, 26.140, 26.902 |  |  |  |
| 3031 | 815 | Dynamic and Interactive Multimedia Scenes | 583d? | 2005-03-15 A | 2007-06-07 A | 100% | 2005-03-15 | 2007-06-07 | 583d? | finish no earlier than 2007-06-07 | S4 | 4664h | 4664h | DIMS | Streamezzo | gaelle.martin-cocher@streamezzo.com | Rel-7 | Paolo | DIMS | 26.140, 26.142, 26.234, 26.244, 23.346 |  |  |  |
| 3032 | 816 | 3G-324M Video Telephony Call Setup Times Improvements | 341d? | 2005-06-08 A | 2006-09-27 A | 100% | 2005-06-08 | 2006-09-27 | 341d? | finish no earlier than 2006-09-27 | S4 | 2728h | 2728h | VTCSTI | Vodafone | edward.hall@vodafone.co.uk | Rel-7 | Paolo | VTCSTI | 26.911 |  |  |  |

Notes:
- 3009: -
- 3010: -
- 3011: -
- 3012: TR 24.930: Signalling flows for the session setup in the IM CN subsystem based on Session Initiation Protocol (SIP)
- 3013: Voice Group Call Service
- 3014: -
- 3015: -
- 3016: -
- 3017: -
- 3018: -
- 3019: -
- 3020: -
- 3021: -
- 3022: CP#34: CT3 not involved in Mp interface definition
- 3023: -
- 3024: -
- 3025: WID approved in CP#34
- 3026: -
- 3027: -
- 3028: CP#47 completed. Update of Rel-6 (U)SIM API for Java Card Testing UID_43007 under Rel-6 UICC/USIM enhancements and interworking UID_1800
- 3029: Following ETSI publication of TS 102 600, expected to be completed at CT6 meeting 45
- 3030: -
- 3031: -
- 3032: -

| ID | WBS | Task | Type | Duration | Start | Finish | Complete | Remaining | Baseline start | Baseline finish | Baseline duration | Total slack | Constraint | Resources | Work | Actual work | Acronym | WI rapporteur name | WI rapporteur e-mail | Release | MCC resp | Acronym_3GU_Export | TSG stopped |
| --- | --- | --- | --- | --- | --- | --- | --- | --- | --- | --- | --- | --- | --- | --- | --- | --- | --- | --- | --- | --- | --- | --- | --- |
| 3033 | 817 | **Optimizations for Multimedia Telephony over IMS** |  | 0d? | 2005-09-28 A | 2005-09-28 | 99% | 0d? | 2005-09-28 | 2005-09-28 | 0d? | 0d |  | S4 |  |  | OMTIMS | Ericsson | olle.franceschi@ericsson.com | Rel-7 | Paolo | OMTIMS |  |
| 3034 | 817.1 | Deleted - Characterisation of Adaptive Jitter Management Performance for VoIP Services | milestone | 0d? | 2005-09-28 A | 2005-09-28 A | 100% |  | 2005-09-28 | 2005-09-28 | 0d? |  | start no earlier than 2007-03-15 | S4 |  |  | OMTIMS-CAJMP | Lucent | dhuo@lucent.com | Rel-7 | Paolo | OMTIMS-CAJMP | SP-35 |
| 3035 | 818 | End-to-End Multimedia Services Performance Metrics |  | 382d? | 2005-09-28 A | 2007-03-15 A | 100% |  | 2005-09-28 | 2007-03-15 | 382d? |  | finish no earlier than 2007-03-15 | S4 | 3056h | 3056h | E2EMSPM | China Mobile | zhangyanyf@chinamobile.com | Rel-7 | Paolo | E2EMSPM |  |
| 3036 | 819 | Packet Switched Streaming Enhancements |  | 261d? | 2006-06-08 A | 2007-06-07 A | 100% |  | 2006-06-08 | 2007-06-07 | 261d? |  | finish no earlier than 2007-06-07 | S4 | 2088h | 2088h | PSSe | Ericsson | olle.franceschi@ericsson.com | Rel-7 | Paolo | PSSe |  |
| 3037 | 820 | **Rel-7 Operations, Administration, Maintenance and Provisioning (OAM&P)** |  | 472.86d? | 2005-09-02 A | 2007-06-26 A | 100% |  | 2005-09-02 | 2007-06-26 | 472.86d? |  |  | S5 | 82725.8h | 82725.8h | OAM7 | Huawei | Christian.Toche@huawei.com | Rel-7 | Mirko | OAM7 |  |
| 3038 | 820.1 | **Rel-7 Network Infrastructure Management** |  | 465d? | 2005-09-02 A | 2007-06-14 A | 100% |  | 2005-09-02 | 2007-06-14 | 465d? |  |  | S5 | 41800h | 41800h | OAM7-NIM |  |  | Rel-7 | Mirko | OAM7-NIM |  |
| 3039 | 820.1.1 | Enhance NRM to accommodate NGN (IMS as basis of the Next Generation Network) |  | 465d? | 2005-09-02 A | 2007-06-14 A | 100% |  | 2005-09-02 | 2007-06-14 | 465d? |  | finish no earlier than 2007-06-14 | S5 | 3720h | 3720h |  | Motorola |  | Rel-7 | Mirko |  |  |
| 3040 | 820.1.2 | Co-operative Element Management interface (CO-OP) (Study + Implementation) |  | 400d? | 2005-09-02 A | 2007-03-15 A | 100% |  | 2005-09-02 | 2007-03-15 | 400d? |  | finish no earlier than 2007-03-15 | S5 | 3200h | 3200h |  | Motorola |  | Rel-7 | Mirko |  |  |
| 3041 | 820.1.3 | Network Management (NM) Itf-N performance criteria |  | 465d? | 2005-09-02 A | 2007-06-14 A | 100% |  | 2005-09-02 | 2007-06-14 | 465d? |  | finish no earlier than 2007-06-14 | S5 | 3720h | 3720h |  | China Mobile |  | Rel-7 | Mirko |  |  |
| 3042 | 820.1.4 | Delta synchronization between IRP Manager and IRP Agent (Study + Implementation) |  | 465d? | 2005-09-02 A | 2007-06-14 A | 100% |  | 2005-09-02 | 2007-06-14 | 465d? |  | finish no earlier than 2007-06-14 | S5 | 3720h | 3720h |  | Siemens |  | Rel-7 | Mirko |  |  |
| 3043 | 820.1.5 | Subscription Management (SuM) IRP Solution Sets |  | 330d? | 2005-09-02 A | 2006-12-07 A | 100% |  | 2005-09-02 | 2006-12-07 | 330d? |  | finish no earlier than 2006-12-07 | S5 | 2640h | 2640h |  | Ericsson |  | Rel-7 | Mirko |  |  |
| 3044 | 820.1.6 | Integration Reference Point (IRP) Security Management |  | 400d? | 2005-09-02 A | 2007-03-15 A | 100% |  | 2005-09-02 | 2007-03-15 | 400d? |  | finish no earlier than 2007-03-15 | S5 | 3200h | 3200h |  | Huawei | Christian.Toche@huawei.com | Rel-7 | Mirko |  |  |
| 3045 | 820.1.7 | Partial suspension of Itf-N during maintenance/testing (Study + Implementation) |  | 465d? | 2005-09-02 A | 2007-06-14 A | 100% |  | 2005-09-02 | 2007-06-14 | 465d? |  | finish no earlier than 2007-06-14 | S5 | 3720h | 3720h |  | Siemens |  | Rel-7 | Mirko |  |  |
| 3046 | 820.1.8 | Deleted - Management of Legacy Equipment |  | 336d? | 2005-09-02 A | 2006-12-15 A | 100% |  | 2005-09-02 | 2006-12-15 | 336d? |  | finish no earlier than 2006-12-15 | S5 | 2688h | 2688h |  | Siemens |  | Rel-7 | Mirko |  | SP-35 |
| 3047 | 820.1.9 | Deleted - Rules for Vendor Specific Extensions |  | 400d? | 2005-09-02 A | 2007-03-15 A | 100% |  | 2005-09-02 | 2007-03-15 | 400d? |  | finish no earlier than 2007-03-15 | S5 | 3200h | 3200h |  | Siemens |  | Rel-7 | Mirko |  | SP-35 |
| 3048 | 820.1.10 | Backward and Forward Compatibility of IRP systems |  | 465d? | 2005-09-02 A | 2007-06-14 A | 100% |  | 2005-09-02 | 2007-06-14 | 465d? |  | finish no earlier than 2007-06-14 | S5 | 3720h | 3720h |  | Ericsson |  | Rel-7 | Mirko |  |  |
| 3049 | 820.1.11 | Repeater Network Resource Model (NRM) definition |  | 214d? | 2006-02-13 A | 2006-12-07 A | 100% |  | 2006-02-13 | 2006-12-07 | 214d? |  | finish no earlier than 2006-12-07 | S5 | 1712h | 1712h |  | China Mobile |  | Rel-7 | Mirko |  |  |
| 3050 | 820.1.12 | UTRAN radio channel power monitoring |  | 284d? | 2006-02-13 A | 2007-03-15 A | 100% |  | 2006-02-13 | 2007-03-15 | 284d? |  | finish no earlier than 2007-03-15 | S5 | 2272h | 2272h |  | China Mobile |  | Rel-7 | Mirko |  |  |
| 3051 | 820.1.13 | Notification XML Schema |  | 71d? | 2006-12-07 A | 2007-03-15 A | 100% |  | 2006-12-07 | 2007-03-15 | 71d? |  | finish no earlier than 2007-03-15 | S5 | 568h | 568h |  | Huawei | Christian.Toche@huawei.com | Rel-7 | Mirko |  |  |
| 3052 | 820.2 | **Rel-7 Performance Management** |  | 465d? | 2005-09-02 A | 2007-06-14 A | 100% |  | 2005-09-02 | 2007-06-14 | 465d? |  |  | S5 | 22992h | 22992h | OAM7-PM |  |  | Rel-7 | Mirko | OAM7-PM |  |
| 3053 | 820.2.1 | Performance measurements definition for CN CS |  | 400d? | 2005-09-02 A | 2007-03-15 A | 100% |  | 2005-09-02 | 2007-03-15 | 400d? |  | finish no earlier than 2007-03-15 | S5 | 3200h | 3200h |  | China Mobile |  | Rel-7 | Mirko |  |  |
| 3054 | 820.2.2 | Enhancement UTRAN performance measurements definition |  | 465d? | 2005-09-02 A | 2007-06-14 A | 100% |  | 2005-09-02 | 2007-06-14 | 465d? |  | finish no earlier than 2007-06-14 | S5 | 3720h | 3720h |  | China Mobile |  | Rel-7 | Mirko |  |  |
| 3055 | 820.2.3 | Add TDD specific counters in Performance measurement |  | 330d? | 2005-09-02 A | 2006-12-07 A | 100% |  | 2005-09-02 | 2006-12-07 | 330d? |  | finish no earlier than 2006-12-15 | S5 | 2640h | 2640h |  | CATT |  | Rel-7 | Mirko |  |  |
| 3056 | 820.2.4 | ATM bearer network Performance measurements |  | 400d? | 2005-09-02 A | 2007-03-15 A | 100% |  | 2005-09-02 | 2007-03-15 | 400d? |  | finish no earlier than 2007-03-15 | S5 | 3200h | 3200h |  | ZTE |  | Rel-7 | Mirko |  |  |
| 3057 | 820.2.5 | Performance measurements definition for IMS |  | 465d? | 2005-09-02 A | 2007-06-14 A | 100% |  | 2005-09-02 | 2007-06-14 | 465d? |  | finish no earlier than 2007-06-14 | S5 | 3720h | 3720h |  | China Mobile |  | Rel-7 | Mirko |  |  |
| 3058 | 820.2.6 | HSDPA performance measurements |  | 349d? | 2006-02-13 A | 2007-06-14 A | 100% |  | 2006-02-13 | 2007-06-14 | 349d? |  | finish no earlier than 2007-06-14 | S5 | 2792h | 2792h |  | China Mobile |  | Rel-7 | Mirko |  |  |

Notes:
- 3033: - / Impacted TSs and TRs: 26.235, 26.236
- 3034: SP-35 stopped
- 3035: - / Impacted TSs and TRs: 26.944
- 3036: - / Impacted TSs and TRs: 26.234, 26.244
- 3037: OAM7 is an umbrella Feature also for OAM&P related TEI7 type of changes that are not part of any other dedicated feature/WI / Impacted TSs and TRs: TR 30.817
- 3038: -
- 3039: - / Impacted TSs and TRs: 32.731/2/3/5, 32.631/2/3/5
- 3040: - / Impacted TSs and TRs: 32.806, 32.814, 32.101
- 3041: - / Impacted TSs and TRs: 32.811
- 3042: - / Impacted TSs and TRs: 32.391/2/3/5
- 3043: - / Impacted TSs and TRs: 32.307/317/607/667/665, 32.101, 32.175
- 3044: - / Impacted TSs and TRs: 32.372/3/5, 32.111,32.30x,32.32x,32.33x,32.34x,32.35x,32.36x,32.41x,32.60x,32.61x,32.66x
- 3045: - / Impacted TSs and TRs: 32.381/2/3/5
- 3046: Request to TSG#35 to STOP the WI / Impacted TSs and TRs: new 32.xxx
- 3047: Request to TSG#35 to STOP the WI / Impacted TSs and TRs: 32.62n; For n = 1 to 5
- 3048: - / Impacted TSs and TRs: 32.154
- 3049: - / Impacted TSs and TRs: 32.721/2/3/5
- 3050: - / Impacted TSs and TRs: 32.405, 32.64n; For n = 1 to 5
- 3051: 12/2006 SP#34 WID approved / Impacted TSs and TRs: New 32.325/345/365/415, CR to 32.335/615/665
- 3052: -
- 3053: - / Impacted TSs and TRs: 32.407, 32.408
- 3054: - / Impacted TSs and TRs: 32.405
- 3055: - / Impacted TSs and TRs: 32.405
- 3056: - / Impacted TSs and TRs: No impact on 32.404, 32.405, 32.406, 32.407
- 3057: - / Impacted TSs and TRs: 32.404,32.409,32.437, 32.632/3/4/5
- 3058: - / Impacted TSs and TRs: 32.405

| ID | WBS | Task | Type | Duration | Start | Finish | Complete | Baseline start | Baseline finish | Baseline duration | Constraint | Resources | Work | Actual work | Acronym | WI rapporteur name | Release | MCC resp | Acronym_3GU_Export | TSG stopped | WI rapporteur e-mail | Status Report |
| --- | --- | --- | --- | --- | --- | --- | --- | --- | --- | --- | --- | --- | --- | --- | --- | --- | --- | --- | --- | --- | --- | --- |
| 3059 | 44.5 | **Rel-7 Trace Management** |  | 472.86d? | 2005-09-02 A | 2007-06-26 A | 100% | 2005-09-02 | 2007-06-26 | 472.86d? |  | S5 | 14150.9h | 14150.9h | OAM7-Trace | Vodafone | Rel-7 | Mirko | OAM7-Trace |  |  |  |
| 3060 | 820.3.1 | End-to-end Service Level tracing for IMS |  | 350d? | 2005-11-11 A | 2007-03-15 A | 100% | 2005-11-11 | 2007-03-15 | 350d? | finish no earlier than 2007-03-15 | S5 | 2800h | 2800h |  | Vodafone | Rel-7 | Mirko |  | SP-31 |  |  |
| 3061 | 820.3.2 | Trace record content for UTRAN TDD |  | 330d? | 2005-09-02 A | 2006-12-07 A | 100% | 2005-09-02 | 2006-12-07 | 330d? | finish no earlier than 2006-12-07 | S5 | 2640h | 2640h |  | Nokia | Rel-7 | Mirko |  |  |  |  |
| 3062 | 820.3.3 | IRP for Subscriber and Equipment Trace Management |  | 465d? | 2005-09-02 A | 2007-06-14 A | 100% | 2005-09-02 | 2007-06-14 | 465d? | finish no earlier than 2007-06-14 | S5 | 3720h | 3720h |  | Nokia | Rel-7 | Mirko |  |  |  |  |
| 3063 | 820.3.4 | Deleted - SIP enhancements for trace | milestone | 0d? | 2007-06-15 A | 2007-06-26 A | 100% | 2007-06-15 | 2007-06-26 | 0d? | start no earlier than 2007-06-15 | C1 |  |  |  |  | Rel-7 | Frederic |  | CP-32 |  |  |
| 3064 | 820.3.5 | Deleted - duplicated with UID 35063 - IRP for Subscriber and Equipment Trace Management |  | 336d? | 2005-09-02 A | 2006-12-15 A | 100% | 2005-09-02 | 2006-12-15 | 336d? | finish no earlier than 2006-12-15 | S5 | 2688h | 2688h |  | Nokia | Rel-7 | Mirko |  | SP-33 |  |  |
| 3065 | 821 | **Rel-7 Charging Management small Enhancements** |  | 279d? | 2006-05-22 A | 2007-06-14 A | 100% | 2006-05-22 | 2007-06-14 | 279d? |  | S5 | 5952h | 5952h | CH7 | Orange | Rel-7 | Mirko | CH7 |  | alain.bibas@orange-ft.com |  |
| 3066 | 821.1 | Alternate Charged Party (ACP) for IMS |  | 279d? | 2006-05-22 A | 2007-06-14 A | 100% | 2006-05-22 | 2007-06-14 | 279d? | finish no earlier than 2007-06-14 | S5 | 2232h | 2232h | CH7-IMS-ACP | Lucent | Rel-7 | Mirko | CH7-IMS-ACP |  | njmazzarella@alcatel-lucent.com |  |
| 3067 | 821.2 | Align 3GPP Charging with OMA PoC Enabler Release 2.0 |  | 186d? | 2006-09-28 A | 2007-06-14 A | 100% | 2006-09-28 | 2007-06-14 | 186d? | finish no earlier than 2007-06-14 | S5 | 1488h | 1488h | CH7-PoC | Siemens | Rel-7 | Mirko | CH7-PoC |  | Gerald.Goermer@nsn.com |  |
| 3068 | 8.5 | **Multiple-Input Multiple-Output (MIMO) antennas** |  | 1301d? | 2003-03-14 A | 2008-03-07 A | 100% | 2003-03-14 | 2008-03-07 | 1301d? |  | R1; R5 | 55848h | 55848h | MIMO | Alcatel-Lucent | Rel-7 | Patrick | MIMO |  | hchuang@Alcatel-Lucent.com |  |
| 3069 | 822.1 | MIMO - Physical layer |  | 915d? | 2003-09-12 A | 2007-03-15 A | 100% | 2003-09-12 | 2007-03-15 | 915d? | finish no earlier than 2007-03-15 | R1 | 7320h | 7320h | MIMO-Phys | Alcatel-Lucent | Rel-7 | Patrick | MIMO-Phys |  | hchuang@Alcatel-Lucent.com | RP-070037 |
| 3070 | 822.2 | MIMO - Layer 2,3 aspects |  | 915d? | 2003-09-12 A | 2007-03-15 A | 100% | 2003-09-12 | 2007-03-15 | 915d? | finish no earlier than 2007-03-15 | R2 | 7320h | 7320h | MIMO-L23 | Alcatel-Lucent | Rel-7 | Yong-Jun | MIMO-L23 |  | hchuang@Alcatel-Lucent.com | RP-070037 |
| 3071 | 822.3 | MIMO - Iub/Iur Protocol Aspects |  | 1045d? | 2003-03-14 A | 2007-03-15 A | 100% | 2003-03-14 | 2007-03-15 | 1045d? | finish no earlier than 2007-03-15 | R3 | 8360h | 8360h | MIMO-IurIub | Alcatel-Lucent | Rel-7 | Juha | MIMO-IurIub |  | hchuang@Alcatel-Lucent.com | RP-070037 |
| 3072 | 822.4 | MIMO - RF Radio Transmission/Reception, System Performance Requirements and Conformance Testing |  | 982d? | 2003-12-12 A | 2007-09-17 A | 100% | 2003-12-12 | 2007-09-17 | 982d? | finish no earlier than 2007-09-17 | R4 | 7856h | 7856h | MIMO-RF | Alcatel-Lucent | Rel-7 | Issam | MIMO-RF |  | ngm@Alcatel-Lucent.com | RP-070531 |
| 3073 | 822.5 | **UE Conformance Testing for Multiple Input Multiple Output antennas (MIMO)** |  | 261d? | 2007-03-09 A | 2008-03-07 A | 100% | 2007-03-09 | 2008-03-07 | 261d? |  | R5 | 4176h | 4176h | MIMO-UEConTest | Qualcomm | Rel-7 | Ingbert | MIMO-UEConTest |  | svora@qualcomm.com |  |
| 3074 | 822.5.1 | Conformance Test Aspects – Multiple Input Multiple Output Antennas (MIMO) for FDD |  | 261d? | 2007-03-09 A | 2008-03-07 A | 100% | 2007-03-09 | 2008-03-07 | 261d? | finish no earlier than 2008-03-07 | R5 | 2088h | 2088h | MIMO-UEConTest_FDD | Qualcomm | Rel-7 | Ingbert | MIMO-UEConTest_FDD |  | svora@qualcomm.com |  |
| 3075 | 823 | **Rel-7 Improvements of the Radio Interface** |  | 709d? | 2004-09-15 A | 2007-06-04 A | 100% | 2004-09-15 | 2007-06-04 | 709d? |  | RP; GP | 40520h | 40520h |  |  | Rel-7 | Issam |  |  |  |  |
| 3076 | 823.1 | Extended UMTS 1.7/2.1 GHz |  | 198d? | 2006-03-15 A | 2006-12-15 A | 100% | 2006-03-15 | 2006-12-15 | 198d? | finish no earlier than 2006-12-15 | R4 | 1584h | 1584h | RInImp-UMTS1721Ext | Ericsson | Rel-7 | Issam | RInImp-UMTS1721Ext |  | johan.skold@ericsson.com | RP-060681 |
| 3077 | 823.2 | UMTS 2.6 GHz 7.68 Mcps TDD |  | 67d? | 2006-06-15 A | 2006-09-15 A | 100% | 2006-06-15 | 2006-09-15 | 67d? | finish no earlier than 2006-09-15 | R4 | 536h | 536h | RInImp-UMTS26VHCRTDD | IPWireless | Rel-7 | Issam | RInImp-UMTS26VHCRTDD |  | Shin Horng Wong (shwong@ipwireless.com) | RP-060451 |
| 3078 | 823.3 | UMTS 2.6 GHz |  | 195d? | 2004-09-15 A | 2005-06-14 A | 100% | 2004-09-15 | 2005-06-14 | 195d? | finish no earlier than 2005-06-14 | R4 | 1560h | 1560h | RInImp-UMTS2600 | Nokia | Rel-7 | Issam | RInImp-UMTS2600 |  | jussi.numminen@nokia.com | RP-050184 |
| 3079 | 823.4 | UMTS 2.6 GHz TDD |  | 261d? | 2004-12-15 A | 2005-12-14 A | 100% | 2004-12-15 | 2005-12-14 | 261d? | finish no earlier than 2005-12-15 | R4 | 2088h | 2088h | RInImp-UMTS2600TDD | IPWireless | Rel-7 | Issam | RInImp-UMTS2600TDD |  | Shin Horng Wong (shwong@ipwireless.com) | RP-050661 |
| 3080 | 823.5 | UMTS 900 MHz |  | 261d? | 2004-12-15 A | 2005-12-14 A | 100% | 2004-12-15 | 2005-12-14 | 261d? | finish no earlier than 2005-12-15 | R4 | 2088h | 2088h | RInImp-UMTS900 | Nortel | Rel-7 | Issam | RInImp-UMTS900 |  | Yannick Li (yli@nortelnetworks.com) | RP-050662 |
| 3081 | 823.6 | UMTS 1700 MHz |  | 197d? | 2005-03-15 A | 2005-12-14 A | 100% | 2005-03-15 | 2005-12-14 | 197d? | finish no earlier than 2005-12-15 | R4 | 1576h | 1576h | RInImp-UMTS1700 | NTT DoCoMo | Rel-7 | Issam | RInImp-UMTS1700 |  | Takehiro Nakamura (nakamurata@nttdocomo.co.jp) | RP-050824 |
| 3082 | 823.7 | UE Antenna Performance Evaluation Method and Requirements |  | 644d? | 2004-12-15 A | 2007-06-04 A | 100% | 2004-12-15 | 2007-06-04 | 644d? | finish no earlier than 2007-06-04 | R4; GP | 10304h | 10304h | RInImp-UEAnt | TeliaSonera | Rel-7 | Issam | RInImp-UEAnt |  | Christian.Bergljung@TeliaSonera.com | RP-070281 |
| 3083 | 823.8 | Improved Performance Requirements for HSDPA UE based on Rx Diversity (type 1) & LMMSE equalizer (type 2) | milestone | 0d? | 2005-03-15 A | 2005-03-15 A | 100% | 2005-03-15 | 2005-03-15 | 0d? | finish no earlier than 2005-03-15 | R4 |  |  | RInImp-HSPerf-Type3 | Cingular | Rel-7 | Issam | RInImp-HSPerf-Type3 |  | Marc Grant | RP-060015 |

Notes:
- 3059: -
- 3060: 07/2005: OMA (Stage 1), Stage 2/3 SA5, CT1/3/4 / Impacted TSs and TRs: 32.101, 32.421, 32.422, 32.423
- 3061: - / Impacted TSs and TRs: 32.421, 32.422, 32.423
- 3062: - / Impacted TSs and TRs: 32.441, 32.442, 32.443, 32.445, 32.632, 32.633, 32.635
- 3063: combined with UID 11067
- 3064: - / Impacted TSs and TRs: 32.421,32.422,32.423. 3 new 32.4x1,2,3
- 3065: CH7 is an umbrella Feature also for OAM&P related TEI7 type of changes that are not part of any other dedicated feature/WI / Impacted TSs and TRs: TR 30.817
- 3066: - / Impacted TSs and TRs: 32.240, 32.260, 32.298, 32.299
- 3067: 09/2006 SP#33 WID approved / Impacted TSs and TRs: 32.240, 32.272, 32.299, 32.298
- 3068: Completed Sep 2007; SR in RP-070037and RP-070531 / Impacted TSs and TRs: 25.876, 25.996
- 3069: Completed Sep 2007; SR in RP-070037 / Impacted TSs and TRs: 25.211, 25.212, 25.213, 25.214, 25.215, 25.221
- 3070: Completed Sep 2007; SR in RP-070037 / Impacted TSs and TRs: 25.876
- 3071: Completed Sep 2007; SR in RP-070037
- 3072: Completed Sep 2007; SR in RP-070531
- 3073: BB place holder for a number of RAN5 Tasks
- 3074: - / Impacted TSs and TRs: TS 34.108, TS 34.109, TS 34.121-1, TS 34.121-2, TS 34.123-1, TS 34.123-2, TS 34.123-3
- 3075: Generic feature
- 3076: RP#34 completed. Introduction of Band X (Extended UMTS 1.7/2.1 GHz) in 25.307 / Impacted TSs and TRs: 25.806, 25.101, 25.104, 25.133, 24.141, 25.331, 25.306, 25.307, 25.423, 25.461, 25.463, 34.121
- 3077: RP#33 completed / Impacted TSs and TRs: 25.102, 25.105, 25.123, 25.113, 25.142, 34.124
- 3078: RP#28 completed / Impacted TSs and TRs: 25.101, 25.104, 25.133, 25.141, 25.331, 25.942, 25.306, 25.307, 34.121
- 3079: RP#30 completed / Impacted TSs and TRs: 25.102, 25.105, 25.113, 25.123, 25.142, 25.331, 25.942, 25.306, 25.307, 34.122, 34.124
- 3080: RP#30 completed / Impacted TSs and TRs: 25.101, 25.104, 25.113, 25.133, 25.141, 25.331, 25.942, 25.306, 25.307, 34.121
- 3081: RP#30 completed / Impacted TSs and TRs: 25.101, 25.104, 25.113, 25.133, 25.141, 25.306, 25.307, 25.331, 34.121
- 3082: RP#36 completed / Impacted TSs and TRs: 25.101, new TR (25.914, 25.963)
- 3083: RP#27 completed / Impacted TSs and TRs: 25.101

| ID | WBS | Task | Type | Duration | Start | Finish | Complete | Baseline start | Baseline finish | Baseline duration | Constraint | Deadline | Resources | Work | Actual work | Acronym | WI rapporteur name | WI rapporteur e-mail | Release | MCC resp | Acronym_3GU_Export | Status Report | TSG stopped | PCG stopped | Created at |
| --- | --- | --- | --- | --- | --- | --- | --- | --- | --- | --- | --- | --- | --- | --- | --- | --- | --- | --- | --- | --- | --- | --- | --- | --- | --- |
| 3084 | 823.9 | **Additional minimum UE performance requirement for non-HSDPA channels based on type 1 enhanced receiver (Rx Diversity)** |  | 327d? | 2005-09-15 A | 2006-12-15 A | 100% | 2005-09-15 | 2006-12-15 | 327d? |  |  | R4 | 7344h | 7344h | RInImp-RxDiv | Qualcomm | Serge Willenegger (sergew@qualcomm.com) | Rel-7 | Issam | RInImp-RxDiv |  |  |  |  |
| 3085 | 823.9.1 | Additional minimum UE performance requirement for DL physical channels in support of DCH/HS-DSCH operation based on type 1 enhanced receiver (RX-Diversity) |  | 195d? | 2005-09-15 A | 2006-06-14 A | 100% | 2005-09-15 | 2006-06-14 | 195d? | finish no earlier than 2006-06-15 |  | R4 | 1560h | 1560h | RInImp-RxDiv-DCH | Cingular | Marc Grant | Rel-7 | Issam | RInImp-RxDiv-DCH | RP-060235 |  |  |  |
| 3086 | 823.9.2 | Additional minimum UE performance requirement for downlink physical channels in support of MTCH and MCCH operation based on type 1 enhanced receiver (Rx-Diversity) |  | 198d? | 2006-03-15 A | 2006-12-15 A | 100% | 2006-03-15 | 2006-12-15 | 198d? | finish no earlier than 2006-12-15 |  | R4 | 1584h | 1584h | RInImp-RxDiv-MBMS | Qualcomm | Serge Willenegger (sergew@qualcomm.com) | Rel-7 | Issam | RInImp-RxDiv-MBMS | RP-060678 |  |  |  |
| 3087 | 823.9.3 | Additional minimum UE performance requirement for downlink physical channels in support of E-DCH operation based on type 1 enhanced receiver (Rx-Diversity) |  | 198d? | 2006-03-15 A | 2006-12-15 A | 100% | 2006-03-15 | 2006-12-15 | 198d? | finish no earlier than 2006-12-15 |  | R4 | 1584h | 1584h | RInImp-RxDiv-EDCH | Qualcomm | Serge Willenegger (sergew@qualcomm.com) | Rel-7 | Issam | RInImp-RxDiv-EDCH | RP-060679 |  |  |  |
| 3088 | 823.10 | Deleted Improved support of gaming over HSDPA/EDCH |  | 262d? | 2005-12-15 A | 2006-12-15 A | 100% | 2005-12-15 | 2006-12-15 | 262d? | finish no earlier than 2006-12-15 |  | R2 | 2096h | 2096h | RInImp-Gaming | Cingular | Don Zelmer (dz1069@att.com) | Rel-7 | Yong-Jun | RInImp-Gaming | RP-060680 | RP-34 |  |  |
| 3089 | 823.11 | Deleted (not approved at PCG) - UMTS 2.6 GHz FDD DL External | milestone | 0d? | 2005-09-15 A | 2005-09-15 A | 100% | 2005-09-15 | 2005-09-15 | 0d? | finish no earlier than 2005-09-15 |  | R4 |  |  | RInImp-UMTS2600Ext | T-mobile | han.van.bussel@t-mobile.de | Rel-7 | Issam | RInImp-UMTS2600Ext |  | RP-31 | PCG-16 |  |
| 3090 | 824 | **Rel-7 Improvements of the Radio Interface - UE Conformance Testing** |  | 741d? | 2005-11-11 A | 2008-09-12 A | 100% | 2005-11-11 | 2008-09-12 | 741d? |  |  | R5 | 17568h | 17568h |  |  |  | Rel-7 | Ingbert |  |  |  |  |  |
| 3091 | 16.5.1 | UE Conformance Test for UMTS 2600 MHz |  | 146d | 2005-11-11 A | 2006-06-02 A | 100% | 2005-11-11 | 2006-06-02 | 146d | finish no earlier than 2006-06-02 | 2006-06-02 | R5 | 1168h | 1168h | RInImp-UMTS2600_Test | Nokia | Aleksi.Heino@nokia.com | Rel-7 | Ingbert | RInImp-UMTS2600_Test |  |  |  | Fri 7/11/05 |
| 3092 | 16.5.1 | UE Conformance Test for UMTS 900 MHz (band VIII) |  | 146d | 2005-11-11 A | 2006-06-02 A | 100% | 2005-11-11 | 2006-06-02 | 146d | finish no earlier than 2006-06-02 | 2006-06-02 | R5 | 1168h | 1168h | RInImp-UMTS900_Test | Qualcomm | hanye@qualcomm.com | Rel-7 | Ingbert | RInImp-UMTS900_Test |  |  |  | Fri 11/03/05 |
| 3093 | 824.3 | Conformance Test Aspects – Improved Performance of HSDPA Receiver type 3 |  | 191d? | 2006-03-10 A | 2006-12-01 A | 100% | 2006-03-10 | 2006-12-01 | 191d? | finish no earlier than 2006-12-01 |  | R5 | 1528h | 1528h | RInImp-HSPerf-Type3_Test | Motorola | carolyn.taylor@motorola.com | Rel-7 | Ingbert | RInImp-HSPerf-Type3_Test |  |  |  |  |
| 3094 | 824.4 | UE antenna Over The Air (OTA) conformance testing |  | 518d? | 2006-09-20 A | 2008-09-12 A | 100% | 2006-09-20 | 2008-09-12 | 518d? | finish no earlier than 2008-09-12 |  | R5 | 4144h | 4144h | RInImp-UEAnt_Test | Nokia | Aleksi.Heino@nokia.com | Rel-7 | Ingbert | RInImp-UEAnt_Test | RP-080535 |  |  |  |
| 3095 | 824.5 | UE conformance testing for FDD Inter-Band Operation |  | 131d? | 2006-06-02 A | 2006-12-01 A | 100% | 2006-06-02 | 2006-12-01 | 131d? | finish no earlier than 2006-12-01 |  | R5 | 1048h | 1048h | RInImp-InterBand_Test | NEC, Motorola | Jacob.John@motorola.com | Rel-7 | Ingbert | RInImp-InterBand_Test |  |  |  |  |
| 3096 | 824.6 | Conformance Test Aspects – Extended UMTS 1.7/2.1 GHz |  | 131d? | 2006-12-01 A | 2007-06-01 A | 100% | 2006-12-01 | 2007-06-01 | 131d? | finish no earlier than 2007-06-01 |  | R5 | 1048h | 1048h | RInImp-UEConTest_UMTS1721Ext | Motorola | carolyn.taylor@motorola.com | Rel-7 | Ingbert | RInImp-UEConTest_UMTS1721Ext | RP-070312 |  |  |  |
| 3097 | 824.7 | Conformance Test Aspects – Minimum UE performance requirement for downlink physical channels in support of E-DCH operation based on type 1 enhanced receiver (Rx-Diversity) |  | 136d? | 2007-06-01 A | 2007-12-07 A | 100% | 2007-06-01 | 2007-12-07 | 136d? | finish no earlier than 2007-12-07 |  | R5 | 1088h | 1088h | RInImp-UEConTest_RxDivEDCH | Motorola | carolyn.taylor@motorola.com | Rel-7 | Ingbert | RInImp-UEConTest_RxDivEDCH | RP-070810 |  |  |  |
| 3098 | 824.8 | Conformance Test Aspects – Minimum UE performance requirement for downlink physical channels in support of MTCGH and MCCH operation based on type 1 enhanced receiver (Rx-Diversity) |  | 201d? | 2007-06-01 A | 2008-03-07 A | 100% | 2007-06-01 | 2008-03-07 | 201d? | finish no earlier than 2008-03-07 |  | R5 | 1608h | 1608h | RInImp-UEConTest_RxDivMBMS | Ericsson | leif.mattisson@ericsson.com | Rel-7 | Ingbert | RInImp-UEConTest_RxDivMBMS | RP-080056 |  |  |  |
| 3099 | 825 | **Rel-7 RAN improvements** |  | 653d? | 2004-12-15 A | 2007-06-15 A | 100% | 2004-12-15 | 2007-06-15 | 653d? |  |  | RP; S5 | 39512h | 39512h |  |  |  | Rel-7 |  |  |  |  |  |  |
| 3100 | 825.1 | Optimization of channelisation code utilisation for 1.28 Mcps TDD |  | 523d? | 2004-12-15 A | 2006-12-15 A | 100% | 2004-12-15 | 2006-12-15 | 523d? | finish no earlier than 2006-12-15 |  | R1 | 4184h | 4184h | RANimp-RABSE-CodOptLCRTDD | UTStarcom | Ka Leong Lo (kaleong.lo@UTSTAR.COM) | Rel-7 | Patrick | RANimp-RABSE-CodOptLCRTDD | RP-060682 |  |  |  |
| 3101 | 825.2 | Delay optimization for procedures applicable to CS and PS Connections |  | 394d? | 2005-03-15 A | 2006-09-15 A | 100% | 2005-03-15 | 2006-09-15 | 394d? | finish no earlier than 2006-09-15 |  | R2 | 3152h | 3152h | RANimp-DelayOpt | Nokia | juho.pirskanen@nokia.com | Rel-7 | Yong-Jun | RANimp-DelayOpt | RP-060453 |  |  |  |
| 3102 | 825.3 | Improved support of IMS Realtime Services using HSDPA/HSUPA |  | 197d? | 2005-03-15 A | 2005-12-14 A | 100% | 2005-03-15 | 2005-12-14 | 197d? | start no earlier than 2005-03-15 |  | R2 | 1576h | 1576h | RANimp-IMSRealTime | Cingular | Don Zelmer (dz1069@att.com) | Rel-7 | Yong-Jun | RANimp-IMSRealTime | RP-050667 |  |  |  |
| 3103 | 825.4 | UE Performance Requirements for MBMS (TDD) |  | 328d? | 2005-03-15 A | 2006-06-15 A | 100% | 2005-03-15 | 2006-06-15 | 328d? | finish no earlier than 2006-06-15 |  | R4 | 2624h | 2624h | MBMS-RAN-RF-TDD | IPwireless | shwong@ipwireless.com | Rel-7 | Issam | MBMS-RAN-RF-TDD | RP-060477 |  |  |  |
| 3104 | 825.5 | Continuous connectivity for packet data users |  | 524d? | 2005-03-14 A | 2007-03-15 A | 100% | 2005-03-14 | 2007-03-15 | 524d? | finish no earlier than 2007-03-15 |  | R1 | 4192h | 4192h | RANimp-CPC | Siemens | Joern.Krause@siemens.com | Rel-7 | Patrick | RANimp-CPC | RP-070033 |  |  |  |
| 3105 | 825.6 | Extended WCDMA Cell Range |  | 198d? | 2006-03-15 A | 2006-12-15 A | 100% | 2006-03-15 | 2006-12-15 | 198d? | finish no earlier than 2006-12-15 |  | R3 | 1584h | 1584h | RANimp-ExtCell | Ericsson | Muhammad Kazmi | Rel-7 | Juha | RANimp-ExtCell | RP-060685 |  |  |  |
| 3106 | 825.7 | 7.68 Mcps TDD Enhanced Uplink |  | 198d? | 2006-03-15 A | 2006-12-15 A | 100% | 2006-03-15 | 2006-12-15 | 198d? | finish no earlier than 2006-12-15 |  | R1 | 1584h | 1584h | RANimp-VHCRTDD-EDCH | IPwireless | nanderson@ipwireless.com | Rel-7 | Patrick | RANimp-VHCRTDD-EDCH | RP-060684 |  |  |  |
| 3107 | 825.8 | Enhanced CELL_FACH State in FDD |  | 181d? | 2006-09-25 A | 2007-06-04 A | 100% | 2006-09-25 | 2007-06-04 | 181d? | finish no earlier than 2007-06-04 |  | R2 | 1448h | 1448h | RANimp-EnhState | Nokia | juho.pirskanen@nokia.com | Rel-7 | Yong-Jun | RANimp-EnhState | RP-070286 |  |  |  |
| 3108 | 825.9 | 64QAM for HSDPA (FDD) |  | 110d? | 2006-12-15 A | 2007-06-04 A | 100% | 2006-12-15 | 2007-06-04 | 110d? | finish no earlier than 2007-06-04 |  | R1 | 880h | 880h | RANimp-64QamDownlink | Ericsson | Johan.Bergman@ericsson.com | Rel-7 | Patrick | RANimp-64QamDownlink | RP-070287 |  |  |  |
| 3109 | 825.10 | Improved L2 support for high data rates |  | 122d? | 2006-12-15 A | 2007-06-04 A | 100% | 2006-12-15 | 2007-06-04 | 122d? | finish no earlier than 2007-06-04 |  | R2 | 976h | 976h | RANimp-L2DataRates | Ericsson | Janne.Peisa@ericsson.com | Rel-7 | Yong-Jun | RANimp-L2DataRates | RP-070289 |  |  |  |
| 3110 | 825.11 | Introduction of 16QAM in HSUPA (FDD) |  | 110d? | 2006-12-15 A | 2007-06-04 A | 100% | 2006-12-15 | 2007-06-04 | 110d? | finish no earlier than 2007-06-04 |  | R1 | 880h | 880h | RANimp-16QamUplink | Nokia | Karri.Ranta-aho@nsn.com | Rel-7 | Patrick | RANimp-16QamUplink | RP-070288 |  |  |  |

Notes:
- 3084: - / Impacted TSs and TRs: 25.101
- 3085: RP#32 completed / Impacted TSs and TRs: 25.101
- 3086: RP#34 completed / Impacted TSs and TRs: 25.101
- 3087: RP#34 completed / Impacted TSs and TRs: 25.101
- 3088: RP#34 stopped. SR in RP-060680
- 3089: This item was conditionnaly approved pending decision of PCG#16 who decided not to approve it / Impacted TSs and TRs: 25.101, 25.104, 25.133, 25.141, 25.331, 25.942, 25.306, 25.307, 34.121
- 3090: Linked to Feature UID_20028 (RInImp)
- 3091: RP#32 completed / Impacted TSs and TRs: 34.108, 34.121
- 3092: RP#32 completed / Impacted TSs and TRs: 34.108, 34.121
- 3093: RP#34 completed / Impacted TSs and TRs: 34.121, 34.108
- 3094: RP#41 completed (GERAN aspects might need to be included later) / Impacted TSs and TRs: 34.114
- 3095: RP#34 completed / Impacted TSs and TRs: 34.108, 34.123-1, 34.123-2, 34.123-3
- 3096: RP#36 completed / Impacted TSs and TRs: 34.108, 34.121-1, 34.121-2
- 3097: RP#38 completed
- 3098: RP#39 completed / Impacted TSs and TRs: 34.121-1, 34.121-2
- 3099: Generic feature
- 3100: RP#34 completed
- 3101: RP#33 completed / Impacted TSs and TRs: 25.815, 25.321, 25.322, 25.331
- 3102: RP#30 completed
- 3103: RP#32 completed / Impacted TSs and TRs: 25.102, 25.123
- 3104: RP#35 completed / Impacted TSs and TRs: 25.903, 25.201, 25.211, 25.212, 25.214, 25.308, 25.321, 25.331, 25.423, 25.433, 25.101, 25.133
- 3105: RP#34 completed / Impacted TSs and TRs: 25.133, 25.423, 25.425, 25.433, 25.435, 25.453, 25.331
- 3106: RP#34 completed / Impacted TSs and TRs: 25.201, 25.202, 25.221, 25.222, 25.223, 25.224, 25.225, 25.331, 23.321, 25.306, 25.302, 25.401, 25.420, 25.423, 25.427, 25.433, 25.102, 25.105, 25.142
- 3107: RP#36 completed / Impacted TSs and TRs: 25.308, 25.304, 25.306, 25.321, 25.331, 25.433, 25.435, 25.423, 25.425,
- 3108: RP#36 completed / Impacted TSs and TRs: 25.308, 25.211, 25.212, 25.213, 25.306, 25.331, 25.433, 25.435, 25.423, 25.425, 25.101, 25.104, 25.141
- 3109: RP#36 completed / Impacted TSs and TRs: 25.301, 25.308,25.306, 25.321, 25.322, 25.331, 25.433, 25.435, 25.423, 25.425, 25.999
- 3110: RP#36 completed / Impacted TSs and TRs: 25.319, 25.101, 25.104, 25.133, 25.141, 25.211, 25.212, 25.213, 25.214, 25.306, 25.321, 25.331, 25.423, 25.433

| ID | WBS | Task | Duration | Start | Finish | Complete | Baseline start | Baseline finish | Baseline duration | Constraint | Resources | Work | Actual work | Acronym | WI rapporteur name | WI rapporteur e-mail | Release | MCC resp | Status Report | Acronym_3GU_Export | PCG approved | TSG approved |
| --- | --- | --- | --- | --- | --- | --- | --- | --- | --- | --- | --- | --- | --- | --- | --- | --- | --- | --- | --- | --- | --- | --- |
| 3111 | 825.12 | **Interface to control Tower Mounted Amplifiers (TMAs)** | 271d? | 2006-06-02 A | 2007-06-15 A | 100% | 2006-06-02 | 2007-06-15 | 271d? |  | R3; S5 | 5984h | 5984h | RANImp-TMA | Vodafone | alexej.kulakov@vodafone.com | Rel-7 | Juha | RP-070140 | RANImp-TMA |  |  |
| 3112 | 825.12.1 | RAN3 part of Interface to control Tower Mounted Amplifiers (TMAs) | 206d? | 2006-06-02 A | 2007-03-16 A | 100% | 2006-06-02 | 2007-03-16 | 206d? |  | R3 | 840h | 840h |  | Vodafone | alexej.kulakov@vodafone.com | Rel-7 | Juha | RP-070140 |  |  |  |
| 3113 | 825.12.2 | OAM aspects to Interface to control TMAs | 101d? | 2007-01-26 A | 2007-06-15 A | 100% | 2007-01-26 | 2007-06-15 | 101d? | finish no earlier than 2007-06-15 | S5 | 808h | 808h | RANImp-TMA-OAM | Vodafone | Adrian.Neal@vodafone.com | Rel-7 | Mirko |  | RANImp-TMA-OAM |  |  |
| 3114 | 826 | **Rel-7 RAN improvements - UE Conformance Testing** | 784d? | 2006-09-20 A | 2009-09-18 A | 100% | 2006-09-20 | 2009-09-18 | 784d? |  | R5 | 25472h | 25472h |  |  |  | Rel-7 | Ingbert |  |  |  |  |
| 3115 | 826.1 | Conformance Test Aspects - 3.84 Mcps and 7.68 Mcps TDD Enhanced Uplink | 518d? | 2006-09-20 A | 2008-09-12 A | 100% | 2006-09-20 | 2008-09-12 | 518d? | finish no earlier than 2008-09-12 | R5 | 4144h | 4144h | RANimp-UEConTest_EDCHTDH | IPWireless | tspeight@ipwireless.com | Rel-7 | Ingbert | RP-080536 | RANimp-UEConTest_EDCHTDH |  |  |
| 3116 | 826.2 | Conformance Test Aspects – 64QAM for HSDPA (FDD) | 257d? | 2007-03-09 A | 2008-03-03 A | 100% | 2007-03-09 | 2008-03-03 | 257d? | finish no earlier than 2008-03-03 | R5 | 2056h | 2056h | RANimp-UEConTest_64QamDownlink | Ericsson | leif.mattisson@ericsson.com | Rel-7 | Ingbert | RP-080059 | RANimp-UEConTest_64QamDownlink |  |  |
| 3117 | 826.3 | Conformance Test Aspects – 16QAM for HSUPA (FDD) | 321d? | 2007-03-09 A | 2008-05-30 A | 100% | 2007-03-09 | 2008-05-30 | 321d? | finish no earlier than 2008-05-30 | R5 | 2568h | 2568h | RANimp-UEConTest_16QamUplink | Motorola | carolyn.taylor@motorola.com | Rel-7 | Ingbert | RP-080281 | RANimp-UEConTest_16QamUplink |  |  |
| 3118 | 826.4 | Conformance Test Aspects – Improved L2 support for high data rates | 321d? | 2007-03-09 A | 2008-05-30 A | 100% | 2007-03-09 | 2008-05-30 | 321d? | finish no earlier than 2008-05-30 | R5 | 2568h | 2568h | RANimp-UEConTest_L2DataRates | Ericsson | leif.mattisson@ericsson.com | Rel-7 | Ingbert | RP-080256 | RANimp-UEConTest_L2DataRates |  |  |
| 3119 | 826.5 | Conformance Test Aspects – Continuous connectivity for packet data users | 321d? | 2007-03-09 A | 2008-05-30 A | 100% | 2007-03-09 | 2008-05-30 | 321d? | finish no earlier than 2008-05-30 | R5 | 2568h | 2568h | RANimp-UEConTest_CPC | Nokia | jarkko.hellsten@nokia.com | Rel-7 | Ingbert | RP-080282 | RANimp-UEConTest_CPC |  |  |
| 3120 | 826.6 | Conformance Test Aspects – Enhanced CELL_FACH state in FDD | 662d? | 2007-03-09 A | 2009-09-18 A | 100% | 2007-03-09 | 2009-09-18 | 662d? | finish no earlier than 2009-09-18 | R5 | 5296h | 5296h | RANimp-UEConTest_EnhancedCellFACHState | Nokia | jarkko.hellsten@nokia.com | Rel-7 | Ingbert | RP-090711 | RANimp-UEConTest_EnhancedCellFACHState |  |  |
| 3121 | 827 | **7.68 Mcps TDD option** | 783d? | 2004-09-15 A | 2007-09-14 A | 100% | 2004-09-15 | 2007-09-14 | 783d? |  | R1; R2; R3; R4; R5 | 49552h | 49552h | VHCRTDD | IPwireless | Martin Beale (mbeale@ipwireless.com) | Rel-7 | Patrick | RP-060684 | VHCRTDD |  |  |
| 3122 | 827.1 | VHCRTDD: Stage 2 | 391d? | 2004-09-15 A | 2006-03-15 A | 100% | 2004-09-15 | 2006-03-15 | 391d? | finish no earlier than 2006-03-15 | R1 | 3128h | 3128h | VHCRTDD-Stage2 | IPwireless | Martin Beale (mbeale@ipwireless.com) | Rel-7 | Patrick | RP-060684 | VHCRTDD-Stage2 |  |  |
| 3123 | 827.2 | VHCRTDD: Physical Layer | 391d? | 2004-09-15 A | 2006-03-15 A | 100% | 2004-09-15 | 2006-03-15 | 391d? | finish no earlier than 2006-03-15 | R1 | 3128h | 3128h | VHCRTDD-Phys | IPwireless | Martin Beale (mbeale@ipwireless.com) | Rel-7 | Patrick | RP-060684 | VHCRTDD-Phys |  |  |
| 3124 | 827.3 | VHCRTDD: Layer 2 and layer 3 protocol aspects | 391d? | 2004-09-15 A | 2006-03-15 A | 100% | 2004-09-15 | 2006-03-15 | 391d? | finish no earlier than 2006-03-15 | R2 | 3128h | 3128h | VHCRTDD-L23 | IPwireless | drichards@ipwireless.com | Rel-7 | Yong-Jun | RP-060684 | VHCRTDD-L23 |  |  |
| 3125 | 827.4 | VHCRTDD: UTRAN Iub/Iur Protocol Aspects | 391d? | 2004-09-15 A | 2006-03-15 A | 100% | 2004-09-15 | 2006-03-15 | 391d? | finish no earlier than 2006-03-15 | R3 | 3128h | 3128h | VHCRTDD-IurIub | IPwireless | Peter Legg (plegg@ipwireless.com) | Rel-7 | Juha | RP-060684 | VHCRTDD-IurIub |  |  |
| 3126 | 827.5 | VHCRTDD: RF Radio Transmission/ Reception, System Performance Requirements and Conformance Testing | 457d? | 2004-09-15 A | 2006-06-15 A | 100% | 2004-09-15 | 2006-06-15 | 457d? | finish no earlier than 2006-06-15 | R4 | 3656h | 3656h | VHCRTDD-RF | IPwireless | Shin Horng Wong (shwong@ipwireless.com) | Rel-7 | Issam | RP-060684 | VHCRTDD-RF |  |  |
| 3127 | 827.6 | Conformance Test Aspects - 7.68 Mcps TDD | 258d? | 2006-09-20 A | 2007-09-14 A | 100% | 2006-09-20 | 2007-09-14 | 258d? | finish no earlier than 2007-09-10 | R5 | 2064h | 2064h | VHCRTDD-UEConTest | IPWireless | tspeight@ipwireless.com | Rel-7 | Ingbert | RP-070307 | VHCRTDD-UEConTest |  |  |
| 3128 | 828 | **3.84 Mcps TDD Enhanced Uplink** | 394d? | 2005-03-15 A | 2006-09-15 A | 100% | 2005-03-15 | 2006-09-15 | 394d? |  | RP | 18384h | 18384h | EDCHTDD | IPwireless | nanderson@ipwireless.com | Rel-7 |  | RP-060462 | EDCHTDD |  |  |
| 3129 | 828.1 | EDCHTDD: Stage 2 | 328d? | 2005-03-15 A | 2006-06-15 A | 100% | 2005-03-15 | 2006-06-15 | 328d? | finish no earlier than 2006-06-15 | R2 | 2624h | 2624h | EDCHTDD-Stage2 | IPwireless | nanderson@ipwireless.com | Rel-7 | Yong-Jun | RP-060462 | EDCHTDD-Stage2 |  |  |
| 3130 | 828.2 | EDCHTDD: Physical Layer | 394d? | 2005-03-15 A | 2006-09-15 A | 100% | 2005-03-15 | 2006-09-15 | 394d? | finish no earlier than 2006-09-15 | R1 | 3152h | 3152h | EDCHTDD-Phys | IPwireless | nanderson@ipwireless.com | Rel-7 | Patrick | RP-060462 | EDCHTDD-Phys |  |  |
| 3131 | 828.3 | EDCHTDD: Layer 2 and 3 Protocol Aspects | 394d? | 2005-03-15 A | 2006-09-15 A | 100% | 2005-03-15 | 2006-09-15 | 394d? | finish no earlier than 2006-09-15 | R2 | 3152h | 3152h | EDCHTDD-L23 | IPwireless | drichards@ipwireless.com | Rel-7 | Yong-Jun | RP-060462 | EDCHTDD-L23 |  |  |
| 3132 | 828.4 | EDCHTDD: UTRAN Iub/Iur Protocol Aspects | 394d? | 2005-03-15 A | 2006-09-15 A | 100% | 2005-03-15 | 2006-09-15 | 394d? | finish no earlier than 2006-09-15 | R3 | 3152h | 3152h | EDCHTDD-IurIub | Interdigital | jim.miller@interdigital.com | Rel-7 | Juha | RP-060462 | EDCHTDD-IurIub |  |  |
| 3133 | 828.5 | EDCHTDD: RF Radio Transmission/ Reception, System Performance Requirements and Conformance Testing | 394d? | 2005-03-15 A | 2006-09-15 A | 100% | 2005-03-15 | 2006-09-15 | 394d? | finish no earlier than 2006-09-15 | R4 | 3152h | 3152h | EDCHTDD-RF | IPwireless | Shin Horng Wong (shwong@ipwireless.com) | Rel-7 | Issam | RP-060462 | EDCHTDD-RF |  |  |
| 3134 | 829 | **1.28 Mcps TDD Enhanced Uplink** | 653d? | 2006-03-15 A | 2008-09-12 A | 100% | 2006-03-15 | 2008-09-12 | 653d? |  | R1; R2; R3; R4; R5 | 35656h | 35656h | LCRTDD-EDCH | CATT | Haijing Hu | Rel-7 | Patrick | RP-070296 | LCRTDD-EDCH |  |  |
| 3135 | 829.1 | 1.28 Mcps TDD Enhanced Uplink: Physical Layer | 262d? | 2006-03-15 A | 2007-03-15 A | 100% | 2006-03-15 | 2007-03-15 | 262d? | finish no earlier than 2007-03-15 | R1 | 2096h | 2096h | LCRTDD-EDCH-Phys | CATT | Ke Wang | Rel-7 | Patrick | RP-070038 | LCRTDD-EDCH-Phys |  |  |
| 3136 | 829.2 | 1.28 Mcps TDD Enhanced Uplink: Layer 2 and 3 Protocol Aspects | 262d? | 2006-03-15 A | 2007-03-15 A | 100% | 2006-03-15 | 2007-03-15 | 262d? | finish no earlier than 2007-03-15 | R2 | 2096h | 2096h | LCRTDD-EDCH-L23 | CATT | Haiyang Quan | Rel-7 | Yong-Jun | RP-070038 | LCRTDD-EDCH-L23 |  |  |
| 3137 | 829.3 | 1.28 Mcps TDD Enhanced Uplink: UTRAN Iub/Iur Protocol Aspects | 262d? | 2006-03-15 A | 2007-03-15 A | 100% | 2006-03-15 | 2007-03-15 | 262d? | finish no earlier than 2007-03-15 | R3 | 2096h | 2096h | LCRTDD-EDCH-IubIur | CATT | Yincheng Zhang | Rel-7 | Juha | RP-070038 | LCRTDD-EDCH-IubIur |  |  |
| 3138 | 829.4 | 1.28 Mcps TDD Enhanced Uplink: RF Radio Transmission/ Reception, System Performance Requirements and Conformance Testing | 328d? | 2006-03-15 A | 2007-06-15 A | 100% | 2006-03-15 | 2007-06-15 | 328d? | finish no earlier than 2007-06-15 | R4 | 2624h | 2624h | LCRTDD-EDCH-RF | CATT | Yuexia Song (songyuexia@catt.cn) | Rel-7 | Issam | RP-070296 | LCRTDD-EDCH-RF |  |  |
| 3139 | 829.5 | 1.28 Mcps TDD Enhanced Uplink - UE Conformance Testing | 257d? | 2007-09-20 A | 2008-09-12 A | 100% | 2007-09-20 | 2008-09-12 | 257d? | finish no earlier than 2008-09-11 | R5 | 624h | 624h | LCRTDD-EDCH-UEConTest | CATT | chenxiaozhong@datangmobile.cn | Rel-7 | Ingbert | RP-080539 | LCRTDD-EDCH-UEConTest |  |  |
| 3140 | 830 | Conformance Test Aspects – Multiple Band and Multiple Frequency operation for LCR TDD | 263d? | 2010-09-17 A | 2011-09-16 A | 100% | 2010-09-17 | 2011-09-16 | 263d? | finish no earlier than 2011-12-09 | R5 | 2091.37h | 2091.37h | LCRTDD_MB_MF_UEConTest | CATR | Ms Jun Chen (chenjun@catr.cn) | Rel-7 | Ingbert | RP-110968 | LCRTDD_MB_MF_UEConTest | PCG-25 | RP-49 |
| 3141 | 831 | MS Antenna Performance Evaluation Method and Requirements | 731d? | 2005-01-28 A | 2007-11-16 A | 100% | 2005-01-28 | 2007-11-16 | 731d? | finish no earlier than 2007-11-16 | GP | 5848h | 5848h | APEMR | TeliaSonera | Ulf.Tegth@teliasonera.com | Rel-7 | Paolo |  | APEMR |  |  |

Notes:
- 3111: RP#35 completed
- 3112: RP#35 completed
- 3113: SP#36 completed / Impacted TSs and TRs: 32.642, 32.643, 32.645 – Align with RAN 25.466
- 3114: Linked to Feature UID_20029 (RANimp)
- 3115: RP#41 completed / Impacted TSs and TRs: 34.108, 34.122, 34.123-1, 34.123-2, 34.123-3
- 3116: RP#39 completed / Impacted TSs and TRs: 34.108, 34.121-1, 34.121-2, 34.123-1, 34.123-2, 34.123-3
- 3117: RP#40 completed / Impacted TSs and TRs: 34.108, 34.121-1, 34.121-2, 34.123-1, 34.123-2, 34.123-3
- 3118: RP#40 completed / Impacted TSs and TRs: 34.108, 34.123-1, 34.123-2, 34.123-3
- 3119: RP#40 completed / Impacted TSs and TRs: 34.108, 34.121-1, 34.121-2, 34.123-1, 34.123-2, 34.123-3
- 3120: RP#45 completed / Impacted TSs and TRs: 34.108, 34.123-1, 34.123-2, 34.123-3
- 3121: RP#31 completed
- 3122: RP#31 completed / Impacted TSs and TRs: 25.202
- 3123: RP#31 completed / Impacted TSs and TRs: 25.221, 25.222, 25.223, 25.224,25.225
- 3124: RP#31 completed / Impacted TSs and TRs: 25.301, 25.302, 25.305, 25.306, 25.321, 25.331
- 3125: RP#31 completed / Impacted TSs and TRs: 25.401, 25.420, 25.423, 25.425, 25.427, 25.430, 25.433, 25.435
- 3126: RP#32 completed / Impacted TSs and TRs: 25.102, 25.105, 25.123, 25.133, 25.142
- 3127: RP#37 completed / Impacted TSs and TRs: 34.108, 34.122, 34.123-1, 34.123-2, 34.123-3
- 3128: RP#33 completed
- 3129: RP#33 completed
- 3130: RP#33 completed / Impacted TSs and TRs: 25.201, 25.221,25.222, 25.223, 25.224, 25.225
- 3131: RP#33 completed / Impacted TSs and TRs: 25.301, 25.302, 25.306, 25.321, 25.331
- 3132: RP#33 completed / Impacted TSs and TRs: 25.401, 25.420, 25.423, 25.427, 25.430, 25.433, 25.435
- 3133: RP#33 completed / Impacted TSs and TRs: 25.102, 25.105, 25.123, 25.142
- 3134: RP#35 completed
- 3135: RP#35 completed / Impacted TSs and TRs: 25.201, 25.221, 25.222, 25.223, 25.224, 25.225
- 3136: RP#35 completed / Impacted TSs and TRs: 25.301, 25.302, 25.306, 25.321, 25.331
- 3137: RP#35 completed / Impacted TSs and TRs: 25.401, 25.420, 25.423, 25.425, 25.427, 25.430, 25.433, 25.435
- 3138: RP#36 completed / Impacted TSs and TRs: 25.102, 25.105, 25.123, 25.142
- 3139: RP#41 completed / Impacted TSs and TRs: 34.108, 34.122, 34.123-1/2/3
- 3140: RP#53 completed. Core specification was introduced via Rel-7 CR under TEI7 (RP#37 RP-070650) and via 2 Rel-8 work items: RInImp9-UMTS1880TDD and RInImp8-UMTS2300TDD. / Impacted TSs and TRs: UTRA 34.108, 34.123-1, 34.123-2, 34.123-3
- 3141: GP#36 completed for R7 / Impacted TSs and TRs: 25.914, 25.144, 45.005

| ID | WBS | Task | Type | Duration | Start | Finish | Complete | Remaining | Baseline start | Baseline finish | Baseline duration | Total slack | Constraint | Resources | Work | Actual work | Acronym | WI rapporteur name | WI rapporteur e-mail | Release | MCC resp | Acronym_3GU_Export | TSG stopped |
| --- | --- | --- | --- | --- | --- | --- | --- | --- | --- | --- | --- | --- | --- | --- | --- | --- | --- | --- | --- | --- | --- | --- | --- |
| 3142 | 832 | **Lower 700 MHz Inclusion in the GERAN Specifications** |  | 390d? | 2005-01-03 A | 2006-06-30 | 99% | 0d? | 2005-01-03 | 2006-06-30 | 390d? | 0d |  | GP | 11112h | 9372h | GSM710 | UTC | dcotton@mtview.union-tel.com | Rel-7 | Paolo | GSM710 |  |
| 3143 | 832.1 | Inclusion of the 698 – 746 MHz band into GERAN core specifications |  | 129d? | 2005-01-03 A | 2005-06-30 A | 100% |  | 2005-01-03 | 2005-06-30 | 129d? |  | finish no earlier than 2005-06-30 | G1 | 1032h | 1032h | GSM710-core |  |  | Rel-7 | Paolo | GSM710-core |  |
| 3144 | 832.2 | **Aspects of GSM710** |  | 217.5d? | 2005-08-31 A | 2006-06-30 | 100% | 0d? | 2005-08-31 | 2006-06-30 | 217.5d? | 0d |  | G1; G3new | 6960h | 5220h | GSM-710-test |  |  | Rel-7 | Paolo | GSM-710-test |  |
| 3145 | 832.2.1 | G1 aspects of GSM710 |  | 217.5d? | 2005-08-31 A | 2006-06-30 A | 100% |  | 2005-08-31 | 2006-06-30 | 217.5d? |  | finish no earlier than 2006-06-30 | G1 | 1740h | 1740h |  |  |  | Rel-7 | Paolo |  |  |
| 3146 | 832.2.2 | G3 aspects of GSM710 |  | 217.5d? | 2005-08-31 A | 2006-06-30 A | 100% |  | 2005-08-31 | 2006-06-30 | 217.5d? |  | finish no earlier than 2006-06-30 | G3new | 1740h | 1740h |  |  |  | Rel-7 | Ingbert |  |  |
| 3147 | 833 | **Support of Conversational Services in A/Gb mode via the PS domain** |  | 626d? | 2005-04-08 A | 2007-08-31 A | 100% |  | 2005-04-08 | 2007-08-31 | 626d? |  |  | GP | 15442.8h | 15442.8h | SCSAGB | Ericsson | gunnar.hedby@ericsson.com | Rel-7 | Paolo | SCSAGB |  |
| 3148 | 833.1 | Minimise the transfer delay between the SGSN and the MS |  | 604.95d? | 2005-04-08 A | 2007-08-31 A | 100% |  | 2005-04-08 | 2007-08-31 | 604.95d? |  | finish no earlier than 2007-08-31 | GP | 4839.6h | 4839.6h | SCSAGB-MTD | Ericsson | gunnar.hedby@ericsson.com | Rel-7 | Paolo | SCSAGB-MTD |  |
| 3149 | 833.2 | Definition of radio resource management functionality for Support of Conversational Services in A/Gb mode via the PS domain |  | 626d? | 2005-04-08 A | 2007-08-31 A | 100% |  | 2005-04-08 | 2007-08-31 | 626d? |  | finish no earlier than 2007-08-31 | G1 | 5008h | 5008h | SCSAGB-RRM | Ericsson | gunnar.hedby@ericsson.com | Rel-7 | Paolo | SCSAGB-RRM |  |
| 3150 | 833.3 | Support of Conversational Services in A/Gb mode via the PS domain – RLC Non-Persistent mode |  | 101d? | 2006-06-30 A | 2006-11-17 A | 100% |  | 2006-06-30 | 2006-11-17 | 101d? |  | finish no earlier than 2006-11-17 | G2 | 808h | 808h | SCSAGB-RLCNP | Ericsson | gunnar.hedby@ericsson.com | Rel-7 | Gert | SCSAGB-RLCNP |  |
| 3151 | 833.4 | Deleted- Radio Channel Support | milestone | 0d? | 2006-07-17 A | 2006-07-17 A | 100% |  | 2006-07-17 | 2006-07-17 | 0d? |  | start no earlier than 2006-07-17 | G2 |  |  | SCSAGB-RCHS | Ericsson | gunnar.hedby@ericsson.com | Rel-7 | Gert | SCSAGB-RCHS | SP-32 |
| 3152 | 833.5 | Deleted- Modifications to FLO | milestone | 0d? | 2006-07-17 A | 2006-07-17 A | 100% |  | 2006-07-17 | 2006-07-17 | 0d? |  | start no earlier than 2006-07-17 | G2 |  |  | SCSAGB-FLO | Ericsson | gunnar.hedby@ericsson.com | Rel-7 | Gert | SCSAGB-FLO | SP-32 |
| 3153 | 834 | **Addition of new frequency band to GSM (T-GSM810)** |  | 626d? | 2005-04-08 A | 2007-08-31 A | 100% |  | 2005-04-08 | 2007-08-31 | 626d? |  |  | GP | 12112h | 12112h | TGSM810 | Huawei | chende@huawei.com | Rel-7 | Paolo | TGSM810 |  |
| 3154 | 834.1 | Changes to core specification |  | 106d? | 2005-04-08 A | 2005-09-02 A | 100% |  | 2005-04-08 | 2005-09-02 | 106d? |  | finish no earlier than 2005-09-02 | GP | 848h | 848h | TGSM810-Core | Huawei | chende@huawei.com | Rel-7 | Paolo | TGSM810-Core |  |
| 3155 | 834.2 | Changes to MS testing specification |  | 626d? | 2005-04-08 A | 2007-08-31 A | 100% |  | 2005-04-08 | 2007-08-31 | 626d? |  | finish no earlier than 2007-08-31 | G3new | 5008h | 5008h | TGSM810-MStest | Huawei | chende@huawei.com | Rel-7 | Ingbert | TGSM810-MStest |  |
| 3156 | 834.3 | Changes to BTS testing specification |  | 156d? | 2005-04-08 A | 2005-11-11 A | 100% |  | 2005-04-08 | 2005-11-11 | 156d? |  | finish no earlier than 2005-11-11 | G1 | 1248h | 1248h | TGSM810-BTStest | Huawei | chende@huawei.com | Rel-7 | Paolo | TGSM810-BTStest |  |
| 3157 | 835 | **Handover of dedicated and shared resources while in Dual Transfer Mode** |  | 421d? | 2005-04-08 A | 2006-11-17 A | 100% |  | 2005-04-08 | 2006-11-17 | 421d? |  |  | GP | 12672h | 12672h | HODSRDTM | Nokia | rami.vaittinen@nokia.com | Rel-7 | Paolo | HODSRDTM |  |
| 3158 | 835.1 | GERAN2 part of Handover of dedicated and shared resources while in Dual Transfer Mode |  | 321d? | 2005-04-08 A | 2006-06-30 A | 100% |  | 2005-04-08 | 2006-06-30 | 321d? |  | finish no earlier than 2006-06-30 | G2 | 2568h | 2568h | HODSRDTM-G2 | Nokia | rami.vaittinen@nokia.com | Rel-7 | Gert | HODSRDTM-G2 |  |
| 3159 | 835.2 | Deleted - MS Conformance Testing |  | 421d? | 2005-04-08 A | 2006-11-17 A | 100% |  | 2005-04-08 | 2006-11-17 | 421d? |  | finish no earlier than 2006-11-17 | G3new | 3368h | 3368h | HODSRDTM-MStest | Nokia | rami.vaittinen@nokia.com | Rel-7 | Ingbert | HODSRDTM-MStest | GP-32 |
| 3160 | 835.3 | Deleted - BTS conformance testing |  | 421d? | 2005-04-08 A | 2006-11-17 A | 100% |  | 2005-04-08 | 2006-11-17 | 421d? |  | finish no earlier than 2006-11-17 | G1 | 3368h | 3368h | HODSRDTM-BTStest | Nokia | rami.vaittinen@nokia.com | Rel-7 | Paolo | HODSRDTM-BTStest | GP-32 |
| 3161 | 836 | **Mobile Station Receive Diversity (DARP Phase II)** |  | 526d? | 2005-11-11 A | 2007-11-16 A | 100% |  | 2005-11-11 | 2007-11-16 | 526d? |  |  | GP | 16360h | 16360h | MSRD2 | Nokia | kent.pedersen@nokia.com | Rel-7 | Paolo | MSRD2 |  |
| 3162 | 836.1 | Performance Requirements for Mobile Station Receive Diversity, DARP Phase II |  | 331d? | 2005-11-11 A | 2007-02-16 A | 100% |  | 2005-11-11 | 2007-02-16 | 331d? |  | finish no earlier than 2007-02-16 | GP | 2648h | 2648h | MSRD2-PerfReq | Nokia | kent.pedersen@nokia.com | Rel-7 | Paolo | MSRD2-PerfReq |  |
| 3163 | 836.2 | Capability signalling of Mobile Station Receive Diversity, DARP Phase II |  | 331d? | 2005-11-11 A | 2007-02-16 A | 100% |  | 2005-11-11 | 2007-02-16 | 331d? |  | finish no earlier than 2007-02-16 | GP | 2648h | 2648h | MSRD2-CapSig | Nokia | kent.pedersen@nokia.com | Rel-7 | Paolo | MSRD2-CapSig |  |
| 3164 | 836.3 | Test Scenarios for Mobile Station Receive Diversity, DARP Phase II |  | 331d? | 2005-11-11 A | 2007-02-16 A | 100% |  | 2005-11-11 | 2007-02-16 | 331d? |  | finish no earlier than 2007-02-16 | GP | 2648h | 2648h | MSRD2-TestSc | Nokia | kent.pedersen@nokia.com | Rel-7 | Paolo | MSRD2-TestSc |  |
| 3165 | 836.4 | MS conformance test of DARP Phase II (MSRD) |  | 526d? | 2005-11-11 A | 2007-11-16 A | 100% |  | 2005-11-11 | 2007-11-16 | 526d? |  | finish no earlier than 2007-11-16 | GP | 4208h | 4208h | MSRD2-Msconf | Nokia | kent.pedersen@nokia.com | Rel-7 | Ingbert | MSRD2-Msconf |  |

Notes:
- 3142: -
- 3143: Completed / Impacted TSs and TRs: 24.008, 43.022, 44.018, 44.118, 45, 001, 45.005,
- 3144: -
- 3145: - / Impacted TSs and TRs: 51.021
- 3146: - / Impacted TSs and TRs: 51.010
- 3147: Originally started Nov. 2003 as GP-030443
- 3148: -
- 3149: -
- 3150: - / Impacted TSs and TRs: 43.955, 43.064, 44.060, 45.001, 45.002, 45.003, 45.005, 45.010, 51.010, 51.021
- 3151: -
- 3152: -
- 3153: - / Impacted TSs and TRs: 45.005, 45.050, 24.008, 45.008, 45.001, 43.022, 43.030, 44.018, 44.060, 51.010-1, 51.021
- 3154: - / Impacted TSs and TRs: 45.005, 45.050, 24.008, 45.008, 45.001, 43.022, 43.030, 44.018, 44.060
- 3155: - / Impacted TSs and TRs: 51010-1
- 3156: - / Impacted TSs and TRs: 51021
- 3157: GP#30 completed. Started at GP#24
- 3158: GP#30 completed / Impacted TSs and TRs: 43.055, 44.018, 44.060
- 3159: Stopped, no work done. 12/2008 Marked as stopped ("deleted") / Impacted TSs and TRs: 51-010
- 3160: Stopped, no work done. 12/2008 Marked as stopped ("deleted") / Impacted TSs and TRs: 51.026
- 3161: GP#36 completed
- 3162: GP#33 completed / Impacted TSs and TRs: 45.005
- 3163: GP#33 completed / Impacted TSs and TRs: 24.008
- 3164: GP#33 completed / Impacted TSs and TRs: 45.005
- 3165: GP#36 completed / Impacted TSs and TRs: 51.010

| ID | WBS | Task | Type | Duration | Start | Finish | Complete | Remaining | Baseline start | Baseline finish | Baseline duration | Total slack | Constraint | Resources | Work | Actual work | Acronym | WI rapporteur name | WI rapporteur e-mail | Release | MCC resp | Acronym_3GU_Export | TSG stopped |
| --- | --- | --- | --- | --- | --- | --- | --- | --- | --- | --- | --- | --- | --- | --- | --- | --- | --- | --- | --- | --- | --- | --- | --- |
| 3166 | 837 | **Downlink Dual Carrier** |  | 947d? | 2006-01-20 A | 2009-09-04 A | 100% |  | 2006-01-20 | 2009-09-04 | 947d? |  |  | GP | 15446.6h | 15446.6h | GDCDL | Nokia Siemens Networks | leonardo.provvedi@roke.co.uk | Rel-7 | Paolo | GDCDL |  |
| 3167 | 837.1 | Downlink Dual Carrier Stage 2 |  | 116d? | 2006-01-20 A | 2006-06-30 A | 100% |  | 2006-01-20 | 2006-06-30 | 116d? |  | finish no earlier than 2006-06-30 | G1 | 928h | 928h | GDCDL-Stage2 | Nokia Siemens Networks | leonardo.provvedi@roke.co.uk | Rel-7 | Paolo | GDCDL-Stage2 |  |
| 3168 | 837.2 | Downlink Dual Carrier Stage 3 |  | 421d? | 2006-01-20 A | 2007-08-31 A | 100% |  | 2006-01-20 | 2007-08-31 | 421d? |  | finish no earlier than 2007-08-31 | G1 | 3368h | 3368h | GDCDL-Stage3 | Nokia Siemens Networks | leonardo.provvedi@roke.co.uk | Rel-7 | Paolo | GDCDL-Stage3 |  |
| 3169 | 837.3 | Downlink Dual Carrier – MS Conformance Test |  | 446.82d? | 2006-01-20 A | 2009-09-04 A | 100% |  | 2006-01-20 | 2009-09-04 | 446.82d? |  | finish no earlier than 2009-09-04 | G3new | 3574.6h | 3574.6h | GDCDL-MStest | Nokia Siemens Networks | leonardo.provvedi@roke.co.uk | Rel-7 | Ingbert | GDCDL-MStest |  |
| 3170 | 838 | Support of SIGTRAN in GERAN |  | 116d? | 2006-01-20 A | 2006-06-30 A | 100% |  | 2006-01-20 | 2006-06-30 | 116d? |  | finish no earlier than 2006-06-30 | GP | 928h | 928h | GSIGT | Ericsson | peter.ostrup@ericsson.com | Rel-7 | Ingbert | GSIGT |  |
| 3171 | 839 | **Latency Reductions** |  | 306d? | 2006-06-30 A | 2007-08-31 A | 100% |  | 2006-06-30 | 2007-08-31 | 306d? |  |  | GP | 7344h | 7344h | LATRED | Ericsson | Hakan.Persson@Ericsson.com | Rel-7 | Paolo | LATRED |  |
| 3172 | 839.1 | Improved Ack/Nack reporting |  | 306d? | 2006-06-30 A | 2007-08-31 A | 100% |  | 2006-06-30 | 2007-08-31 | 306d? |  | finish no earlier than 2007-08-31 | G2 | 2448h | 2448h | LATRED-ACKNAR | Ericsson | Hakan.Persson@Ericsson.com | Rel-7 | Gert | LATRED-ACKNAR |  |
| 3173 | 839.2 | Reduced TTI |  | 306d? | 2006-06-30 A | 2007-08-31 A | 100% |  | 2006-06-30 | 2007-08-31 | 306d? |  | finish no earlier than 2007-08-31 | G2 | 2448h | 2448h | LATRED-REDTTI | Ericsson | Hakan.Persson@Ericsson.com | Rel-7 | Gert | LATRED-REDTTI |  |
| 3174 | 840 | PS Handover between GERAN/UTRAN mode and GAN Mode |  | 166d? | 2006-06-30 A | 2007-02-16 A | 100% |  | 2006-06-30 | 2007-02-16 | 166d? |  | finish no earlier than 2007-02-16 | G2 | 1328h | 1328h | GUGAN | Ericsson | John.Diachina@Ericsson.com | Rel-7 | Gert | GUGAN |  |
| 3175 | 841 | **Higher Uplink performance for GERAN Evolution** |  | 1227d? | 2006-09-08 A | 2011-05-20 A | 100% |  | 2006-09-08 | 2011-05-20 | 1227d? |  |  | GP | 37184h | 37184h | HUGE | Nokia Siemens Networks, Ericsson | eddie.riddington@nokia.com, stefan.g.eriksson@ericsson.com | Rel-7 | Paolo | HUGE |  |
| 3176 | 841.1 | Stage 2 for HUGE |  | 261d? | 2006-09-08 A | 2007-09-07 A | 100% |  | 2006-09-08 | 2007-09-07 | 261d? |  | finish no earlier than 2007-09-07 | G1 | 2088h | 2088h | HUGE-Stage2 | Nokia Siemens Networks, Ericsson | eddie.riddington@nokia.com, stefan.g.eriksson@ericsson.com | Rel-7 | Paolo | HUGE-Stage2 |  |
| 3177 | 841.2 | Layer 1 Support for HUGE |  | 381d? | 2006-09-08 A | 2008-02-22 A | 100% |  | 2006-09-08 | 2008-02-22 | 381d? |  | finish no earlier than 2008-02-22 | G1 | 3048h | 3048h | HUGE-Layer1 | Nokia Siemens Networks, Ericsson | eddie.riddington@nokia.com, stefan.g.eriksson@ericsson.com | Rel-7 | Paolo | HUGE-Layer1 |  |
| 3178 | 841.3 | Layer 2/3 Support for HUGE |  | 256d? | 2006-09-08 A | 2007-08-31 A | 100% |  | 2006-09-08 | 2007-08-31 | 256d? |  | finish no earlier than 2007-08-31 | G2 | 2048h | 2048h | HUGE-Layer23 | Nokia Siemens Networks, Ericsson | eddie.riddington@nokia.com, stefan.g.eriksson@ericsson.com | Rel-7 | Gert | HUGE-Layer23 |  |
| 3179 | 841.4 | Performance requirements for HUGE |  | 516d? | 2006-09-08 A | 2008-08-29 A | 100% |  | 2006-09-08 | 2008-08-29 | 516d? |  | finish no earlier than 2008-08-29 | G1 | 4128h | 4128h | HUGE-Perfreq | Nokia Siemens Networks, Ericsson | eddie.riddington@nokia.com, stefan.g.eriksson@ericsson.com | Rel-7 | Paolo | HUGE-Perfreq |  |
| 3180 | 841.5 | BTS Conformance Test for HUGE |  | 782d? | 2006-09-08 A | 2009-09-04 A | 100% |  | 2006-09-08 | 2009-09-04 | 782d? |  | finish no earlier than 2009-09-04 | G1 | 6248h | 6248h | HUGE-BTStest | Nokia Siemens Networks, Ericsson | eddie.riddington@nokia.com, stefan.g.eriksson@ericsson.com | Rel-7 | Paolo | HUGE-BTStest |  |
| 3181 | 841.6 | MS Conformance Test for HUGE |  | 1226d? | 2006-09-08 A | 2011-05-20 A | 100% |  | 2006-09-08 | 2011-05-20 | 1226d? |  | finish no earlier than 2011-05-20 | G3new | 9808h | 9808h | HUGE-Mstest | Nokia Siemens Networks, Ericsson | eddie.riddington@nokia.com, stefan.g.eriksson@ericsson.com | Rel-7 | Ingbert | HUGE-Mstest |  |
| 3182 | 842 | **REduced symbol Duration, Higher Order modulation and Turbo coding (RED HOT) for downlink** |  | 1177d? | 2006-11-17 A | 2011-05-20 A | 100% |  | 2006-11-17 | 2011-05-20 | 1177d? |  |  | GP | 28808h | 28808h | REDHOT | Ericsson, Nokia Siemens Networks, Marvell | stefan.g.eriksson@ericsson.com | Rel-7 | Paolo | REDHOT |  |
| 3183 | 842.1 | Stage 2 for REDHOT |  | 206d? | 2006-11-17 A | 2007-08-31 A | 100% |  | 2006-11-17 | 2007-08-31 | 206d? |  | finish no earlier than 2007-08-31 | G1 | 1648h | 1648h | REDHOT-Stage2 | Ericsson, Nokia Siemens Networks, Marvell | stefan.g.eriksson@ericsson.com | Rel-7 | Paolo | REDHOT-Stage2 |  |
| 3184 | 842.2 | Stage 3 for REDHOT |  | 391d? | 2006-11-17 A | 2008-05-16 A | 100% |  | 2006-11-17 | 2008-05-16 | 391d? |  | finish no earlier than 2008-05-16 | G1 | 3128h | 3128h | REDHOT-Stage3 | Ericsson, Nokia Siemens Networks, Marvell | stefan.g.eriksson@ericsson.com | Rel-7 | Paolo | REDHOT-Stage3 |  |
| 3185 | 842.3 | BTS Conformance Tests for REDHOT |  | 651d? | 2006-11-17 A | 2009-05-15 A | 100% |  | 2006-11-17 | 2009-05-15 | 651d? |  | finish no earlier than 2009-05-15 | G1 | 5208h | 5208h | REDHOT-BTStest | Ericsson, Nokia Siemens Networks, Marvell | stefan.g.eriksson@ericsson.com | Rel-7 | Paolo | REDHOT-BTStest |  |
| 3186 | 842.4 | MS Conformance Tests for REDHOT |  | 1176d? | 2006-11-17 A | 2011-05-20 A | 100% |  | 2006-11-17 | 2011-05-20 | 1176d? |  | finish no earlier than 2011-05-20 | G3new | 9408h | 9408h | REDHOT-Mstest | Ericsson, Nokia Siemens Networks, Marvell | stefan.g.eriksson@ericsson.com | Rel-7 | Ingbert | REDHOT-Mstest |  |
| 3187 | 843 | (Small) Technical Enhancements and Improvements for Rel-7 | milestone | 0d? | 2007-03-26 A | 2007-03-26 A | 100% |  | 2007-03-26 | 2007-03-26 | 0d? |  | start no earlier than 2007-03-26 | SP; CP; RP; GP |  |  | TEI7 |  |  | Rel-7 | All | TEI7 |  |
| 3188 | 844 | Test - (Small) Technical Enhancements and Improvements for Rel-7 |  | 389d? | 2006-06-02 A | 2007-11-28 A | 100% |  | 2006-06-02 | 2007-11-28 | 389d? |  | finish no earlier than 2010-06-04 | R5 | 3112h | 3112h | TEI7_Test |  |  | Rel-7 | Ingbert | TEI7_Test |  |
| 3189 | 845 | **Deleted - PS domain and IMS support for IMS Emergency sessions** |  | 63.69d? | 2006-06-23 A | 2006-09-21 | 99% | 0d? | 2006-06-23 | 2006-09-21 | 63.69d? | 0d |  | S2 |  |  | IMS-EMER | Nokia | curt.c.wong@nokia.com | Rel-7 | Maurice | IMS-EMER | SP-30 |
| 3190 | 845.1 | Deleted - IMS aspects to support IMS Emergency sessions | milestone | 0d? | 2006-06-23 A | 2006-09-21 A | 100% |  | 2006-06-23 | 2006-09-21 | 0d? |  | start no earlier than 2006-06-23 | S2 |  |  |  | Nokia | curt.c.wong@nokia.com | Rel-7 | Maurice |  | SP-30 |
| 3191 | 845.2 | Deleted - PS domain aspects to support IMS Emergency sessions | milestone | 0d? | 2006-06-23 A | 2006-09-21 A | 100% |  | 2006-06-23 | 2006-09-21 | 0d? |  | start no earlier than 2006-06-23 | S2 |  |  |  | Nokia | curt.c.wong@nokia.com | Rel-7 | Maurice |  | SP-30 |

Notes:
- 3166: GP#35 completed
- 3167: GP#30 completed / Impacted TSs and TRs: 43.055, 43.064
- 3168: GP#35 completed / Impacted TSs and TRs: 24.008, 44.018, 44.060, 45.001, 45.002, 45.005, 45.008
- 3169: GP#43 completed / Impacted TSs and TRs: 51.010
- 3170: GP#30 completed / Impacted TSs and TRs: 48.001, 48.006, 43.059, 49.031
- 3171: GP#35 completed / Impacted TSs and TRs: 45.001, 45.002, 45.003, 45.005, 45.010, 43.055, 43.064, 44.060, 51.010-1, 51.021
- 3172: GP#35 completed / Impacted TSs and TRs: 45.001, 45.002, 45.003, 45.005, 45.010, 43.055, 43.064, 44.060, 51.010-1, 51.021
- 3173: GP#35 completed / Impacted TSs and TRs: 45.001, 45.002, 45.003, 45.005, 45.010, 43.055, 43.064, 44.060, 51.010-1, 51.021
- 3174: GP#33 completed / Impacted TSs and TRs: 43.318, 44.318, 43.129, 25.306, 24.008, 44.060, 25.331, 51.010
- 3175: GP#39 completed
- 3176: GP#35 completed / Impacted TSs and TRs: 43.055, 43.064
- 3177: GP#37 completed / Impacted TSs and TRs: 45.001, 45.002, 45.003, 45.004, 45.008
- 3178: GP#35 completed / Impacted TSs and TRs: 24.008, 44.018, 44.060
- 3179: GP#39 completed / Impacted TSs and TRs: 45.005
- 3180: GP#43 completed / Impacted TSs and TRs: 51.021
- 3181: GP#50 completed / Impacted TSs and TRs: 51.010
- 3182: GP#38 completed
- 3183: GP#35 completed / Impacted TSs and TRs: 43.055, 43.064
- 3184: GP#38 completed / Impacted TSs and TRs: 24.008, 44.018, 44.060, 45.001, 45.002, 45.003, 45.004, 45.005, 45.008
- 3185: GP#42 completed / Impacted TSs and TRs: 51.021
- 3186: GP#50 completed / Impacted TSs and TRs: 51.010
- 3187: -
- 3188: -
- 3189: Approved at SP#29 / Impacted TSs and TRs: 23.867, 23.abc, 23.060, 23.002, 23.271
- 3190: Approved at SP#29 / Impacted TSs and TRs: 23.867, 23.abc, 23.060, 23.002, 23.271
- 3191: Approved at SP#29 / Impacted TSs and TRs: 23.867, 23.abc, 23.060, 23.002, 23.271

| ID | WBS | Task | Type | Duration | Start | Finish | Complete | Remaining | Baseline start | Baseline finish | Baseline duration | Total slack | Constraint | Resources | Work | Actual work | Acronym | Impacted TSs and TRs | Release | MCC resp | TSG stopped | Acronym_3GU_Export | WI rapporteur name | WI rapporteur e-mail | Special Focus Doc |
| --- | --- | --- | --- | --- | --- | --- | --- | --- | --- | --- | --- | --- | --- | --- | --- | --- | --- | --- | --- | --- | --- | --- | --- | --- | --- |
| 3192 | 16.7 | **Deleted - IMS Local services** |  | 0d? | 2006-01-06 A | 2006-01-06 | 99% | 0d? | 2006-01-06 | 2006-01-06 | 0d? | 0d |  | S2 |  |  | IMSLocal | 23.228 | Rel-7 | Maurice | SP-28 | IMSLocal |  |  |  |
| 3193 | 16.7.1 | Deleted - Stage 2 | milestone | 0d | 2006-01-06 A | 2006-01-06 A | 100% |  | 2006-01-06 | 2006-01-06 | 0d |  | start no earlier than 2006-01-06 | S2 |  |  |  |  | Rel-7 | Maurice | SP-26 |  |  |  |  |
| 3194 | 846.2 | Deleted - Stage 3 for IMS Local services | milestone | 0d? | 2006-01-06 A | 2006-01-06 A | 100% |  | 2006-01-06 | 2006-01-06 | 0d? |  | finish no earlier than 2006-01-06 | C1 |  |  |  |  | Rel-7 | Frederic | SP-25 |  | Lucent | Keith Drage (drage@alcatel-lucent.com) |  |
| 3195 | 847 | Deleted - IMS Phase 3 | milestone | 0d? | 2006-01-06 A | 2006-01-06 A | 100% |  | 2006-01-06 | 2006-01-06 | 0d? |  | start no earlier than 2006-01-06 | S2 |  |  |  |  | Rel-7 | Maurice | SP-25 |  |  |  |  |
| 3196 | 848 | Deleted - Improvements of Radio Interface | milestone | 0d? | 2004-09-15 A | 2004-09-15 A | 100% |  | 2004-09-15 | 2004-09-15 | 0d? |  | start no earlier than 2004-09-15 | RP |  |  |  |  | Rel-7 | Issam | SP-24 |  |  |  |  |
| 3197 | 849 | Deleted: Generic User Profile Phase 2 | milestone | 0d | 2005-08-08 A | 2006-06-30 A | 100% |  | 2005-08-08 | 2006-06-30 | 0d |  |  | C4 |  |  |  |  | Rel-7 | Kimmo | SP-27 |  |  |  |  |
| 3198 | 30.4 | Deleted - Stage 3 - Common objects | milestone | 0d | 2005-08-08 A | 2006-06-30 A | 100% |  | 2005-08-08 | 2006-06-30 | 0d |  | finish no earlier than 2006-06-30 | C4 |  |  |  | 24.241 | Rel-7 | Kimmo | SP-27 |  |  |  |  |
| 3199 | 851 | Release 7 Studies |  | 841d? | 2004-06-28 A | 2007-09-17 A | 100% |  | 2004-06-28 | 2007-09-17 | 841d? |  |  | CP; GP; RP; SP | 26912h | 26912h |  |  | Rel-7 | All |  |  |  |  |  |
| 3200 | 852 | Study on Multimedia Telephony Capabilities for IMS |  | 276d? | 2005-07-11 A | 2006-07-31 A | 100% |  | 2005-07-11 | 2006-07-31 | 276d? |  |  | S1 | 2145.6h | 2145.6h | MITE | 22.973 | Rel-7 | Alain |  | MITE | Ericsson | peter.bleckert@ericsson.com |  |
| 3201 | 853 | Study on Behaviour of Multi system UEs |  | 384d? | 2004-06-28 A | 2005-12-15 A | 100% |  | 2004-06-28 | 2005-12-15 | 384d? |  | start no earlier than 2004-06-28 | S1 | 3072h | 3072h | BMSU | 22.936 | Rel-7 | Alain |  | BMSU | Qualcomm | dwilliams@qualcomm.com |  |
| 3202 | 854 | Study on Combining CS calls and IMS sessions |  | 189d? | 2004-06-28 A | 2005-03-17 A | 100% |  | 2004-06-28 | 2005-03-17 | 189d? |  | start no earlier than 2004-06-28 | S1 | 1512h | 1512h | IRTSD-CS_IMS | 22.979 | Rel-7 | Alain |  | IRTSD-CS_IMS | TeliaSonera | robert.frank@teliasonera.com |  |
| 3203 | 855 | Study on All-IP Network |  | 188d? | 2004-06-28 A | 2005-03-16 A | 100% |  | 2004-06-28 | 2005-03-16 | 188d? |  | start no earlier than 2004-06-28 | S1 | 1504h | 1504h | FS_AIPN | 22.978 | Rel-7 | Alain |  | FS_AIPN | NTT DoCoMo | Shin-ichi Isobe (isobes@nttdocomo.co.jp) |  |
| 3204 | 856 | Study on Videotelephony teleservice |  | 231d? | 2005-03-01 A | 2006-01-17 A | 100% |  | 2005-03-01 | 2006-01-17 | 231d? |  |  | S1 | 1848h | 1848h | VidTel | 22.903 | Rel-7 | Alain |  | VidTel | T-Mobile | michael.kurz@t-mobile.at |  |
| 3205 | 857 | Study on Network Selection Principles |  | 193d? | 2005-03-15 A | 2005-12-08 A | 100% |  | 2005-03-15 | 2005-12-08 | 193d? |  |  | S1 | 1544h | 1544h | NetSel | 22.811 | Rel-7 | Alain |  | NetSel | O2 | chris.friel@O2.com |  |
| 3206 | 858 | Study on Multimedia Priority Service |  | 851d? | 2003-03-28 A | 2006-06-30 A | 100% |  | 2003-03-28 | 2006-06-30 | 851d? |  | finish no earlier than 2005-12-16 | S1 | 6808h | 6808h | PRIOR-MM | 22.953 | Rel-7 | Alain |  | PRIOR-MM | Telcordia | James Garrahan (jgarraha@telcordia.com) | Public Safety (I-A) |
| 3207 | 859 | Study on Transferring of emergency Call data |  | 190d? | 2005-07-11 A | 2006-03-31 A | 100% |  | 2005-07-11 | 2006-03-31 | 190d? |  | finish no earlier than 2005-12-08 | S1 | 1520h | 1520h | eCALL | 22.967 | Rel-7 | Alain |  | eCALL | Motorola | jian.j.wu@motorola.com | Public Safety (I-A) |
| 3208 | 860 | Study on Enhancement of E2E QoS |  | 281.4d? | 2004-06-28 A | 2005-09-15 A | 100% |  | 2004-06-28 | 2005-09-15 | 281.4d? |  | finish no earlier than 2005-12-01 | S2 | 2251.2h | 2251.2h | QoS7 | 23.802 | Rel-7 | Maurice |  | QoS7 | Huawei | Robert Jaksa |  |
| 3209 | 861 | Study on SOAP/HTTP IRP Solution Sets |  | 330d? | 2005-09-02 A | 2006-12-07 A | 100% |  | 2005-09-02 | 2006-12-07 | 330d? |  | finish no earlier than 2006-12-07 | S5 | 2640h | 2640h | OAM7-NIM-XML | 32.809 | Rel-7 | Mirko |  | OAM7-NIM-XML | Nortel | Suzèle Lariven (lariven@nortel.com) |  |
| 3210 | 862 | Study on Itf-N Implementation Conformance Statement (ICS) template |  | 400d? | 2005-09-02 A | 2007-03-15 A | 100% |  | 2005-09-02 | 2007-03-15 | 400d? |  | finish no earlier than 2007-03-15 | S5 | 3200h | 3200h | OAM7-NIM-ICS | 32.812 | Rel-7 | Mirko |  | OAM7-NIM-ICS | China Mobile | Li Yewen (liyewen@chinamobile.com) |  |
| 3211 | 863 | Study on IRP Information Model |  | 400d? | 2005-09-02 A | 2007-03-15 A | 100% |  | 2005-09-02 | 2007-03-15 | 400d? |  | finish no earlier than 2007-03-15 | S5 | 3200h | 3200h | OAM7-NIM-IM | 32.810 | Rel-7 | Mirko |  | OAM7-NIM-IM | Motorola | trevor.pirt@motorola.com |  |
| 3212 | 864 | Study on Bandwidth Saving at Nb Interface with IP transport |  | 261d? | 2006-03-10 A | 2007-03-09 A | 100% |  | 2006-03-10 | 2007-03-09 | 261d? |  | finish no earlier than 2007-03-09 | C3 | 2088h | 2088h | BSNbIP | 29.814 | Rel-7 | Adrian |  | BSNbIP | Siemens | Thomas.Belling@siemens.com |  |
| 3213 | 865 | Study on Routeing of MT-SMS via the HPLMN |  | 301d? | 2005-10-07 A | 2006-12-01 A | 100% |  | 2005-10-07 | 2006-12-01 | 301d? |  | finish no earlier than 2006-12-01 | C4 | 2408h | 2408h | SMS7 | 23.840 | Rel-7 | Kimmo |  | SMS7 | Vodafone | Nick.Russell@vodafone.com |  |
| 3214 | 866 | Feasibility Study on the TCAPsec Gateway concept |  | 96d? | 2005-10-28 A | 2006-03-10 A | 100% |  | 2005-10-28 | 2006-03-10 | 96d? |  | finish no earlier than 2006-03-10 | C4 | 768h | 768h | FS_SEC7-TCAP | 29.800 | Rel-7 | Kimmo |  | FS_SEC7-TCAP | Siemens | Ulrich.wiehe@gksag.de |  |
| 3215 | 867 | Study on using M2PA in 3GPP network |  | 318d? | 2006-03-22 A | 2007-06-08 A | 100% |  | 2006-03-22 | 2007-06-08 | 318d? |  | finish no earlier than 2007-06-08 | C4 | 2544h | 2544h | FS-M2PA | 29.801 | Rel-7 | Kimmo |  | FS-M2PA | China Mobile | zhaoyuyi@chinamobile.com |  |

Notes:
- 3192: -
- 3193: DAB - Not yet required in SA2 as it exists in previous releases
- 3194: -
- 3195: -
- 3196: Stage 2 description of Interim conclusion
- 3197: Created at TSG#27 by A. Sultan because of the move to Rel-7 of "Common Objects".
- 3198: No progress in CN4#26. This have to be moved to Rel-7. It was deleted from WID
- 3199: -
- 3200: Spin-off Feature UID_7038 (MTSI)
- 3201: -
- 3202: -
- 3203: 07/08 Moved to Rel-7 as Study out of stopped Rel-8 Feature UID_31067 All-IP Network (AIPN)
- 3204: -
- 3205: Spin-off Feature Network selection enhancements (NSP-CR) UID_7041
- 3206: Spin-off Feature PRIOR UID_340044
- 3207: -
- 3208: -
- 3209: SP#34 completed
- 3210: SP#35 completed
- 3211: SP#35 completed
- 3212: Moved to FS at CT32 (in line with slides)
- 3213: Previously known as "Study of a SMS Centre for MT SMS"
- 3214: TR 29.800 content moved to TS 29.204 under implementation WI UID_310005 TCAPsec Gateway
- 3215: -

| ID | WBS | Task | Type | Duration | Start | Finish | Complete | Remaining | Baseline start | Baseline finish | Baseline duration | Total slack | Constraint | Resources | Work | Actual work | Acronym | Impacted TSs and TRs | WI rapporteur name | WI rapporteur e-mail | Release | MCC resp | Acronym_3GU_Export | Status Report | Special Focus Doc | TSG stopped |
| --- | --- | --- | --- | --- | --- | --- | --- | --- | --- | --- | --- | --- | --- | --- | --- | --- | --- | --- | --- | --- | --- | --- | --- | --- | --- | --- |
| 3216 | 868 | **Study on Support of (G)MSC-S - (G)MSC-S Nc Interface based on the SIP-I protocol** |  | 350d? | 2006-05-15 A | 2007-09-14 A | 100% |  | 2006-05-15 | 2007-09-14 | 350d? |  |  | C4; C3 | 10600h | 10600h | NcSIP | 29.802 | Vodafone | david.hutton@vodafone.com | Rel-7 | Kimmo | NcSIP |  |  |  |
| 3217 | 868.1 | CT4 aspects of NcSIP |  | 275d? | 2006-05-15 A | 2007-06-01 A | 100% |  | 2006-05-15 | 2007-06-01 | 275d? |  | finish no earlier than 2007-06-01 | C4 | 2200h | 2200h |  | 29.802 | Vodafone | david.hutton@vodafone.com | Rel-7 | Kimmo |  |  |  |  |
| 3218 | 868.2 | CT3 aspects of NcSIP |  | 350d? | 2006-05-15 A | 2007-09-14 A | 100% |  | 2006-05-15 | 2007-09-14 | 350d? |  | finish no earlier than 2007-09-14 | C3 | 2800h | 2800h |  | 29.802 | Ericsson | ragnar.huslende@ericsson.com | Rel-7 | Adrian |  |  |  |  |
| 3219 | 869 | Study on Evolved UTRA and UTRAN |  | 458d? | 2004-12-15 A | 2006-09-15 A | 100% |  | 2004-12-15 | 2006-09-15 | 458d? |  | finish no earlier than 2006-09-15 | RP | 3664h | 3664h | RANFS-Evo | 25.912 | NTT DoCoMo | nakamurata@NTTDOCOMO.CO.JP | Rel-7 | Issam | RANFS-Evo | RP-060472 |  |  |
| 3220 | 870 | Study on Performance Evaluation of the UE behaviour in high speed trains with speeds up to 350 kmph |  | 328d? | 2005-03-15 A | 2006-06-15 A | 100% |  | 2005-03-15 | 2006-06-15 | 328d? |  | finish no earlier than 2006-06-15 | R4 | 2624h | 2624h | RANFS-HSTrains | none | Vodafone | Mike.vogel@vodafone.com,tim.frost@vodafone.com | Rel-7 | Issam | RANFS-HSTrains | RP-060412 |  |  |
| 3221 | 871 | Study on UTRA Tower Mounted Amplifier (FDD) |  | 195d? | 2005-06-15 A | 2006-03-14 A | 100% |  | 2005-06-15 | 2006-03-14 | 195d? |  | finish no earlier than 2006-03-15 | R4 | 1560h | 1560h | RANFS-TMA | 25.818 | Ericsson | Klas.Sjerling@ericsson.com | Rel-7 | Issam | RANFS-TMA | RP-060035 |  |  |
| 3222 | 872 | Study on Continuous connectivity for packet data users |  | 132d? | 2005-03-15 A | 2005-09-14 A | 100% |  | 2005-03-15 | 2005-09-14 | 132d? |  | finish no earlier than 2005-09-15 | R1 | 1056h | 1056h | RANFS-cont-packet | none | Siemens | joerg.gustrau@siemens.com | Rel-7 | Patrick | RANFS-cont-packet | RP-050427 |  |  |
| 3223 | 873 | Study on Improvement of the Multimedia Broadcast Multicast Service (MBMS) in UTRAN |  | 262d? | 2005-12-15 A | 2006-12-15 A | 100% |  | 2005-12-15 | 2006-12-15 | 262d? |  | finish no earlier than 2006-12-15 | R2 | 2096h | 2096h | RANFS-MBMSImp | 25.905 | LG Electronics | leego@lge.com | Rel-7 | Yong-Jun | RANFS-MBMSImp | RP-060692 |  |  |
| 3224 | 874 | Deleted - Study on Performance Improvements in Small Cells using HSDPA/EDCH |  | 131d? | 2005-12-15 A | 2006-06-15 A | 100% |  | 2005-12-15 | 2006-06-15 | 131d? |  | finish no earlier than 2006-06-15 | R1; R4 | 2096h | 2096h | SMALLCELLS | none | Cingular | Marc Grant | Rel-7 | Issam | SMALLCELLS | RP-060263 | Small cell |  |
| 3225 | 875 | Study on Further Improved Performance Requirements for UMTS/HSDPA UE (FDD) |  | 383d? | 2005-12-15 A | 2007-06-04 A | 100% |  | 2005-12-15 | 2007-06-04 | 383d? |  | finish no earlier than 2007-06-04 | R4 | 3064h | 3064h | RANFS-IC | 25.963 | Cingular | Marc Grant | Rel-7 | Issam | RANFS-IC | RP-070499 |  |  |
| 3226 | 876 | Study on Scope of future FDD HSPA Evolution |  | 394d? | 2006-03-15 A | 2007-09-17 A | 100% |  | 2006-03-15 | 2007-09-17 | 394d? |  | finish no earlier than 2007-09-17 | RP | 3152h | 3152h | RANFS-HSPAEvo | 25.999 | Cingular | Don Zelmer (dz1069@att.com) | Rel-7 | Issam | RANFS-HSPAEvo | RP-070533 |  |  |
| 3227 | 877 | Study on Dynamically reconfiguring a FDD UE receiver to reduce power consumption when desired Quality of Service is met | milestone | 0d? | 2007-06-22 A | 2007-06-22 A | 100% |  | 2007-06-22 | 2007-06-22 | 0d? |  |  | R4 |  |  | FSUEPow | 25.906 | Nokia | Chris.callender@nokia.com, tiina.s.koskinen@nokia.com | Rel-7 | Issam | FSUEPow | RP-070534 |  |  |
| 3228 | 878 | Study on Future GERAN Evolution |  | 486d? | 2005-04-08 A | 2007-02-16 A | 100% |  | 2005-04-08 | 2007-02-16 | 486d? |  | finish no earlier than 2007-02-16 | GP | 3888h | 3888h | FGE | 45.912 | Nokia | eddie.riddington@nokia.com | Rel-7 | Paolo | FGE |  |  |  |
| 3229 | 879 | Study on GAN Enhancements | milestone | 0d? | 2007-08-31 A | 2007-08-31 A | 100% |  | 2007-08-31 | 2007-08-31 | 0d? |  | start no earlier than 2007-08-31 | GP |  |  | EGAN | 43.902 | T-Mobile | janne.linkola@t-mobile.com | Rel-7 | Paolo | EGAN |  |  |  |
| 3230 | 880 | Deleted - Study on IMS with real time services deployment |  | 316d? | 2004-06-28 A | 2005-09-12 A | 100% |  | 2004-06-28 | 2005-09-12 | 316d? |  |  | S1 | 2528h | 2528h | IRTSD |  |  |  | Rel-7 | Alain | IRTSD |  |  | SP-30 |
| 3231 | 881 | Deleted - Covered by SI - Personal Network (PN) and Personal Area Network (PAN) | milestone | 0d? | 2005-12-08 A | 2005-12-20 A | 100% |  | 2005-12-08 | 2005-12-20 | 0d? |  | start no earlier than 2005-12-08 | S1 |  |  | PNPAN |  | Vodafone | armin.toepfer@vodafone.com | Rel-7 | Alain | PNPAN |  |  | SP-30 |
| 3232 | 882 | Deleted - Study on Customised Alerting Tone (CAT) Requirements (was duplicated) | milestone | 0d? | 2006-06-30 A | 2006-06-30 A | 100% |  | 2006-06-30 | 2006-06-30 | 0d? |  | start no earlier than 2006-06-30 | S1 |  |  |  |  |  |  | Rel-7 | Alain |  |  |  | SP-31 |
| 3233 | 883 | Deleted - IMS security extensions (covered by UID33027) | milestone | 0d? | 2005-12-08 A | 2005-12-08 A | 100% |  | 2005-12-08 | 2005-12-08 | 0d? |  | start no earlier than 2005-12-08 | S3 |  |  | IMS-SE |  | Ericsson | Bengt.Sahlin@ericsson.com | Rel-7 | Mirko | IMS-SE |  |  | SP-30 |
| 3234 | 884 | **Deleted - Study on applicability of GALILEO for LCS** |  | 0d? | 2005-06-30 A | 2005-06-30 | 99% | 0d? | 2005-06-30 | 2005-06-30 | 0d? | 0d |  | S2 |  |  | Galileo |  |  |  | Rel-7 | Maurice | Galileo |  |  | SP-25 |
| 3235 | 884.1 | Deleted - TR on Stage 2 | milestone | 0d? | 2005-06-30 A | 2005-06-30 A | 100% |  | 2005-06-30 | 2005-06-30 | 0d? |  | finish no earlier than 2005-06-30 | S2 |  |  |  |  |  |  | Rel-7 | Maurice |  |  |  | SP-25 |
| 3236 | 884.2 | Deleted - GERAN review of the TR | milestone | 0d? | 2005-06-30 A | 2005-06-30 A | 100% |  | 2005-06-30 | 2005-06-30 | 0d? |  | start no earlier than 2005-06-30 | GP |  |  |  |  |  |  | Rel-7 | Paolo |  |  |  | SP-26 |
| 3237 | 885 | Deleted - Study on Stage 2 (IMS services using CS bearers) |  | 316d? | 2004-06-28 A | 2005-09-12 A | 100% |  | 2004-06-28 | 2005-09-12 | 316d? |  | finish no earlier than 2005-09-12 | S2 | 2528h | 2528h | IRTSD-IMSCS | 23.899 | Nortel | Mark Watson | Rel-7 | Maurice | IRTSD-IMSCS |  |  | SP-30 |
| 3238 | 886 | **Deleted - VoIMS bearer related enhancements** |  | 0d? | 2006-07-21 A | 2006-07-21 | 99% | 0d? | 2006-07-21 | 2006-07-21 | 0d? | 0d |  | S2 |  |  | VoIMS |  |  |  | Rel-7 | Maurice | VoIMS |  |  | SP-32 |
| 3239 | 886.1 | Deleted - Study on enhancement of radio performance for VoIMS | milestone | 0d? | 2006-07-21 A | 2006-07-21 A | 100% |  | 2006-07-21 | 2006-07-21 | 0d? |  | start no earlier than 2006-07-21 | S2 |  |  |  | 23.807 | Nortel | Laurence Lautier (lautierl@nortel.com) | Rel-7 | Maurice |  |  |  | SP-32 |
| 3240 | 887 | Deleted - Study on IMS enhancements and optimizations for real time communication. |  | 430d? | 2005-10-10 A | 2007-06-01 A | 100% |  | 2005-10-10 | 2007-06-01 | 430d? |  | finish no earlier than 2007-06-01 | S2 | 3440h | 3440h | IMS-RT | 23.818 | Ericsson | stephen.terrill@ericsson.com | Rel-7 | Maurice | IMS-RT |  |  | SP-35 |
| 3241 | 888 | Deleted - Study on Terminating Session handling |  | 255d? | 2006-01-09 A | 2006-12-29 A | 100% |  | 2006-01-09 | 2006-12-29 | 255d? |  | finish no earlier than 2006-12-29 | S2 | 2040h | 2040h | CSIterm | 23.819 | Samsung |  | Rel-7 | Maurice | CSIterm |  |  | SP-32 |
| 3242 | 889 | Deleted eCALLIBMS - Study on Transferring of emergency call data – in-band modem solution (moved to Rel-8) | milestone | 0d? | 2007-06-22 A | 2007-06-22 A | 100% |  | 2007-06-22 | 2007-06-22 | 0d? |  | start no earlier than 2007-06-22 | S4 |  |  |  | 26.967 | Airbiquity | lhong@airbiquity.com | Rel-7 | Paolo |  |  | Public Safety (I-A) | SP-38 |
| 3243 | 890 | Deleted - Study on IRP usage scenarios |  | 330d? | 2005-09-02 A | 2006-12-07 A | 100% |  | 2005-09-02 | 2006-12-07 | 330d? |  | finish no earlier than 2006-12-07 | S5 | 2640h | 2640h | OAM-Study | 32.8xy | Lucent |  | Rel-7 | Mirko | OAM-Study |  |  | SP-32 |
| 3244 | 891 | Deleted - Study on Interference Cancellation for UTRA FDD UE (covered by UID 20053) |  | 1d? | 2007-03-28 A | 2007-03-28 A | 100% |  | 2007-03-28 | 2007-03-28 | 1d? |  | start no earlier than 2007-03-28 | R4 | 8h | 8h | RANFS-InterfCanc |  |  |  | Rel-7 | Issam | RANFS-InterfCanc |  |  | SP-38 |
| 3245 | 892 | Deleted - Study on enhanced support of Video Telephony | milestone | 0d? | 2006-06-30 A | 2006-06-30 A | 100% |  | 2006-06-30 | 2006-06-30 | 0d? |  | start no earlier than 2006-06-30 | GP |  |  | VIDGER |  | Ericsson | stefan.g.eriksson@ericsson.com | Rel-7 | Paolo | VIDGER |  |  | SP-32 |
| 3246 | 893 | Release 6 Features |  | 915d? | 2002-06-28 A | 2005-12-30 A | 100% |  | 2002-06-28 | 2005-12-30 | 915d? |  |  | NP; GP; RP; SP; TP | 36600h | 36600h |  |  |  |  | Rel-6 | All |  |  |  |  |

Notes:
- 3216: -
- 3217: -
- 3218: -
- 3219: RP#33 (Sep 2006) completed. SR in RP-060472
- 3220: RP#32 (Jun 2006) completed. SR in RP-060412
- 3221: RP#31 (Mar 2006) completed. SR in RP-060035
- 3222: RP#29 (Sep 2006) completed. SR in RP-050427
- 3223: RP#34 completed
- 3224: RP#32 (Jun 2006) stopped at 0% completion
- 3225: RP#36 (May 2007) completed. SR in RP-070499
- 3226: RP#37 (Sep 2007) completed. SR in RP-070533
- 3227: RP#37 (Sep 2007) completed. SR in RP-070534
- 3228: GP#33 completed
- 3229: GP#35 completed
- 3230: -
- 3231: -
- 3232: Awaiting MCC SA3 input
- 3233: -
- 3234: -
- 3235: -
- 3236: -
- 3237: SP-30: S2 has no intention for TR completion
- 3238: Created by MCC to group all VoIMS related items, after consultation of chairs
- 3239: WID approved SP#28. SA2#52 stopped
- 3240: abandoned at 65%
- 3241: SP#32 Jun 2006 Study abandoned => spin-off Implementation work UID_320029
- 3242: SP-38 stopped
- 3243: -
- 3244: Deleted. Same as FS on Further Improved Performance Requirements for UMTS/HSDPA UE (FDD)
- 3245: FS CLOSED at G#28 (no input)
- 3246: -

| ID | WBS | Task | Type | Duration | Start | Finish | Complete | Baseline start | Baseline finish | Baseline duration | Constraint | Resources | Work | Actual work | Release | Acronym | WI rapporteur name | WI rapporteur e-mail | MCC resp | Acronym_3GU_Export | Impacted TSs and TRs | Created at | TSG stopped |
| --- | --- | --- | --- | --- | --- | --- | --- | --- | --- | --- | --- | --- | --- | --- | --- | --- | --- | --- | --- | --- | --- | --- | --- |
| 3247 | 8 | **Rel-6 Improvements of Radio Interface** |  | 1645d? | 2000-08-14 A | 2006-12-01 A | 100% | 2000-08-14 | 2006-12-01 | 1645d? |  | R2; R4; R5 | 87632h | 87632h | Rel-6 |  |  |  |  |  |  |  |  |
| 3248 | 894.1 | Improved support of IMS Realtime Services using HSDPA/EDCH |  | 197d? | 2005-03-15 A | 2005-12-14 A | 100% | 2005-03-15 | 2005-12-14 | 197d? | finish no earlier than 2005-12-14 | R2 | 1576h | 1576h | Rel-6 | RInImp-IMSRealTime | Cingular | Don Zelmer (dz1069@att.com) | Yong-Jun | RInImp-IMSRealTime |  |  |  |
| 3249 | 894.2 | Improving Receiver Performance Requirements for the FDD UE |  | 401d | 2002-03-08 A | 2003-09-19 A | 100% | 2002-03-08 | 2003-09-19 | 401d | start no earlier than 2002-03-08 | R4 | 3208h | 3208h | Rel-6 | RInImp-UERecPerf | Intel | shimon.moshavi@INTEL.COM | Issam | RInImp-UERecPerf | 25.101 |  |  |
| 3250 | 8.2 | **Base station classification for FDD** |  | 603d | 2000-08-14 A | 2002-12-04 A | 100% | 2000-08-14 | 2002-12-04 | 603d |  | R4 | 9648h | 9648h | Rel-6 | RInImp-BSClass-FDD |  |  | Issam | RInImp-BSClass-FDD |  |  |  |
| 3251 | 8.2.1 | FDD Base station classification |  | 603d | 2000-08-14 A | 2002-12-04 A | 100% | 2000-08-14 | 2002-12-04 | 603d | finish no earlier than 2002-12-04 | R4 | 4824h | 4824h | Rel-6 |  | Nokia | antti.toskala@nokia.com | Issam |  | 25.104, 25.141 |  |  |
| 3252 | 894.4 | UMTS-850 |  | 266d | 2002-12-06 A | 2003-12-12 A | 100% | 2002-12-06 | 2003-12-12 | 266d | finish no earlier than 2003-12-15 | R4 | 2128h | 2128h | Rel-6 | RInImp-UMTS850 | Cingular | Don Zelmer (dz1069@att.com) | Issam | RInImp-UMTS850 | 25.101, 25.104, 25.133, 25.141, 25.307, 25.331, 25.942 |  |  |
| 3253 | 894.5 | DS-CDMA introduction in the 800 MHz band |  | 196d | 2003-03-14 A | 2003-12-12 A | 100% | 2003-03-14 | 2003-12-12 | 196d | finish no earlier than 2003-12-15 | R4 | 1568h | 1568h | Rel-6 | RInImp-UMTS800 | NTT DoCoMo | Takehiro Nakamura (nakamurata@nttdocomo.co.jp) | Issam | RInImp-UMTS800 | 25.101, 25.104, 25.133, 25.141, 25.307, 25.331 |  |  |
| 3254 | 894.6 | UMTS 1.7/2.1 GHz | milestone | 0d? | 2003-03-14 A | 2003-03-14 A | 100% | 2003-03-14 | 2003-03-14 | 0d? |  | R4 |  |  | Rel-6 | RInImp-UMTS1721 | Nokia | jussi.numminen@NOKIA.COM | Issam | RInImp-UMTS1721 | 25.101, 25.104, 25.133, 25.141, 25.307, 25.331 |  |  |
| 3255 | 894.7 | Conformance Test Aspects – UMTS 1.7/2.1 GHz Band |  | 191d? | 2006-03-10 A | 2006-12-01 A | 100% | 2006-03-10 | 2006-12-01 | 191d? | finish no earlier than 2006-12-01 | R5 | 1528h | 1528h | Rel-6 | RInImp-UMTS1721_Test | Motorola | carolyn.taylor@motorola.com | Ingbert | RInImp-UMTS1721_Test | TS34.121, TS34.108 |  |  |
| 3256 | 894.8 | **Improved Receiver Performance Requirements for HSDPA** |  | 711d | 2003-09-19 A | 2006-06-09 A | 100% | 2003-09-19 | 2006-06-09 | 711d |  | R4; R5 | 28496h | 28496h | Rel-6 | RInImp-HSPerf | Nokia | jussi.numminen@NOKIA.COM | Issam | RInImp-HSPerf |  |  |  |
| 3257 | 894.8.1 | Improved Minimum Performance Requirements for HSDPA UE categories 7 and 8 |  | 453d | 2004-09-15 A | 2006-06-09 A | 100% | 2004-09-15 | 2006-06-09 | 453d |  | R4 | 3624h | 3624h | Rel-6 | RInImp-HSPerf-10code | Nokia | jussi.numminen@nokia.com | Issam | RInImp-HSPerf-10code | 25.101 |  |  |
| 3258 | 894.8.2 | Testing of Improved Minimum Performance for HSDPA |  | 650d | 2003-09-19 A | 2006-03-16 A | 100% | 2003-09-19 | 2006-03-16 | 650d | finish no earlier than 2006-03-16 | R5 | 5200h | 5200h | Rel-6 | RInImp-HSPerf-10Code_Test | Motorola | carolyn.taylor@motorola.com | Ingbert | RInImp-HSPerf-10Code_Test | 34.108, 34.121, 34.122, 34.123-1, 34.123-2, 34.123-3 | 19/9/2003 |  |
| 3259 | 894.8.3 | Performance Requirements of Receive Diversity for HSDPA |  | 387d | 2003-12-15 A | 2005-06-07 A | 100% | 2003-12-15 | 2005-06-07 | 387d |  | R4 | 3096h | 3096h | Rel-6 | RInImp-HSPerf-RxDiv | NTT DoCoMo | Takehiro Nakamura (nakamurata@nttdocomo.co.jp) | Issam | RInImp-HSPerf-RxDiv | 25.101 |  |  |
| 3260 | 894.8.4 | Testing of Performance of Receiver diversity for HSDPA |  | 650d | 2003-09-19 A | 2006-03-16 A | 100% | 2003-09-19 | 2006-03-16 | 650d | finish no earlier than 2006-03-16 | R5 | 5200h | 5200h | Rel-6 | RInImp-HSPerf-RxDiv_Test | Motorola | carolyn.taylor@motorola.com | Ingbert | RInImp-HSPerf-RxDiv_Test | 34.108, 34.121, 34.122, 34.123-1, 34.123-2, 34.123-3 | 19/9/2003 |  |
| 3261 | 895 | **Rel-6 RAN Feasibility Studies** |  | 1196d? | 2000-08-14 A | 2005-03-14 A | 100% | 2000-08-14 | 2005-03-14 | 1196d? |  | RP | 43048h | 43048h | Rel-6 |  |  |  |  |  |  |  |  |
| 3262 | 895.1 | FS of the improved access to UE measurement data for CRNC to support TDD RRM |  | 270d? | 2002-12-06 A | 2003-12-18 A | 100% | 2002-12-06 | 2003-12-18 | 270d? | finish no earlier than 2003-09-19 | R3 | 2160h | 2160h | Rel-6 | RANimp-RRMopt-FSUEMsD | Interdigital | jim.miller@interdigital.com | Juha | RANimp-RRMopt-FSUEMsD | 25.801, 25.423 | SP-24 |  |
| 3263 | 895.2 | FS on Radio link performance enhancements |  | 1067d | 2000-08-14 A | 2004-09-14 A | 100% | 2000-08-14 | 2004-09-14 | 1067d | finish no earlier than 2004-09-14 | R1 | 8536h | 8536h | Rel-6 | RInImp-Rlperf | Nokia | antti.toskala@nokia.com | Patrick | RInImp-Rlperf | 25.899 |  |  |
| 3264 | 895.3 | FS on Improvement of inter-frequency and inter-system measurements for 1.28 Mcps TDD |  | 461d | 2001-12-14 A | 2003-09-19 A | 100% | 2001-12-14 | 2003-09-19 | 461d | start no earlier than 2001-12-14 | R1 | 3688h | 3688h | Rel-6 | RInImp-IfIsMLCR | Samsung | Li Xiao Qiang (xqli@samsung.co.kr) | Patrick | RInImp-IfIsMLCR | 25.888 |  |  |
| 3265 | 895.4 | FS for the analysis of OFDM for UTRAN enhancement |  | 526d | 2002-06-10 A | 2004-06-14 A | 100% | 2002-06-10 | 2004-06-14 | 526d | start no earlier than 2002-06-10 | R1 | 4208h | 4208h | Rel-6 | RInImp-FSOFDM | Nortel | Sarah Boumendil | Patrick | RInImp-FSOFDM | 25.892 |  |  |
| 3266 | 895.5 | FS on Uplink Enhancements for Dedicated Transport Channels |  | 396d | 2002-09-06 A | 2004-03-12 A | 100% | 2002-09-06 | 2004-03-12 | 396d | finish no earlier than 2004-03-12 | R1 | 3168h | 3168h | Rel-6 | RInImp-FSUpDTrCh | Nokia | Karri.Ranta-aho@nsn.com | Patrick | RInImp-FSUpDTrCh | 25.896 |  |  |
| 3267 | 895.6 | FS on Analysis on Higher Chip Rates for UTRA TDD evolutions |  | 528d | 2002-09-06 A | 2004-09-14 A | 100% | 2002-09-06 | 2004-09-14 | 528d | finish no earlier than 2004-09-14 | R1 | 4224h | 4224h | Rel-6 | RInImp-FSVHCRTDD | IPWireless | mbeale@ipwireless.com | Patrick | RInImp-FSVHCRTDD | 25.895 |  |  |
| 3268 | 895.7 | FS on Low Output Powers for general purpose FDD BSs |  | 128d | 2003-06-13 A | 2004-03-12 A | 100% | 2003-06-13 | 2004-03-12 | 128d | finish no earlier than 2004-03-12 | R3 | 1024h | 1024h | Rel-6 | RInImp-FSLoPw | Telefónica | Ana Burgos (burgos_a@tsm.es) | Juha | RInImp-FSLoPw | 25.807 |  |  |
| 3269 | 895.8 | FS on Uplink enhancements for UTRA TDD |  | 462d | 2003-06-06 A | 2005-03-14 A | 100% | 2003-06-06 | 2005-03-14 | 462d | finish no earlier than 2005-03-14 | R1 | 3696h | 3696h | Rel-6 | RInImp-FSUpEnhTDD | Interdigital | Marian.Rudolf@InterDigital.com | Patrick | RInImp-FSUpEnhTDD | 25.804 |  |  |
| 3270 | 8.8 | FS on UE antenna efficiency test methods performance requirements (2) |  | 131d | 2002-03-08 A | 2002-09-06 A | 100% | 2002-03-08 | 2002-09-06 | 131d | finish no earlier than 2002-09-06 | R4 | 1048h | 1048h | Rel-6 | RInImp-UEAnTM2 | Allgon | Alf Ahlström (alf.ahlstrom@pwav.com) | Issam | RInImp-UEAnTM2 |  |  |  |
| 3271 | 9.4 | Deleted - FS on the evolution of the UTRAN architecture |  | 592d | 2002-09-09 A | 2004-12-14 A | 100% | 2002-09-09 | 2004-12-14 | 592d | finish no earlier than 2004-12-15 | R3 | 4736h | 4736h | Rel-6 | RANimp-FSEvo | Nokia | woonhee.hwang@nsn.com, Antti.Toskala@nokia.com | Juha | RANimp-FSEvo |  |  | RP-26 |

Notes:
- 3247: -
- 3248: -
- 3249: -
- 3250: -
- 3251: -
- 3252: Introduction of UMTS850 (Band V) in 25.307
- 3253: Introduction of UMTS800 in 25.307
- 3254: Introduction of UMTS1700/2100 (Band IV)
- 3255: -
- 3256: -
- 3257: Approved at RP#25 as RP-040375
- 3258: -
- 3259: -
- 3260: -
- 3261: -
- 3262: -
- 3263: Study finished at RP#25
- 3264: -
- 3265: -
- 3266: -
- 3267: Study finished at RP#25
- 3268: -
- 3269: -
- 3270: The RInImp-UEAnTM FS was re-opened at TSG RP#15 upon request from WG4
- 3271: Study Closed, work will continue within the FS on evolved UTRA and UTRAN

| ID | WBS | Task | Type | Duration | Start | Finish | Complete | Baseline start | Baseline finish | Baseline duration | Constraint | Deadline | Resources | Work | Actual work | Acronym | WI rapporteur name | WI rapporteur e-mail | Release | MCC resp | Acronym_3GU_Export | Impacted TSs and TRs | Created at | TSG stopped |
| --- | --- | --- | --- | --- | --- | --- | --- | --- | --- | --- | --- | --- | --- | --- | --- | --- | --- | --- | --- | --- | --- | --- | --- | --- |
| 3272 | 896 | **FDD Enhanced Uplink** |  | 915d | 2004-03-15 A | 2007-09-14 A | 100% | 2004-03-15 | 2007-09-14 | 915d |  |  | R2; R1; R3; R4; R5 | 49800h | 49800h | EDCH | Ericsson | Joakim Bergström | Rel-6 | Yong-Jun | EDCH |  |  |  |
| 3273 | 896.1 | FDD Enhanced Uplink - Stage 2 |  | 197d | 2004-03-15 A | 2004-12-14 A | 100% | 2004-03-15 | 2004-12-14 | 197d | finish no earlier than 2004-12-14 |  | R2 | 1576h | 1576h | EDCH-Stage2 |  |  | Rel-6 | Yong-Jun | EDCH-Stage2 | 25.309 |  |  |
| 3274 | 896.2 | FDD Enhanced Uplink - Physical Layer |  | 261d | 2004-03-15 A | 2005-03-14 A | 100% | 2004-03-15 | 2005-03-14 | 261d | finish no earlier than 2005-03-14 |  | R1 | 2088h | 2088h | EDCH-Phys | Nokia | Karri.Ranta-aho@nsn.com | Rel-6 | Patrick | EDCH-Phys | 25.211, 25.212, 25.213, 25.214, 25.215 |  |  |
| 3275 | 896.3 | FDD Enhanced Uplink - Layer 2 and 3 Protocol Aspects |  | 261d | 2004-03-15 A | 2005-03-14 A | 100% | 2004-03-15 | 2005-03-14 | 261d | finish no earlier than 2005-03-14 |  | R2 | 2088h | 2088h | EDCH-L23 | Ericsson | Joakim Bergström | Rel-6 | Yong-Jun | EDCH-L23 | 25.301, 25.302, 25.306, 25.321, 25.331 |  |  |
| 3276 | 896.4 | FDD Enhanced Uplink - UTRAN Iub/Iur Protocol Aspects |  | 261d | 2004-03-15 A | 2005-03-14 A | 100% | 2004-03-15 | 2005-03-14 | 261d | finish no earlier than 2005-03-14 |  | R3 | 2088h | 2088h | EDCH-IurIub | Nortel | Saso Stojanovski | Rel-6 | Juha | EDCH-IurIub | 25.401, 25.420, 25.423, 25.430, 25.433 |  |  |
| 3277 | 896.5 | FDD Enhanced Uplink - RF Radio Transmission/ Reception, System Performance Requirements and Conformance Testing |  | 74d | 2004-03-15 A | 2004-06-24 A | 100% | 2004-03-15 | 2004-06-24 | 74d |  |  | R4 | 592h | 592h | EDCH-RF | Ericsson | thomas.unshelm@ericsson.com | Rel-6 | Issam | EDCH-RF | 25.101, 25.104, 25.133, 25.141 |  |  |
| 3278 | 896.6 | Conformance Test Aspects – FDD Enhanced Uplink |  | 596d | 2005-06-03 A | 2007-09-14 A | 100% | 2005-06-03 | 2007-09-14 | 596d | finish no earlier than 2007-09-14 | 2006-06-02 | R5 | 4768h | 4768h | EDCH_Test | Ericsson | Leif.Mattisson@ericsson.com | Rel-6 | Ingbert | EDCH_Test | 34.108, 34.109, 34.121, 34.123-1, 34.123-2, 34.123-3 | Fri 03/06/05 |  |
| 3279 | 897 | **Rel-6 RAN improvements** |  | 656d? | 2002-09-09 A | 2005-03-14 A | 100% | 2002-09-09 | 2005-03-14 | 656d? |  |  | RP; S5 | 36720h | 36720h |  |  |  | Rel-6 |  |  |  |  |  |
| 3280 | 9.2 | **RAB support enhancement** |  | 522d? | 2003-03-14 A | 2005-03-14 A | 100% | 2003-03-14 | 2005-03-14 | 522d? |  |  | R2 | 9360h | 9360h |  | Nokia | Jussi Kähtävä (juha.mikola@nokia.com) | Rel-6 | Yong-Jun |  | 25.862 |  |  |
| 3281 | 897.1.1 | Optimization of downlink channelisation code utilisation |  | 262d | 2004-03-12 A | 2005-03-14 A | 100% | 2004-03-12 | 2005-03-14 | 262d | finish no earlier than 2005-03-14 |  | R1 | 2096h | 2096h | RANimp-RABSE-CodeOptFDD | Nortel | Sarah Boumendil | Rel-6 | Patrick | RANimp-RABSE-CodeOptFDD |  |  |  |
| 3282 | 897.1.2 | optimization of channelisation code utilisation for 3.84 Mcps TDD |  | 261d | 2004-03-15 A | 2005-03-14 A | 100% | 2004-03-15 | 2005-03-14 | 261d | finish no earlier than 2005-03-15 |  | R1 | 2088h | 2088h | RANimp-RABSE-CodOptTDD | IPWireless | Nicholas Anderson | Rel-6 | Patrick | RANimp-RABSE-CodOptTDD |  |  |  |
| 3283 | 897.1.3 | HS-DPCCH ACK/NACK Enhancement |  | 65d? | 2004-09-15 A | 2004-12-14 A | 100% | 2004-09-15 | 2004-12-14 | 65d? | finish no earlier than 2004-12-15 |  | R1 | 520h | 520h | RANimp-RABSE-ACKNACK | Nokia | Jussi Kähtävä (juha.mikola@nokia.com) | Rel-6 | Patrick | RANimp-RABSE-ACKNACK | 25.212, 25.214, 24.331, 25.433 |  |  |
| 3284 | 897.1.4 | Deleted - Iu enhancements for IMS support in RAN |  | 320d? | 2003-03-14 A | 2004-06-03 A | 100% | 2003-03-14 | 2004-06-03 | 320d? | start no earlier than 2003-03-14 |  | R3 | 2560h | 2560h | RANimp-RABSE-IuEnhIMS | Nortel | Philippe.Godin@nortelnetworks.com | Rel-6 | Juha | RANimp-RABSE-IuEnhIMS |  |  | RP-24 |
| 3285 | 897.1.5 | Deleted - Improvement of RRM across RNS and RNS/BSS | milestone | 0d? | 2003-12-05 A | 2003-12-05 A | 100% | 2003-12-05 | 2003-12-05 | 0d? | finish no earlier than 2003-12-05 |  | R3 |  |  | RANimp-RRM1 | Nokia | antti.toskala@nokia.com | Rel-6 | Juha | RANimp-RRM1 |  |  | RP-23 |
| 3286 | 9.1 | Beamforming Enhancements |  | 66d | 2003-09-19 A | 2003-12-19 A | 100% | 2003-09-19 | 2003-12-19 | 66d | finish no earlier than 2004-03-12 |  | R1 | 528h | 528h | RANimp-BFE | Nokia | Jussi Kähtävä (juha.mikola@nokia.com) | Rel-6 | Patrick | RANimp-BFE | 24.215, 25.423, 25.425, 25.433, 25.435 |  |  |
| 3287 | 897.3 | **Rel-6 RRM optimization for Iur and Iub** |  | 126d | 2003-09-19 A | 2004-03-12 A | 100% | 2003-09-19 | 2004-03-12 | 126d |  |  | R3 | 2016h | 2016h | RANimp-RRMopt-UEMsD | Ericsson | Gert-Jan.van.Lieshout@eln.ericsson.se | Rel-6 | Juha | RANimp-RRMopt-UEMsD |  |  |  |
| 3288 | 897.3.1 | Improved access to UE measurement data for CRNC to support TDD RRM |  | 126d | 2003-09-19 A | 2004-03-12 A | 100% | 2003-09-19 | 2004-03-12 | 126d | finish no earlier than 2004-03-15 |  | R3 | 1008h | 1008h |  | Interdigital | jim.miller@interdigital.com | Rel-6 | Juha |  | 25.423 |  | RP-22 |
| 3289 | 897.4 | **Remote Control of Electrical Tilting Antennas** |  | 395d? | 2003-03-14 A | 2004-09-16 A | 100% | 2003-03-14 | 2004-09-16 | 395d? |  |  | R3; S5 | 10624h | 10624h | RANimp-TiltAnt | Vodafone | Andreas.Hauser@vodafone.com | Rel-6 | Juha | RANimp-TiltAnt |  |  |  |
| 3290 | 897.4.1 | Tilting Antenna - RAN aspects |  | 393d? | 2003-03-14 A | 2004-09-14 A | 100% | 2003-03-14 | 2004-09-14 | 393d? | finish no earlier than 2004-09-14 |  | R3 | 3144h | 3144h |  | Vodafone | Andreas.Hauser@vodafone.com | Rel-6 | Juha |  | 25.460, 25.461, 25.462, 25.463 |  |  |
| 3291 | 897.4.2 | OAM&P impacts |  | 145d | 2004-02-27 A | 2004-09-16 A | 100% | 2004-02-27 | 2004-09-16 | 145d | finish no earlier than 2004-09-16 |  | S5 | 1160h | 1160h | RANimp-TiltAnt-OAM | Vodafone | Adrian.Neal@vodafone.com | Rel-6 | Mirko | RANimp-TiltAnt-OAM | 32.804, 32.64x | SP-24 |  |
| 3292 | 897.5 | Network Assisted Cell Change (NACC) from UTRAN to GERAN - network-side aspects |  | 462d? | 2002-09-09 A | 2004-06-15 A | 100% | 2002-09-09 | 2004-06-15 | 462d? | finish no earlier than 2004-06-15 |  | R3 | 3696h | 3696h | RANimp-NACC | Vodafone | Brendan.McWilliams@gb.vodafone.co.uk | Rel-6 | Juha | RANimp-NACC |  |  |  |
| 3293 | 12 | **Location Services enhancements 2** |  | 1024d? | 2001-01-15 A | 2004-12-16 A | 100% | 2001-01-15 | 2004-12-16 | 1024d? |  |  | S2; S5; N4; R2; R4; R5; OMA | 175184h | 175184h | LCS2 | Nokia | Jan Kåll | Rel-6 | Maurice | LCS2 |  |  |  |
| 3294 | 12.1 | **Improvement on Le interface** |  | 653d? | 2002-06-17 A | 2004-12-15 A | 100% | 2002-06-17 | 2004-12-15 | 653d? |  |  | S2; OMA | 15096h | 15096h |  | Nokia | Jan Kåll | Rel-6 | Maurice |  |  |  |  |
| 3295 | 898.1.1 | Stage 2 for Improvement on Le interface |  | 331d? | 2002-06-17 A | 2003-09-22 A | 100% | 2002-06-17 | 2003-09-22 | 331d? | start no earlier than 2002-06-17 |  | S2 | 2648h | 2648h |  | Nokia | Jan Kåll | Rel-6 | Maurice |  | 23.002,23.271 |  |  |
| 3296 | 898.1.2 | Stage 3 - impacts MLP (Mobile Location Protocol) |  | 250d? | 2004-01-01 A | 2004-12-15 A | 100% | 2004-01-01 | 2004-12-15 | 250d? | finish no earlier than 2004-12-15 |  | OMA | 2000h | 2000h |  | OMA | OMA-LIAISON@mail.openmobilealliance.org | Rel-6 |  |  |  |  |  |

Notes:
- 3272: -
- 3273: -
- 3274: -
- 3275: -
- 3276: -
- 3277: -
- 3278: -
- 3279: Generic feature
- 3280: building block without particular end date
- 3281: -
- 3282: WIDS modified in RP#26, RP-040551
- 3283: Approved at RP#25 as RP-040390
- 3284: Closed RP#24 due to the lack of progress
- 3285: abandoned RP-23
- 3286: -
- 3287: -
- 3288: -
- 3289: -
- 3290: Finished at RP#25
- 3291: SP#25 09/2004 completed
- 3292: -
- 3293: -
- 3294: -
- 3295: -
- 3296: -

| ID | WBS | Task | Type | Duration | Start | Finish | Complete | Baseline start | Baseline finish | Baseline duration | Constraint | Resources | Work | Actual work | WI rapporteur name | WI rapporteur e-mail | Release | MCC resp | Acronym | Acronym_3GU_Export | TSG stopped |
| --- | --- | --- | --- | --- | --- | --- | --- | --- | --- | --- | --- | --- | --- | --- | --- | --- | --- | --- | --- | --- | --- |
| 3297 | 12.2 | **Enhanced support for anonymity and user privacy** |  | 638d? | 2002-07-08 A | 2004-12-15 A | 100% | 2002-07-08 | 2004-12-15 | 638d? |  | S2; OMA | 14248h | 14248h | Nokia | Jan Kåll | Rel-6 | Maurice |  |  |  |
| 3298 | 898.2.1 | Stage 2 for Enhanced support for anonymity and user privacy |  | 255d? | 2002-07-08 A | 2003-06-27 A | 100% | 2002-07-08 | 2003-06-27 | 255d? | finish no earlier than 2003-06-27 | S2 | 2040h | 2040h | Nokia | Jan Kåll | Rel-6 | Maurice |  |  |  |
| 3299 | 898.2.2 | Stage 3 - impacts MLP and RLP |  | 250d? | 2004-01-01 A | 2004-12-15 A | 100% | 2004-01-01 | 2004-12-15 | 250d? | finish no earlier than 2004-12-15 | OMA | 2000h | 2000h | OMA | OMA-LIAISON@mail.openmobilealliance.org | Rel-6 |  |  |  |  |
| 3300 | 12.3 | **Enhanced inter-GMLC interface** |  | 648d? | 2002-06-24 A | 2004-12-15 A | 100% | 2002-06-24 | 2004-12-15 | 648d? |  | S2; OMA | 14888h | 14888h | Nokia | Jan Kåll | Rel-6 | Maurice |  |  |  |
| 3301 | 898.3.1 | Stage 2 for Enhanced inter-GMLC interface |  | 315d? | 2002-06-24 A | 2003-09-05 A | 100% | 2002-06-24 | 2003-09-05 | 315d? | finish no earlier than 2003-09-05 | S2 | 2520h | 2520h | Nokia | Jan Kåll | Rel-6 | Maurice |  |  |  |
| 3302 | 898.3.2 | Stage 3 - definition of RLP and PCP |  | 250d? | 2004-01-01 A | 2004-12-15 A | 100% | 2004-01-01 | 2004-12-15 | 250d? | finish no earlier than 2004-12-15 | OMA | 2000h | 2000h | OMA | OMA-LIAISON@mail.openmobilealliance.org | Rel-6 |  |  |  |  |
| 3303 | 12.4 | **Location Services support for IMS public identities** |  | 473d? | 2003-02-24 A | 2004-12-15 A | 100% | 2003-02-24 | 2004-12-15 | 473d? |  | S2; OMA | 11488h | 11488h | Nokia | Jan Kåll | Rel-6 | Maurice |  |  |  |
| 3304 | 898.4.1 | Stage 2 for Location Services support for IMS public identities |  | 240d? | 2003-02-24 A | 2004-01-23 A | 100% | 2003-02-24 | 2004-01-23 | 240d? | finish no earlier than 2004-01-23 | S2 | 1920h | 1920h | Nokia | Jan Kåll | Rel-6 | Maurice |  |  |  |
| 3305 | 898.4.2 | OMA Stage 3 for Location Services support for IMS public identities - impacts MLP, RLP and PCP |  | 250d? | 2004-01-01 A | 2004-12-15 A | 100% | 2004-01-01 | 2004-12-15 | 250d? | finish no earlier than 2004-12-15 | OMA | 2000h | 2000h | OMA | OMA-LIAISON@mail.openmobilealliance.org | Rel-6 |  |  |  |  |
| 3306 | 12.5 | **New area event for location service triggering reports** |  | 663d? | 2002-06-03 A | 2004-12-15 A | 100% | 2002-06-03 | 2004-12-15 | 663d? |  | S2; N4; OMA | 22024h | 22024h | Nokia | Jan Kåll | Rel-6 | Maurice |  |  |  |
| 3307 | 898.5.1 | Stage 2 for New area event for location service triggering reports |  | 280d? | 2002-06-03 A | 2003-06-27 A | 100% | 2002-06-03 | 2003-06-27 | 280d? | finish no earlier than 2003-06-27 | S2 | 2240h | 2240h | Nokia | Jan Kåll | Rel-6 | Maurice |  |  |  |
| 3308 | 898.5.2 | Stage 3 for UE-CN signalling |  | 234d? | 2003-10-09 A | 2004-08-31 A | 100% | 2003-10-09 | 2004-08-31 | 234d? | start no earlier than 2003-10-09 | N4 | 1872h | 1872h | Nokia |  | Rel-6 | Kimmo |  |  |  |
| 3309 | 898.5.3 | Stage 3 for New area event for location service triggering reports - impacts MLP, RLP and PCP |  | 250d? | 2004-01-01 A | 2004-12-15 A | 100% | 2004-01-01 | 2004-12-15 | 250d? | finish no earlier than 2004-12-15 | OMA | 2000h | 2000h | OMA | OMA-LIAISON@mail.openmobilealliance.org | Rel-6 |  |  |  |  |
| 3310 | 12.7 | **UE positioning for Location Services enhancements 2** |  | 957d? | 2001-01-15 A | 2004-09-14 A | 100% | 2001-01-15 | 2004-09-14 | 957d? |  | R2; R4; R5 | 36456h | 36456h |  |  | Rel-6 | Issam | LCS2-UEpos | LCS2-UEpos |  |
| 3311 | 12.8 | Open SMLC-SRNC Interface within the UTRAN to support UTRAN Rel-4 positioning methods |  | 700d? | 2001-01-15 A | 2003-09-19 A | 100% | 2001-01-15 | 2003-09-19 | 700d? | finish no earlier than 2003-09-19 | R2 | 5600h | 5600h | Siemens | Meik.Kottkamp@siemens.com | Rel-6 | Yong-Jun | LCS-Rel4Pos | LCS-Rel4Pos |  |
| 3312 | 898.6.2 | A-GPS minimum performance specification |  | 333d? | 2003-06-06 A | 2004-09-14 A | 100% | 2003-06-06 | 2004-09-14 | 333d? | finish no earlier than 2004-09-14 | R4; R5 | 5328h | 5328h | AT&T Wireless | donglin.shen@attws.com | Rel-6 | Issam | LCS-UEPos-AGPSPerf | LCS-UEPos-AGPSPerf |  |
| 3313 | 12.7.2 | Deleted - FS on Enhancements to OTDOA Positioning using advanced blanking methods |  | 320d | 2002-07-01 A | 2003-09-19 A | 100% | 2002-07-01 | 2003-09-19 | 320d | finish no earlier than 2003-09-19 | R2 | 2560h | 2560h | Cambridge Positioning Systems | david.bartlett@cursor-system.com | Rel-6 | Yong-Jun | LCS2-UEpos-FSBlank | LCS2-UEpos-FSBlank | RP-38 |
| 3314 | 898.6.4 | Deleted - UE positioning enhancements - other methods | milestone | 0d? | 2003-09-26 A | 2003-09-26 A | 100% | 2003-09-26 | 2003-09-26 | 0d? | finish no earlier than 2003-09-26 | R2 |  |  | Siemens | Meik.Kottkamp@siemens.com | Rel-6 | Yong-Jun | LCS2-UEpos-enh | LCS2-UEpos-enh | RP-24 |
| 3315 | 898.7 | LCS charging |  | 455d? | 2003-03-21 A | 2004-12-16 A | 100% | 2003-03-21 | 2004-12-16 | 455d? | start no earlier than 2003-03-21 | S5 | 3640h | 3640h | France Telecom | alain.bibas@orange-ft.com | Rel-6 | Mirko | LCS2-CH | LCS2-CH |  |
| 3316 | 14 | **Rel-6 Security enhancements** |  | 1018d? | 2001-01-03 A | 2004-11-26 A | 100% | 2001-01-03 | 2004-11-26 | 1018d? |  | S3 | 28824h | 28824h | Vodafone | Peter.Howard@vodafone.com | Rel-6 | Mirko | SEC1, Rel-6 | SEC1, Rel-6 |  |
| 3317 | 14.1 | **Enhanced HE control of security (including positive authentication reporting)** |  | 712d | 2001-01-03 A | 2003-09-25 A | 100% | 2001-01-03 | 2003-09-25 | 712d |  | S3 | 14064h | 14064h | Vodafone | Peter.Howard@vodafone.com | Rel-6 | Mirko |  |  |  |
| 3318 | 14.1.1 | Deleted - SEC1 Stage 2 (Enhanced HE control of security) |  | 378d | 2001-01-03 A | 2002-06-14 A | 100% | 2001-01-03 | 2002-06-14 | 378d | finish no earlier than 2002-06-14 | S3 | 3024h | 3024h |  |  | Rel-6 | Mirko |  |  | SP-16 |
| 3319 | 14.1.3 | **Rel-6 Network Domain Security** |  | 334d | 2002-06-17 A | 2003-09-25 A | 100% | 2002-06-17 | 2003-09-25 | 334d |  | S3 | 5344h | 5344h | Telenor | Geir-myrdahl.koien@telenor.com | Rel-6 | Mirko | SEC1-NDS | SEC1-NDS |  |
| 3320 | 14.1.3.1 | Rel-6 IP network layer security (NDS/IP) |  | 334d | 2002-06-17 A | 2003-09-25 A | 100% | 2002-06-17 | 2003-09-25 | 334d | finish no earlier than 2003-09-25 | S3 | 2672h | 2672h |  |  | Rel-6 | Mirko | SEC1-NDS-IP | SEC1-NDS-IP |  |
| 3321 | 899.2 | Network Domain Security; Authentication Framework (NDS/AF) |  | 521d? | 2002-02-15 A | 2004-02-13 A | 100% | 2002-02-15 | 2004-02-13 | 521d? | finish no earlier than 2004-02-13 | S3 | 4168h | 4168h | Nokia | tommi.viitanen@nokia.com | Rel-6 | Mirko | SEC1-NDS-AF | SEC1-NDS-AF |  |
| 3322 | 899.3 | Key Management of group keys for Voice Group Call Services |  | 306d | 2003-09-26 A | 2004-11-26 A | 100% | 2003-09-26 | 2004-11-26 | 306d | finish no earlier than 2004-11-26 | S3 | 2448h | 2448h | Vodafone | benno.tietz@vodafone.com | Rel-6 | Mirko | SECGKYV | SECGKYV |  |
| 3323 | 900 | Network Domain Security; MAP application layer security (NDS/MAPsec) |  | 127d? | 2004-07-06 A | 2004-12-29 A | 100% | 2004-07-06 | 2004-12-29 | 127d? | finish no earlier than 2003-12-26 | S3 | 1016h | 1016h | Vodafone | Peter.Howard@vodafone.com | Rel-6 | Mirko | MAPSEC | MAPSEC |  |

Notes:
- 3297: -
- 3298: - / Impacted TSs and TRs: 23.002,23.271
- 3299: -
- 3300: -
- 3301: - / Impacted TSs and TRs: 23.002,23.271
- 3302: -
- 3303: -
- 3304: - / Impacted TSs and TRs: 23.002,23.271
- 3305: -
- 3306: -
- 3307: - / Impacted TSs and TRs: 23.002,23.271
- 3308: Current stage 3 fullfills stage 2
- 3309: -
- 3310: -
- 3311: - / Impacted TSs and TRs: 25.305, 25.401, 25.450, 25.452, 25.453
- 3312: RP#25 completed (FDD) / Impacted TSs and TRs: new 25.171, 34.171 (testing)
- 3313: RP#38 Work stopped / Impacted TSs and TRs: new TR 25.894
- 3314: RP#24 Work stopped
- 3315: SP#26 completed / Impacted TSs and TRs: new TS 32.271
- 3316: SP#9 approved WID
- 3317: SP#9 approved WID S3-000490 (Enhanced home control of security by HE) / Impacted TSs and TRs: 33.102
- 3318: Marked as stopped 12/2008
- 3319: SP#9 approved WID S3-000606 (Network Domain Security) / Impacted TSs and TRs: 33.102, 33.103, 33.105
- 3320: SP#9 approved WID S3-000626 (Access security for IP-based services) / Impacted TSs and TRs: 33.210
- 3321: SP#19 approved WID / Impacted TSs and TRs: 33.810
- 3322: - / Impacted TSs and TRs: 42.068, 43.068, 44.068, 42.069, 43.069, 44.069, 31.102, 24.008, 48.008, 42.009, 43.020, New TSs (55.236, 55.205) MILENAGE algorithms
- 3323: SP#19 approved WID. Marked as closed 12/2008 (was marked 20% complete) / Impacted TSs and TRs: 33.200

| ID | WBS | Task | Type | Duration | Start | Finish | Complete | Baseline start | Baseline finish | Baseline duration | Constraint | Resources | Work | Actual work | Acronym | Release | MCC resp | Acronym_3GU_Export | Impacted TSs and TRs | WI rapporteur name | WI rapporteur e-mail | TSG stopped |
| --- | --- | --- | --- | --- | --- | --- | --- | --- | --- | --- | --- | --- | --- | --- | --- | --- | --- | --- | --- | --- | --- | --- |
| 3324 | 16 | **IMS Phase 2** |  | 1840d? | 2000-08-28 A | 2007-09-14 A | 100% | 2000-08-28 | 2007-09-14 | 1840d? |  | S1; S2; S3; S5; NP; R5 | 210576h | 210576h | IMS2 | Rel-6 | Alain | IMS2 |  |  |  |  |
| 3325 | 901.1 | Enhancements to the Cx and Sh interfaces |  | 323d? | 2003-06-06 A | 2004-08-31 A | 100% | 2003-06-06 | 2004-08-31 | 323d? | finish no earlier than 2004-08-31 | N4 | 2584h | 2584h | IMS2-CCR | Rel-6 | Kimmo | IMS2-CCR |  |  |  |  |
| 3326 | 901.2 | Conformance Test Aspects – IMS Call Control Rel-6 enhancements |  | 396d? | 2006-03-10 A | 2007-09-14 A | 100% | 2006-03-10 | 2007-09-14 | 396d? | finish no earlier than 2007-09-14 | R5 | 3168h | 3168h | IMS2_CCR_Test | Rel-6 | Ingbert | IMS2_CCR_Test | 34.229-1, 34.229-2, 34.229-3, 34.108 | Ericsson | Jacob.John@motorola.com, Leif.Mattisson@ericsson.com |  |
| 3327 | 16.12 | **IMS Group Management** |  | 715d? | 2002-03-14 A | 2004-12-08 A | 100% | 2002-03-14 | 2004-12-08 | 715d? |  | S1 | 12680h | 12680h | IMSGM | Rel-6 | Alain | IMSGM |  | Nokia | juha.kalliokulju@nokia.com |  |
| 3328 | 16.12.1 | Stage 1 - TS on IMS group management |  | 193d | 2002-03-14 A | 2002-12-09 A | 100% | 2002-03-14 | 2002-12-09 | 193d | finish no earlier than 2002-12-09 | S1 | 1544h | 1544h |  | Rel-6 | Alain |  |  | Nokia | juha.kalliokulju@nokia.com |  |
| 3329 | 901.3.2 | Stage 2 for IMS Group Management |  | 158d? | 2003-05-26 A | 2003-12-31 A | 100% | 2003-05-26 | 2003-12-31 | 158d? | finish no earlier than 2003-12-31 | S2 | 1264h | 1264h |  | Rel-6 | Maurice |  | 23.228 |  |  |  |
| 3330 | 901.3.3 | Stage 3 for IMS Group management (e.g. chat) |  | 519d? | 2002-12-13 A | 2004-12-08 A | 100% | 2002-12-13 | 2004-12-08 | 519d? | finish no earlier than 2004-12-08 | N1 | 4152h | 4152h |  | Rel-6 | Frederic |  |  | Lucent | Keith Drage (drage@alcatel-lucent.com) |  |
| 3331 | 901.4 | **IMS Conferencing** |  | 548d? | 2002-11-04 A | 2004-12-08 A | 100% | 2002-11-04 | 2004-12-08 | 548d? |  | N1 | 10960h | 10960h |  | Rel-6 | Frederic |  |  |  |  |  |
| 3332 | 901.4.1 | Stage 2 for IMS Conferencing |  | 303d? | 2002-11-04 A | 2003-12-31 A | 100% | 2002-11-04 | 2003-12-31 | 303d? | finish no earlier than 2003-12-31 | S2 | 2424h | 2424h |  | Rel-6 | Maurice |  | 23.228 |  |  |  |
| 3333 | 901.4.2 | Stage 3 for IMS Conferencing |  | 519d? | 2002-12-13 A | 2004-12-08 A | 100% | 2002-12-13 | 2004-12-08 | 519d? | finish no earlier than 2004-12-08 | N1 | 4152h | 4152h |  | Rel-6 | Frederic |  |  | Lucent | Keith Drage (drage@alcatel-lucent.com) |  |
| 3334 | 16.11 | **IMS Messaging** |  | 992d? | 2002-03-14 A | 2005-12-30 A | 100% | 2002-03-14 | 2005-12-30 | 992d? |  | S1 | 23912h | 23912h | IMSM | Rel-6 | Alain | IMSM |  | Nokia | juha.kalliokulju@nokia.com |  |
| 3335 | 16.11.1 | TR on support of messaging in the IMS |  | 193d | 2002-03-14 A | 2002-12-09 A | 100% | 2002-03-14 | 2002-12-09 | 193d | finish no earlier than 2002-12-09 | S1 | 1544h | 1544h | IMSM-TR | Rel-6 | Alain | IMSM-TR | New 22.940 | Nokia | juha.kalliokulju@nokia.com |  |
| 3336 | 901.5.2 | Stage 1 22.340 |  | 23d? | 2002-11-11 A | 2002-12-11 A | 100% | 2002-11-11 | 2002-12-11 | 23d? | finish no earlier than 2002-12-11 | S1 | 184h | 184h | IMSM-TS | Rel-6 | Alain | IMSM-TS | 22.340 | Nokia | juha.kalliokulju@nokia.com |  |
| 3337 | 901.5.3 | CRs to 22.140 & 22.228 |  | 263d? | 2002-03-14 A | 2003-03-17 A | 100% | 2002-03-14 | 2003-03-17 | 263d? | finish no earlier than 2003-03-17 | S1 | 2104h | 2104h | IMSM-CR | Rel-6 | Alain | IMSM-CR | 22.140,22.228 | Nokia | juha.kalliokulju@nokia.com |  |
| 3338 | 16.11.3 | Stage 2 for IMS Messaging |  | 477d | 2002-11-04 A | 2004-08-31 A | 100% | 2002-11-04 | 2004-08-31 | 477d | finish no earlier than 2004-08-31 | S2 | 3816h | 3816h |  | Rel-6 | Maurice |  | 23.228 |  |  |  |
| 3339 | 901.5.5 | Stage 3 for IMS Messaging |  | 519d? | 2002-12-13 A | 2004-12-08 A | 100% | 2002-12-13 | 2004-12-08 | 519d? | finish no earlier than 2004-12-08 | N1 | 4152h | 4152h |  | Rel-6 | Frederic |  |  | Lucent | Keith Drage (drage@alcatel-lucent.com) |  |
| 3340 | 901.5.6 | SIP/SIMPLE Instant messaging |  | 522d? | 2004-01-01 A | 2005-12-30 A | 100% | 2004-01-01 | 2005-12-30 | 522d? | finish no earlier than 2005-06-30 | OMA | 4176h | 4176h |  | Rel-6 |  |  |  |  | OMA-LIAISON@mail.openmobilealliance.org |  |
| 3341 | 901.6 | **Additional SIP Capabilities support not covered by Rel-5** |  | 680d? | 2002-11-11 A | 2005-06-17 A | 100% | 2002-11-11 | 2005-06-17 | 680d? |  | N1 | 13392h | 13392h |  | Rel-6 | Frederic |  |  |  |  |  |
| 3342 | 901.6.1 | Stage 2 for add SIP cap (e.g. forking) |  | 335d? | 2002-11-11 A | 2004-02-20 A | 100% | 2002-11-11 | 2004-02-20 | 335d? | finish no earlier than 2004-02-20 | S2 | 2680h | 2680h |  | Rel-6 | Maurice |  | 23.228 |  |  |  |
| 3343 | 901.6.2 | Stage 3 for Additional SIP Capabilities |  | 454d? | 2002-12-13 A | 2004-09-08 A | 100% | 2002-12-13 | 2004-09-08 | 454d? | finish no earlier than 2004-09-08 | N1 | 3632h | 3632h |  | Rel-6 | Frederic |  |  | Lucent | Keith Drage (drage@alcatel-lucent.com) |  |
| 3344 | 901.6.3 | Procedured associated with IMS-ALG |  | 205d? | 2004-09-06 A | 2005-06-17 A | 100% | 2004-09-06 | 2005-06-17 | 205d? | start no earlier than 2004-09-06 | N1 | 1640h | 1640h |  | Rel-6 | Frederic |  |  |  |  |  |
| 3345 | 901.7 | Review additional SIP Capabilities against IMS |  | 454d? | 2002-12-13 A | 2004-09-08 A | 100% | 2002-12-13 | 2004-09-08 | 454d? | finish no earlier than 2004-09-08 | N1 | 3632h | 3632h |  | Rel-6 | Frederic |  |  | Lucent | Keith Drage (drage@alcatel-lucent.com) |  |
| 3346 | 16.5 | **Interworking between IMS and IP networks** |  | 1118d? | 2000-08-28 A | 2004-12-08 A | 100% | 2000-08-28 | 2004-12-08 | 1118d? |  | N3 | 31712h | 31712h | IMS-CCR-IWIP | Rel-6 | Gwiho | IMS-CCR-IWIP | 23.821, 29.061, 29.162 | BT | nigel.holland@bt.com |  |
| 3347 | 16.5.1 | Interworking for 3GPP_SIP and IETF_SIP |  | 730d | 2000-08-28 A | 2003-06-13 A | 100% | 2000-08-28 | 2003-06-13 | 730d | finish no earlier than 2003-06-13 | N3 | 5840h | 5840h |  | Rel-6 | Gwiho |  | New 29.962 | Siemens | Thomas.Belling@nsn.com |  |
| 3348 | 16.5.2 | Interworking for IPv6 to IPv4 |  | 1118d | 2000-08-28 A | 2004-12-08 A | 100% | 2000-08-28 | 2004-12-08 | 1118d | finish no earlier than 2004-12-08 | N3 | 8944h | 8944h |  | Rel-6 | Gwiho |  | 29.163 |  |  |  |
| 3349 | 901.8.3 | Interworking for IPv6 to IPv4 (SIP / SDP aspects) |  | 87d? | 2004-05-11 A | 2004-09-08 A | 100% | 2004-05-11 | 2004-09-08 | 87d? | finish no earlier than 2004-09-08 | N1 | 696h | 696h |  | Rel-6 | Frederic |  |  |  |  |  |
| 3350 | 16.8.1 | stage 3 of interworking with non-IMS IP networks |  | 911d | 2001-03-14 A | 2004-09-08 A | 100% | 2001-03-14 | 2004-09-08 | 911d | finish no earlier than 2004-09-08 | N1 | 7288h | 7288h |  | Rel-6 | Frederic |  |  |  |  |  |
| 3351 | 16.6.1 | Interworking between IMS and CS networks |  | 929d? | 2000-08-28 A | 2004-03-18 A | 100% | 2000-08-28 | 2004-03-18 | 929d? | finish no earlier than 2004-03-18 | N3 | 7432h | 7432h | IMS-CCR-IWCS | Rel-6 | Gwiho | IMS-CCR-IWCS | 29.163, 29.061, 24.228, and New CN4 specification | Vodafone | Brendan.McWilliams@gb.vodafone.co.uk |  |
| 3352 | 16.10 | Mn interface (IM-MGW to MGCF) enhancements (CN4 Part) |  | 418d | 2001-08-07 A | 2004-09-01 A | 100% | 2001-08-07 | 2004-09-01 | 418d | finish no earlier than 2004-09-01 | N4 | 3344h | 3344h | IMS-CCR-Mn | Rel-6 | Kimmo | IMS-CCR-Mn |  |  |  |  |
| 3353 | 901.11 | Study of subscriber and operators relationship in IMS and related ISIM requirements for Rel 6” |  | 20d? | 2002-11-15 A | 2002-12-12 A | 100% | 2002-11-15 | 2002-12-12 | 20d? | finish no earlier than 2002-12-12 | S1 | 160h | 160h |  | Rel-6 | Alain |  |  | Nokia | juha.kalliokulju@nokia.com |  |
| 3354 | 901.12 | Lawful Interception in Rel-6 architecture |  | 269d? | 2002-12-09 A | 2003-12-18 A | 100% | 2002-12-09 | 2003-12-18 | 269d? | finish no earlier than 2003-12-18 | S3 | 2152h | 2152h | SEC1-LI, Rel-6 | Rel-6 | Mirko | SEC1-LI, Rel-6 | 33.106, 33.107, 33.108 | Reg TP, Nortel | berthold.wilhelm@regtp.de, Ron Ryan |  |
| 3355 | 901.13 | IMS Subscription and access scenarios |  | 130d? | 2002-12-16 A | 2003-06-13 A | 100% | 2002-12-16 | 2003-06-13 | 130d? | start no earlier than 2002-12-16 | S1 | 1040h | 1040h |  | Rel-6 | Alain |  | 22.800 | TeliaSonera | FRANK, Robert |  |
| 3356 | 901.14 | IMS charging |  | 455d? | 2003-03-21 A | 2004-12-16 A | 100% | 2003-03-21 | 2004-12-16 | 455d? | finish no earlier than 2004-12-16 | S5 | 3640h | 3640h | IMS2-CH | Rel-6 | Mirko | IMS2-CH | 32.260 | Ericsson | Patrik TEPPO |  |
| 3357 | 901.15 | IMS Management objects |  | 306d? | 2004-09-03 A | 2005-11-04 A | 100% | 2004-09-03 | 2005-11-04 | 306d? | finish no earlier than 2005-03-04 | N1 | 2448h | 2448h |  | Rel-6 | Frederic |  | 24.167 |  |  |  |
| 3358 | 901.16 | Deleted - Stage 2 of IMS Phase 2 | milestone | 0d? | 2003-09-19 A | 2003-09-19 A | 100% | 2003-09-19 | 2003-09-19 | 0d? | finish no earlier than 2003-09-19 | S2 |  |  |  | Rel-6 | Maurice |  |  |  |  | SP-21 |

Notes:
- 3324: -
- 3325: Shared public user identities need to be solved. If email approval CR is accepted. Work 100% done....
- 3326: -
- 3327: -
- 3328: -
- 3329: -
- 3330: Depends on CN decision on CPCP in Rel-6. Complete, if unresolved IETF dependencies are dropped (-> LS to CN plenary)
- 3331: -
- 3332: -
- 3333: Depends on CN decision on IETF dependencies in Rel-6. Higher figure if CPCP is dropped (-> LS to CN plenary)
- 3334: -
- 3335: -
- 3336: -
- 3337: -
- 3338: -
- 3339: -
- 3340: Updated according to SP-040232
- 3341: -
- 3342: -
- 3343: -
- 3344: -
- 3345: -
- 3346: [DAB 14.02.02] - end date pushed back to March 2003
- 3347: [DAB - 20.08.03] - CN Part of TR Complete @ CN#20
- 3348: -
- 3349: -
- 3350: -
- 3351: [DAB - 25.05.04] - CN3 consider this work to be complete
- 3352: TISPAN issue is open
- 3353: -
- 3354: -
- 3355: -
- 3356: SP#26 12/2004 completed
- 3357: -
- 3358: -

| ID | WBS | Task | Type | Duration | Start | Finish | Complete | Baseline start | Baseline finish | Baseline duration | Constraint | Resources | Work | Actual work | Acronym | WI rapporteur name | WI rapporteur e-mail | Release | MCC resp | Acronym_3GU_Export | Impacted TSs and TRs | Created at | TSG stopped |
| --- | --- | --- | --- | --- | --- | --- | --- | --- | --- | --- | --- | --- | --- | --- | --- | --- | --- | --- | --- | --- | --- | --- | --- |
| 3359 | 902 | **3GPP Enablers for services like Push to Talk over Cellular (PoC)** |  | 459d? | 2003-09-08 A | 2005-06-09 A | 100% | 2003-09-08 | 2005-06-09 | 459d? |  | S2; S4; S5 | 18040h | 18040h | PoC | Ericsson | Shabnam Sultana | Rel-6 | Maurice | PoC |  |  |  |
| 3360 | 902.1 | Feasibility Study on 3GPP Enablers for services like Push to Talk over Cellular (PoC) |  | 322d? | 2003-09-08 A | 2004-11-30 A | 100% | 2003-09-08 | 2004-11-30 | 322d? | finish no earlier than 2004-11-30 | S2 | 2576h | 2576h |  | Ericsson | Shabnam Sultana | Rel-6 | Maurice |  | 23.979 | SP-24 |  |
| 3361 | 902.2 | Dependencies on OMA PoC |  | 303d? | 2004-01-01 A | 2005-02-28 A | 100% | 2004-01-01 | 2005-02-28 | 303d? | finish no earlier than 2004-12-30 | OMA | 2424h | 2424h |  |  | OMA-LIAISON@mail.openmobilealliance.org | Rel-6 |  |  |  | SP-24 |  |
| 3362 | 902.3 | Selection of one or more PoC codec(s) for PoC |  | 69d? | 2004-09-13 A | 2004-12-16 A | 100% | 2004-09-13 | 2004-12-16 | 69d? | start no earlier than 2004-09-13 | S4 | 552h | 552h |  |  |  | Rel-6 | Paolo |  | 26.235, 26.236 | SP-25 |  |
| 3363 | 902.4 | PoC charging |  | 184d? | 2004-09-27 A | 2005-06-09 A | 100% | 2004-09-27 | 2005-06-09 | 184d? | finish no earlier than 2005-06-09 | S5 | 1472h | 1472h | PoC-CH | Siemens | Gerald.Goermer@nsn.com | Rel-6 | Mirko | PoC-CH | 32.272 |  |  |
| 3364 | 903 | Study on Interworking aspects and migration scenarios for IPv4 based IMS Implementations |  | 210d? | 2003-09-08 A | 2004-06-25 A | 100% | 2003-09-08 | 2004-06-25 | 210d? | finish no earlier than 2004-06-25 | S2 | 1680h | 1680h | IPv4IMS | Siemens | Alexander Milinski | Rel-6 | Maurice | IPv4IMS | 23.981 |  |  |
| 3365 | 16.3 | **Interoperability and Commonality between IMS using different IP-connectivity Networks** |  | 325d? | 2002-09-16 A | 2003-12-12 A | 100% | 2002-09-16 | 2003-12-12 | 325d? |  | S2 | 9176h | 9176h | IMSCOOP |  |  | Rel-6 | Maurice | IMSCOOP | 23.864 |  |  |
| 3366 | 16.3.1 | Stage 2 for Interoperability |  | 272d | 2002-09-16 A | 2003-09-30 A | 100% | 2002-09-16 | 2003-09-30 | 272d | finish no earlier than 2003-09-30 | S2 | 2176h | 2176h |  | Nokia | balazs.bertenyi@nsn.com | Rel-6 | Maurice |  | 23.864 |  |  |
| 3367 | 904.2 | Stage 2 for commonality |  | 265d? | 2002-09-16 A | 2003-09-19 A | 100% | 2002-09-16 | 2003-09-19 | 265d? | start no earlier than 2002-09-16 | S2 | 2120h | 2120h |  | Nokia | balazs.bertenyi@nsn.com | Rel-6 | Maurice |  | 23.864 |  |  |
| 3368 | 16.3.2 | Stage 3 for Interoperability and Commonality between IMS using different IP-connectivity Networks |  | 305d | 2002-10-14 A | 2003-12-12 A | 100% | 2002-10-14 | 2003-12-12 | 305d | finish no earlier than 2003-12-12 | N1 | 2440h | 2440h |  | Lucent | Keith Drage (drage@alcatel-lucent.com) | Rel-6 | Frederic |  |  |  |  |
| 3369 | 17 | **Support of Push Services** |  | 823d | 2001-01-03 A | 2004-02-27 A | 100% | 2001-01-03 | 2004-02-27 | 823d |  | S1 | 11390.6h | 11390.6h | PUSH | NTT Comware | Yoshinori Kitada | Rel-6 | Alain | PUSH | 23.976 |  |  |
| 3370 | 17.1 | Stage 1 for Support of Push Services |  | 378d | 2001-01-03 A | 2002-06-14 A | 100% | 2001-01-03 | 2002-06-14 | 378d | finish no earlier than 2002-06-14 | S1 | 3024h | 3024h |  |  |  | Rel-6 | Alain |  |  |  |  |
| 3371 | 17.3 | TR 23.976 on Push Architecture |  | 340d | 2002-11-11 A | 2004-02-27 A | 100% | 2002-11-11 | 2004-02-27 | 340d | finish no earlier than 2004-02-27 | S2 | 2720h | 2720h |  | Research In Motion | Nick Alfano | Rel-6 | Maurice |  | 23.976 |  |  |
| 3372 | 18 | **Rel-6 Multimedia Messaging (MMS) enhancements** |  | 865d? | 2002-08-15 A | 2005-12-07 A | 100% | 2002-08-15 | 2005-12-07 | 865d? |  | T2; S1; S4; S5; OMA | 59616h | 59616h | MMS6 | Siemens | Josef.Laumen@SAL.SIEMENS.DE | Rel-6 | Kimmo | MMS6 |  |  |  |
| 3373 | 18.1 | **Definition of service requirements for MMS6** |  | 286d? | 2002-11-15 A | 2003-12-19 A | 100% | 2002-11-15 | 2003-12-19 | 286d? |  | S1 | 4576h | 4576h | MMS6-SR |  |  | Rel-6 | Alain | MMS6-SR | 22.140 |  |  |
| 3374 | 906.1.1 | Definition of service requirements charging |  | 286d? | 2002-11-15 A | 2003-12-19 A | 100% | 2002-11-15 | 2003-12-19 | 286d? | finish no earlier than 2003-12-20 | S1 | 2288h | 2288h |  | Siemens | Josef.Laumen@SAL.SIEMENS.DE | Rel-6 | Alain |  | 22.140 |  |  |
| 3375 | 18.2 | Technical realization of MMS6 |  | 591d | 2002-09-06 A | 2004-12-10 A | 100% | 2002-09-06 | 2004-12-10 | 591d | finish no earlier than 2004-12-10 | T2 | 4728h | 4728h |  | Siemens | Josef.Laumen@SAL.SIEMENS.DE | Rel-6 | Kimmo |  | 23.140 |  |  |
| 3376 | 18.3 | OMA dependencies |  | 446d | 2003-08-15 A | 2005-04-29 A | 100% | 2003-08-15 | 2005-04-29 | 446d | finish no earlier than 2004-12-10 | OMA | 3568h | 3568h |  |  |  | Rel-6 | Kimmo |  | OMA specs |  |  |
| 3377 | 18.4 | MMS formats and codecs for MMS6 |  | 865d | 2002-08-15 A | 2005-12-07 A | 100% | 2002-08-15 | 2005-12-07 | 865d | finish no earlier than 2005-12-07 | S4 | 6920h | 6920h | MMS6-Codec | Nokia | roberto.castagno@nokia.com | Rel-6 | Paolo | MMS6-Codec | 26.140, 26.936 |  |  |
| 3378 | 906.5 | Handling of private addressing schemes in MMS |  | 263d | 2003-12-10 A | 2004-12-10 A | 100% | 2003-12-10 | 2004-12-10 | 263d | finish no earlier than 2004-12-10 | T2 | 2104h | 2104h |  | T-Mobile | Steffen.Habermann@T-MOBILE.DE | Rel-6 | Kimmo |  | 23.140 |  |  |
| 3379 | 906.6 | MMS charging |  | 390d? | 2003-03-21 A | 2004-09-16 A | 100% | 2003-03-21 | 2004-09-16 | 390d? | start no earlier than 2003-03-21 | S5 | 3120h | 3120h | MMS6-CH |  |  | Rel-6 | Mirko | MMS6-CH | 32.270 |  |  |
| 3380 | 906.7 | Deleted - FS Multiple MMS Relay/Server Architecture | milestone | 0d | 2004-12-10 A | 2004-12-10 A | 100% | 2004-12-10 | 2004-12-10 | 0d | finish no earlier than 2004-12-10 | T2 |  |  |  | Telefónica Móviles | Juan Gorospe (gorospe_j@tsm.es) | Rel-6 | Kimmo |  | probably Annex to 23.140 |  | TP-26 |
| 3381 | 19 | **Rel-6 MExE enhancements** |  | 326d | 2002-03-08 A | 2003-06-06 A | 100% | 2002-03-08 | 2003-06-06 | 326d |  | T2 | 7328h | 7328h | MEXE6 |  |  | Rel-6 | Kimmo | MEXE6 |  |  |  |
| 3382 | 19.1 | MExE Rel-6 Improvements and Investigations |  | 264d | 2002-03-08 A | 2003-03-12 A | 100% | 2002-03-08 | 2003-03-12 | 264d | finish no earlier than 2003-03-12 | T2 | 2112h | 2112h | MEXE6-ENHANC | TTPCom | Lars Brenk ( (lsb_ttpcom@HOTMAIL.COM) | Rel-6 | Kimmo | MEXE6-ENHANC |  |  |  |
| 3383 | 19.2 | MExE Run-Time Independent Framework Feasibility Study |  | 326d | 2002-03-08 A | 2003-06-06 A | 100% | 2002-03-08 | 2003-06-06 | 326d | finish no earlier than 2003-06-06 | T2 | 2608h | 2608h | MEXE6-RTIF | Nokia Siemens Networks | balazs.bertenyi@nokia.com | Rel-6 | Kimmo | MEXE6-RTIF | 22.857 |  |  |
| 3384 | 21 | Subscription Management |  | 650d | 2002-09-20 A | 2005-03-17 A | 100% | 2002-09-20 | 2005-03-17 | 650d | finish no earlier than 2005-03-17 | S5 | 5200h | 5200h | SuM | T-Mobile | istvan.aba@t-mobile.at | Rel-6 | Mirko | SuM | 32.140/1, 32.171/2/5, 32.803 |  |  |

Notes:
- 3359: -
- 3360: -
- 3361: Updated according to SP-040232
- 3362: Completed
- 3363: SP#28 06/2005 completed
- 3364: -
- 3365: -
- 3366: No contributions assumed that no more will be done in 3GPP hence work may need to be done in 3GPP2
- 3367: -
- 3368: -
- 3369: Changed from FS to actual support of Push
- 3370: -
- 3371: -
- 3372: -
- 3373: -
- 3374: -
- 3375: -
- 3376: -
- 3377: -
- 3378: -
- 3379: SP#25 09/2004 completed
- 3380: originally it was intended to create a FS TR but most likely the work will become an Annex of 23.140
- 3381: -
- 3382: -
- 3383: -
- 3384: SP#27 03/2005 completed

| ID | WBS | Task | Duration | Start | Finish | Complete | Baseline start | Baseline finish | Baseline duration | Constraint | Resources | Work | Actual work | Acronym | WI rapporteur name | WI rapporteur e-mail | Release | MCC resp | Acronym_3GU_Export |
| --- | --- | --- | --- | --- | --- | --- | --- | --- | --- | --- | --- | --- | --- | --- | --- | --- | --- | --- | --- |
| 3385 | 22 | **Presence Capability** | 1233d? | 2001-03-19 A | 2005-12-07 A | 100% | 2001-03-19 | 2005-12-07 | 1233d? |  | S1; S2; S3; S4; N1; N3; N4; OMA | 111784h | 111784h | PRESNC | Motorola | Mark Cataldo | Rel-6 | Alain | PRESNC |
| 3386 | 22.1 | Stage 1 for Presence Capability | 610d | 2001-03-19 A | 2003-07-18 A | 100% | 2001-03-19 | 2003-07-18 | 610d | finish no earlier than 2003-07-18 | S1 | 4880h | 4880h |  | Motorola | Mark Cataldo | Rel-6 | Alain |  |
| 3387 | 22.2 | Stage 2 for Presence Capability | 268d | 2001-09-12 A | 2002-09-20 A | 100% | 2001-09-12 | 2002-09-20 | 268d | finish no earlier than 2002-09-20 | S2 | 2144h | 2144h |  | Nokia | balazs.bertenyi@nsn.com | Rel-6 | Maurice |  |
| 3388 | 22.3 | Stage 3 for Presence Capability | 703d | 2002-04-01 A | 2004-12-08 A | 100% | 2002-04-01 | 2004-12-08 | 703d | finish no earlier than 2004-12-08 | N1; N4 | 11248h | 11248h |  | Lucent | Keith Drage (drage@alcatel-lucent.com) | Rel-6 | Frederic |  |
| 3389 | 909.4 | Stage 3 (CN3 Part Pk interface) | 770d? | 2002-04-01 A | 2005-03-11 A | 100% | 2002-04-01 | 2005-03-11 | 770d? | finish no earlier than 2005-03-11 | N3 | 6160h | 6160h |  | Lucent | Keith Drage (drage@alcatel-lucent.com) | Rel-6 | Gwiho |  |
| 3390 | 909.5 | Media Codecs and Formats for IMS Messaging and Presence | 650d? | 2003-06-12 A | 2005-12-07 A | 100% | 2003-06-12 | 2005-12-07 | 650d? | finish no earlier than 2005-12-07 | S4 | 5200h | 5200h | PRESNC-COFIMP | Nokia | harri.honko@nokia.com | Rel-6 | Paolo | PRESNC-COFIMP |
| 3391 | 22.4 | Security aspects of Presence Capability | 79d | 2002-08-26 A | 2002-12-12 A | 100% | 2002-08-26 | 2002-12-12 | 79d | finish no earlier than 2002-12-12 | S3 | 632h | 632h |  | Ericsson | krister.boman@erv.ericsson.se | Rel-6 | Mirko |  |
| 3392 | 909.7 | SIMPLE Presence | 326d? | 2004-01-01 A | 2005-03-31 A | 100% | 2004-01-01 | 2005-03-31 | 326d? | finish no earlier than 2004-12-30 | OMA | 2608h | 2608h |  |  | OMA-LIAISON@mail.openmobilealliance.org | Rel-6 |  |  |
| 3393 | 25 | **Enhanced A/Gb feasibility study** | 51d? | 2002-08-30 A | 2002-11-08 A | 100% | 2002-08-30 | 2002-11-08 | 51d? |  | GP | 3264h | 3264h | AGbEnFS | Vodafone | jose-luis.carrizo@vodafone.co.uk | Rel-6 | Paolo | AGbEnFS |
| 3394 | 25.1 | **Feasibility study on A/Gb enhancements** | 51d? | 2002-08-30 A | 2002-11-08 A | 100% | 2002-08-30 | 2002-11-08 | 51d? |  | G2 | 2856h | 2856h | AGbEnFS-FS | Vodafone | jose-luis.carrizo@vodafone.co.uk | Rel-6 | Gert | AGbEnFS-FS |
| 3395 | 25.1.1 | Requirements for the support of conversational services | 51d | 2002-08-30 A | 2002-11-08 A | 100% | 2002-08-30 | 2002-11-08 | 51d | finish no earlier than 2002-11-08 | GP | 408h | 408h |  |  |  | Rel-6 | Paolo |  |
| 3396 | 910.1.2 | Identification of the different building blocks for the provision of conversational services on the existing A/Gb protocol stack | 51d? | 2002-08-30 A | 2002-11-08 A | 100% | 2002-08-30 | 2002-11-08 | 51d? | finish no earlier than 2002-11-08 | GP | 408h | 408h |  |  |  | Rel-6 | Paolo |  |
| 3397 | 910.1.3 | Outline of impact and feasibility of these building blocks and their different solutions | 51d? | 2002-08-30 A | 2002-11-08 A | 100% | 2002-08-30 | 2002-11-08 | 51d? | finish no earlier than 2002-11-08 | GP | 408h | 408h |  |  |  | Rel-6 | Paolo |  |
| 3398 | 25.1.4 | Impact on 3GPP architecture and requirement to co-ordinatge with other TSGs (CN, SA) | 51d | 2002-08-30 A | 2002-11-08 A | 100% | 2002-08-30 | 2002-11-08 | 51d | finish no earlier than 2002-11-08 | GP | 408h | 408h |  |  |  | Rel-6 | Paolo |  |
| 3399 | 25.1.5 | Standardisation effort | 51d | 2002-08-30 A | 2002-11-08 A | 100% | 2002-08-30 | 2002-11-08 | 51d | finish no earlier than 2002-11-08 | GP | 408h | 408h |  |  |  | Rel-6 | Paolo |  |
| 3400 | 25.1.6 | Dependency to other features of Enhanced A/Gb feasibility study | 51d | 2002-08-30 A | 2002-11-08 A | 100% | 2002-08-30 | 2002-11-08 | 51d | finish no earlier than 2002-11-08 | GP | 408h | 408h |  |  |  | Rel-6 | Paolo |  |
| 3401 | 26 | **Flexible Layer One for GERAN** | 1171d | 2000-01-03 A | 2004-06-25 A | 100% | 2000-01-03 | 2004-06-25 | 1171d |  | GP; S3 | 86648h | 86648h | FLOGER | Nokia | benoist.sebire@nokia.com | Rel-6 | Paolo | FLOGER |
| 3402 | 26.1 | **Realisation of a Flexible Layer One** | 1126d | 2000-01-03 A | 2004-04-23 A | 100% | 2000-01-03 | 2004-04-23 | 1126d |  | GP | 42816h | 42816h | FLOGER-Real | Nokia | benoist.sebire@nokia.com | Rel-6 | Paolo | FLOGER-Real |
| 3403 | 26.1.1 | Technical Report on Realisation of a Flexible Layer One | 471d | 2002-04-19 A | 2004-02-06 A | 100% | 2002-04-19 | 2004-02-06 | 471d | finish no earlier than 2004-02-06 | GP | 3768h | 3768h |  | Nokia | benoist.sebire@nokia.com | Rel-6 | Paolo |  |
| 3404 | 26.1.2 | Architecture in 45.001 and 43.051 | 526d | 2002-04-19 A | 2004-04-23 A | 100% | 2002-04-19 | 2004-04-23 | 526d | finish no earlier than 2004-04-23 | G1 | 4208h | 4208h |  | Nokia | benoist.sebire@nokia.com | Rel-6 | Paolo |  |
| 3405 | 26.1.3 | Multiplexing in 45.002 | 526d | 2002-04-19 A | 2004-04-23 A | 100% | 2002-04-19 | 2004-04-23 | 526d | finish no earlier than 2004-04-23 | G1 | 4208h | 4208h |  | Nokia | benoist.sebire@nokia.com | Rel-6 | Paolo |  |
| 3406 | 26.1.4 | Channel Coding in 45.003 for Realisation of a Flexible Layer One | 526d | 2002-04-19 A | 2004-04-23 A | 100% | 2002-04-19 | 2004-04-23 | 526d | finish no earlier than 2004-04-23 | G1 | 4208h | 4208h |  | Nokia | benoist.sebire@nokia.com | Rel-6 | Paolo |  |
| 3407 | 26.1.5 | Performance Requirements in 45.005 for Realisation of a Flexible Layer One | 1126d | 2000-01-03 A | 2004-04-23 A | 100% | 2000-01-03 | 2004-04-23 | 1126d | finish no earlier than 2004-04-23 | G1 | 9000h | 9000h |  | Nokia | benoist.sebire@nokia.com | Rel-6 | Paolo |  |
| 3408 | 26.1.6 | Radio subsystem link control in 45.008 for Realisation of a Flexible Layer One | 526d | 2002-04-19 A | 2004-04-23 A | 100% | 2002-04-19 | 2004-04-23 | 526d | finish no earlier than 2004-04-23 | G1 | 4208h | 4208h |  | Nokia | benoist.sebire@nokia.com | Rel-6 | Paolo |  |
| 3409 | 26.1.7 | Requirements in 44.004 | 526d | 2002-04-19 A | 2004-04-23 A | 100% | 2002-04-19 | 2004-04-23 | 526d | finish no earlier than 2004-04-23 | G2 | 4208h | 4208h |  | Nokia | benoist.sebire@nokia.com | Rel-6 | Gert |  |

Notes:
- 3385: merged "Presence Service Enhancements" (UID31028, PRES1) to this feature as no answer was provided on why Presence and Presence Encmts had same target completion date
- 3386: TP#16 moved Stage 1 to Rel-6 TS 22.141 (existed already in Rel-5) / Impacted TSs and TRs: 22.141
- 3387: - / Impacted TSs and TRs: 23.002, 24.229, New 23.141
- 3388: Dependency to 2 IETF drafts, no known work at the moment / Impacted TSs and TRs: New N1 (24.141, 24.841), N4 (29.002, 29.228, 29.230, 29.328)
- 3389: - / Impacted TSs and TRs: 29.061, 29.161
- 3390: - / Impacted TSs and TRs: 26.141, 26.936
- 3391: SP#17 approved WID S3-020429
- 3392: SP#24 OMA LS_in update in SP-040232 OMA dependencies on 3GPP deliverables
- 3393: - / Impacted TSs and TRs: None
- 3394: - / Impacted TSs and TRs: None
- 3395: - / Impacted TSs and TRs: None
- 3396: - / Impacted TSs and TRs: None
- 3397: - / Impacted TSs and TRs: None
- 3398: - / Impacted TSs and TRs: None
- 3399: - / Impacted TSs and TRs: None
- 3400: - / Impacted TSs and TRs: None
- 3401: -
- 3402: -
- 3403: -
- 3404: -
- 3405: -
- 3406: -
- 3407: -
- 3408: -
- 3409: -

| ID | WBS | Task | Type | Duration | Start | Finish | Complete | Baseline start | Baseline finish | Baseline duration | Constraint | Resources | Work | Actual work | Acronym | WI rapporteur name | WI rapporteur e-mail | Release | MCC resp | Acronym_3GU_Export | Impacted TSs and TRs | TSG stopped |
| --- | --- | --- | --- | --- | --- | --- | --- | --- | --- | --- | --- | --- | --- | --- | --- | --- | --- | --- | --- | --- | --- | --- |
| 3410 | 26.2 | **Signalling and protocol support for a Flexible Layer One** |  | 571d | 2002-04-19 A | 2004-06-25 A | 100% | 2002-04-19 | 2004-06-25 | 571d |  | G2 | 13704h | 13704h | FLOGER-SigPro | Nokia | benoist.sebire@nokia.com | Rel-6 | Gert | FLOGER-SigPro |  |  |
| 3411 | 26.2.1 | Modifications to RLC/MAC in 44.060 and 44.160 |  | 571d | 2002-04-19 A | 2004-06-25 A | 100% | 2002-04-19 | 2004-06-25 | 571d | finish no earlier than 2004-06-25 | G2 | 4568h | 4568h |  | Nokia | benoist.sebire@nokia.com | Rel-6 | Gert |  |  |  |
| 3412 | 26.2.2 | Modifications to RRC in 44.118 and 44.018 |  | 571d | 2002-04-19 A | 2004-06-25 A | 100% | 2002-04-19 | 2004-06-25 | 571d | finish no earlier than 2004-06-25 | G2 | 4568h | 4568h |  | Nokia | benoist.sebire@nokia.com | Rel-6 | Gert |  |  |  |
| 3413 | 26.3 | **Security for a Flexible Layer One** |  | 356d | 2002-04-19 A | 2003-08-29 A | 100% | 2002-04-19 | 2003-08-29 | 356d |  | S3; G2 | 11392h | 11392h | FLOGER-SecFLO | Nokia | benoist.sebire@nokia.com | Rel-6 | Mirko | FLOGER-SecFLO |  |  |
| 3414 | 26.3.1 | Ciphering in 44.060, 44.160, 44.018, 44.118 |  | 356d | 2002-04-19 A | 2003-08-29 A | 100% | 2002-04-19 | 2003-08-29 | 356d | finish no earlier than 2003-08-29 | S3; G2 | 5696h | 5696h |  | Nokia | benoist.sebire@nokia.com | Rel-6 | Mirko |  | 44.060, 44.160, 44.018, 44.118 |  |
| 3415 | 26.4 | **Deleted - GERAN MS Conformance test for the Flexible Layer One - DELETE** |  | 0d | 2004-02-06 A | 2004-02-06 A | 100% | 2004-02-06 | 2004-02-06 | 0d |  | G4; G5 |  |  | FLOGER-Msconf | Nokia | benoist.sebire@nokia.com | Rel-6 | Paolo | FLOGER-Msconf |  | GP-27 |
| 3416 | 26.4.1 | Deleted at TSG #27 - MS Test in 51.010 | milestone | 0d | 2004-02-06 A | 2004-02-06 A | 100% | 2004-02-06 | 2004-02-06 | 0d | finish no earlier than 2004-02-06 | G4; G5 |  |  |  | Nokia | benoist.sebire@nokia.com | Rel-6 | Paolo |  |  | GP-22 |
| 3417 | 26.5 | **Deleted - GERAN BTS Conformance test for the Flexible Layer One - DELETE** |  | 0d | 2004-02-06 A | 2004-02-06 A | 100% | 2004-02-06 | 2004-02-06 | 0d |  | G3new |  |  | FLOGER-BTSconf | Nokia | benoist.sebire@nokia.com | Rel-6 | Ingbert | FLOGER-BTSconf |  | GP-27 |
| 3418 | 26.5.1 | Deleted at TGS #27 - BTS Test in 51.021 - DELETE | milestone | 0d | 2004-02-06 A | 2004-02-06 A | 100% | 2004-02-06 | 2004-02-06 | 0d | finish no earlier than 2004-02-06 | G3new |  |  |  | Nokia | benoist.sebire@nokia.com | Rel-6 | Ingbert |  |  | GP-22 |
| 3419 | 27 | Uplink TDOA feasibility study |  | 151d | 2001-11-30 A | 2002-06-28 A | 100% | 2001-11-30 | 2002-06-28 | 151d | finish no earlier than 2002-06-28 | GP | 1208h | 1208h | TDOAF | TruePosition | Bob Gross (rlgross@trueposition.com) | Rel-6 | Paolo | TDOAF | 45.811 |  |
| 3420 | 28 | **Multimedia Broadcast and Multicast Service** |  | 1781d? | 2001-05-11 A | 2008-03-07 A | 100% | 2001-05-11 | 2008-03-07 | 1781d? |  | S1; S2; S3; S4; S5; N1; N3; R2; R4; R5; T1; GP; G2; G3new | 391176h | 391176h | MBMS |  |  | Rel-6 | Alain | MBMS |  |  |
| 3421 | 28.1 | Stage 1 for Multimedia Broadcast and Multicast Service |  | 232d | 2001-05-11 A | 2002-04-01 A | 100% | 2001-05-11 | 2002-04-01 | 232d | finish no earlier than 2002-04-01 | S1 | 1856h | 1856h |  |  |  | Rel-6 | Alain |  | 22.146, 22.101 |  |
| 3422 | 28.2 | **Stage 2 for Multimedia Broadcast and Multicast Service** |  | 648d | 2001-09-24 A | 2004-03-17 A | 100% | 2001-09-24 | 2004-03-17 | 648d |  | S2 | 10408h | 10408h |  |  |  | Rel-6 | Maurice |  |  |  |
| 3423 | 28.2.1 | TR on MBMS Architectural Study |  | 240d | 2001-09-24 A | 2002-08-23 A | 100% | 2001-09-24 | 2002-08-23 | 240d | finish no earlier than 2002-08-23 | S2 | 1920h | 1920h |  |  |  | Rel-6 | Maurice |  | 23.846 |  |
| 3424 | 28.2.2 | Stage 2 MBMS Specification Work |  | 413d | 2002-08-19 A | 2004-03-17 A | 100% | 2002-08-19 | 2004-03-17 | 413d | finish no earlier than 2004-03-17 | S2 | 3304h | 3304h |  |  |  | Rel-6 | Maurice |  | 23.246 |  |
| 3425 | 28.4 | Support of the MBMS in CN protocols |  | 647d | 2002-06-18 A | 2004-12-08 A | 100% | 2002-06-18 | 2004-12-08 | 647d | finish no earlier than 2004-12-08 | N1 | 5176h | 5176h |  |  |  | Rel-6 | Frederic |  |  |  |
| 3426 | 913.4 | Gmb interface for MBMS (CN3 part) |  | 334d | 2003-08-29 A | 2004-12-08 A | 100% | 2003-08-29 | 2004-12-08 | 334d | finish no earlier than 2004-12-08 | N3 | 2672h | 2672h |  |  |  | Rel-6 | Gwiho |  | 29.061 |  |
| 3427 | 28.5 | Security aspects of MBMS |  | 710d | 2002-07-01 A | 2005-03-18 A | 100% | 2002-07-01 | 2005-03-18 | 710d | finish no earlier than 2005-03-18 | S3 | 5680h | 5680h |  |  | adrian.escott@three.co.uk | Rel-6 | Mirko |  | New 33.246 |  |
| 3428 | 913.6 | MBMS Charging |  | 108d? | 2005-01-11 A | 2005-06-09 A | 100% | 2005-01-11 | 2005-06-09 | 108d? | start no earlier than 2005-01-11 | S5 | 864h | 864h | MBMS-CH |  |  | Rel-6 | Mirko | MBMS-CH | 32.273 |  |
| 3429 | 28.1 | **MBMS User Services** |  | 743d? | 2003-05-13 A | 2006-03-16 A | 100% | 2003-05-13 | 2006-03-16 | 743d? |  | S1; S4 | 19520h | 19520h |  |  |  | Rel-6 | Alain |  |  |  |
| 3430 | 28.1 | Stage 1 for MBMS User Services |  | 233d | 2003-05-13 A | 2004-04-01 A | 100% | 2003-05-13 | 2004-04-01 | 233d | start no earlier than 2003-05-13 | S1 | 1864h | 1864h |  |  |  | Rel-6 | Alain |  | 22.246 |  |
| 3431 | 913.7.2 | Definition of MBMS user services, media codecs, formats and transport/application protocols using MBMS |  | 721d? | 2003-06-12 A | 2006-03-16 A | 100% | 2003-06-12 | 2006-03-16 | 721d? | finish no earlier than 2006-03-16 | S4 | 5768h | 5768h | MBMS-TSMBMS | Nokia | igor.curcio@nokia.com | Rel-6 | Paolo | MBMS-TSMBMS | 26.346, 26.936, 26.946 |  |
| 3432 | 28.3 | **Introduction of MBMS in RAN** |  | 967d? | 2002-01-01 A | 2005-09-14 A | 100% | 2002-01-01 | 2005-09-14 | 967d? |  | R2; R4 | 23728h | 23728h | MBMS-RAN | Nokia | juho.pirskanen@nokia.com | Rel-6 | Yong-Jun | MBMS-RAN |  |  |
| 3433 | 913.8.1 | Introduction of MBMS in RAN (physical & upper layers, access network interfaces) |  | 771d? | 2002-01-01 A | 2004-12-14 A | 100% | 2002-01-01 | 2004-12-14 | 771d? | finish no earlier than 2004-12-14 | R2 | 6168h | 6168h |  | Nokia | juho.pirskanen@nokia.com | Rel-6 | Yong-Jun |  | 25.346, 25.304, 25.321, 25.322, 25.323 |  |
| 3434 | 913.8.2 | UE Performance Requirements for MBMS |  | 261d? | 2004-09-15 A | 2005-09-14 A | 100% | 2004-09-15 | 2005-09-14 | 261d? | finish no earlier than 2005-09-15 | R4 | 2088h | 2088h | MBMS-RAN-RF | Ericsson | Torgny.Palenius@ericsson.com | Rel-6 | Issam | MBMS-RAN-RF | 25.101, 25.133 |  |

Notes:
- 3410: -
- 3411: -
- 3412: -
- 3413: -
- 3414: -
- 3415: -
- 3416: -
- 3417: -
- 3418: -
- 3419: -
- 3420: SP#13 Title renamed
- 3421: -
- 3422: -
- 3423: -
- 3424: -
- 3425: -
- 3426: -
- 3427: SP#17 approved WID S3-020433
- 3428: SP#28 completed
- 3429: -
- 3430: -
- 3431: -
- 3432: -
- 3433: -
- 3434: RP#25 approved WID RP-040370

| ID | WBS | Task | Type | Duration | Start | Finish | Complete | Baseline start | Baseline finish | Baseline duration | Constraint | Deadline | Resources | Work | Actual work | Acronym | Release | MCC resp | Acronym_3GU_Export | Impacted TSs and TRs | WI rapporteur name | WI rapporteur e-mail | Created at | TSG stopped |
| --- | --- | --- | --- | --- | --- | --- | --- | --- | --- | --- | --- | --- | --- | --- | --- | --- | --- | --- | --- | --- | --- | --- | --- | --- |
| 3435 | 913.9 | **MBMS UE Conformance Testing** |  | 521d? | 2006-03-10 A | 2008-03-07 A | 100% | 2006-03-10 | 2008-03-07 | 521d? |  |  | R5; T1 | 34400h | 34400h | MBMS-UEConTest | Rel-6 | Ingbert | MBMS-UEConTest |  |  |  |  |  |
| 3436 | 16.5.1 | RF/RRM Conformance Test Aspects – MBMS (FDD) |  | 461d | 2006-06-02 A | 2008-03-07 A | 100% | 2006-06-02 | 2008-03-07 | 461d | finish no earlier than 2008-03-07 | 2006-06-02 | R5; T1 | 7376h | 7376h | MBMS-RAN-RF_Test | Rel-6 | Ingbert | MBMS-RAN-RF_Test | 34.108, 34.109, 34.121-1, 34.121-2 | Ericsson | leif.mattisson@ericsson.com | Fri 11/03/05 |  |
| 3437 | 913.9.2 | Conformance Test Aspects - MBMS for 3.84 Mcps and 7.68 Mcps TDD |  | 318d? | 2006-09-20 A | 2007-12-07 A | 100% | 2006-09-20 | 2007-12-07 | 318d? | finish no earlier than 2007-12-07 |  | R5; T1 | 5088h | 5088h | MBMS-UEConTest_TDH | Rel-6 | Ingbert | MBMS-UEConTest_TDH | 34.108, 34.122, 34.123-1, 34.123-2, 34.123-3 | IPWireless | Timothy Speight (tspeight@ipwireless.com) |  |  |
| 3438 | 913.9.3 | Signalling Conformance Test Aspects – MBMS for LCR TDD |  | 318d? | 2006-09-20 A | 2007-12-07 A | 100% | 2006-09-20 | 2007-12-07 | 318d? | finish no earlier than 2007-12-07 |  | R5; T1 | 5088h | 5088h | MBMS-UEConTest_SIGTDL | Rel-6 | Ingbert | MBMS-UEConTest_SIGTDL | 34.108, 34.123-1, 34.123-2, 34.123-3 | Datang | zhaojian@datangmobile.cn |  |  |
| 3439 | 913.9.4 | Conformance Test Aspects – MBMS |  | 396d? | 2006-03-10 A | 2007-09-14 A | 100% | 2006-03-10 | 2007-09-14 | 396d? | finish no earlier than 2007-09-14 |  | R5; T1 | 6336h | 6336h | MBMS_Test | Rel-6 | Ingbert | MBMS_Test | 34.108, 34.123-1, 34.123-2, 34.123-3 | Qualcomm | Shubhang Vora (svora@qualcomm.com) |  |  |
| 3440 | 16.5.1 | Conformance Test Aspects - 1.28 Mcps TDD MBMS RF/RRM |  | 136d | 2007-06-01 A | 2007-12-07 A | 100% | 2007-06-01 | 2007-12-07 | 136d | finish no earlier than 2007-12-07 | 2006-06-02 | R5; T1 | 2176h | 2176h | MBMS-UEConTest_RFTDL | Rel-6 | Ingbert | MBMS-UEConTest_RFTDL | 34.108, 34.109, 34.122 | Datang | chenxiaozhong@datangmobile.cn | Fri 11/03/05 |  |
| 3441 | 28.6 | **Support of MBMS in GERAN** |  | 892d? | 2001-08-30 A | 2005-01-28 A | 100% | 2001-08-30 | 2005-01-28 | 892d? |  |  | GP; G2; G3new | 87400h | 87400h | MBMS-GERAN | Rel-6 | Paolo | MBMS-GERAN |  |  |  |  |  |
| 3442 | 28.6.1 | MBMS Impact on the logical and physical channels |  | 631d | 2002-08-30 A | 2005-01-28 A | 100% | 2002-08-30 | 2005-01-28 | 631d | finish no earlier than 2005-01-28 |  | GP | 5048h | 5048h |  | Rel-6 | Paolo |  |  |  |  |  |  |
| 3443 | 28.6.4 | MBMS Re-synchronisation at cell change |  | 631d | 2002-08-30 A | 2005-01-28 A | 100% | 2002-08-30 | 2005-01-28 | 631d | finish no earlier than 2005-01-28 |  | G2 | 5048h | 5048h |  | Rel-6 | Gert |  |  |  |  |  |  |
| 3444 | 913.10.3 | Simultaneous support of MBMS services |  | 631d? | 2002-08-30 A | 2005-01-28 A | 100% | 2002-08-30 | 2005-01-28 | 631d? | finish no earlier than 2005-01-28 |  | GP | 5048h | 5048h |  | Rel-6 | Paolo |  |  |  |  |  |  |
| 3445 | 913.10.4 | Simultaneous support of MBMS and non-MBMS services |  | 892d? | 2001-08-30 A | 2005-01-28 A | 100% | 2001-08-30 | 2005-01-28 | 892d? | finish no earlier than 2005-01-28 |  | GP | 7136h | 7136h |  | Rel-6 | Paolo |  |  |  |  |  |  |
| 3446 | 913.10.5 | MBMS Resynchronization at cell change |  | 892d? | 2001-08-30 A | 2005-01-28 A | 100% | 2001-08-30 | 2005-01-28 | 892d? | finish no earlier than 2005-01-28 |  | GP | 7136h | 7136h |  | Rel-6 | Paolo |  |  |  |  |  |  |
| 3447 | 28.6.5 | MBMS Decision making process between point-to-point or point-to-multipoint configurations |  | 631d | 2002-08-30 A | 2005-01-28 A | 100% | 2002-08-30 | 2005-01-28 | 631d | finish no earlier than 2005-01-28 |  | GP | 5048h | 5048h |  | Rel-6 | Paolo |  |  |  |  |  |  |
| 3448 | 28.6.6 | MBMS channel allocations procedures to multiple MSs |  | 631d | 2002-08-30 A | 2005-01-28 A | 100% | 2002-08-30 | 2005-01-28 | 631d | finish no earlier than 2005-01-28 |  | GP | 5048h | 5048h |  | Rel-6 | Paolo |  |  |  |  |  |  |
| 3449 | 28.6.7 | MBMS Changes to the Gb interface |  | 631d | 2002-08-30 A | 2005-01-28 A | 100% | 2002-08-30 | 2005-01-28 | 631d | finish no earlier than 2005-01-28 |  | GP | 5048h | 5048h |  | Rel-6 | Paolo |  |  |  |  |  |  |
| 3450 | 28.6.8 | GERAN specific changes to the Iu-ps interface for MBMS |  | 631d | 2002-08-30 A | 2005-01-28 A | 100% | 2002-08-30 | 2005-01-28 | 631d | finish no earlier than 2005-01-28 |  | GP | 5048h | 5048h |  | Rel-6 | Paolo |  |  |  |  |  |  |
| 3451 | 28.6.9 | Interaction between MBMS and Iu-flex |  | 631d | 2002-08-30 A | 2005-01-28 A | 100% | 2002-08-30 | 2005-01-28 | 631d | finish no earlier than 2005-01-28 |  | GP | 5048h | 5048h |  | Rel-6 | Paolo |  |  |  |  |  |  |
| 3452 | 28.6.10 | MBMS Security aspects |  | 631d | 2002-08-30 A | 2005-01-28 A | 100% | 2002-08-30 | 2005-01-28 | 631d | finish no earlier than 2005-01-28 |  | GP | 5048h | 5048h |  | Rel-6 | Paolo |  |  |  |  |  |  |
| 3453 | 913.10.12 | MBMS-GERAN - MS conformance tests |  | 786d? | 2002-01-25 A | 2005-01-28 A | 100% | 2002-01-25 | 2005-01-28 | 786d? | finish no earlier than 2005-01-28 |  | G3new | 6288h | 6288h |  | Rel-6 | Ingbert |  |  |  |  |  |  |
| 3454 | 913.10.13 | Deleted - MS conformance tests - G5 | milestone | 0d? | 2003-06-27 A | 2003-06-27 A | 100% | 2003-06-27 | 2003-06-27 | 0d? | start no earlier than 2003-06-27 |  | G5 |  |  |  | Rel-6 | Paolo |  |  |  |  |  | GP-19 |
| 3455 | 29 | **Speech Recognition and Speech Enabled Services** |  | 1105d? | 2001-10-08 A | 2005-12-30 A | 100% | 2001-10-08 | 2005-12-30 | 1105d? |  |  | S1; S2; S4; OMA | 46696h | 46696h | SRSES | Rel-6 | Alain | SRSES |  |  |  |  |  |
| 3456 | 29.1 | Speech Enabled Services Based on Distributed Speech Recognition (DSR) |  | 115d | 2001-10-08 A | 2002-03-15 A | 100% | 2001-10-08 | 2002-03-15 | 115d | finish no earlier than 2002-03-15 |  | S1 | 920h | 920h | DSR | Rel-6 | Alain | DSR | 22.977, 22.941, 23.207, 22.243 | Qualcomm | Dwilliams@qualcomm.com |  |  |
| 3457 | 29.2 | TR on Architectural impacts |  | 212d | 2003-05-12 A | 2004-03-02 A | 100% | 2003-05-12 | 2004-03-02 | 212d | finish no earlier than 2004-03-02 |  | S2 | 1696h | 1696h |  | Rel-6 | Maurice |  | 23.877 |  |  |  |  |
| 3458 | 914.3 | Codec Work to Support Speech Recognition Framework for Automated Voice Services |  | 568d? | 2002-10-15 A | 2004-12-16 A | 100% | 2002-10-15 | 2004-12-16 | 568d? | finish no earlier than 2004-12-16 |  | S4 | 4544h | 4544h | SRSES-Codec | Rel-6 | Paolo | SRSES-Codec | 26.235, 26.236, 26.243, 26.177, 26.943 | Motorola | David Pearce (bdp003@motorola.com) |  |  |
| 3459 | 914.4 | Multimodal support |  | 522d? | 2004-01-01 A | 2005-12-30 A | 100% | 2004-01-01 | 2005-12-30 | 522d? | finish no earlier than 2005-06-30 |  | OMA | 4176h | 4176h |  | Rel-6 | Paolo |  |  |  | OMA-LIAISON@mail.openmobilealliance.org | SP-24 |  |
| 3460 | 914.5 | Deleted - SES codec negotiation at Session Description Protocol (SDP) | milestone | 0d? | 2003-06-04 A | 2003-06-04 A | 100% | 2003-06-04 | 2003-06-04 | 0d? | start no earlier than 2003-06-04 |  | N1 |  |  |  | Rel-6 | Frederic |  |  |  |  |  | NP-23 |

Notes:
- 3435: -
- 3436: -
- 3437: -
- 3438: -
- 3439: -
- 3440: -
- 3441: -
- 3442: -
- 3443: -
- 3444: -
- 3445: -
- 3446: -
- 3447: -
- 3448: -
- 3449: -
- 3450: -
- 3451: -
- 3452: -
- 3453: -
- 3454: -
- 3455: -
- 3456: -
- 3457: -
- 3458: -
- 3459: -
- 3460: Abandoned NP-23

| ID | WBS | Task | Type | Duration | Start | Finish | Complete | Baseline start | Baseline finish | Baseline duration | Constraint | Resources | Work | Actual work | Acronym | Release | MCC resp | Acronym_3GU_Export | WI rapporteur name | WI rapporteur e-mail | Created at | TSG stopped | Special Focus Doc |
| --- | --- | --- | --- | --- | --- | --- | --- | --- | --- | --- | --- | --- | --- | --- | --- | --- | --- | --- | --- | --- | --- | --- | --- |
| 3461 | 30 | **Generic User Profile Rel-6** |  | 889d | 2001-10-08 A | 2005-03-03 A | 100% | 2001-10-08 | 2005-03-03 | 889d |  | S1; S3; N4 | 38519.8h | 38519.8h | GUP | Rel-6 | Alain | GUP |  |  |  |  |  |
| 3462 | 30.1 | Stage 1 - Requirements for Generic User Profile |  | 430d | 2001-10-08 A | 2003-05-30 A | 100% | 2001-10-08 | 2003-05-30 | 430d | finish no earlier than 2002-12-09 | S1 | 3440h | 3440h |  | Rel-6 | Alain |  | T-Mobile | kurt.bischinger@t-mobile.at |  |  |  |
| 3463 | 30.3 | Stage 2 - Architecture |  | 355d | 2002-01-28 A | 2003-06-06 A | 100% | 2002-01-28 | 2003-06-06 | 355d | finish no earlier than 2003-06-06 | S2 | 2840h | 2840h |  | Rel-6 | Maurice |  | Nokia | harri.o.koskinen@nokia.com |  |  |  |
| 3464 | 30.2 | Stage 2 - Data Description Method |  | 586d | 2002-12-05 A | 2005-03-03 A | 100% | 2002-12-05 | 2005-03-03 | 586d | finish no earlier than 2005-03-03 | N4 | 4688h | 4688h |  | Rel-6 | Kimmo |  | T-Mobile | kurt.bischinger@t-mobile.at |  |  |  |
| 3465 | 30.5 | Stage 3 - Network |  | 468.98d | 2003-05-19 A | 2005-03-03 A | 100% | 2003-05-19 | 2005-03-03 | 468.98d | finish no earlier than 2005-03-03 | N4 | 3751.83h | 3751.83h |  | Rel-6 | Kimmo |  |  |  |  |  |  |
| 3466 | 30.6 | Security aspects of GUP |  | 308d | 2002-07-16 A | 2003-09-18 A | 100% | 2002-07-16 | 2003-09-18 | 308d | finish no earlier than 2003-09-18 | S3 | 2464h | 2464h |  | Rel-6 | Mirko |  | Lucent | Bradley Owen (bvowen@lucent.com) |  |  |  |
| 3467 | 31 | **Digital Rights Management** |  | 690d? | 2001-10-08 A | 2004-05-28 A | 100% | 2001-10-08 | 2004-05-28 | 690d? |  | S1; OMA | 15672h | 15672h | DRM | Rel-6 | Alain | DRM |  |  |  |  |  |
| 3468 | 31.1 | Requirements for Digital Rights Management |  | 179d | 2001-10-08 A | 2002-06-13 A | 100% | 2001-10-08 | 2002-06-13 | 179d | finish no earlier than 2002-06-13 | S1 | 1432h | 1432h |  | Rel-6 | Alain |  | Openwave | nicholas.wood@openwave.com |  |  |  |
| 3469 | 916.2 | Stage 2 for Digital Rights Management |  | 107d? | 2004-01-01 A | 2004-05-28 A | 100% | 2004-01-01 | 2004-05-28 | 107d? | finish no earlier than 2004-05-28 | OMA | 856h | 856h |  | Rel-6 |  |  |  | OMA-LIAISON@mail.openmobilealliance.org | SP-24 |  |  |
| 3470 | 916.3 | Stage 3 for Digital Rights Management |  | 107d? | 2004-01-01 A | 2004-05-28 A | 100% | 2004-01-01 | 2004-05-28 | 107d? | finish no earlier than 2004-05-28 | OMA | 856h | 856h |  | Rel-6 |  |  |  | OMA-LIAISON@mail.openmobilealliance.org | SP-24 |  |  |
| 3471 | 31.3 | Security for Digital Rights Management |  | 186d | 2002-06-17 A | 2003-03-03 A | 100% | 2002-06-17 | 2003-03-03 | 186d | finish no earlier than 2003-03-03 | OMA | 1488h | 1488h |  | Rel-6 |  |  |  |  |  |  |  |
| 3472 | 916.5 | Deleted - Monitoring of Stages 2 and 3 progress (actual work to be done by OMA) | milestone | 0d? | 2003-03-21 A | 2003-03-21 A | 100% | 2003-03-21 | 2003-03-21 | 0d? | start no earlier than 2002-08-19 | S1 |  |  |  | Rel-6 | Alain |  |  |  |  | SP-19 |  |
| 3473 | 32 | **WLAN-UMTS Interworking Rel-6** |  | 1495d? | 2000-01-03 A | 2005-09-22 A | 100% | 2000-01-03 | 2005-09-22 | 1495d? |  | S1; S2; S3; S5; N1; N3; N4; T3 | 129192h | 129192h | WLAN | Rel-6 | Alain | WLAN | Telenor | frederic.paint@telenor.com |  |  | WLAN |
| 3474 | 32.1 | Technical Report on WLAN-UMTS Interworking |  | 901d? | 2000-01-03 A | 2003-06-13 A | 100% | 2000-01-03 | 2003-06-13 | 901d? | finish no earlier than 2003-06-13 | S1 | 7200h | 7200h | WLAN-TR | Rel-6 | Alain | WLAN-TR | T-mobile | Mark.Younge@t-mobile.com |  |  | WLAN |
| 3475 | 917.2 | Stage 1 for WLAN-UMTS Interworking Rel-6 |  | 375d? | 2003-01-06 A | 2004-06-11 A | 100% | 2003-01-06 | 2004-06-11 | 375d? |  | S1 | 920h | 920h | WLAN-TS | Rel-6 | Alain | WLAN-TS | Telenor | frederic.paint@telenor.com | SP-24 |  | WLAN |
| 3476 | 32.2 | Architecture Definition for scenarii 2 and 3 |  | 571d | 2002-03-25 A | 2004-05-31 A | 100% | 2002-03-25 | 2004-05-31 | 571d | finish no earlier than 2004-05-31 | S2 | 4568h | 4568h |  | Rel-6 | Maurice |  |  |  |  |  | WLAN |
| 3477 | 32.3 | Security aspects of WLAN-UMTS Interworking |  | 125d | 2002-09-30 A | 2003-03-21 A | 100% | 2002-09-30 | 2003-03-21 | 125d | finish no earlier than 2003-03-21 | S3 | 1000h | 1000h |  | Rel-6 | Mirko |  | Ericsson, BT | luis.lopez-soria@ece.ericsson.se, colin.blanchard@bt.com |  |  | WLAN |
| 3478 | 917.5 | Stage 3 - CN4 aspects |  | 334d? | 2003-05-23 A | 2004-09-01 A | 100% | 2003-05-23 | 2004-09-01 | 334d? | finish no earlier than 2004-09-01 | N4 | 2672h | 2672h | WLAN-IW | Rel-6 | Kimmo | WLAN-IW | Nokia | raquel.rodriguez@nokia.com |  |  | WLAN |
| 3479 | 917.6 | Stage 3 - CN3 aspects (Wi Interface for Scenario 3) |  | 355d? | 2003-05-23 A | 2004-09-30 A | 100% | 2003-05-23 | 2004-09-30 | 355d? | start no earlier than 2003-05-23 | N3 | 2840h | 2840h |  | Rel-6 | Gwiho |  |  |  | SP-24 |  | WLAN |
| 3480 | 917.7 | Stage 3 for scenario 2 |  | 339d? | 2003-05-23 A | 2004-09-08 A | 100% | 2003-05-23 | 2004-09-08 | 339d? | finish no earlier than 2004-09-08 | N1 | 2712h | 2712h |  | Rel-6 | Frederic |  |  |  |  |  | WLAN |
| 3481 | 917.8 | Stage 3 for scenario 3 |  | 404d? | 2003-05-23 A | 2004-12-08 A | 100% | 2003-05-23 | 2004-12-08 | 404d? | finish no earlier than 2004-12-08 | N1 | 3232h | 3232h |  | Rel-6 | Frederic |  |  |  | SP-24 |  | WLAN |
| 3482 | 917.9 | WLAN charging |  | 655d? | 2003-03-21 A | 2005-09-22 A | 100% | 2003-03-21 | 2005-09-22 | 655d? | finish no earlier than 2005-09-22 | S5 | 5240h | 5240h | WLAN-CH | Rel-6 | Mirko | WLAN-CH | Nokia | Benni ALEXANDER |  |  | WLAN |
| 3483 | 917.10 | USIM enhancements for WLAN Interworking |  | 391d? | 2003-09-05 A | 2005-03-04 A | 100% | 2003-09-05 | 2005-03-04 | 391d? | finish no earlier than 2005-03-04 | T3 | 3128h | 3128h |  | Rel-6 | Xavier |  | Axalto | Jabellan@axalto.com |  |  | WLAN |
| 3484 | 33 | **Priority Service** |  | 347d? | 2002-05-30 A | 2003-09-26 A | 100% | 2002-05-30 | 2003-09-26 | 347d? |  | S1 | 6464h | 6464h | PRIOR1 | Rel-6 | Alain | PRIOR1 | Telcordia | James Garrahan (jgarraha@telcordia.com) |  |  | Public Safety (I-A) |
| 3485 | 33.1 | Feasibility Study on Priority Service |  | 1d | 2002-06-14 A | 2002-06-14 A | 100% | 2002-06-14 | 2002-06-14 | 1d | finish no earlier than 2002-06-14 | S1 | 8h | 8h | PRIOR-FS | Rel-6 | Alain | PRIOR-FS | Telcordia | James Garrahan (jgarraha@telcordia.com) |  |  | Public Safety (I-A) |
| 3486 | 33.2 | Stage 1 - Requirements for Priority Service |  | 340d | 2002-05-30 A | 2003-09-17 A | 100% | 2002-05-30 | 2003-09-17 | 340d | finish no earlier than 2003-09-17 | S1 | 2720h | 2720h | PRIOR-SR | Rel-6 | Alain | PRIOR-SR | Telcordia | James Garrahan (jgarraha@telcordia.com) |  |  | Public Safety (I-A) |
| 3487 | 918.3 | Priority service implementation guide |  | 131d? | 2003-03-28 A | 2003-09-26 A | 100% | 2003-03-28 | 2003-09-26 | 131d? | finish no earlier than 2003-09-26 | S1 | 1048h | 1048h |  | Rel-6 | Alain |  | Telcordia | James Garrahan (jgarraha@telcordia.com) |  |  | Public Safety (I-A) |

Notes:
- 3461: -
- 3462: - / Impacted TSs and TRs: 22.240, 22.228
- 3463: - / Impacted TSs and TRs: 23.240
- 3464: TR approved in CN#26 / Impacted TSs and TRs: 23.241
- 3465: - / Impacted TSs and TRs: 29.240
- 3466: SP#19 approved WID / Impacted TSs and TRs: 33.102, 33.203, 33.210
- 3467: Foreseen start and completion dates introduced by MCC (no indication at all on the WID)
- 3468: -
- 3469: -
- 3470: -
- 3471: SA3 acknowledge role in WI at SA3#20. Active contribution S3#24, S3#25. S3 WID approved SP#17
- 3472: Replaced by UID 60005 and 60006
- 3473: -
- 3474: - / Impacted TSs and TRs: 22.934
- 3475: - / Impacted TSs and TRs: 22.101, 22.105
- 3476: - / Impacted TSs and TRs: 23.234
- 3477: SP#17 approved WID S3-020451 / Impacted TSs and TRs: 21.133, 33.106, 33.107, 33.108, 33.200, 33.203, 33.210, New 33.234
- 3478: WID approved at CN#19 / Impacted TSs and TRs: 29.234, 29.061
- 3479: - / Impacted TSs and TRs: 29.161
- 3480: -
- 3481: -
- 3482: - / Impacted TSs and TRs: 32.252
- 3483: - / Impacted TSs and TRs: 31.102
- 3484: -
- 3485: - / Impacted TSs and TRs: 22.950
- 3486: -
- 3487: - / Impacted TSs and TRs: 22.952

| ID | WBS | Task | Type | Duration | Start | Finish | Complete | Baseline start | Baseline finish | Baseline duration | Constraint | Deadline | Resources | Work | Actual work | Acronym | WI rapporteur name | WI rapporteur e-mail | Release | MCC resp | Acronym_3GU_Export | Created at | TSG stopped |
| --- | --- | --- | --- | --- | --- | --- | --- | --- | --- | --- | --- | --- | --- | --- | --- | --- | --- | --- | --- | --- | --- | --- | --- |
| 3488 | 34 | **Network Sharing** |  | 820d? | 2003-01-20 A | 2006-03-10 A | 100% | 2003-01-20 | 2006-03-10 | 820d? |  |  | S1; S2; N1; R2; R5 | 44936h | 44936h | NTShar | T-Mobile | michele.zarri@t-mobile.co.uk | Rel-6 | Alain | NTShar |  |  |
| 3489 | 34.1 | Technical Report on Network Sharing |  | 240d? | 2003-01-20 A | 2003-12-19 A | 100% | 2003-01-20 | 2003-12-19 | 240d? |  |  | S1 | 1920h | 1920h | NTShar-TR | T-Mobile | michele.zarri@t-mobile.co.uk | Rel-6 | Alain | NTShar-TR |  |  |
| 3490 | 919.2 | Stage 1 - CRs to implement Network Sharing |  | 240d? | 2003-01-20 A | 2003-12-19 A | 100% | 2003-01-20 | 2003-12-19 | 240d? | finish no earlier than 2003-12-19 |  | S1 | 1920h | 1920h | NTSharCR | T-Mobile | michele.zarri@t-mobile.co.uk | Rel-6 | Alain | NTSharCR |  |  |
| 3491 | 919.3 | Stage 2 for Network Sharing |  | 372d? | 2003-02-27 A | 2004-07-30 A | 100% | 2003-02-27 | 2004-07-30 | 372d? | finish no earlier than 2004-07-30 |  | S2 | 2976h | 2976h |  | T-Mobile | michele.zarri@t-mobile.co.uk | Rel-6 | Maurice |  |  |  |
| 3492 | 919.4 | Network sharing - stage 3 |  | 404d? | 2003-05-23 A | 2004-12-08 A | 100% | 2003-05-23 | 2004-12-08 | 404d? | finish no earlier than 2004-12-08 |  | N1 | 3232h | 3232h |  | T-Mobile | michele.zarri@t-mobile.co.uk | Rel-6 | Frederic |  |  |  |
| 3493 | 919.5 | Enhancement of the support of network sharing in the UTRAN | milestone | 0d | 2003-09-19 A | 2003-09-19 A | 100% | 2003-09-19 | 2003-09-19 | 0d |  |  | R2 |  |  | NTShar-UTRANEnh | TeliaSonera | Anders.Dahlen@TeliaSonera.com | Rel-6 | Yong-Jun | NTShar-UTRANEnh |  |  |
| 3494 | 16.5.1 | Conformance Test Aspects – Network Sharing |  | 261d | 2005-03-11 A | 2006-03-10 A | 100% | 2005-03-11 | 2006-03-10 | 261d | finish no earlier than 2006-03-10 | 2006-03-10 | R5 | 2088h | 2088h | NTShar-UTRANEnh_Test | TeliaSonera | Niklas.Wiren@TeliaSonera.com | Rel-6 | Ingbert | NTShar-UTRANEnh_Test | Fri 11/03/05 |  |
| 3495 | 35 | **QoS Improvements** |  | 628d? | 2002-07-15 A | 2004-12-08 A | 100% | 2002-07-15 | 2004-12-08 | 628d? |  |  | S2; N3 | 18152h | 18152h | QoS1 | Nokia |  | Rel-6 | Maurice | QoS1 |  |  |
| 3496 | 35.1 | FS on Dynamic Policy control enhancements for end-to-end QoS |  | 465d | 2002-07-15 A | 2004-04-23 A | 100% | 2002-07-15 | 2004-04-23 | 465d | finish no earlier than 2004-04-23 |  | S2 | 3720h | 3720h |  | Nortel | Claire Mousset | Rel-6 | Maurice |  |  |  |
| 3497 | 920.2 | Definition of the Gq interface |  | 214d? | 2003-07-01 A | 2004-04-23 A | 100% | 2003-07-01 | 2004-04-23 | 214d? | finish no earlier than 2004-04-23 |  | S2 | 1712h | 1712h |  |  | Janne Rinne | Rel-6 | Maurice |  |  |  |
| 3498 | 920.3 | Gq interface specification for Dynamic Policy control enhancements – Stage 3 |  | 334d | 2003-08-29 A | 2004-12-08 A | 100% | 2003-08-29 | 2004-12-08 | 334d | finish no earlier than 2004-12-08 |  | N3 | 2672h | 2672h |  | Nokia | Anna.Sillanpaai@nokia.com | Rel-6 | Gwiho |  |  |  |
| 3499 | 36 | **Subscriber certificates** |  | 728d? | 2002-02-25 A | 2004-12-08 A | 100% | 2002-02-25 | 2004-12-08 | 728d? |  |  | S3; S2; N1; N4; T3; OMA | 44512h | 44512h | SEC1-SC | Nokia | valtteri.niemi@nokia.com | Rel-6 | Mirko | SEC1-SC |  |  |
| 3500 | 36.1 | Stage 1 of Subscriber certificates |  | 144d | 2002-02-25 A | 2002-09-12 A | 100% | 2002-02-25 | 2002-09-12 | 144d | finish no earlier than 2002-09-12 |  | S3 | 1152h | 1152h |  | Nokia | valtteri.niemi@nokia.com | Rel-6 | Mirko |  |  |  |
| 3501 | 36.2 | Architecture review |  | 24d | 2002-10-14 A | 2002-11-14 A | 100% | 2002-10-14 | 2002-11-14 | 24d | finish no earlier than 2002-11-14 |  | S2 | 192h | 192h |  | Nokia |  | Rel-6 | Maurice |  |  |  |
| 3502 | 921.3 | Stage 3 for Subscriber certificates |  | 313d? | 2003-09-19 A | 2004-11-30 A | 100% | 2003-09-19 | 2004-11-30 | 313d? | finish no earlier than 2004-11-30 |  | N4; T3 | 5008h | 5008h |  | Nokia | Lauri Laitinen | Rel-6 | Kimmo |  |  |  |
| 3503 | 921.4 | Stage 3 Ua & Ub interfaces |  | 288d? | 2003-11-03 A | 2004-12-08 A | 100% | 2003-11-03 | 2004-12-08 | 288d? | finish no earlier than 2004-12-08 |  | N1 | 2304h | 2304h |  | Nokia |  | Rel-6 | Frederic |  |  |  |
| 3504 | 921.5 | OMA dependencies on Subscriber certificates |  | 114d? | 2004-01-01 A | 2004-06-08 A | 100% | 2004-01-01 | 2004-06-08 | 114d? | finish no earlier than 2004-06-08 |  | OMA | 912h | 912h |  | Nokia | OMA-LIAISON@mail.openmobilealliance.org | Rel-6 |  |  | SP-24 |  |
| 3505 | 922 | **Rel-6 Open Service Access (OSA) enhancements** |  | 616d? | 2002-10-31 A | 2005-03-10 A | 100% | 2002-10-31 | 2005-03-10 | 616d? |  |  | N5 | 22576h | 22576h | OSA3 | Alcatel | Chelo.Abarca@alcatel.fr | Rel-6 | Kimmo | OSA3 |  |  |
| 3506 | 922.1 | Scope of the Open Service Access Release 6 |  | 66d? | 2003-03-28 A | 2003-06-27 A | 100% | 2003-03-28 | 2003-06-27 | 66d? | finish no earlier than 2003-06-27 |  | S1 | 528h | 528h |  |  |  | Rel-6 | Alain |  |  |  |
| 3507 | 922.2 | OSA Stage 2 |  | 150d? | 2004-08-13 A | 2005-03-10 A | 100% | 2004-08-13 | 2005-03-10 | 150d? | finish no earlier than 2005-03-10 |  | N5 | 1200h | 1200h |  |  |  | Rel-6 | Kimmo |  |  |  |
| 3508 | 922.3 | Multi Media Messaging function |  | 487d? | 2002-10-31 A | 2004-09-10 A | 100% | 2002-10-31 | 2004-09-10 | 487d? | finish no earlier than 2004-09-10 |  | N5 | 3896h | 3896h |  |  |  | Rel-6 | Kimmo |  |  |  |
| 3509 | 922.4 | Policy management extensions |  | 292d? | 2002-10-31 A | 2003-12-12 A | 100% | 2002-10-31 | 2003-12-12 | 292d? | finish no earlier than 2003-12-12 |  | N5 | 2336h | 2336h |  |  |  | Rel-6 | Kimmo |  |  |  |
| 3510 | 922.5 | TS on Presence and Availability Management (from the PRESNC WI) |  | 367d? | 2002-10-31 A | 2004-03-26 A | 100% | 2002-10-31 | 2004-03-26 | 367d? | finish no earlier than 2004-03-26 |  | N5 | 2936h | 2936h |  |  |  | Rel-6 | Kimmo |  |  |  |
| 3511 | 922.6 | OSA interfaces at different levels of abstractions (Parlay X, Web services) |  | 305d? | 2003-07-14 A | 2004-09-10 A | 100% | 2003-07-14 | 2004-09-10 | 305d? | finish no earlier than 2004-09-10 |  | N5 | 2440h | 2440h |  |  |  | Rel-6 | Kimmo |  |  |  |
| 3512 | 922.7 | Introduction of migration support mechanism |  | 290d? | 2002-10-31 A | 2003-12-10 A | 100% | 2002-10-31 | 2003-12-10 | 290d? | finish no earlier than 2003-12-12 |  | N5 | 2320h | 2320h |  |  |  | Rel-6 | Kimmo |  |  |  |
| 3513 | 922.8 | Framework Function for Federation |  | 225d? | 2003-02-03 A | 2003-12-12 A | 100% | 2003-02-03 | 2003-12-12 | 225d? | finish no earlier than 2003-12-12 |  | N5 | 1800h | 1800h |  |  |  | Rel-6 | Kimmo |  |  |  |
| 3514 | 922.9 | OMA potential overlaps with 3GPP OSA Stage 3 (Web services) |  | 196d? | 2003-12-18 A | 2004-09-16 A | 100% | 2003-12-18 | 2004-09-16 | 196d? | start no earlier than 2003-12-18 |  | OMA | 1568h | 1568h |  |  |  | Rel-6 |  |  | SP-24 |  |
| 3515 | 922.10 | Deleted - TR on Presence and Availability Management (from the PRESNC WI) | milestone | 0d? | 2004-09-17 A | 2004-09-17 A | 100% | 2004-09-17 | 2004-09-17 | 0d? | start no earlier than 2004-09-17 |  | N5 |  |  |  |  |  | Rel-6 | Kimmo |  |  | NP-24 |

Notes:
- 3488: -
- 3489: - / Impacted TSs and TRs: 22.951
- 3490: - / Impacted TSs and TRs: 22.011, 22.101, 22.115, 22.129
- 3491: - / Impacted TSs and TRs: 23.002, 23.060, 23.221, 23.236, new TS 23.251, TR 23.851
- 3492: - / Impacted TSs and TRs: 23.008, 23.122, 24.007, 24.008, 29.018
- 3493: - / Impacted TSs and TRs: 25.401, 25.413, 25.331, 25.304
- 3494: - / Impacted TSs and TRs: 34.108, 34.123-1, 34.123-2, 34.123-3
- 3495: - / Impacted TSs and TRs: 23.107, 23.207, 23.221
- 3496: - / Impacted TSs and TRs: 23.917 withdrawn (Contents all in 23.207)
- 3497: - / Impacted TSs and TRs: 23.207
- 3498: [DAB - 25.05.04] - Delayed to Sept - possibly Dec 2004 / Impacted TSs and TRs: 29.207, 29.208, 29.209
- 3499: SP#14 approved WID
- 3500: - / Impacted TSs and TRs: New (33.220, 33.221, 33.222, 33.246, 33.919)
- 3501: -
- 3502: Finished in CN4#26 / Impacted TSs and TRs: 23.003, 23.008, 29.109, 29.230, T3 31.102, 31.103, 31.111
- 3503: - / Impacted TSs and TRs: 24.109
- 3504: Updated according to SP-040420
- 3505: CN#25: Updated WID NP-040351 replaces NP-040144. / Impacted TSs and TRs: 22.127, 23.198, 29.198, 29.199, 29.998
- 3506: -
- 3507: Inherited by CN5 from SA2 at TSG#25 Sep 2004. SA2's 23.127 (OSA/VHE Stage 2) replaced from Rel-6 onwards by a new CN5 TS 23.198 (Stage 2 OSA-only). / Impacted TSs and TRs: 23.198 OSA Stage 2-ONLY replaces 23.127 (OSA/VHE) from Rel-6 onwards
- 3508: - / Impacted TSs and TRs: 29.198-15
- 3509: - / Impacted TSs and TRs: 29.198, 29.998
- 3510: N5#26: Split WI into TS & TR. / Impacted TSs and TRs: 29.198-14
- 3511: - / Impacted TSs and TRs: 29.199
- 3512: - / Impacted TSs and TRs: 29.198, 29.998
- 3513: - / Impacted TSs and TRs: 29.198, 29.998
- 3514: TSG#25 Approved CN5 29.199 Parlay X Web services. Ongoing 3GPP/OMA co-ordination to avoid OMA producing conflicting/OVERLAPING specs (NP-040283/SP-040493).
- 3515: N5#26:TR Completion 09/04; consistent with CN1 delayed Rel-6 completion.

| ID | WBS | Task | Duration | Start | Finish | Complete | Baseline start | Baseline finish | Baseline duration | Constraint | Resources | Work | Actual work | Acronym | WI rapporteur name | WI rapporteur e-mail | Release | MCC resp | Acronym_3GU_Export | TSG stopped |
| --- | --- | --- | --- | --- | --- | --- | --- | --- | --- | --- | --- | --- | --- | --- | --- | --- | --- | --- | --- | --- |
| 3516 | 39 | **Addition of frequency bands to GSM (TAPS)** | 676d | 2002-06-28 A | 2005-01-28 A | 100% | 2002-06-28 | 2005-01-28 | 676d |  | GP | 16640h | 16640h | TAPS | Nokia | Torben Themsen | Rel-6 | Paolo | TAPS |  |
| 3517 | 39.1 | **Addition of frequency bands to GSM – Changes to core specs** | 26d | 2002-11-15 A | 2002-12-20 A | 100% | 2002-11-15 | 2002-12-20 | 26d |  | G1 | 416h | 416h | TAPS-Specs | Nokia | Torben Themsen | Rel-6 | Paolo | TAPS-Specs |  |
| 3518 | 39.1.1 | Changes to core specs | 26d | 2002-11-15 A | 2002-12-20 A | 100% | 2002-11-15 | 2002-12-20 | 26d | finish no earlier than 2002-12-20 | G1 | 208h | 208h |  | Nokia | Torben Themsen | Rel-6 | Paolo |  |  |
| 3519 | 39.2 | **Deleted - Addition of frequency bands to GSM – Changes for conformance tests** | 676d | 2002-06-28 A | 2005-01-28 A | 100% | 2002-06-28 | 2005-01-28 | 676d |  | G4 | 10816h | 10816h | TAPS-Conf | Nokia | Torben Themsen | Rel-6 | Paolo | TAPS-Conf | GP-23 |
| 3520 | 39.2.1 | Deleted - 51.010-1 Add testing | 676d | 2002-06-28 A | 2005-01-28 A | 100% | 2002-06-28 | 2005-01-28 | 676d | finish no earlier than 2005-01-28 | G4 | 5408h | 5408h |  | Nokia | Torben Themsen | Rel-6 | Paolo |  | GP-23 |
| 3521 | 40 | **Seamless support of streaming services in A/Gb mode** | 1426d? | 2000-01-03 A | 2005-06-17 A | 100% | 2000-01-03 | 2005-06-17 | 1426d? |  | GP; S3 | 70312h | 70312h | SSStrea | Vodafone | José Luis Carrizo Martínez | Rel-6 | Paolo | SSStrea |  |
| 3522 | 40.1 | **Identification of requirements for streaming** | 46d? | 2003-06-27 A | 2003-08-29 A | 100% | 2003-06-27 | 2003-08-29 | 46d? |  | G1 | 736h | 736h |  | Vodafone | José Luis Carrizo Martínez | Rel-6 | Paolo |  |  |
| 3523 | 924.1.1 | Requirements for streaming | 46d? | 2003-06-27 A | 2003-08-29 A | 100% | 2003-06-27 | 2003-08-29 | 46d? | finish no earlier than 2003-08-29 | G1 | 368h | 368h |  | Vodafone | José Luis Carrizo Martínez | Rel-6 | Paolo |  |  |
| 3524 | 40.2 | **Performance study of cell change mechanisms** | 956d? | 2000-01-03 A | 2003-08-29 A | 100% | 2000-01-03 | 2003-08-29 | 956d? |  | G1 | 30568h | 30568h |  | Vodafone | José Luis Carrizo Martínez | Rel-6 | Paolo |  |  |
| 3525 | 924.2.1 | Performance of NACC | 956d? | 2000-01-03 A | 2003-08-29 A | 100% | 2000-01-03 | 2003-08-29 | 956d? | finish no earlier than 2003-08-29 | G1 | 7640h | 7640h |  | Vodafone | José Luis Carrizo Martínez | Rel-6 | Paolo |  |  |
| 3526 | 924.2.2 | Performance of cell change in DTM for the PS domain | 956d? | 2000-01-03 A | 2003-08-29 A | 100% | 2000-01-03 | 2003-08-29 | 956d? | finish no earlier than 2003-08-29 | G1 | 7640h | 7640h |  | Vodafone | José Luis Carrizo Martínez | Rel-6 | Paolo |  |  |
| 3527 | 924.2.3 | Handover for Seamless support of streaming services in A/Gb mode | 956d? | 2000-01-03 A | 2003-08-29 A | 100% | 2000-01-03 | 2003-08-29 | 956d? | finish no earlier than 2003-08-29 | G1 | 7640h | 7640h |  | Vodafone | José Luis Carrizo Martínez | Rel-6 | Paolo |  |  |
| 3528 | 40.3 | **Reduction of service interruption times and packet loss during mobility procedures** | 516d? | 2003-06-27 A | 2005-06-17 A | 100% | 2003-06-27 | 2005-06-17 | 516d? |  | G2 | 10800h | 10800h |  | Vodafone | José Luis Carrizo Martínez | Rel-6 | Gert |  |  |
| 3529 | 924.3.1 | optimizations of existing mechanisms/procedures | 106d? | 2003-06-27 A | 2003-11-21 A | 100% | 2003-06-27 | 2003-11-21 | 106d? | finish no earlier than 2003-11-21 | G2 | 848h | 848h |  | Vodafone | José Luis Carrizo Martínez | Rel-6 | Gert |  |  |
| 3530 | 924.3.2 | Inter-system NACC | 106d? | 2003-06-27 A | 2003-11-21 A | 100% | 2003-06-27 | 2003-11-21 | 106d? | finish no earlier than 2003-11-21 | G2 | 848h | 848h |  | Vodafone | José Luis Carrizo Martínez | Rel-6 | Gert |  |  |
| 3531 | 924.3.3 | PS Handover (within GERAN and between GERAN and UTRAN) | 516d? | 2003-06-27 A | 2005-06-17 A | 100% | 2003-06-27 | 2005-06-17 | 516d? | finish no earlier than 2003-11-21 | G2 | 4128h | 4128h |  | Vodafone | José Luis Carrizo Martínez | Rel-6 | Gert |  |  |
| 3532 | 924.3.4 | Dependency to other features of Reduction of service interruption times and packet loss during mobility procedures | 106d? | 2003-06-27 A | 2003-11-21 A | 100% | 2003-06-27 | 2003-11-21 | 106d? | finish no earlier than 2003-11-21 | G2 | 848h | 848h |  | Vodafone | José Luis Carrizo Martínez | Rel-6 | Gert |  |  |
| 3533 | 40.5 | **Deleted - MS conformance testing for Seamless support of streaming services in A/Gb mode** | 31d? | 2003-12-19 A | 2004-01-30 A | 100% | 2003-12-19 | 2004-01-30 | 31d? |  | G3new | 496h | 496h |  | Vodafone | José Luis Carrizo Martínez | Rel-6 | Ingbert |  | GP-27 |
| 3534 | 924.4.1 | Deleted - MS conformance tests for Seamless support of streaming services in A/Gb mode | 31d? | 2003-12-19 A | 2004-01-30 A | 100% | 2003-12-19 | 2004-01-30 | 31d? | finish no earlier than 2004-01-30 | G4; G5 | 496h | 496h |  | Vodafone | José Luis Carrizo Martínez | Rel-6 | Ingbert |  | GP-27 |
| 3535 | 924.5 | GERAN A/Gb mode security enhancements | 612d? | 2002-09-26 A | 2005-01-28 A | 100% | 2002-09-26 | 2005-01-28 | 612d? | finish no earlier than 2005-01-28 | S3 | 4896h | 4896h |  | Vodafone | peter.howard@vodafone.com | Rel-6 | Mirko |  |  |
| 3536 | 41 | Performance characterisation of default codecs for PS conversational multimedia application | 455d | 2002-09-13 A | 2004-06-10 A | 100% | 2002-09-13 | 2004-06-10 | 455d | finish no earlier than 2004-06-10 | S4 | 3640h | 3640h | CODCAR | Nokia | pasi.s.ojala@nokia.com | Rel-6 | Paolo | CODCAR |  |
| 3537 | 43 | Study on Privacy Capability | 83d | 2003-11-10 A | 2004-03-03 A | 100% | 2003-11-10 | 2004-03-03 | 83d | start no earlier than 2003-11-10 | S1 | 664h | 664h | PrivCap | Lucent | Michael Boote (mboote@alcatel-lucent.com) | Rel-6 | Alain | PrivCap |  |
| 3538 | 44 | **Rel-6 Operations, Administration, Maintenance and Provisioning (OAM&P)** | 652d? | 2002-09-12 A | 2005-03-11 A | 100% | 2002-09-12 | 2005-03-11 | 652d? |  | S5 | 42635.5h | 42635.5h | OAM6 |  |  | Rel-6 | Mirko | OAM6 |  |
| 3539 | 44.1 | Principles, high level Requirements and Architecture | 526d | 2002-09-12 A | 2004-09-16 A | 100% | 2002-09-12 | 2004-09-16 | 526d | finish no earlier than 2004-09-16 | S5 | 4208h | 4208h |  | Motorola |  | Rel-6 | Mirko |  |  |
| 3540 | 44.2 | Performance Management | 591d | 2002-09-12 A | 2004-12-16 A | 100% | 2002-09-12 | 2004-12-16 | 591d | finish no earlier than 2004-12-16 | S5 | 4728h | 4728h |  | Nortel |  | Rel-6 | Mirko |  |  |
| 3541 | 44.4 | Network Infrastructure Management | 591d | 2002-09-12 A | 2004-12-16 A | 100% | 2002-09-12 | 2004-12-16 | 591d | finish no earlier than 2004-12-16 | S5 | 4728h | 4728h |  | Ericsson | thomas.tovinger@ericsson.com | Rel-6 | Mirko |  |  |

Notes:
- 3516: -
- 3517: -
- 3518: -
- 3519: -
- 3520: -
- 3521: -
- 3522: -
- 3523: -
- 3524: -
- 3525: -
- 3526: -
- 3527: -
- 3528: Completed at GERP#17
- 3529: -
- 3530: -
- 3531: -
- 3532: -
- 3533: Marked as stopped 10/2009
- 3534: Marked as stopped 10/2009
- 3535: SP#19 approved WID / Impacted TSs and TRs: 33.102
- 3536: - / Impacted TSs and TRs: 26.935
- 3537: - / Impacted TSs and TRs: 22.949
- 3538: SP#26: Updated WID SP-040766 was SP-020445. Completion delayed 12/04->03/05 due to OAM-Trace in CN1/4.
- 3539: SP#25 09/2004 completed / Impacted TSs and TRs: 32.101, 32.102
- 3540: SP#26 12/2004 completed / Impacted TSs and TRs: 32.401, 32.403, 52.402, 32.411, 32.412, 32.413, 32.432, 32.435, 32.436
- 3541: SP#26 12/2004 completed / Impacted TSs and TRs: 32.150/1/2, 32.805, 32.111-5, 32.313/4, 32.331/2/3/4/5, 32.341/2/3/4, 32.351/2/3/4, 32.361/2/3/4, 32.371/2/3/4, 32.804, 32.675, 32.690, 32.695, 32.71/2/3/4/5, 32.741/2/3/4/5

| ID | WBS | Task | Duration | Start | Finish | Complete | Baseline start | Baseline finish | Baseline duration | Constraint | Resources | Work | Actual work | Acronym | WI rapporteur name | WI rapporteur e-mail | Release | MCC resp | Acronym_3GU_Export | Impacted TSs and TRs | Created at | TSG stopped |
| --- | --- | --- | --- | --- | --- | --- | --- | --- | --- | --- | --- | --- | --- | --- | --- | --- | --- | --- | --- | --- | --- | --- |
| 3542 | 44.5 | **Rel-6 Trace Management** | 646d? | 2002-09-20 A | 2005-03-11 A | 100% | 2002-09-20 | 2005-03-11 | 646d? |  | S5; N4; R3 | 23877.9h | 23877.9h | OAM-Trace | Nokia | kari.t.ronka@nokia.com | Rel-6 | Mirko | OAM-Trace |  |  |  |
| 3543 | 927.4.1 | Subscriber and UE trace management | 585d | 2002-09-20 A | 2004-12-16 A | 100% | 2002-09-20 | 2004-12-16 | 585d | finish no earlier than 2004-12-16 | S5 | 4680h | 4680h |  | Nokia | kari.t.ronka@nokia.com | Rel-6 | Mirko |  | 32.421, 32.422, 32.423, 52.008 |  |  |
| 3544 | 927.4.2 | Subscriber and equipment trace in UTRAN | 268d? | 2003-06-06 A | 2004-06-15 A | 100% | 2003-06-06 | 2004-06-15 | 268d? | finish no earlier than 2004-06-15 | R3 | 2144h | 2144h | OAM-Trace-RAN | Nortel | Yann Sehedi (sehedic@nortelnetworks.com) | Rel-6 | Juha | OAM-Trace-RAN | 25.413, 25.420, 25.423 |  |  |
| 3545 | 927.4.3 | Trace Management, Stage3 | 193.74d? | 2004-06-09 A | 2005-03-11 A | 100% | 2004-06-09 | 2005-03-11 | 193.74d? | finish no earlier than 2005-03-11 | N4 | 1549.92h | 1549.92h |  | Nokia | seppo.kauntola@nokia.com | Rel-6 | Kimmo |  | 23.205, 29.232, 29.060, 29.002, 29.228 |  |  |
| 3546 | 928 | **Rel-6 Charging Management** | 666d? | 2002-11-21 A | 2005-06-09 A | 100% | 2002-11-21 | 2005-06-09 | 666d? |  | S5; S2; N3 | 67152h | 67152h | CH | T-Mobile | karl-heinz.nenner@t-mobile.de | Rel-6 | Mirko | CH |  |  |  |
| 3547 | 928.1 | Charging architecture and principles | 390d? | 2003-03-21 A | 2004-09-16 A | 100% | 2003-03-21 | 2004-09-16 | 390d? | start no earlier than 2003-03-21 | S5 | 3120h | 3120h |  |  |  | Rel-6 | Mirko |  | 32.240 |  |  |
| 3548 | 928.2 | Charging Data Record (CDR) file format and transfer | 260d? | 2003-03-21 A | 2004-03-18 A | 100% | 2003-03-21 | 2004-03-18 | 260d? | start no earlier than 2003-03-21 | S5 | 2080h | 2080h |  |  |  | Rel-6 | Mirko |  | 32.297 |  |  |
| 3549 | 928.3 | CDR parameter description | 580d? | 2003-03-21 A | 2005-06-09 A | 100% | 2003-03-21 | 2005-06-09 | 580d? | finish no earlier than 2005-06-09 | S5 | 4640h | 4640h |  |  |  | Rel-6 | Mirko |  | 32.298 |  |  |
| 3550 | 928.4 | Diameter charging applications | 390d? | 2003-03-21 A | 2004-09-16 A | 100% | 2003-03-21 | 2004-09-16 | 390d? | start no earlier than 2003-03-21 | S5 | 3120h | 3120h |  |  |  | Rel-6 | Mirko |  | 32.299 |  |  |
| 3551 | 928.5 | Online Charging System (OCS) architecture study | 130d? | 2003-03-21 A | 2003-09-18 A | 100% | 2003-03-21 | 2003-09-18 | 130d? | start no earlier than 2003-03-21 | S5 | 1040h | 1040h |  |  |  | Rel-6 | Mirko |  | 32.815 |  |  |
| 3552 | 928.6 | OCS: Applications and interfaces | 455d? | 2003-03-21 A | 2004-12-16 A | 100% | 2003-03-21 | 2004-12-16 | 455d? | start no earlier than 2003-03-21 | S5 | 3640h | 3640h |  |  |  | Rel-6 | Mirko |  | 32.296 |  |  |
| 3553 | 928.7 | **Charging Management for Bearer level** | 390d? | 2003-03-21 A | 2004-09-16 A | 100% | 2003-03-21 | 2004-09-16 | 390d? |  | S5 | 11440h | 11440h | CH-BC | Nokia | Benni ALEXANDER | Rel-6 | Mirko | CH-BC |  |  |  |
| 3554 | 928.7.1 | CS domain charging | 260d? | 2003-03-21 A | 2004-03-18 A | 100% | 2003-03-21 | 2004-03-18 | 260d? | start no earlier than 2003-03-21 | S5 | 2080h | 2080h |  |  |  | Rel-6 | Mirko |  | 32.250 |  |  |
| 3555 | 928.7.2 | PS domain charging | 390d? | 2003-03-21 A | 2004-09-16 A | 100% | 2003-03-21 | 2004-09-16 | 390d? | start no earlier than 2003-03-21 | S5 | 3120h | 3120h |  |  |  | Rel-6 | Mirko |  | 32.251 |  |  |
| 3556 | 928.7.3 | CDR transfer | 390d? | 2003-03-21 A | 2004-09-16 A | 100% | 2003-03-21 | 2004-09-16 | 390d? | start no earlier than 2003-03-21 | S5 | 3120h | 3120h |  |  |  | Rel-6 | Mirko |  | 32.295 |  |  |
| 3557 | 928.8 | Charging Management for the Service domain | 580d? | 2003-03-21 A | 2005-06-09 A | 100% | 2003-03-21 | 2005-06-09 | 580d? | finish no earlier than 2005-06-09 | S5 | 4640h | 4640h |  | Siemens | Gerald.Goermer@nsn.com | Rel-6 | Mirko |  | 32.252, 32.270, 32.271, 32.272 |  |  |
| 3558 | 928.9 | **Overall architectural aspects of IP flow based bearer level charging** | 602d? | 2002-11-21 A | 2005-03-11 A | 100% | 2002-11-21 | 2005-03-11 | 602d? |  | S2; N3 | 17448h | 17448h | CH-FBC |  |  | Rel-6 | Maurice | CH-FBC | 23.125 |  |  |
| 3559 | 928.9.1 | Overall definition of FBC architecture | 334d? | 2002-11-21 A | 2004-03-02 A | 100% | 2002-11-21 | 2004-03-02 | 334d? | start no earlier than 2002-11-21 | S2 | 2672h | 2672h |  |  |  | Rel-6 | Maurice |  |  | SP-24 |  |
| 3560 | 928.9.2 | Study on providing policy control with FBC | 130d? | 2004-02-02 A | 2004-07-30 A | 100% | 2004-02-02 | 2004-07-30 | 130d? | start no earlier than 2004-02-01 | S2 | 1040h | 1040h |  |  |  | Rel-6 | Maurice |  |  | SP-24 |  |
| 3561 | 928.9.3 | Gx interface for flow based charging | 223d? | 2004-02-02 A | 2004-12-08 A | 100% | 2004-02-02 | 2004-12-08 | 223d? | start no earlier than 2004-02-01 | N3 | 1784h | 1784h |  | Nokia | juha.a.rasanen@nokia.com | Rel-6 | Gwiho |  | 29.210 | SP-25 |  |
| 3562 | 928.9.4 | Rx interface for flow based charging | 290d? | 2004-02-02 A | 2005-03-11 A | 100% | 2004-02-02 | 2005-03-11 | 290d? | finish no earlier than 2005-03-11 | N3 | 2320h | 2320h |  | Nortel | Javier Gonzalez Gallego | Rel-6 | Gwiho |  | 29.209 | SP-25 |  |
| 3563 | 13 | **Rel-6 UICC/USIM enhancements and interworking** | 1164d? | 2000-09-25 A | 2005-03-10 A | 100% | 2000-09-25 | 2005-03-10 | 1164d? |  | T3 | 43088h | 43088h | USAT1 |  |  | Rel-6 | Xavier | USAT1 |  |  |  |
| 3564 | 13.1 | **UICC API** | 777d | 2002-03-20 A | 2005-03-10 A | 100% | 2002-03-20 | 2005-03-10 | 777d |  | T3 | 15024h | 15024h | USAT1-API |  |  | Rel-6 | Xavier | USAT1-API |  |  |  |
| 3565 | 13.1.1 | Rel-6 Java API Test specification | 59d | 2002-03-20 A | 2002-06-10 A | 100% | 2002-03-20 | 2002-06-10 | 59d | finish no earlier than 2002-09-20 | T3 | 472h | 472h |  | Microelectrónica Española | Mario Pérez | Rel-6 | Xavier |  |  |  |  |
| 3566 | 929.1.2 | 2G/3G Java Card™ API based applet interworking | 255d | 2003-03-17 A | 2004-03-05 A | 100% | 2003-03-17 | 2004-03-05 | 255d | finish no earlier than 2004-02-19 | T3 | 2040h | 2040h |  | Oberthur Card Systems | Stéphane Andrau | Rel-6 | Xavier |  |  |  |  |
| 3567 | 929.1.3 | (U)SIM API for Java Card Testing | 519d | 2003-03-17 A | 2005-03-10 A | 100% | 2003-03-17 | 2005-03-10 | 519d | finish no earlier than 2005-03-10 | T3 | 4152h | 4152h |  | Axalto | Christophe Begassat (cbegassat@axalto.com) | Rel-6 | Xavier |  | 31.213 |  |  |
| 3568 | 13.1.2 | Deleted - Java API Test specification (TS 43.019 Rel-5) | 268d | 2002-05-30 A | 2003-06-09 A | 100% | 2002-05-30 | 2003-06-09 | 268d | finish no earlier than 2003-09-17 | T3 | 2144h | 2144h |  | Microelectrónica Española | Mario Pérez | Rel-6 | Xavier |  |  |  | TP-20 |

Notes:
- 3542: SP#26 12/2004 SA5 completed 12/04. Signalling Based Trace Activation for IMS (SIP) moved to Rel-7. Reason: CN1 cannot complete 24.229 trace without IETF dependency => estimate 05/2005.
- 3543: SP#26 12/2004 completed
- 3544: -
- 3545: -
- 3546: SP#28 Target 09/2005 for WLAN Charging 32.252
- 3547: SP#25 09/2004 completed
- 3548: SP#23 03/2004 completed
- 3549: SP#28 06/2005 completed
- 3550: SP#25 09/2004 completed
- 3551: SP#21 09/2003 completed
- 3552: SP#26 12/2004 completed
- 3553: SP#28 Target 09/2005 for WLAN Charging 32.252
- 3554: SP#23 03/2004 completed
- 3555: SP#25 09/2004 completed
- 3556: SP#25 09/2004 completed
- 3557: SP#26: Updated WID SP-040778 was SP-030050. Target completion 06/2005. Consisting of MMS-CH, LCS-CH, WLAN-CH, POC-CH, MBMS-CH
- 3558: -
- 3559: -
- 3560: -
- 3561: -
- 3562: -
- 3563: -
- 3564: 8/3/2001: test spec is based on R99 core spec, so deleted from Workplan
- 3565: -
- 3566: -
- 3567: -
- 3568: MOVED to Rel-5 WP

| ID | WBS | Task | Type | Duration | Start | Finish | Complete | Remaining | Baseline start | Baseline finish | Baseline duration | Total slack | Constraint | Resources | Work | Actual work | Acronym | WI rapporteur name | WI rapporteur e-mail | Release | MCC resp | Acronym_3GU_Export | TSG stopped |
| --- | --- | --- | --- | --- | --- | --- | --- | --- | --- | --- | --- | --- | --- | --- | --- | --- | --- | --- | --- | --- | --- | --- | --- |
| 3569 | 929.2 | **Rel-6 USIM toolkit enhancements** |  | 1160d? | 2000-09-25 A | 2005-03-04 A | 100% |  | 2000-09-25 | 2005-03-04 | 1160d? |  |  | T3 | 21848h | 21848h | USAT1-API-MULTOS | Aspects Software | Neil Livingston | Rel-6 | Xavier | USAT1-API-MULTOS |  |
| 3570 | 929.2.1 | **C SIM API** |  | 525d | 2000-09-25 A | 2002-09-27 A | 100% |  | 2000-09-25 | 2002-09-27 | 525d |  |  | T3 | 9960h | 9960h |  | Aspects Software | Neil Livingston | Rel-6 | Xavier |  |  |
| 3571 | 929.2.1.1 | Specification of C SIM API |  | 525d | 2000-09-25 A | 2002-09-27 A | 100% |  | 2000-09-25 | 2002-09-27 | 525d |  | finish no earlier than 2002-09-27 | T3 | 4200h | 4200h |  | Aspects Software | Neil Livingston | Rel-6 | Xavier |  |  |
| 3572 | 929.2.1.2 | Test specification for C SIM API |  | 195d | 2001-01-01 A | 2001-09-28 A | 100% |  | 2001-01-01 | 2001-09-28 | 195d |  | finish no earlier than 2001-09-28 | T3 | 1560h | 1560h |  | Aspects Software | Neil Livingston | Rel-6 | Xavier |  |  |
| 3573 | 929.2.2 | USIM application toolkit Conformance Test Specification for Mobile Equipments |  | 326d? | 2003-12-05 A | 2005-03-04 A | 100% |  | 2003-12-05 | 2005-03-04 | 326d? |  | start no earlier than 2003-12-05 | T3 | 2608h | 2608h |  | Gemplus | Eric.laffont@gemplus.com | Rel-6 | Xavier |  |  |
| 3574 | 930 | **Packet Switched Streaming Services Rel-6** |  | 798d? | 2002-11-18 A | 2005-12-07 A | 100% |  | 2002-11-18 | 2005-12-07 | 798d? |  |  | S4; S1 | 19688h | 19688h | PSSrel6 | Ericsson | olle.franceschi@ericsson.com | Rel-6 | Paolo | PSSrel6 |  |
| 3575 | 930.1 | Stage 1 for Packet Switched Streaming Services Rel-6 |  | 86d? | 2002-11-18 A | 2003-03-17 A | 100% |  | 2002-11-18 | 2003-03-17 | 86d? |  | finish no earlier than 2003-03-17 | S1 | 688h | 688h |  | Ericsson |  | Rel-6 | Alain |  |  |
| 3576 | 930.2 | Stage 3 for Packet Switched Streaming Services Rel-6 |  | 779d? | 2002-12-13 A | 2005-12-07 A | 100% |  | 2002-12-13 | 2005-12-07 | 779d? |  | finish no earlier than 2005-12-07 | S4 | 6232h | 6232h | PSSrel6-Stage3 | Ericsson | olle.franceschi@ericsson.com | Rel-6 | Paolo | PSSrel6-Stage3 |  |
| 3577 | 931 | AMR-WB extension for high audio quality |  | 779d | 2002-12-13 A | 2005-12-07 A | 100% |  | 2002-12-13 | 2005-12-07 | 779d |  | finish no earlier than 2005-12-07 | S4 | 6232h | 6232h | AMRWB+ | Nokia | janne.m.vainio@nokia.com | Rel-6 | Paolo | AMRWB+ |  |
| 3578 | 932 | Codec Enhancements for Packet Switched Conversational Multimedia Applications |  | 198d? | 2004-03-16 A | 2004-12-16 A | 100% |  | 2004-03-16 | 2004-12-16 | 198d? |  | finish no earlier than 2004-12-16 | S4 | 1584h | 1584h | CEPSCM | Nokia | miska.hannuksela@nokia.com | Rel-6 | Paolo | CEPSCM |  |
| 3579 | 933 | 3G-324M Improvements |  | 198d? | 2004-03-16 A | 2004-12-16 A | 100% |  | 2004-03-16 | 2004-12-16 | 198d? |  | finish no earlier than 2004-12-16 | S4 | 1584h | 1584h | 3G-324MI | Ericsson | bo.burman@ericsson.com | Rel-6 | Paolo | 3G-324MI |  |
| 3580 | 934 | Single Antenna Receiver Interference Cancellation (SAIC) |  | 420.92d? | 2002-11-15 A | 2004-06-25 A | 100% |  | 2002-11-15 | 2004-06-25 | 420.92d? |  | finish no earlier than 2004-08-27 | GP; G1 | 6734.72h | 6734.72h | SAIC | Cingular | Marc Grant | Rel-6 | Paolo | SAIC |  |
| 3581 | 935 | **Enhancement of dialled service for CAMEL** |  | 199d | 2003-03-28 A | 2003-12-31 A | 100% |  | 2003-03-28 | 2003-12-31 | 199d |  |  | S1; N2; N4 | 7960h | 7960h | EDCAMEL | Samsung | craig.bishop@samsung.com | Rel-6 | Alain | EDCAMEL |  |
| 3582 | 935.1 | Stages 2 and 3 for Enhancement of dialled service for CAMEL |  | 199d | 2003-03-28 A | 2003-12-31 A | 100% |  | 2003-03-28 | 2003-12-31 | 199d |  | finish no earlier than 2003-09-19 | N2; N4 | 3184h | 3184h |  | Samsung | Richard Brook | Rel-6 | Kimmo |  |  |
| 3583 | 936 | Study on Bandwidth and resource savings in CS networks |  | 273d? | 2003-06-01 A | 2004-06-16 A | 100% |  | 2003-06-01 | 2004-06-16 | 273d? |  | finish no earlier than 2004-06-16 | S2 | 2184h | 2184h | BARS |  |  | Rel-6 | Maurice | BARS |  |
| 3584 | 937 | **Multiple TBF in A/Gb mode** |  | 736d? | 2002-04-05 A | 2005-01-28 A | 100% |  | 2002-04-05 | 2005-01-28 | 736d? |  |  | GP; G2 | 35200h | 35200h | MULTBF | Ericsson | gunnar.mildh@era.ericsson.se | Rel-6 | Paolo | MULTBF |  |
| 3585 | 937.1 | **Multiple TBF in A/Gb mode - Core** |  | 366d? | 2002-04-05 A | 2003-08-29 A | 100% |  | 2002-04-05 | 2003-08-29 | 366d? |  |  | GP; G2 | 23424h | 23424h | MULTBF-Agbmode | Ericsson | gunnar.mildh@era.ericsson.se | Rel-6 | Paolo | MULTBF-Agbmode |  |
| 3586 | 937.1.1 | Multiple TBF Concept paper |  | 366d? | 2002-04-05 A | 2003-08-29 A | 100% |  | 2002-04-05 | 2003-08-29 | 366d? |  | finish no earlier than 2003-08-29 | GP; G2 | 5856h | 5856h |  |  |  | Rel-6 | Paolo |  |  |
| 3587 | 937.1.2 | Multiple TBF Stage 2 (43.064) CRs |  | 366d? | 2002-04-05 A | 2003-08-29 A | 100% |  | 2002-04-05 | 2003-08-29 | 366d? |  | finish no earlier than 2003-08-29 | GP; G2 | 5856h | 5856h |  |  |  | Rel-6 | Paolo |  |  |
| 3588 | 937.1.3 | Multiple TBF Stage 3 (44.060) CRs |  | 366d? | 2002-04-05 A | 2003-08-29 A | 100% |  | 2002-04-05 | 2003-08-29 | 366d? |  | finish no earlier than 2003-08-29 | GP; G2 | 5856h | 5856h |  |  |  | Rel-6 | Paolo |  |  |
| 3589 | 937.2 | Deleted - Multiple TBF in A/Gb mode – MS testing | milestone | 0d? | 2005-01-28 A | 2005-01-28 A | 100% |  | 2005-01-28 | 2005-01-28 | 0d? |  | start no earlier than 2005-01-28 | G3new |  |  | MULTBF-Testing | Ericsson | gunnar.mildh@era.ericsson.se | Rel-6 | Paolo | MULTBF-Testing | GP-27 |
| 3590 | 938 | **Alignment between the test-regimes for GERAN capable MS** |  | 526d? | 2003-08-29 A | 2005-09-02 | 99% | 0d? | 2003-08-29 | 2005-09-02 | 526d? | 0d |  | G3new | 4208h | 4208h | ALTERE | Ericsson | anthony.toubassi@sonyericsson.com | Rel-6 | Ingbert | ALTERE |  |
| 3591 | 938.1 | Determine the controversial test cases in the different test regimes and align them with 3GPP GERAN test specifications. Such test cases to be added to TS 51.010. |  | 526d? | 2003-08-29 A | 2005-09-02 A | 100% |  | 2003-08-29 | 2005-09-02 | 526d? |  | finish no earlier than 2005-09-02 | G3new | 4208h | 4208h | ALTERE-TC |  |  | Rel-6 | Ingbert | ALTERE-TC |  |
| 3592 | 939 | Addition of U-TDOA in the CS domain |  | 111d? | 2003-11-21 A | 2004-04-23 A | 100% |  | 2003-11-21 | 2004-04-23 | 111d? |  | finish no earlier than 2004-04-23 | GP | 888h | 888h | UTDOACS | TruePosition | Bob Gross, Rhys Robinson (rlgross@trueposition.com) | Rel-6 | Paolo | UTDOACS |  |
| 3593 | 940 | Addition of U-TDOA in the PS domain |  | 361d? | 2003-06-27 A | 2004-11-12 A | 100% |  | 2003-06-27 | 2004-11-12 | 361d? |  | finish no earlier than 2004-11-12 | GP | 2888h | 2888h | UTDOAPS | TruePosition | Bob Gross, Rhys Robinson (rlgross@trueposition.com) | Rel-6 | Paolo | UTDOAPS |  |

Notes:
- 3569: -
- 3570: - / Impacted TSs and TRs: 31.101, 31.102, 31.103, 31.111, 31.113, new 31.115, 31.116
- 3571: -
- 3572: -
- 3573: - / Impacted TSs and TRs: 31.124
- 3574: -
- 3575: 2nd resp SA4 / Impacted TSs and TRs: 22.233
- 3576: TR tbc by Sept. 05 / Impacted TSs and TRs: 26.233, 26.234, 26.244, 26.245, 26.246, 26.401, 26.402, 26.403, 26.404, 26.405, 26.406, 26.410, 26.411, 26.412, 26.273, 26.290, 26.304, 26.412, 26.274, 26.936
- 3577: TR tbc by Sept. 05 / Impacted TSs and TRs: 26.290, 26.304, 26.273, 26.274, 26.412, 26.936
- 3578: - / Impacted TSs and TRs: 26.235, 26.236
- 3579: - / Impacted TSs and TRs: 26.111, 26.911
- 3580: - / Impacted TSs and TRs: 45.903
- 3581: - / Impacted TSs and TRs: 22.078
- 3582: - / Impacted TSs and TRs: 23.008, 23.016, 23.018, 23.078, 29.002, 29.078
- 3583: - / Impacted TSs and TRs: 23.977
- 3584: GP#17 Nov 2003 Moved from Rel-5 UID_50058 MULTBF (Only Multiple TBF Concept paper produced in Rel-5)
- 3585: -
- 3586: -
- 3587: -
- 3588: -
- 3589: -
- 3590: -
- 3591: -
- 3592: Completed, except for potential LMU performance specs
- 3593: -

| ID | WBS | Task | Type | Duration | Start | Finish | Complete | Baseline start | Baseline finish | Baseline duration | Constraint | Resources | Work | Actual work | Acronym | WI rapporteur name | WI rapporteur e-mail | Release | MCC resp | Acronym_3GU_Export | TSG stopped | Impacted TSs and TRs | Created at |
| --- | --- | --- | --- | --- | --- | --- | --- | --- | --- | --- | --- | --- | --- | --- | --- | --- | --- | --- | --- | --- | --- | --- | --- |
| 3594 | 941 | **Downlink Advanced Receiver Performance** |  | 466d? | 2003-11-21 A | 2005-09-02 A | 100% | 2003-11-21 | 2005-09-02 | 466d? |  | GP | 19160h | 19160h | DARP | Nokia | tommy.bysted@nokia.com | Rel-6 | Paolo | DARP |  |  |  |
| 3595 | 941.1 | DARP test scenarios |  | 201d? | 2003-11-21 A | 2004-08-27 A | 100% | 2003-11-21 | 2004-08-27 | 201d? | finish no earlier than 2004-08-27 | GP | 1608h | 1608h | DARP-TS | Nokia | tommy.bysted@nokia.com | Rel-6 | Paolo | DARP-TS |  |  |  |
| 3596 | 941.2 | **DARP for GMSK modulated voice services** |  | 201d? | 2004-02-06 A | 2004-11-12 A | 100% | 2004-02-06 | 2004-11-12 | 201d? |  | GP | 4824h | 4824h | DARP-GMSK | Nokia | tommy.bysted@nokia.com | Rel-6 | Paolo | DARP-GMSK |  |  |  |
| 3597 | 941.2.1 | Performance requirements in 45.005 for DARP for GMSK modulated voice services |  | 201d? | 2004-02-06 A | 2004-11-12 A | 100% | 2004-02-06 | 2004-11-12 | 201d? | finish no earlier than 2004-11-12 | GP | 1608h | 1608h | DARP-GMSK-Perf |  |  | Rel-6 | Paolo | DARP-GMSK-Perf |  |  |  |
| 3598 | 941.2.2 | Radio subsystem link control in 45.008 for DARP for GMSK modulated voice services |  | 201d? | 2004-02-06 A | 2004-11-12 A | 100% | 2004-02-06 | 2004-11-12 | 201d? | finish no earlier than 2004-11-12 | GP | 1608h | 1608h | DARP-GMSK-LC |  |  | Rel-6 | Paolo | DARP-GMSK-LC |  |  |  |
| 3599 | 941.3 | **DARP for GPRS and EGPRS MCS1-MCS4** |  | 201d? | 2004-02-06 A | 2004-11-12 A | 100% | 2004-02-06 | 2004-11-12 | 201d? |  | GP | 4824h | 4824h | DARP-GPRSE | Nokia | tommy.bysted@nokia.com | Rel-6 | Paolo | DARP-GPRSE |  |  |  |
| 3600 | 941.3.1 | Performance requirements in 45.005 for DARP for GPRS and EGPRS MCS1-MCS4 |  | 201d? | 2004-02-06 A | 2004-11-12 A | 100% | 2004-02-06 | 2004-11-12 | 201d? | finish no earlier than 2004-11-12 | GP | 1608h | 1608h | DARP-GPRSE-Perf |  |  | Rel-6 | Paolo | DARP-GPRSE-Perf |  |  |  |
| 3601 | 941.3.2 | Radio subsystem link control in 45.008 for DARP for GPRS and EGPRS MCS1-MCS4 |  | 201d? | 2004-02-06 A | 2004-11-12 A | 100% | 2004-02-06 | 2004-11-12 | 201d? | finish no earlier than 2004-11-12 | GP | 1608h | 1608h | DARP-GPRSE-LC |  |  | Rel-6 | Paolo | DARP-GPRSE-LC |  |  |  |
| 3602 | 941.4 | DARP Capability signalling |  | 256d? | 2003-11-21 A | 2004-11-12 A | 100% | 2003-11-21 | 2004-11-12 | 256d? | finish no earlier than 2004-11-12 | GP | 2048h | 2048h | DARP-CAPSIG | Nokia | tommy.bysted@nokia.com | Rel-6 | Paolo | DARP-CAPSIG |  |  |  |
| 3603 | 941.5 | GERAN MS Conformance test for DARP |  | 266d? | 2004-08-27 A | 2005-09-02 A | 100% | 2004-08-27 | 2005-09-02 | 266d? | finish no earlier than 2005-06-24 | G3new | 2128h | 2128h | ARP-ConfTest | Nokia | tommy.bysted@nokia.com | Rel-6 | Ingbert | ARP-ConfTest |  |  |  |
| 3604 | 942 | **Reduction of PS service interruption in Dual Transfer Mode** |  | 416d? | 2003-11-21 A | 2005-06-24 A | 100% | 2003-11-21 | 2005-06-24 | 416d? |  | G2 | 8360h | 8360h | PSintDTM | Siemens | toby.proctor@roke.co.uk | Rel-6 | Gert | PSintDTM |  |  |  |
| 3605 | 942.1 | Use case and requirement definition |  | 111d? | 2003-11-21 A | 2004-04-23 A | 100% | 2003-11-21 | 2004-04-23 | 111d? | finish no earlier than 2004-04-23 | G2 | 888h | 888h | PSintDTM-Req | Siemens | toby.proctor@roke.co.uk | Rel-6 | Gert | PSintDTM-Req |  |  |  |
| 3606 | 942.2 | Performance Study of Current Procedures |  | 111d? | 2003-11-21 A | 2004-04-23 A | 100% | 2003-11-21 | 2004-04-23 | 111d? | start no earlier than 2003-11-21 | G2 | 888h | 888h | PSintDTM-Perf | Siemens | toby.proctor@roke.co.uk | Rel-6 | Gert | PSintDTM-Perf |  |  |  |
| 3607 | 942.3 | Reduction of service interruption times and packet loss during Dual Transfer Mode and mobility procedures |  | 146d? | 2004-04-23 A | 2004-11-12 A | 100% | 2004-04-23 | 2004-11-12 | 146d? | finish no earlier than 2004-11-12 | G2 | 1168h | 1168h | PSintDTM-Reduct | Siemens | toby.proctor@roke.co.uk | Rel-6 | Gert | PSintDTM-Reduct |  |  |  |
| 3608 | 942.4 | Deleted - MS Conformance testing - Reduction of PS service interruption in DTM |  | 261d? | 2004-06-25 A | 2005-06-24 A | 100% | 2004-06-25 | 2005-06-24 | 261d? | finish no earlier than 2005-06-24 | G3new | 2088h | 2088h | PSintDTM-ConfMS |  |  | Rel-6 | Ingbert | PSintDTM-ConfMS | GP-25 |  |  |
| 3609 | 942.5 | Deleted - BTS Conformance testing - Reduction of PS service interruption in DTM | milestone | 0d? | 2005-06-24 A | 2005-06-24 A | 100% | 2005-06-24 | 2005-06-24 | 0d? | finish no earlier than 2005-06-24 | G3new |  |  | PSintDTM-ConfBTS |  |  | Rel-6 | Ingbert | PSintDTM-ConfBTS | GP-25 |  |  |
| 3610 | 943 | CAMEL prepay interworking with SCUDIF |  | 216.3d | 2003-12-08 A | 2004-10-05 A | 100% | 2003-12-08 | 2004-10-05 | 216.3d |  | N4; N3; S1 | 5191.2h | 5191.2h | SCCAMEL | Nokia | Keijo.Palviainen@Nokia.Com | Rel-6 | Kimmo | SCCAMEL |  | 22.078, 23.078, 29.078, 29.002, 23.172 |  |
| 3611 | 944 | **Circuit Switched Video and Voice Service Improvements** |  | 430d? | 2004-01-12 A | 2005-09-02 A | 100% | 2004-01-12 | 2005-09-02 | 430d? |  | S2; N1 | 12696h | 12696h | CS_VSS | Vodafone | John Watson | Rel-6 | Alain | CS_VSS |  |  |  |
| 3612 | 944.1 | Deleted - Stage 1 - Requirements |  | 199d | 2004-01-12 A | 2004-10-14 A | 100% | 2004-01-12 | 2004-10-14 | 199d | finish no earlier than 2004-10-14 | S1 | 1592h | 1592h |  | Vodafone | John Watson | Rel-6 | Alain |  | SP-26 | 22.101 |  |
| 3613 | 944.2 | Stage 2 Study on architecture alternatives |  | 244d? | 2004-01-12 A | 2004-12-16 A | 100% | 2004-01-12 | 2004-12-16 | 244d? | finish no earlier than 2004-08-13 | S2 | 1952h | 1952h |  | Vodafone | chris.pudney@vodafone.com | Rel-6 | Maurice |  |  | 23.903 | SP-24 |
| 3614 | 944.3 | Deleted - Stage 2 description on Redial |  | 164d? | 2004-05-03 A | 2004-12-16 A | 100% | 2004-05-03 | 2004-12-16 | 164d? | finish no earlier than 2004-12-16 | S2 | 1312h | 1312h |  | Vodafone | chris.pudney@vodafone.com | Rel-6 | Maurice |  | SP-26 |  | SP-24 |
| 3615 | 944.4 | Switching between voice and video call - Redial solution |  | 120d? | 2005-01-03 A | 2005-06-17 A | 100% | 2005-01-03 | 2005-06-17 | 120d? | start no earlier than 2005-01-03 | N1 | 960h | 960h |  | Vodafone |  | Rel-6 | Frederic |  |  | 23.009, 24.008 |  |
| 3616 | 944.5 | Deleted - CS_VSS - GERAN2 Part | milestone | 0d | 2005-09-02 A | 2005-09-02 A | 100% | 2005-09-02 | 2005-09-02 | 0d | start no earlier than 2005-09-02 | G2 |  |  |  | Vodafone |  | Rel-6 | Gert |  | GP-26 |  |  |
| 3617 | 944.6 | Deleted - CS_VSS - CN3 Part | milestone | 0d? | 2004-10-14 A | 2004-10-14 A | 100% | 2004-10-14 | 2004-10-14 | 0d? | start no earlier than 2004-10-14 | N3 |  |  |  | Vodafone |  | Rel-6 | Gwiho |  | TP-26 |  |  |
| 3618 | 945 | Reorganisation of CS Data Specifications |  | 14d? | 2004-11-19 A | 2004-12-08 A | 100% | 2004-11-19 | 2004-12-08 | 14d? | finish no earlier than 2004-12-24 | N3 | 112h | 112h | CS Data | Siemens | Thomas.Belling@nsn.com | Rel-6 | Gwiho | CS Data |  | 23.910, 29.007, New 23.202 |  |

Notes:
- 3594: -
- 3595: -
- 3596: -
- 3597: -
- 3598: -
- 3599: -
- 3600: -
- 3601: -
- 3602: -
- 3603: -
- 3604: -
- 3605: -
- 3606: -
- 3607: -
- 3608: -
- 3609: -
- 3610: -
- 3611: -
- 3612: -
- 3613: -
- 3614: -
- 3615: -
- 3616: -
- 3617: -
- 3618: Created at TSG#27 as 100 % complete

| ID | WBS | Task | Type | Duration | Start | Finish | Complete | Baseline start | Baseline finish | Baseline duration | Constraint | Resources | Work | Actual work | Acronym | WI rapporteur name | Release | MCC resp | Acronym_3GU_Export | Impacted TSs and TRs | WI rapporteur e-mail | TSG stopped |
| --- | --- | --- | --- | --- | --- | --- | --- | --- | --- | --- | --- | --- | --- | --- | --- | --- | --- | --- | --- | --- | --- | --- |
| 3619 | 946 | **Generic Access to A/Gb Interface (GAAI)** |  | 411d? | 2004-06-25 A | 2006-01-20 A | 100% | 2004-06-25 | 2006-01-20 | 411d? |  | GP | 9160h | 9160h | GAAI | Motorola | Rel-6 | Paolo | GAAI |  |  |  |
| 3620 | 946.1 | FS on GAAI |  | 46d? | 2004-06-25 A | 2004-08-27 A | 100% | 2004-06-25 | 2004-08-27 | 46d? | finish no earlier than 2004-08-27 | GP | 368h | 368h | GAAG | Motorola | Rel-6 | Paolo | GAAG | 43.901 |  |  |
| 3621 | 946.2 | GAAI – Stage 2 |  | 161d? | 2004-08-27 A | 2005-04-08 A | 100% | 2004-08-27 | 2005-04-08 | 161d? | finish no earlier than 2005-04-08 | GP | 1288h | 1288h | GAAI-Stage2 | Ericsson | Rel-6 | Paolo | GAAI-Stage2 | 43.318 | jari.vikberg@ericsson.com |  |
| 3622 | 946.3 | GAAI – Stage 3 |  | 161d? | 2004-08-27 A | 2005-04-08 A | 100% | 2004-08-27 | 2005-04-08 | 161d? | finish no earlier than 2005-04-08 | GP | 1288h | 1288h | GAAI-Stage3 |  | Rel-6 | Paolo | GAAI-Stage3 | 44.318 |  |  |
| 3623 | 946.4 | MS Conformance Test for GAAI |  | 366d? | 2004-08-27 A | 2006-01-20 A | 100% | 2004-08-27 | 2006-01-20 | 366d? | finish no earlier than 2006-01-20 | GP | 2928h | 2928h | GAAI-CT |  | Rel-6 | Ingbert | GAAI-CT |  |  |  |
| 3624 | 947 | **Support of PS Handover for GERAN A/Gb mode** |  | 473d? | 2003-11-03 A | 2005-08-24 A | 100% | 2003-11-03 | 2005-08-24 | 473d? |  | GP; G2 | 30272h | 30272h | SPSHAGB | Ericsson | Rel-6 | Paolo | SPSHAGB |  | gunnar.hedby@ericsson.com |  |
| 3625 | 947.1 | Stage 2 for Support of PS Handover for GERAN A/Gb mode |  | 473d? | 2003-11-03 A | 2005-08-24 A | 100% | 2003-11-03 | 2005-08-24 | 473d? | finish no earlier than 2005-09-02 | GP; G2 | 7568h | 7568h | SPSHAGB-Stage2 | Ericsson | Rel-6 | Paolo | SPSHAGB-Stage2 | 43.129 | gunnar.hedby@ericsson.com |  |
| 3626 | 947.2 | PS handover for Support of PS Handover for GERAN A/Gb mode |  | 473d? | 2003-11-03 A | 2005-08-24 A | 100% | 2003-11-03 | 2005-08-24 | 473d? | finish no earlier than 2005-09-02 | GP; G2 | 7568h | 7568h | SPSHAGB-PSHO | Ericsson | Rel-6 | Paolo | SPSHAGB-PSHO |  | gunnar.hedby@ericsson.com |  |
| 3627 | 947.3 | Definition of radio resource management functionality for Support of PS Handover for GERAN A/Gb mode |  | 473d? | 2003-11-03 A | 2005-08-24 A | 100% | 2003-11-03 | 2005-08-24 | 473d? | finish no earlier than 2005-09-02 | GP; G2 | 7568h | 7568h | SPSHAGB-RRM | Ericsson | Rel-6 | Paolo | SPSHAGB-RRM |  | gunnar.hedby@ericsson.com |  |
| 3628 | 948 | Study on (U)SIM Security Reuse by Peripheral Devices on Local Interfaces |  | 127d? | 2003-07-03 A | 2003-12-26 A | 100% | 2003-07-03 | 2003-12-26 | 127d? | finish no earlier than 2003-12-26 | S3 | 1016h | 1016h |  | Toshiba | Rel-6 | Mirko |  | 33.817 | Raziq Yaqub (ryaqub@tari.toshiba.com) |  |
| 3629 | 949 | Study on Security for early IMS |  | 127d? | 2004-10-01 A | 2005-03-28 A | 100% | 2004-10-01 | 2005-03-28 | 127d? | finish no earlier than 2003-12-26 | S3 | 1016h | 1016h | SEC-IMS | Vodafone | Rel-6 | Mirko | SEC-IMS | 33.978 | Peter.Howard@vodafone.com |  |
| 3630 | 950 | (Small) Technical Enhancements and Improvements for Rel-6 | milestone | 0d? | 2006-06-02 A | 2006-06-02 A | 100% | 2006-06-02 | 2006-06-02 | 0d? |  | SP; CP; RP; GP |  |  | TEI6 |  | Rel-6 | all | TEI6 |  |  |  |
| 3631 | 951 | Test - (Small) Technical Enhancements and Improvements for Rel-6 |  | 503d? | 2006-06-02 A | 2008-05-06 A | 100% | 2006-06-02 | 2008-05-06 | 503d? | start no earlier than 2006-06-02 | R5; T1 | 8048h | 8048h | TEI6_Test |  | Rel-6 | Ingbert | TEI6_Test | 34.108,34.121-1/2,34.122,34.123-1/2/3 |  |  |
| 3632 | 952 | Deleted - Study of Feature Interactions Requirements | milestone | 0d? | 2004-09-16 A | 2004-09-16 A | 100% | 2004-09-16 | 2004-09-16 | 0d? | finish no earlier than 2004-10-01 | S1 |  |  | FINTER |  | Rel-6 | Alain | FINTER |  |  | SP-25 |
| 3633 | 953 | Deleted EVGCS - Enhancements of VGCS in public networks for communication of public authority officials |  | 7d? | 2005-08-25 A | 2005-09-02 A | 100% | 2005-08-25 | 2005-09-02 | 7d? | start no earlier than 2005-08-24 | GP; G2 | 112h | 112h |  | Siemens | Rel-6 | Paolo |  | 44.018, 44.068, 48.008 | kenneth.isaacs@roke.co.uk | GP-26 |
| 3634 | 954 | **Deleted SCSAGB - Support of Conversational Services in A/Gb mode via the PS domain** |  | 64d? | 2003-11-21 A | 2004-02-19 A | 100% | 2003-11-21 | 2004-02-19 | 64d? |  | GP; N1 | 2048h | 2048h |  | Ericsson | Rel-6 | Paolo |  |  | David Bladsjö (david.bladsjo@ericsson.com) | GP-18 |
| 3635 | 954.1 | Deleted - Creation of a TR | milestone | 0d? | 2003-11-21 A | 2003-11-21 A | 100% | 2003-11-21 | 2003-11-21 | 0d? | start no earlier than 2003-11-21 | GP |  |  | SCSAGB-TR | Ericsson | Rel-6 | Paolo | SCSAGB-TR |  | David Bladsjö (david.bladsjo@ericsson.com) | GP-17 |
| 3636 | 954.2 | Deleted - Stage 2 | milestone | 0d? | 2003-11-21 A | 2003-11-21 A | 100% | 2003-11-21 | 2003-11-21 | 0d? | finish no earlier than 2003-11-21 | GP |  |  | SCSAGB-Stage2 | Ericsson | Rel-6 | Paolo | SCSAGB-Stage2 |  | David Bladsjö (david.bladsjo@ericsson.com) | GP-17 |
| 3637 | 954.3 | Deleted - Radio Channel Support | milestone | 0d? | 2003-11-21 A | 2003-11-21 A | 100% | 2003-11-21 | 2003-11-21 | 0d? | finish no earlier than 2003-11-21 | GP |  |  | SCSAGB-RCS | Ericsson | Rel-6 | Paolo | SCSAGB-RCS |  | David Bladsjö (david.bladsjo@ericsson.com) | GP-17 |
| 3638 | 954.4 | Deleted SCSAGB-RRM - Definition of radio resource management functionality | milestone | 0d? | 2003-11-21 A | 2003-11-21 A | 100% | 2003-11-21 | 2003-11-21 | 0d? | finish no earlier than 2003-11-21 | GP |  |  |  | Ericsson | Rel-6 | Paolo |  |  | David Bladsjö (david.bladsjo@ericsson.com) | GP-17 |
| 3639 | 954.5 | Deleted - replaced by 50561 - PS Handover |  | 64d | 2003-11-24 A | 2004-02-19 A | 100% | 2003-11-24 | 2004-02-19 | 64d | start no earlier than 2003-11-21 | GP; N1 | 1024h | 1024h | SCSAGB-PSH | Ericsson | Rel-6 | Paolo | SCSAGB-PSH |  | David Bladsjö (david.bladsjo@ericsson.com) | GP-18 |
| 3640 | 954.6 | Deleted SCSAGB-FLO - Modifications to FLO | milestone | 0d? | 2003-11-21 A | 2003-11-21 A | 100% | 2003-11-21 | 2003-11-21 | 0d? | finish no earlier than 2003-11-21 | GP |  |  |  | Ericsson | Rel-6 | Paolo |  |  | David Bladsjö (david.bladsjo@ericsson.com) | RP-29 |
| 3641 | 955 | Deleted - Rel-6 Evolutions of the transport in the UTRAN (ETRAN) | milestone | 0d | 2003-12-31 A | 2003-12-31 A | 100% | 2003-12-31 | 2003-12-31 | 0d | start no earlier than 2003-12-31 | RP |  |  |  | Alcatel | Rel-6 | Issam |  |  | Francois Courau | RP-22 |
| 3642 | 956 | Release 5 Features |  | 325d? | 2000-01-03 A | 2001-03-29 A | 100% | 2000-01-03 | 2001-03-29 | 325d? |  | NP; GP; RP; SP; TP | 13000h | 13000h |  |  | Rel-5 | All |  |  |  |  |
| 3643 | 75 | IP transport in the UTRAN |  | 445d | 2000-07-17 A | 2002-03-29 A | 100% | 2000-07-17 | 2002-03-29 | 445d | finish no earlier than 2002-03-29 | R3 | 3560h | 3560h | ETRAN-IPtrans | Alcatel | Rel-5 | Juha | ETRAN-IPtrans |  | Nicolas Drevon |  |
| 3644 | 76 | Feasibility study on SS7 signalling transportation in the core network with SCCP-User Adaptation (SUA) |  | 205d | 2001-03-12 A | 2001-12-21 A | 100% | 2001-03-12 | 2001-12-21 | 205d | finish no earlier than 2001-12-21 | N4 | 1640h | 1640h | FS_SS7IP |  | Rel-5 | Kimmo | FS_SS7IP | 29.903 |  |  |

Notes:
- 3619: -
- 3620: Feasibility Study
- 3621: -
- 3622: -
- 3623: Marked as closed 12/2008 (was marked 90% complete)
- 3624: Replaces SCSAGB- Originally Started Nov 2003 as GP-030443
- 3625: Replaces SCSAGB-Stage2
- 3626: Replaces SCSAGB-PSH
- 3627: Replaces SCSAGB-RRM
- 3628: SP#20 approved WID
- 3629: SP#24 approved WID. SP#46 withdrawn TR 33.978 from Rel-8 onwards
- 3630: "Joker" WI, to be used for a Rel 6 CR not related to any feature and with very limited impact on the system. Moved in from Stoyan/Testing WP
- 3631: "Joker" WI, to be used for small modifications applicable to Rel 4 conformance testing
- 3632: SP#25 stopped
- 3633: GP#26 moved to Rel-7 as UID_11045 Enhancements of VGCS in public networks for communication of public authority officials
- 3634: -
- 3635: -
- 3636: Started
- 3637: Not started
- 3638: Not started
- 3639: Started
- 3640: Not started
- 3641: Generic feature ETRAN
- 3642: -
- 3643: -
- 3644: -

| ID | WBS | Task | Duration | Start | Finish | Complete | Baseline start | Baseline finish | Baseline duration | Constraint | Deadline | Resources | Work | Actual work | Acronym | WI rapporteur name | WI rapporteur e-mail | Release | MCC resp | Acronym_3GU_Export | Impacted TSs and TRs | Created at | TSG stopped |
| --- | --- | --- | --- | --- | --- | --- | --- | --- | --- | --- | --- | --- | --- | --- | --- | --- | --- | --- | --- | --- | --- | --- | --- |
| 3645 | 77 | **High Speed Downlink Packet Access** | 1550d? | 2001-04-02 A | 2007-03-09 A | 100% | 2001-04-02 | 2007-03-09 | 1550d? |  |  | R2; R5 | 43888h | 43888h | HSDPA | Motorola | Ravi Kuchibhotla | Rel-5 | Yong-Jun | HSDPA |  |  |  |
| 3646 | 77.1 | Physical Layer for High Speed Downlink Packet Access | 257d | 2001-04-05 A | 2002-03-29 A | 100% | 2001-04-05 | 2002-03-29 | 257d | finish no earlier than 2002-03-29 |  | R1 | 2056h | 2056h | HSDPA-Phys | Motorola | Amitabha Ghosh (qa0047@email.mot.com) | Rel-5 | Patrick | HSDPA-Phys |  |  |  |
| 3647 | 77.2 | Layer 2 and 3 aspects | 257d | 2001-04-05 A | 2002-03-29 A | 100% | 2001-04-05 | 2002-03-29 | 257d | finish no earlier than 2002-03-29 |  | R2 | 2056h | 2056h | HSDPA-L23 | Motorola | Ravi Kuchibhotla | Rel-5 | Yong-Jun | HSDPA-L23 |  |  |  |
| 3648 | 77.3 | Iub/Iur protocol aspects - for High Speed Downlink Packet Access | 260d | 2001-04-02 A | 2002-03-29 A | 100% | 2001-04-02 | 2002-03-29 | 260d | finish no earlier than 2002-03-29 |  | R3 | 2080h | 2080h | HSDPA-IubIur | Motorola | Mike Diesen | Rel-5 | Juha | HSDPA-IubIur |  |  |  |
| 3649 | 77.4 | RF Radio Transmission/ Reception, System Performance Requirements and Conformance Testing | 565d | 2001-04-09 A | 2003-06-06 A | 100% | 2001-04-09 | 2003-06-06 | 565d | finish no earlier than 2003-06-06 |  | R4 | 4520h | 4520h | HSDPA-RF | Motorola | Howard Benn | Rel-5 | Issam | HSDPA-RF |  |  |  |
| 3650 | 959.5 | Conformance Testing of HSDPA | 786d | 2003-09-19 A | 2006-09-22 A | 100% | 2003-09-19 | 2006-09-22 | 786d | finish no earlier than 2006-09-22 |  | R5 | 6288h | 6288h | HSDPA_Test | Motorola | carolyn.taylor@motorola.com | Rel-5 | Ingbert | HSDPA_Test | 34.108, 34.121, 34.122, 34.123-1, 34.123-2, 34.123-3 | 19/9/2003 |  |
| 3651 | 959.6 | Conformance Testing of HCR TDD HSDPA | 261d? | 2006-03-10 A | 2007-03-09 A | 100% | 2006-03-10 | 2007-03-09 | 261d? | finish no earlier than 2007-03-09 |  | R5 | 2088h | 2088h | HSDPA_HCRTDD_Test | IPWireless | drichards@ipwireless.com | Rel-5 | Ingbert | HSDPA_HCRTDD_Test | 34.108, 34.122, 34.123-1, 34.123-2, 34.123-3 |  |  |
| 3652 | 78 | **Rel-5 Improvements of Radio Interface** | 535d | 2000-08-14 A | 2002-08-30 A | 100% | 2000-08-14 | 2002-08-30 | 535d |  |  | RP | 30376h | 30376h |  |  |  | Rel-5 |  |  |  |  |  |
| 3653 | 78.1 | **Base station classification for TDD** | 480d | 2000-08-14 A | 2002-06-14 A | 100% | 2000-08-14 | 2002-06-14 | 480d |  |  | R4 | 9208h | 9208h | RInImp-BSClass | Nokia | antti.toskala@nokia.com | Rel-5 | Issam | RInImp-BSClass |  |  |  |
| 3654 | 78.1.1 | TDD Base station classification | 410d | 2000-08-14 A | 2002-03-08 A | 100% | 2000-08-14 | 2002-03-08 | 410d | finish no earlier than 2002-03-08 |  | R4 | 3280h | 3280h | RInImp-BSClass-TDD | Nokia | antti.toskala@nokia.com | Rel-5 | Issam | RInImp-BSClass-TDD |  |  |  |
| 3655 | 78.1.2 | Base Station Classification for 1.28 Mcps TDD option | 261d | 2001-06-15 A | 2002-06-14 A | 100% | 2001-06-15 | 2002-06-14 | 261d | finish no earlier than 2002-06-14 |  | R4 | 2088h | 2088h | RInImp-BSClass-LCRTDD | Siemens | Meik.Kottkamp@siemens.com | Rel-5 | Issam | RInImp-BSClass-LCRTDD |  |  |  |
| 3656 | 78.2 | Enhancement on the DSCH hard split mode | 271d | 2001-03-16 A | 2002-03-29 A | 100% | 2001-03-16 | 2002-03-29 | 271d | finish no earlier than 2002-03-29 |  | R1 | 2168h | 2168h | RInImp-DSCHhsp | Samsung | Jaeyoel KIM | Rel-5 | Patrick | RInImp-DSCHhsp |  |  |  |
| 3657 | 78.3 | Hybrid ARQ II/III | 355d | 2000-08-21 A | 2001-12-28 A | 100% | 2000-08-21 | 2001-12-28 | 355d | finish no earlier than 2001-12-28 |  | R2 | 2840h | 2840h | RInImp-HARQ | Siemens | armin.sitte@siemens.com | Rel-5 | Yong-Jun | RInImp-HARQ |  |  | RP-14 |
| 3658 | 78.4 | FS on USTS | 355d | 2000-08-14 A | 2001-12-21 A | 100% | 2000-08-14 | 2001-12-21 | 355d | finish no earlier than 2001-12-21 |  | R1 | 2840h | 2840h | RInImp-USTS | SK Telecom | D. Kim | Rel-5 | Patrick | RInImp-USTS |  |  |  |
| 3659 | 78.5 | FS on UE antenna efficiency test method performance requirements | 255d | 2000-09-25 A | 2001-09-14 A | 100% | 2000-09-25 | 2001-09-14 | 255d | finish no earlier than 2001-09-14 |  | R4 | 2040h | 2040h | RInImp-UEAnTM | Allgon | O. Edvardsson | Rel-5 | Issam | RInImp-UEAnTM |  |  |  |
| 3660 | 78.6 | FS on the re-introduction of the downlink SIR measurement | 200d | 2001-03-12 A | 2001-12-14 A | 100% | 2001-03-12 | 2001-12-14 | 200d | finish no earlier than 2001-12-14 |  | R4 | 1600h | 1600h | RInImp-SIR | Ericsson | Torgny.Palenius@ericsson.com | Rel-5 | Issam | RInImp-SIR |  |  |  |
| 3661 | 78.7 | FS on mitigating the effect of CPICH interference at the UE | 255d | 2001-03-19 A | 2002-03-08 A | 100% | 2001-03-19 | 2002-03-08 | 255d | finish no earlier than 2002-03-08 |  | R4 | 2040h | 2040h | RInImp-CPICH_Intf | Intel | shimon.moshavi@INTEL.COM | Rel-5 | Issam | RInImp-CPICH_Intf |  |  |  |
| 3662 | 78.8 | **Deleted - Conformance Test Spec. improvements in Radio Interface** | 140d | 2002-02-18 A | 2002-08-30 A | 100% | 2002-02-18 | 2002-08-30 | 140d |  |  | T1 | 3360h | 3360h |  |  |  | Rel-5 | Ingbert |  |  |  | TP-17 |
| 3663 | 78.8.1 | Deleted - Testing improvement of inter-frequency and inter-system measurement | 140d | 2002-02-18 A | 2002-08-30 A | 100% | 2002-02-18 | 2002-08-30 | 140d | finish no earlier than 2002-08-30 |  | T1 | 1120h | 1120h |  |  |  | Rel-5 | Ingbert |  |  |  | TP-17 |
| 3664 | 78.8.2 | Deleted - Testing Hybrid ARQ II/III | 140d | 2002-02-18 A | 2002-08-30 A | 100% | 2002-02-18 | 2002-08-30 | 140d | finish no earlier than 2002-08-30 |  | T1 | 1120h | 1120h |  |  |  | Rel-5 | Ingbert |  |  |  | TP-17 |
| 3665 | 79 | **Rel-5 RAN improvements** | 1561d? | 2001-03-16 A | 2007-03-09 A | 100% | 2001-03-16 | 2007-03-09 | 1561d? |  |  | RP | 49424h | 49424h |  |  |  | Rel-5 |  |  |  |  |  |
| 3666 | 79.1 | **RRM optimization for Iur and Iub** | 318d | 2001-03-16 A | 2002-06-04 A | 100% | 2001-03-16 | 2002-06-04 | 318d |  |  | R3 | 8904h | 8904h | RANimp-RRMopt | Ericsson | Gert-Jan.van.Lieshout@eln.ericsson.se | Rel-5 | Juha | RANimp-RRMopt |  |  |  |
| 3667 | 79.1.1 | Iur common transport channel efficiency optimization | 271d | 2001-03-16 A | 2002-03-29 A | 100% | 2001-03-16 | 2002-03-29 | 271d | finish no earlier than 2002-03-29 |  | R3 | 2168h | 2168h | RANimp-RRMopt-ctc | Ericsson | Shahrokh Amirijoo | Rel-5 | Juha | RANimp-RRMopt-ctc |  |  |  |
| 3668 | 79.1.2 | Iur neighbouring cell reporting efficiency optimization | 271d | 2001-03-16 A | 2002-03-29 A | 100% | 2001-03-16 | 2002-03-29 | 271d | finish no earlier than 2002-03-29 |  | R3 | 2168h | 2168h | RANimp-RRMopt-ncr | Ericsson | Shahrokh Amirijoo | Rel-5 | Juha | RANimp-RRMopt-ncr |  |  |  |
| 3669 | 79.1.3 | FS Introduction of direct transport bearers between SRNC and Node-B | 253d | 2001-06-15 A | 2002-06-04 A | 100% | 2001-06-15 | 2002-06-04 | 253d | finish no earlier than 2002-06-28 |  | R3 | 2024h | 2024h | RAN-imp-RRMopt-DTB | Ericsson | Risto Sepponen | Rel-5 | Juha | RAN-imp-RRMopt-DTB |  |  |  |
| 3670 | 79.2 | RL Timing Adjustment | 271d | 2001-03-16 A | 2002-03-29 A | 100% | 2001-03-16 | 2002-03-29 | 271d | finish no earlier than 2002-03-29 |  | R3 | 2168h | 2168h | RANimp-RLTA | Ericsson | Elena Voltolina | Rel-5 | Juha | RANimp-RLTA |  |  |  |
| 3671 | 79.3 | Separation of resource reservation and radio link activation | 271d | 2001-03-16 A | 2002-03-29 A | 100% | 2001-03-16 | 2002-03-29 | 271d | finish no earlier than 2002-03-29 |  | R3 | 2168h | 2168h | RANimp-SepRR | Ericsson | Gert-Jan.van.Lieshout@eln.ericsson.se | Rel-5 | Juha | RANimp-SepRR |  |  |  |
| 3672 | 79.4 | FS SRNS Relocation Procedure Enhancement | 318d | 2001-06-15 A | 2002-09-03 A | 100% | 2001-06-15 | 2002-09-03 | 318d | finish no earlier than 2002-09-06 |  | R3 | 2544h | 2544h | RANimp-SRNS | Nokia | Olivier Guyot | Rel-5 | Juha | RANimp-SRNS |  |  |  |
| 3673 | 79.5 | FS Improvement of Radio Resource Management across RNS and RNS/PSS | 201d | 2001-03-16 A | 2001-12-21 A | 100% | 2001-03-16 | 2001-12-21 | 201d | finish no earlier than 2001-12-21 |  | R3 | 1608h | 1608h | RANimp-ImpRRM | Nokia | antti.toskala@nokia.com | Rel-5 | Juha | RANimp-ImpRRM |  |  |  |
| 3674 | 79.6 | Re-arrangements of Iub transport bearers | 271d | 2001-03-16 A | 2002-03-29 A | 100% | 2001-03-16 | 2002-03-29 | 271d | finish no earlier than 2002-03-29 |  | R3 | 2168h | 2168h | RANimp-TTPS | Nokia | antti.toskala@nokia.com | Rel-5 | Juha | RANimp-TTPS |  |  |  |
| 3675 | 79.7 | RAB support enhancement for Rel-5 | 325d | 2001-04-02 A | 2002-06-28 A | 100% | 2001-04-02 | 2002-06-28 | 325d |  |  | R2 | 2600h | 2600h | RANimp-RABSE5 | Nokia | Juha Mikola | Rel-5 | Yong-Jun | RANimp-RABSE5 |  |  |  |
| 3676 | 16.5.1 | Testing of ROHC performance | 391d | 2005-09-09 A | 2007-03-09 A | 100% | 2005-09-09 | 2007-03-09 | 391d | finish no earlier than 2007-03-09 | 2006-06-02 | R5 | 3128h | 3128h | RANimp-RABSE5_Test | Nokia | jarkko.hellsten@nokia.com | Rel-5 | Ingbert | RANimp-RABSE5_Test | 34.108, 34.123-1, 34.123-2, 34.123-3 | Fri 11/03/05 |  |
| 3677 | 79.8 | Beamforming requirements for UE | 61d | 2001-09-21 A | 2001-12-14 A | 100% | 2001-09-21 | 2001-12-14 | 61d | finish no earlier than 2001-12-14 |  | R1 | 488h | 488h | RANimp-BFR-UE | Nokia | Jussi Kähtävä (juha.mikola@nokia.com) | Rel-5 | Patrick | RANimp-BFR-UE |  |  |  |
| 3678 | 79.9 | Support of Site Selection Diversity Transmission in UTRAN | 123d | 2001-12-14 A | 2002-06-04 A | 100% | 2001-12-14 | 2002-06-04 | 123d | finish no earlier than 2002-06-04 |  | R1 | 984h | 984h | RANimp-SSDT | NEC |  | Rel-5 | Patrick | RANimp-SSDT |  |  |  |
| 3679 | 79.10 | Node B Synchronisation for 1.28 Mcps TDD | 271d | 2001-03-16 A | 2002-03-29 A | 100% | 2001-03-16 | 2002-03-29 | 271d | finish no earlier than 2002-03-29 |  | R1 | 2168h | 2168h | RANimp-NBSLCR | CATT | Jinling HU | Rel-5 | Patrick | RANimp-NBSLCR |  |  |  |

Notes:
- 3645: -
- 3646: -
- 3647: -
- 3648: -
- 3649: -
- 3650: -
- 3651: -
- 3652: -
- 3653: -
- 3654: -
- 3655: -
- 3656: -
- 3657: Stopped at RP#14; work on this task was performed as part of High Speed Downlink Packet Access feature
- 3658: -
- 3659: -
- 3660: -
- 3661: -
- 3662: Marked as stopped 12/2008
- 3663: Marked as stopped 12/2008
- 3664: Marked as stopped 12/2008
- 3665: -
- 3666: -
- 3667: -
- 3668: -
- 3669: FS was closed and introduction of WI not agreed at RAN #16
- 3670: -
- 3671: -
- 3672: -
- 3673: FS was closed and WI was introduced at RAN #14
- 3674: -
- 3675: RFC 3095 context relocation
- 3676: -
- 3677: -
- 3678: RP-020356
- 3679: -

| ID | WBS | Task | Duration | Start | Finish | Complete | Baseline start | Baseline finish | Baseline duration | Constraint | Deadline | Resources | Work | Actual work | Release | MCC resp | TSG stopped | Acronym | Impacted TSs and TRs | Acronym_3GU_Export | WI rapporteur name | WI rapporteur e-mail | Created at |
| --- | --- | --- | --- | --- | --- | --- | --- | --- | --- | --- | --- | --- | --- | --- | --- | --- | --- | --- | --- | --- | --- | --- | --- |
| 3680 | 79.12 | **Deleted - Conformance Test Aspects - RAN Improvements** | 565d? | 2002-01-01 A | 2004-03-01 A | 100% | 2002-01-01 | 2004-03-01 | 565d? |  |  | T1 | 8008h | 8008h | Rel-5 | Ingbert | TP-23 |  |  |  |  |  |  |
| 3681 | 79.12.1 | Deleted - Testing Radio access bearer support enhancements | 175d | 2002-01-01 A | 2002-09-02 A | 100% | 2002-01-01 | 2002-09-02 | 175d | finish no earlier than 2002-09-02 |  | T1 | 1400h | 1400h | Rel-5 | Ingbert | TP-17 |  |  |  |  |  |  |
| 3682 | 961.12.2 | Deleted - General changes to TS34.121 and TS34.122 corresponding to release 5 | 261d? | 2003-03-03 A | 2004-03-01 A | 100% | 2003-03-03 | 2004-03-01 | 261d? | finish no earlier than 2004-03-01 |  | T1 | 2088h | 2088h | Rel-5 | Ingbert | TP-23 | RANimp-test, TEI5 | 34.108, 34.121, 34.122 | RANimp-test, TEI5 |  |  |  |
| 3683 | 80 | UTRAN Sharing in Connected Mode | 197d | 2001-12-03 A | 2002-09-03 A | 100% | 2001-12-03 | 2002-09-03 | 197d | finish no earlier than 2002-09-06 |  | R3 | 1576h | 1576h | Rel-5 | Juha |  | NETSHARE |  | NETSHARE | Ericsson | Martin Israelsson |  |
| 3684 | 81 | **Provisioning of IP-based multimedia services** | 1806d | 2000-01-03 A | 2006-12-01 A | 100% | 2000-01-03 | 2006-12-01 | 1806d |  |  | S1; S2; S3; S5; NP; T3; T1; R5 | 325092h | 325092h | Rel-5 | Alain |  | IMS |  | IMS | Openwave | Mark Cataldo |  |
| 3685 | 81.1 | **Call control and roaming to support IMS in UMTS** | 1806d | 2000-01-03 A | 2006-12-01 A | 100% | 2000-01-03 | 2006-12-01 | 1806d |  |  | S2; R5 | 109760h | 109760h | Rel-5 | Maurice |  | IMS-CCR |  | IMS-CCR | Lucent | Liz Daniel |  |
| 3686 | 81.1.1 | Stage 1 for Call control and roaming to support IMS in UMTS | 215d | 2000-02-21 A | 2000-12-15 A | 100% | 2000-02-21 | 2000-12-15 | 215d | finish no earlier than 2000-09-21 |  | S1 | 1720h | 1720h | Rel-5 | Alain |  |  | 22.228 |  | Motorola | Mark Cataldo |  |
| 3687 | 81.1.2 | Stage 2 (Architecture and Main flows) | 246d | 2000-04-14 A | 2001-03-23 A | 100% | 2000-04-14 | 2001-03-23 | 246d | finish no earlier than 2001-03-23 |  | S2 | 1968h | 1968h | Rel-5 | Maurice |  |  | 23.228 |  | Lucent | Liz Daniel |  |
| 3688 | 81.1.3 | Impact on MM/CC/SM | 400d | 2000-08-28 A | 2002-03-08 A | 100% | 2000-08-28 | 2002-03-08 | 400d | finish no earlier than 2002-03-08 |  | N1 | 3200h | 3200h | Rel-5 | Frederic |  | IMS-CCR-IWMM |  | IMS-CCR-IWMM | Lucent | Keith Drage (drage@alcatel-lucent.com) |  |
| 3689 | 81.1.4 | **SIP Call Control protocol for the IMS** | 385d | 2000-10-02 A | 2002-03-22 A | 100% | 2000-10-02 | 2002-03-22 | 385d |  |  | N1 | 12320h | 12320h | Rel-5 | Frederic |  |  | 24.228, 24.229, 23.218 |  | Lucent | Keith Drage (drage@alcatel-lucent.com) |  |
| 3690 | 81.1.4.1 | IMS signalling flows | 385d | 2000-10-02 A | 2002-03-22 A | 100% | 2000-10-02 | 2002-03-22 | 385d | finish no earlier than 2002-03-22 |  | N1 | 3080h | 3080h | Rel-5 | Frederic |  |  | 24.228 |  |  |  |  |
| 3691 | 81.1.4.2 | IMS stage 3 | 385d | 2000-10-02 A | 2002-03-22 A | 100% | 2000-10-02 | 2002-03-22 | 385d | finish no earlier than 2002-03-22 |  | N1 | 3080h | 3080h | Rel-5 | Frederic |  |  | 24.229 |  |  |  |  |
| 3692 | 81.1.4.3 | IMS Session Handling; stage 2 | 385d | 2000-10-02 A | 2002-03-22 A | 100% | 2000-10-02 | 2002-03-22 | 385d | finish no earlier than 2002-03-22 |  | N1 | 3080h | 3080h | Rel-5 | Frederic |  |  | 23.218 |  |  |  |  |
| 3693 | 16.5.1 | Conformance Test Aspects – IMS Call Control | 451d | 2005-03-11 A | 2006-12-01 A | 100% | 2005-03-11 | 2006-12-01 | 451d |  | 2006-06-02 | R5 | 3608h | 3608h | Rel-5 | Ingbert |  | IMS-CCR_Test | 34.108, 34.229-1, 34.229-2, 34.229-3 | IMS-CCR_Test | Motorola | Jacob.John@motorola.com | Fri 11/03/05 |
| 3694 | 81.1.4.4 | **Main IETF dependencies** | 641d | 2000-01-03 A | 2002-06-14 A | 100% | 2000-01-03 | 2002-06-14 | 641d |  |  | NP | 58048h | 58048h | Rel-5 | Kimmo |  |  |  |  | Lucent |  |  |
| 3695 | 81.1.4.4.1 | IETF: RFC 3261 (Session Initiation Protocol) | 346d | 2000-11-24 A | 2002-03-22 A | 100% | 2000-11-24 | 2002-03-22 | 346d | finish no earlier than 2002-03-22 |  | N1 | 2768h | 2768h | Rel-5 | Frederic |  |  |  |  | Lucent |  |  |
| 3696 | 81.1.4.4.2 | IETF: RFC 3262 (Reliability of provisional responses) | 346d | 2000-11-24 A | 2002-03-22 A | 100% | 2000-11-24 | 2002-03-22 | 346d | finish no earlier than 2002-03-22 |  | N1 | 2768h | 2768h | Rel-5 | Frederic |  |  |  |  | Lucent |  |  |
| 3697 | 81.1.4.4.3 | IETF: RFC 3312 (Without COMET)(Integration of resource management and SIP) | 382d | 2000-11-24 A | 2002-05-13 A | 100% | 2000-11-24 | 2002-05-13 | 382d | finish no earlier than 2002-05-13 |  | N1 | 3056h | 3056h | Rel-5 | Frederic |  |  |  |  | Lucent |  |  |
| 3698 | 81.1.4.4.4 | IETF: RFC 3323 (SIP extensions for caller identity and privacy) | 382d | 2000-11-24 A | 2002-05-13 A | 100% | 2000-11-24 | 2002-05-13 | 382d | finish no earlier than 2002-05-13 |  | N1 | 3056h | 3056h | Rel-5 | Frederic |  |  |  |  | Lucent |  |  |
| 3699 | 81.1.4.4.5 | IETF: RFC 3313 (SIP extensions for media authorization) | 382d | 2000-11-24 A | 2002-05-13 A | 100% | 2000-11-24 | 2002-05-13 | 382d | finish no earlier than 2002-05-13 |  | N1 | 3056h | 3056h | Rel-5 | Frederic |  |  |  |  | Lucent |  |  |
| 3700 | 81.1.4.4.6 | IETF: RFC 3265 (specific event notification) | 346d | 2000-11-24 A | 2002-03-22 A | 100% | 2000-11-24 | 2002-03-22 | 346d | finish no earlier than 2002-03-22 |  | N1 | 2768h | 2768h | Rel-5 | Frederic |  |  |  |  | Lucent |  |  |
| 3701 | 81.1.4.4.7 | IETF: RFC editor Queue (refer method) | 401d | 2000-11-24 A | 2002-06-07 A | 100% | 2000-11-24 | 2002-06-07 | 401d | finish no earlier than 2002-06-07 |  | N1 | 3208h | 3208h | Rel-5 | Frederic |  |  |  |  | Lucent |  |  |
| 3702 | 81.1.4.4.8 | IETF: RFC editor Queue (DHCP options for SIP servers) | 382d | 2000-11-24 A | 2002-05-13 A | 100% | 2000-11-24 | 2002-05-13 | 382d | finish no earlier than 2002-05-13 |  | N1 | 3056h | 3056h | Rel-5 | Frederic |  |  |  |  | Lucent |  |  |
| 3703 | 81.1.4.4.10 | IETF: RFC 3267 (AMR and AMR WB RTP and SDP) | 346d | 2000-11-24 A | 2002-03-22 A | 100% | 2000-11-24 | 2002-03-22 | 346d | finish no earlier than 2002-03-22 |  | N1 | 2768h | 2768h | Rel-5 | Frederic |  |  |  |  | Lucent |  |  |
| 3704 | 81.1.4.4.11 | IETF: RFC 3266 (IPv6 support within SDP) | 581d | 2000-01-03 A | 2002-03-22 A | 100% | 2000-01-03 | 2002-03-22 | 581d | finish no earlier than 2002-03-22 |  | N1 | 4640h | 4640h | Rel-5 | Frederic |  |  |  |  | Lucent |  |  |
| 3705 | 81.1.4.4.12 | IETF: RFC 3311 (The Update method) | 382d | 2000-11-24 A | 2002-05-13 A | 100% | 2000-11-24 | 2002-05-13 | 382d | finish no earlier than 2002-05-13 |  | N1 | 3056h | 3056h | Rel-5 | Frederic |  |  |  |  | Lucent |  |  |
| 3706 | 81.1.4.4.13 | IETF: RFC 3324 (Network Asserted Identity) | 382d | 2000-11-24 A | 2002-05-13 A | 100% | 2000-11-24 | 2002-05-13 | 382d | finish no earlier than 2002-05-13 |  | N1 | 3056h | 3056h | Rel-5 | Frederic |  |  |  |  | Lucent |  |  |
| 3707 | 81.1.4.4.14 | IETF: RFC editor Queue (Various 3GPP Private Extensions) | 382d | 2000-11-24 A | 2002-05-13 A | 100% | 2000-11-24 | 2002-05-13 | 382d | finish no earlier than 2002-05-13 |  | N1 | 3056h | 3056h | Rel-5 | Frederic |  |  |  |  | Lucent |  |  |

Notes:
- 3680: Marked as stopped 12/2008
- 3681: Marked as stopped 12/2008
- 3682: Marked as stopped 12/2008
- 3683: Formerly 'Shared Network support in connected mode', renamed at RAN #16.
- 3684: -
- 3685: -
- 3686: Issues include e.g.: Roaming requirements, Requirements on supplementary services, Interworking requirements
- 3687: Issues include e.g.: Mobile IP, RAB selection principles, Optimized VoIP bearer mechanisms, SIP multimedia protocol
- 3688: Per 26/2-02: This is understood to be the PCO & TFT CRs which CN1 provides to TSGN #15 for approval. If this is correct understanding, then the task is 100 % complete.
- 3689: TSGN_10 approved the change:CN1 - SA2 SIP joint meeting spotted one more place for improvement: work tasks with ID 1998 and 1278 are actually subtasks under of single CN1 WT. One WI has been approved for the CN1 WT with title "SIP Call Control protocol
- 3690: 24.228
- 3691: 24.229
- 3692: 23.218
- 3693: -
- 3694: -
- 3695: -
- 3696: -
- 3697: -
- 3698: -
- 3699: -
- 3700: -
- 3701: -
- 3702: -
- 3703: -
- 3704: -
- 3705: -
- 3706: -
- 3707: -

| ID | WBS | Task | Duration | Start | Finish | Complete | Baseline start | Baseline finish | Baseline duration | Constraint | Resources | Work | Actual work | Release | MCC resp | Acronym | Impacted TSs and TRs | WI rapporteur name | WI rapporteur e-mail | Acronym_3GU_Export |
| --- | --- | --- | --- | --- | --- | --- | --- | --- | --- | --- | --- | --- | --- | --- | --- | --- | --- | --- | --- | --- |
| 3708 | 81.1.4.5 | **Addressing** | 380d | 2000-10-09 A | 2002-03-22 A | 100% | 2000-10-09 | 2002-03-22 | 380d |  | S2 | 7744h | 7744h | Rel-5 | Maurice |  |  |  |  |  |
| 3709 | 81.1.4.5.1 | Architectural issues | 235d | 2000-10-09 A | 2001-08-31 A | 100% | 2000-10-09 | 2001-08-31 | 235d | finish no earlier than 2001-03-16 | S2 | 1880h | 1880h | Rel-5 | Maurice |  |  |  |  |  |
| 3710 | 81.1.4.5.2 | Impact on HSS | 353d | 2000-11-15 A | 2002-03-22 A | 100% | 2000-11-15 | 2002-03-22 | 353d | finish no earlier than 2002-03-22 | N4 | 2824h | 2824h | Rel-5 | Kimmo |  |  |  |  |  |
| 3711 | 81.1.4.6 | **Service Examples (Work stopped)** | 304d | 2001-04-17 A | 2002-06-14 A | 100% | 2001-04-17 | 2002-06-14 | 304d |  | S1 | 4864h | 4864h | Rel-5 | Alain | IMS-Sex | 22.928 | Motorola | Mark Cataldo | IMS-Sex |
| 3712 | 81.1.4.6.1 | IMS Framework Report (work stopped) | 304d | 2001-04-17 A | 2002-06-14 A | 100% | 2001-04-17 | 2002-06-14 | 304d | finish no earlier than 2002-06-14 | S1 | 2432h | 2432h | Rel-5 | Alain | IMS-FrWk | 22.941 | SBC | Randolph Wohlert (rwohlert@tri.sbc.com) | IMS-FrWk |
| 3713 | 81.2 | **Access Security for IMS** | 190d | 2001-10-08 A | 2002-06-28 A | 100% | 2001-10-08 | 2002-06-28 | 190d |  | S3; T3 | 5640h | 5640h | Rel-5 | Mirko | IMS-ASEC |  | Ericsson | krister.boman@emw.ericsson.se | IMS-ASEC |
| 3714 | 81.2.2 | IMS impacts on UICC (ISIM application) | 185d | 2001-10-08 A | 2002-06-21 A | 100% | 2001-10-08 | 2002-06-21 | 185d | finish no earlier than 2002-06-21 | T3 | 1480h | 1480h | Rel-5 | Xavier |  | 33.102, New TS 31.103 | Vodafone | Jeremy Norris |  |
| 3715 | 81.2.3 | Deleted - SIP extensions for Integrity protection | 140d | 2001-12-17 A | 2002-06-28 A | 100% | 2001-12-17 | 2002-06-28 | 140d | finish no earlier than 2002-06-28 | N1 | 1120h | 1120h | Rel-5 | Frederic |  |  |  |  |  |
| 3716 | 81.3 | Security Aspects of Requirement for Network Configuration Independence | 130d | 2001-07-02 A | 2001-12-28 A | 100% | 2001-07-02 | 2001-12-28 | 130d | finish no earlier than 2001-12-28 | S3 | 1040h | 1040h | Rel-5 | Mirko | SEC1-NCI | 33.203 | AT&T Wireless | hugh.shieh@attws.com | SEC1-NCI |
| 3717 | 81.4 | IMS Lawful Interception | 410d | 2000-09-04 A | 2002-03-29 A | 100% | 2000-09-04 | 2002-03-29 | 410d | finish no earlier than 2002-03-29 | S3 | 3280h | 3280h | Rel-5 | Mirko | IMS-LI | 33.106, 33.107, New 33.108 | Reg TP | berthold.wilhelm@regtp.de | IMS-LI |
| 3718 | 81.5 | Charging and OAM&P for IMS | 383d | 2000-12-25 A | 2002-06-12 A | 100% | 2000-12-25 | 2002-06-12 | 383d | finish no earlier than 2002-06-12 | S5 | 3064h | 3064h | Rel-5 | Mirko | IMS-OAM | 32-series |  |  | IMS-OAM |
| 3719 | 81.6 | **Multimedia codecs and protocols for conversational PS services** | 568d | 2000-07-26 A | 2002-09-27 A | 100% | 2000-07-26 | 2002-09-27 | 568d |  | S4 | 15640h | 15640h | Rel-5 | Paolo | IMS-CODEC | 26.235, 26.236 | Toshiba, Nokia | B. Aronson (Toshiba), pasi.s.ojala@nokia.com | IMS-CODEC |
| 3720 | 81.6.1 | Codecs | 427d | 2000-07-26 A | 2002-03-14 A | 100% | 2000-07-26 | 2002-03-14 | 427d | finish no earlier than 2001-03-21 | S4 | 3416h | 3416h | Rel-5 | Paolo |  | 26.235, 26.236 |  |  |  |
| 3721 | 81.6.2 | Transport protocols | 1d | 2002-03-12 A | 2002-03-12 A | 100% | 2002-03-12 | 2002-03-12 | 1d | finish no earlier than 2002-03-12 | S4 | 8h | 8h | Rel-5 | Paolo |  | 26.236 | Nokia | P. Ojala |  |
| 3722 | 81.6.4 | recommendation for QoS parameter values for various media types | 195d | 2001-12-31 A | 2002-09-27 A | 100% | 2001-12-31 | 2002-09-27 | 195d | finish no earlier than 2002-09-27 | S4 | 1560h | 1560h | Rel-5 | Paolo |  |  |  |  |  |
| 3723 | 81.6.5 | IETF: RFC 3310 (HTTP Digest Authentication using AKA) | 382d | 2000-11-24 A | 2002-05-13 A | 100% | 2000-11-24 | 2002-05-13 | 382d | finish no earlier than 2002-05-13 | N1 | 3056h | 3056h | Rel-5 | Frederic |  |  |  |  |  |
| 3724 | 81.6.6 | IETF: RFC 3329 (Security mechanism agreement for SIP connections) | 382d | 2000-11-24 A | 2002-05-13 A | 100% | 2000-11-24 | 2002-05-13 | 382d | finish no earlier than 2002-05-13 | N1 | 3056h | 3056h | Rel-5 | Frederic |  |  |  |  |  |
| 3725 | 81.7 | **SIP message compression** | 185d | 2001-09-24 A | 2002-06-07 A | 100% | 2001-09-24 | 2002-06-07 | 185d |  | S2 | 3128h | 3128h | Rel-5 | Maurice |  |  |  |  |  |
| 3726 | 81.7.1 | Stage 2 for SIP message compression | 25d | 2001-09-24 A | 2001-10-26 A | 100% | 2001-09-24 | 2001-10-26 | 25d | finish no earlier than 2001-10-26 | S2 | 200h | 200h | Rel-5 | Maurice |  |  |  |  |  |
| 3727 | 81.7.2 | Compression signalling | 181d | 2001-09-28 A | 2002-06-07 A | 100% | 2001-09-28 | 2002-06-07 | 181d | finish no earlier than 2002-06-07 | N1 | 1448h | 1448h | Rel-5 | Frederic |  |  |  |  |  |
| 3728 | 81.8 | **Stage 3 description of IMS interfaces** | 383d | 2001-03-14 A | 2002-08-30 A | 100% | 2001-03-14 | 2002-08-30 | 383d |  | NP | 29531.6h | 29531.6h | Rel-5 | Kimmo |  |  |  |  |  |
| 3729 | 81.8.1 | Cx interface (HSS to CSCF) | 135.95d | 2001-03-14 A | 2002-06-07 A | 100% | 2001-03-14 | 2002-06-07 | 135.95d | finish no earlier than 2002-06-07 | N4 | 1087.58h | 1087.58h | Rel-5 | Kimmo |  |  |  |  |  |
| 3730 | 81.8.2 | Mp interface (MRFC - MRFP) enhancements | 258d | 2001-03-14 A | 2002-03-08 A | 100% | 2001-03-14 | 2002-03-08 | 258d | finish no earlier than 2002-06-07 | N4 | 2064h | 2064h | Rel-5 | Kimmo |  |  |  |  |  |
| 3731 | 81.8.3 | Mw interface (CSCF to P-CSCF) | 323d | 2001-03-14 A | 2002-06-07 A | 100% | 2001-03-14 | 2002-06-07 | 323d | finish no earlier than 2002-06-07 | N1 | 2584h | 2584h | Rel-5 | Frederic |  |  |  |  |  |
| 3732 | 81.8.4 | Mr interface (CSCF to MRF) | 273d | 2001-03-14 A | 2002-03-29 A | 100% | 2001-03-14 | 2002-03-29 | 273d | finish no earlier than 2002-03-29 | N1 | 2184h | 2184h | Rel-5 | Frederic |  |  |  |  |  |
| 3733 | 81.8.5 | Dx interface (I-CSCF to SLF) | 323d | 2001-03-14 A | 2002-06-07 A | 100% | 2001-03-14 | 2002-06-07 | 323d | finish no earlier than 2002-06-07 | N4 | 2584h | 2584h | Rel-5 | Kimmo |  |  |  |  |  |
| 3734 | 81.8.6 | Go interface (GGSN to PCF) | 323d | 2001-03-14 A | 2002-06-07 A | 100% | 2001-03-14 | 2002-06-07 | 323d | finish no earlier than 2002-06-07 | N3 | 2584h | 2584h | Rel-5 | Gwiho |  |  |  |  |  |
| 3735 | 81.8.7 | ISC (IMS Service Control) Interface | 323d | 2001-03-14 A | 2002-06-07 A | 100% | 2001-03-14 | 2002-06-07 | 323d | finish no earlier than 2002-06-07 | N1 | 2584h | 2584h | Rel-5 | Frederic |  |  |  |  |  |
| 3736 | 81.8.8 | Sh interface (HSS to AS) | 82d | 2002-02-14 A | 2002-06-07 A | 100% | 2002-02-14 | 2002-06-07 | 82d | finish no earlier than 2002-06-07 | N4 | 656h | 656h | Rel-5 | Kimmo |  |  |  |  |  |
| 3737 | 81.8.9 | Si interface (HSS to IM-SSF) | 162.5d | 2002-01-16 A | 2002-08-30 A | 100% | 2002-01-16 | 2002-08-30 | 162.5d | finish no earlier than 2002-06-07 | N4 | 1300h | 1300h | Rel-5 | Kimmo |  |  |  |  |  |
| 3738 | 81.8.10 | Gm interface (UE to CSCF) | 323d | 2001-03-14 A | 2002-06-07 A | 100% | 2001-03-14 | 2002-06-07 | 323d | finish no earlier than 2002-06-07 | N1 | 2584h | 2584h | Rel-5 | Frederic |  |  |  |  |  |
| 3739 | 81.8.11 | Mi interface (CSCF to BGCF) | 323d | 2001-03-14 A | 2002-06-07 A | 100% | 2001-03-14 | 2002-06-07 | 323d | finish no earlier than 2002-06-07 | N1 | 2584h | 2584h | Rel-5 | Frederic |  |  |  |  |  |
| 3740 | 81.8.12 | Mj interface (BGCF to MGCF) | 323d | 2001-03-14 A | 2002-06-07 A | 100% | 2001-03-14 | 2002-06-07 | 323d | finish no earlier than 2002-06-07 | N1 | 2584h | 2584h | Rel-5 | Frederic |  |  |  |  |  |
| 3741 | 81.8.13 | Mk interface (BGCF to BGCF) | 323d | 2001-03-14 A | 2002-06-07 A | 100% | 2001-03-14 | 2002-06-07 | 323d | finish no earlier than 2002-06-07 | N1 | 2584h | 2584h | Rel-5 | Frederic |  |  |  |  |  |
| 3742 | 81.9 | Support of VHE/OSA by entities and protocols of the IMS (e.g. CSCF) | 186d | 2001-09-21 A | 2002-06-07 A | 100% | 2001-09-21 | 2002-06-07 | 186d | finish no earlier than 2002-06-07 | N5 | 1488h | 1488h | Rel-5 | Kimmo | IMS-ONOSA | 29.198, 29.998 | Ericsson | Ard.Jan.Moerdijk@eln.ericsson.se | IMS-ONOSA |

Notes:
- 3708: -
- 3709: -
- 3710: Covered by 29.228 & 29228
- 3711: -
- 3712: -
- 3713: -
- 3714: -
- 3715: CN1 is not aware of any requirements and is not doing anything on this task
- 3716: Consider security aspects in SA2 TS 23.228 clause 4.4 & annex C
- 3717: SP#17 completed
- 3718: -
- 3719: -
- 3720: -
- 3721: -
- 3722: -
- 3723: -
- 3724: -
- 3725: -
- 3726: -
- 3727: -
- 3728: -
- 3729: -
- 3730: [DAB 08-03-02] - No work required in CN4
- 3731: -
- 3732: -
- 3733: CN4#11 30/11/01: No inputs received in CN4 / 14/02/02 Completed(introduced in 29.228)
- 3734: [DAB - 23/05/03] - 100 % complete
- 3735: -
- 3736: CN4#11 30/11/01: No inputs received in CN4 / CN4#12bis 14/02/02: WID approved / 17th May 100% complete. 3GPP TS 29.329 will be sent for approval in CN#16
- 3737: SA16: Part of Rel5 only if completed in September 02. Marked as closed 12/2008 (was marked 72% complete)
- 3738: -
- 3739: -
- 3740: -
- 3741: -
- 3742: -

| ID | WBS | Task | Duration | Start | Finish | Predecessors | Complete | Baseline start | Baseline finish | Baseline duration | Constraint | Resources | Work | Actual work | Acronym | WI rapporteur name | WI rapporteur e-mail | Release | MCC resp | Acronym_3GU_Export | TSG stopped | Impacted TSs and TRs |
| --- | --- | --- | --- | --- | --- | --- | --- | --- | --- | --- | --- | --- | --- | --- | --- | --- | --- | --- | --- | --- | --- | --- |
| 3743 | 81.10 | **CAMEL control of IMS services** | 365d | 2001-04-16 A | 2002-09-06 A |  | 100% | 2001-04-16 | 2002-09-06 | 365d |  | N2 | 9952h | 9952h | IMS-CAMEL | Lucent | Angelica Remoquillo | Rel-5 | Kimmo | IMS-CAMEL |  |  |
| 3744 | 81.10.1 | Stage2 work 'general' | 365d | 2001-04-16 A | 2002-09-06 A |  | 100% | 2001-04-16 | 2002-09-06 | 365d | finish no earlier than 2002-09-06 | N2 | 2920h | 2920h |  |  |  | Rel-5 | Kimmo |  |  |  |
| 3745 | 81.10.2 | Stage3 work 'CAP' | 175d | 2002-01-07 A | 2002-09-06 A |  | 100% | 2002-01-07 | 2002-09-06 | 175d | finish no earlier than 2002-09-06 | N2 | 1400h | 1400h |  |  |  | Rel-5 | Kimmo |  |  |  |
| 3746 | 81.10.3 | Stage2 work 'Si interface' | 175d | 2002-01-07 A | 2002-09-06 A |  | 100% | 2002-01-07 | 2002-09-06 | 175d | finish no earlier than 2002-09-06 | N2 | 1400h | 1400h |  |  |  | Rel-5 | Kimmo |  |  |  |
| 3747 | 81.10.4 | Stage3 work 'Si interface' | 82d | 2002-02-14 A | 2002-06-07 A |  | 100% | 2002-02-14 | 2002-06-07 | 82d | finish no earlier than 2002-06-07 | N4 | 656h | 656h |  |  |  | Rel-5 | Kimmo |  |  |  |
| 3748 | 81.10.5 | Deleted - SDM issues for CAMEL control of IMS | 82d | 2002-02-14 A | 2002-06-07 A |  | 100% | 2002-02-14 | 2002-06-07 | 82d | finish no earlier than 2002-06-07 | N4 | 656h | 656h |  |  |  | Rel-5 | Kimmo |  | NP-17 |  |
| 3749 | 81.11 | Pre-pay/real-time charging in IMS | 196d | 2001-06-15 A | 2002-03-15 A |  | 100% | 2001-06-15 | 2002-03-15 | 196d | finish no earlier than 2002-03-15 | S1 | 1568h | 1568h |  |  |  | Rel-5 | Alain |  |  |  |
| 3750 | 81.12 | **IMS Charging** | 289d | 2001-08-06 A | 2002-09-12 A |  | 100% | 2001-08-06 | 2002-09-12 | 289d |  | S2; S5 | 8944h | 8944h | OAM-CH | T-Mobile | karl-heinz.nenner@t-mobile.de | Rel-5 | Mirko | OAM-CH |  | 32.225 |
| 3751 | 81.12.1 | Charging Implications of IMS architecture | 75d | 2001-08-06 A | 2001-11-16 A |  | 100% | 2001-08-06 | 2001-11-16 | 75d | finish no earlier than 2001-11-16 | S2 | 600h | 600h |  |  |  | Rel-5 | Maurice |  |  |  |
| 3752 | 81.12.2 | Charging management for IMS (off-line & on-line) | 214d | 2001-11-19 A | 2002-09-12 A | 3751 | 100% | 2001-11-19 | 2002-09-12 | 214d | finish no earlier than 2002-09-12 | S5 | 1712h | 1712h |  |  |  | Rel-5 | Mirko |  |  | 32.225 |
| 3753 | 86.1.6.10 | Billing, accounting and call detail record aspects | 251d | 2001-09-27 A | 2002-09-12 A |  | 100% | 2001-09-27 | 2002-09-12 | 251d | finish no earlier than 2002-09-12 | S5 | 2008h | 2008h |  | T-Mobile | Karl-Heinz.Nenner@T-MOBILE.DE | Rel-5 | Mirko |  |  | 32.225 |
| 3754 | 81.13 | **Other IETF dependencies** | 401d | 2000-11-24 A | 2002-06-07 A |  | 100% | 2000-11-24 | 2002-06-07 | 401d |  | NP | 9624h | 9624h |  |  |  | Rel-5 |  |  |  |  |
| 3755 | 81.13.1 | IETF: draft-ietf-aaa-diameter - should be CN4 | 401d | 2000-11-24 A | 2002-06-07 A |  | 100% | 2000-11-24 | 2002-06-07 | 401d | finish no earlier than 2002-06-07 | NP | 3208h | 3208h |  |  |  | Rel-5 |  |  |  |  |
| 3756 | 81.13.2 | IETF: draft-johansson-aaa-diameter-mm-app - should be CN4 | 401d | 2000-11-24 A | 2002-06-07 A |  | 100% | 2000-11-24 | 2002-06-07 | 401d | finish no earlier than 2002-06-07 | NP | 3208h | 3208h |  |  |  | Rel-5 |  |  |  |  |
| 3757 | 81.15 | Conformance Test Aspects - Provisioning of IMS | 205d | 2002-03-18 A | 2002-12-27 A |  | 100% | 2002-03-18 | 2002-12-27 | 205d | finish no earlier than 2002-12-27 | T1 | 1640h | 1640h | IMS-TEST |  |  | Rel-5 | Ingbert | IMS-TEST |  |  |
| 3758 | 81.16 | Testing of support for IMS - prose | 270d | 2002-09-18 A | 2003-09-30 A |  | 100% | 2002-09-18 | 2003-09-30 | 270d | finish no earlier than 2003-09-30 | T1 | 2160h | 2160h |  | Anritsu | dan.fox@eu.anritsu.com | Rel-5 | Ingbert |  |  | 34.108, 34.123 |
| 3759 | 81.17 | Testing of support for IMS - TTCN | 381d | 2002-09-18 A | 2004-03-03 A |  | 100% | 2002-09-18 | 2004-03-03 | 381d | finish no earlier than 2004-03-03 | T1 | 3048h | 3048h |  | Anritsu | dan.fox@eu.anritsu.com | Rel-5 | Ingbert |  |  | 34.108, 34.123 |
| 3760 | 82 | **Extended Transparent End-to-End PS Streaming Service** | 313d? | 2002-01-03 A | 2003-03-17 A |  | 100% | 2002-01-03 | 2003-03-17 | 313d? |  | S4 | 6224h | 6224h | PSS-E | Ericsson | olle.franceschi@ericsson.com | Rel-5 | Paolo | PSS-E |  | 26.233, 26.234 |
| 3761 | 82.1 | **Stage 1 for Extended Transparent End-to-End PS Streaming Service** | 86d? | 2002-11-18 A | 2003-03-17 A |  | 100% | 2002-11-18 | 2003-03-17 | 86d? |  | S1 | 1376h | 1376h |  | Vodafone | stephen.wolak@vodafone.com | Rel-5 | Alain |  |  | 22.233 |
| 3762 | 964.1.1 | Interaction with other services | 86d? | 2002-11-18 A | 2003-03-17 A |  | 100% | 2002-11-18 | 2003-03-17 | 86d? | finish no earlier than 2003-03-17 | S1 | 688h | 688h |  | Vodafone | stephen.wolak@vodafone.com | Rel-5 | Alain |  |  | 22.233 |
| 3763 | 82.2 | Stage 2 (version Rel-5 of TS 26.234) | 51d | 2002-01-03 A | 2002-03-14 A |  | 100% | 2002-01-03 | 2002-03-14 | 51d | finish no earlier than 2002-03-26 | S4 | 408h | 408h |  |  |  | Rel-5 | Paolo |  |  | 26.234 |
| 3764 | 82.3 | RTP usage model | 242d | 2002-01-03 A | 2002-12-06 A |  | 100% | 2002-01-03 | 2002-12-06 | 242d | finish no earlier than 2002-12-06 | S4 | 1936h | 1936h |  |  |  | Rel-5 | Paolo |  |  | 26.937 |
| 3765 | 83 | **Rel-5 Open Service Access (OSA) enhancements** | 955d | 1999-04-27 A | 2002-12-20 A |  | 100% | 1999-04-27 | 2002-12-20 | 955d |  | S1; S3 | 72648h | 72648h | OSA1 | Siemens | joerg.swetina@neclab.eu | Rel-5 | Alain | OSA1 |  | 22.127, 23.127, 29.198-x, 29.998-x |
| 3766 | 83.1 | General Stage 2 for Rel-5 | 194d | 2001-09-11 A | 2002-06-07 A |  | 100% | 2001-09-11 | 2002-06-07 | 194d |  | S2 | 1232h | 1232h |  |  |  | Rel-5 | Maurice |  |  |  |

Notes:
- 3743: -
- 3744: DAB 12.12.01 split into cn4 and cn2 parts
- 3745: DAB 12.12.01 split into cn4 and cn2 parts
- 3746: DAB 12.12.01 split into cn4 and cn2 parts
- 3747: [DAB 08-03-02] - UID 12004 is MASTER of UID 14998 / 17 May need to be recearch possible impact on 23.008 & 23.016, changes to 29.002 are done.
- 3748: Marked as stopped 12/2008
- 3749: Marked as closed 12/2008 (was marked 60% complete)
- 3750: -
- 3751: -
- 3752: -
- 3753: -
- 3754: Was introduced at SP#13 by Ileana Leuca (exact position in the WP and related WG have to be defined)
- 3755: Marked as closed 12/2008 (was marked 90% complete)
- 3756: Marked as closed 12/2008 (was marked 50% complete)
- 3757: The task is a BB, individual work items were considered but are constrained by lack of supporting companies. Marked as stopped 12/2008
- 3758: Marked as stopped 12/2008
- 3759: Marked as stopped 12/2008
- 3760: -
- 3761: 2nd resp SA4
- 3762: 2nd resp SA4. Marked as closed 12/2008 (was marked 65% complete)
- 3763: 2nd resp SA2
- 3764: Marked as closed 12/2008 (was marked 90% complete)
- 3765: -
- 3766: Marked as closed 12/2008 (was marked 47% complete)

| ID | WBS | Task | Duration | Start | Finish | Predecessors | Complete | Baseline start | Baseline finish | Baseline duration | Constraint | Resources | Work | Actual work | Acronym | Release | MCC resp | Acronym_3GU_Export | Impacted TSs and TRs | WI rapporteur name | WI rapporteur e-mail |
| --- | --- | --- | --- | --- | --- | --- | --- | --- | --- | --- | --- | --- | --- | --- | --- | --- | --- | --- | --- | --- | --- |
| 3767 | 83.2 | **OSA APIs for Multimedia Call Control** | 499d | 2000-07-11 A | 2002-06-07 A |  | 100% | 2000-07-11 | 2002-06-07 | 499d |  | S2 | 5960h | 5960h | OSA1-CSCF | Rel-5 | Maurice | OSA1-CSCF |  |  |  |
| 3768 | 83.2.1 | Stage 1 for OSA APIs for Multimedia Call Control | 438d | 2000-07-11 A | 2002-03-14 A |  | 100% | 2000-07-11 | 2002-03-14 | 438d | finish no earlier than 2002-03-14 | S1 | 3504h | 3504h |  | Rel-5 | Alain |  | 22.127 | Siemens | Manfred.leitgeb@siemens.at |
| 3769 | 83.2.2 | Stages 2 and 3 for Multimedia Call Control | 194d | 2001-09-11 A | 2002-06-07 A |  | 100% | 2001-09-11 | 2002-06-07 | 194d | finish no earlier than 2002-06-07 | N5 | 1552h | 1552h |  | Rel-5 | Kimmo |  | 29.198-04 |  |  |
| 3770 | 83.3 | Generic user interaction - Stage 3 | 194d | 2001-09-11 A | 2002-06-07 A |  | 100% | 2001-09-11 | 2002-06-07 | 194d | finish no earlier than 2002-06-07 | N5 | 1552h | 1552h |  | Rel-5 | Kimmo |  | 29.198-05 |  |  |
| 3771 | 83.4 | OSA Charging - Stage 3 | 194d | 2001-09-11 A | 2002-06-07 A |  | 100% | 2001-09-11 | 2002-06-07 | 194d | finish no earlier than 2002-06-07 | N5 | 1552h | 1552h |  | Rel-5 | Kimmo |  | 29.198-12 |  |  |
| 3772 | 83.5 | Call Control Service Mapping; Multiparty Call Control SIP - Stage 3 | 194d | 2001-09-11 A | 2002-06-07 A |  | 100% | 2001-09-11 | 2002-06-07 | 194d | finish no earlier than 2002-06-07 | N5 | 1552h | 1552h |  | Rel-5 | Kimmo |  | 29.998-04-4 |  |  |
| 3773 | 83.6 | WSDL APIs for SOAP/HTTP - Stage 3 | 455d | 2000-09-11 A | 2002-06-07 A |  | 100% | 2000-09-11 | 2002-06-07 | 455d | finish no earlier than 2002-06-07 | N5 | 3640h | 3640h |  | Rel-5 | Kimmo |  | 29.198, 29.998 |  |  |
| 3774 | 83.7 | **OSA Security** | 639d | 2000-07-11 A | 2002-12-20 A |  | 100% | 2000-07-11 | 2002-12-20 | 639d |  | S3 | 15000h | 15000h | OSA1-SEC | Rel-5 | Mirko | OSA1-SEC | 33.102 | Ericsson | colin.blanchard@bt.com |
| 3775 | 83.7.1 | Stage 1 for OSA Security | 349d | 2000-07-11 A | 2001-11-09 A |  | 100% | 2000-07-11 | 2001-11-09 | 349d | finish no earlier than 2001-11-09 | S1 | 2792h | 2792h |  | Rel-5 | Alain |  | 22.127 | Siemens | Manfred.leitgeb@siemens.at |
| 3776 | 83.7.2 | OSA Stage 3 | 430d | 2000-10-23 A | 2002-06-14 A |  | 100% | 2000-10-23 | 2002-06-14 | 430d | finish no earlier than 2002-06-14 | S3 | 3440h | 3440h |  | Rel-5 | Mirko |  | 33.102 | BT, Ericsson | colin.blanchard@bt.com |
| 3777 | 83.7.3 | security related SCF(s) definition | 186d | 2001-09-21 A | 2002-06-07 A |  | 100% | 2001-09-21 | 2002-06-07 | 186d | finish no earlier than 2002-06-07 | N5 | 1488h | 1488h |  | Rel-5 | Kimmo |  | 29.198, 29.998 | Ericsson | Ard.Jan.Moerdijk@eln.ericsson.se |
| 3778 | 83.7.4 | OSA changes required from supporting platforms, e.g. gsmSCF, HLR | 69d | 2000-09-11 A | 2000-12-14 A |  | 100% | 2000-09-11 | 2000-12-14 | 69d | finish no earlier than 2000-12-14 | S3 | 552h | 552h |  | Rel-5 | Mirko |  | 33.102 | BT, Ericsson | colin.blanchard@bt.com |
| 3779 | 965.7.5 | OSA Security (moved from Rel-6) | 202d | 2002-03-14 A | 2002-12-20 A |  | 100% | 2002-03-14 | 2002-12-20 | 202d | finish no earlier than 2002-12-20 | S3 | 1616h | 1616h |  | Rel-5 | Mirko |  | 33.102 | BT, Ericsson | colin.blanchard@bt.com |
| 3780 | 83.8 | **Interactions OSA - e-commerce** | 815d | 1999-04-27 A | 2002-06-07 A |  | 100% | 1999-04-27 | 2002-06-07 | 815d |  | S2 | 6152h | 6152h | OSA1-ECOM | Rel-5 | Maurice | OSA1-ECOM |  |  |  |
| 3781 | 83.8.1 | Stage 1 for Interactions OSA - e-commerce | 439d | 1999-04-27 A | 2000-12-28 A |  | 100% | 1999-04-27 | 2000-12-28 | 439d | finish no earlier than 2000-12-28 | S1 | 3504h | 3504h |  | Rel-5 | Alain |  | 22.127 | Siemens | joerg.swetina@neclab.eu |
| 3782 | 83.8.2 | Stages 2 and 3 for Interactions OSA - e-commerce | 186d | 2001-09-21 A | 2002-06-07 A |  | 100% | 2001-09-21 | 2002-06-07 | 186d | finish no earlier than 2002-06-07 | N5 | 1488h | 1488h |  | Rel-5 | Kimmo |  | 29.198, 29.998 | Ericsson | Ard.Jan.Moerdijk@eln.ericsson.se |
| 3783 | 83.9 | Policy Management - Stage 3 | 194d | 2001-09-11 A | 2002-06-07 A |  | 100% | 2001-09-11 | 2002-06-07 | 194d | finish no earlier than 2002-06-07 | N5 | 1552h | 1552h |  | Rel-5 | Kimmo |  | 29.198-13 |  |  |
| 3784 | 83.10 | Presence and Availability Management (PAM) - Stage 3 | 194d | 2001-09-11 A | 2002-06-07 A |  | 100% | 2001-09-11 | 2002-06-07 | 194d | finish no earlier than 2002-06-07 | N5 | 1552h | 1552h |  | Rel-5 | Kimmo |  | 29.198-14 |  |  |
| 3785 | 83.11 | **LCS - OSA interfaces** | 455d | 2000-09-11 A | 2002-06-07 A |  | 100% | 2000-09-11 | 2002-06-07 | 455d |  | S1 | 5656h | 5656h | OSA1-LCSI | Rel-5 | Alain | OSA1-LCSI |  | Siemens | joerg.swetina@neclab.eu |
| 3786 | 83.11.1 | Stage 1 for LCS - OSA interfaces | 65d | 2000-09-11 A | 2000-12-08 A |  | 100% | 2000-09-11 | 2000-12-08 | 65d | finish no earlier than 2000-12-08 | S1 | 520h | 520h |  | Rel-5 | Alain |  | 22.127 | Siemens | joerg.swetina@neclab.eu |
| 3787 | 83.11.2 | Stage 2 for LCS - OSA interfaces | 1d | 2000-12-11 A | 2000-12-11 A | 3786 | 100% | 2000-12-11 | 2000-12-11 | 1d | finish no earlier than 2000-12-11 | S2 | 8h | 8h |  | Rel-5 | Maurice |  | 23.127 | Ericsson | Christophe GOURRAUD |
| 3788 | 83.11.3 | Stage 3 for LCS - OSA interfaces | 186d | 2001-09-21 A | 2002-06-07 A | 3787 | 100% | 2001-09-21 | 2002-06-07 | 186d | finish no earlier than 2002-06-07 | N5 | 1488h | 1488h |  | Rel-5 | Kimmo |  | 29.198, 29.998 | Ericsson | Ard.Jan.Moerdijk@eln.ericsson.se |
| 3789 | 965.12 | Access to User Profile | 145d | 2001-06-01 A | 2001-12-20 A |  | 100% | 2001-06-01 | 2001-12-20 | 145d | finish no earlier than 2001-12-20 | S1 | 1160h | 1160h | OSA2-UP | Rel-5 | Alain | OSA2-UP |  |  |  |
| 3790 | 965.13 | **Retrieval of Terminal capabilities** | 634d | 2000-07-11 A | 2002-12-13 A |  | 100% | 2000-07-11 | 2002-12-13 | 634d |  | S2 | 10808h | 10808h | OSA2-TC | Rel-5 | Maurice | OSA2-TC |  |  |  |
| 3791 | 965.13.1 | Stage 1 for Retrieval of Terminal capabilities | 132d | 2000-07-11 A | 2001-01-10 A |  | 100% | 2000-07-11 | 2001-01-10 | 132d | finish no earlier than 2001-01-10 | S1 | 1056h | 1056h |  | Rel-5 | Alain |  | 22.127 | Siemens | joerg.swetina@neclab.eu |
| 3792 | 965.13.2 | Stages 2 and 3 for Retrieval of Terminal capabilities | 321d | 2001-09-21 A | 2002-12-13 A | 3791 | 100% | 2001-09-21 | 2002-12-13 | 321d | finish no earlier than 2002-12-13 | N5 | 2568h | 2568h |  | Rel-5 | Kimmo |  | 29.198, 29.998 | Ericsson | Ard.Jan.Moerdijk@eln.ericsson.se |
| 3793 | 965.13.3 | Provisioning of the terminal capabilities | 445d | 2001-04-02 A | 2002-12-13 A |  | 100% | 2001-04-02 | 2002-12-13 | 445d | finish no earlier than 2002-12-13 | T2 | 3560h | 3560h |  | Rel-5 |  |  | 23.057 |  |  |

Notes:
- 3767: For Rel5 even if completed by March
- 3768: -
- 3769: -
- 3770: -
- 3771: -
- 3772: -
- 3773: -
- 3774: SP#8 approved WID
- 3775: -
- 3776: SP#8 approved WID
- 3777: -
- 3778: SP#8 approved WID
- 3779: SP#8 approved WID
- 3780: -
- 3781: Marked as closed 12/2008 (was marked 95% complete)
- 3782: -
- 3783: -
- 3784: -
- 3785: az: CN#13 - changed to Rel5
- 3786: -
- 3787: az 24/05/01: Rel4 completion 90->100%.
- 3788: -
- 3789: -
- 3790: -
- 3791: -
- 3792: -
- 3793: According to T2 SWG1 M. Cataldo this is automatically supported by the MExE support of UAProf therefore 100% complete

| ID | WBS | Task | Duration | Start | Finish | Predecessors | Complete | Baseline start | Baseline finish | Baseline duration | Constraint | Resources | Work | Actual work | Acronym | WI rapporteur name | WI rapporteur e-mail | Release | MCC resp | Acronym_3GU_Export | Impacted TSs and TRs |
| --- | --- | --- | --- | --- | --- | --- | --- | --- | --- | --- | --- | --- | --- | --- | --- | --- | --- | --- | --- | --- | --- |
| 3794 | 84 | **CAMEL phase 4** | 625d | 2000-04-17 A | 2002-09-06 A |  | 100% | 2000-04-17 | 2002-09-06 | 625d |  | S1 | 41104h | 41104h | CAMEL4 | Nokia | keijo.palviainen@nokia.com | Rel-5 | Alain | CAMEL4 |  |
| 3795 | 84.1 | Service requirements | 565d | 2000-04-17 A | 2002-06-14 A |  | 100% | 2000-04-17 | 2002-06-14 | 565d | finish no earlier than 2002-06-14 | S1 | 4520h | 4520h |  |  |  | Rel-5 | Alain |  |  |
| 3796 | 84.2 | Call Party Handling | 500d | 2000-07-10 A | 2002-06-07 A |  | 100% | 2000-07-10 | 2002-06-07 | 500d | finish no earlier than 2002-06-07 | N2 | 4000h | 4000h | CAMEL4-CPH |  |  | Rel-5 | Kimmo | CAMEL4-CPH |  |
| 3797 | 84.3 | Mid call procedure for MO and MT calls | 495d | 2000-07-17 A | 2002-06-07 A |  | 100% | 2000-07-17 | 2002-06-07 | 495d | finish no earlier than 2002-06-07 | N2 | 3960h | 3960h | CAMEL4-MCP |  |  | Rel-5 | Kimmo | CAMEL4-MCP |  |
| 3798 | 84.4 | Interactions with Optimal Routing | 430d | 2000-07-17 A | 2002-03-08 A |  | 100% | 2000-07-17 | 2002-03-08 | 430d | finish no earlier than 2002-03-08 | N2 | 3440h | 3440h | CAMEL4-IOR |  |  | Rel-5 | Kimmo | CAMEL4-IOR |  |
| 3799 | 84.5 | Inclusion of flexible tone injection | 430d | 2000-07-17 A | 2002-03-08 A |  | 100% | 2000-07-17 | 2002-03-08 | 430d | finish no earlier than 2002-03-08 | N2 | 3440h | 3440h | CAMEL4-IFTI |  |  | Rel-5 | Kimmo | CAMEL4-IFTI |  |
| 3800 | 84.6 | CSE control over MT SMS | 430d | 2000-07-17 A | 2002-03-08 A |  | 100% | 2000-07-17 | 2002-03-08 | 430d | finish no earlier than 2002-03-08 | N2 | 3440h | 3440h | CAMEL4-CCSMS |  |  | Rel-5 | Kimmo | CAMEL4-CCSMS |  |
| 3801 | 84.7 | Notification of GPRS mobility management to CSE | 331d | 2001-03-02 A | 2002-06-07 A |  | 100% | 2001-03-02 | 2002-06-07 | 331d | finish no earlier than 2002-06-07 | N2 | 2648h | 2648h | CAMEL4-NMM |  |  | Rel-5 | Kimmo | CAMEL4-NMM |  |
| 3802 | 84.8 | Provision of location information of called subscriber | 266d | 2001-03-02 A | 2002-03-08 A |  | 100% | 2001-03-02 | 2002-03-08 | 266d | finish no earlier than 2002-03-08 | N2 | 2128h | 2128h | CAMEL4-LOCB |  |  | Rel-5 | Kimmo | CAMEL4-LOCB |  |
| 3803 | 84.9 | Inclusion of ODB data in the CSE_HLR interface | 175d | 2001-07-09 A | 2002-03-08 A |  | 100% | 2001-07-09 | 2002-03-08 | 175d | finish no earlier than 2002-03-08 | N2 | 1400h | 1400h | CAMEL4-ODB |  |  | Rel-5 | Kimmo | CAMEL4-ODB |  |
| 3804 | 84.10 | Location information during an ongoing call (Handover DP) | 280d | 2001-05-14 A | 2002-06-07 A |  | 100% | 2001-05-14 | 2002-06-07 | 280d | finish no earlier than 2002-06-07 | N2 | 2240h | 2240h | CAMEL4-HODP |  |  | Rel-5 | Kimmo | CAMEL4-HODP |  |
| 3805 | 84.11 | GPRS Any Time Interrogation | 240d | 2001-07-09 A | 2002-06-07 A |  | 100% | 2001-07-09 | 2002-06-07 | 240d | finish no earlier than 2002-06-07 | N2 | 1920h | 1920h | CAMEL4-ATI |  |  | Rel-5 | Kimmo | CAMEL4-ATI |  |
| 3806 | 84.12 | Transfer of IMEI (with SW version) to CSE (CAMEL4-ATI) | 240d | 2001-07-09 A | 2002-06-07 A |  | 100% | 2001-07-09 | 2002-06-07 | 240d | finish no earlier than 2002-06-07 | N2 | 1920h | 1920h |  |  |  | Rel-5 | Kimmo |  |  |
| 3807 | 84.13 | Handling of partial implementations of CAMEL4 | 131d | 2002-03-08 A | 2002-09-06 A |  | 100% | 2002-03-08 | 2002-09-06 | 131d | finish no earlier than 2002-06-07 | N2 | 1048h | 1048h | CAMEL4-SUB |  |  | Rel-5 | Kimmo | CAMEL4-SUB |  |
| 3808 | 85 | **Rel-5 MExE enhancements** | 250d | 2001-03-26 A | 2002-03-08 A |  | 100% | 2001-03-26 | 2002-03-08 | 250d |  | T2 | 2880h | 2880h | MEXE5 |  |  | Rel-5 | Kimmo | MEXE5 |  |
| 3809 | 85.1 | MExE Rel-5 Improvements and Investigations | 110d | 2001-03-26 A | 2002-03-08 A |  | 100% | 2001-03-26 | 2002-03-08 | 110d | finish no earlier than 2001-12-17 | T2 | 880h | 880h | MEXE5-ENHANC | Motorola | Mark Cataldo | Rel-5 | Kimmo | MEXE5-ENHANC | 22.057, 23.057 |
| 3810 | 86 | **Wideband Telephony Service - AMR** | 1036d | 2000-01-01 A | 2003-12-19 A |  | 100% | 2000-01-01 | 2003-12-19 | 1036d |  | S4 | 75408h | 75408h | AMRWB | Siemens | Imre.Varga@mch.siemens.de | Rel-5 | Paolo | AMRWB |  |
| 3811 | 86.1 | **Specification** | 636d | 2000-01-01 A | 2002-06-07 A |  | 100% | 2000-01-01 | 2002-06-07 | 636d |  | S4 | 19984h | 19984h |  |  |  | Rel-5 | Paolo |  |  |
| 3812 | 86.1.1 | Stage 1 for Wideband Telephony Service - AMR | 125d | 2001-10-01 A | 2002-03-22 A |  | 100% | 2001-10-01 | 2002-03-22 | 125d | finish no earlier than 2002-03-22 | S1 | 1000h | 1000h |  |  |  | Rel-5 | Alain |  |  |
| 3813 | 86.1.2 | **Stage 2 for Wideband Telephony Service - AMR** | 77d | 2000-01-03 A | 2000-04-17 A |  | 100% | 2000-01-03 | 2000-04-17 | 77d |  | S4 | 1232h | 1232h |  |  |  | Rel-5 | Paolo |  |  |
| 3814 | 86.1.2.1 | Design Constraints for Wideband Telephony Service - AMR | 27d | 2000-01-03 A | 2000-02-07 A |  | 100% | 2000-01-03 | 2000-02-07 | 27d |  | S4 | 208h | 208h |  |  |  | Rel-5 | Paolo |  |  |
| 3815 | 86.1.2.2 | General Description for Wideband Telephony Service - AMR | 51d | 2000-02-07 A | 2000-04-17 A | 3814 | 100% | 2000-02-07 | 2000-04-17 | 51d | start no earlier than 2000-09-25 | S4 | 408h | 408h |  |  |  | Rel-5 | Paolo |  |  |
| 3816 | 86.1.3 | Feasibility Study for Wideband Telephony Service - AMR | 26d | 2000-04-28 A | 2000-06-02 A | 3815 | 100% | 2000-04-28 | 2000-06-02 | 26d | finish no earlier than 2000-06-02 | S4 | 208h | 208h |  |  |  | Rel-5 | Paolo |  | 26.901 |
| 3817 | 86.1.4 | N1 Aspects for Wideband Telephony Service - AMR | 66d | 2001-09-21 A | 2001-12-21 A |  | 100% | 2001-09-21 | 2001-12-21 | 66d | finish no earlier than 2001-12-21 | N1 | 528h | 528h |  |  |  | Rel-5 | Frederic |  |  |
| 3818 | 86.1.5 | N4 work for Wideband Telephony Service - AMR | 83d | 2002-02-13 A | 2002-06-07 A |  | 100% | 2002-02-13 | 2002-06-07 | 83d | finish no earlier than 2002-06-07 | N4 | 664h | 664h |  |  |  | Rel-5 | Kimmo |  |  |

Notes:
- 3794: -
- 3795: -
- 3796: -
- 3797: -
- 3798: -
- 3799: -
- 3800: -
- 3801: -
- 3802: -
- 3803: Added on May 29, 2001
- 3804: -
- 3805: -
- 3806: -
- 3807: stage2 and stage3 CRs for approval at CN#17
- 3808: -
- 3809: -
- 3810: -
- 3811: -
- 3812: -
- 3813: -
- 3814: -
- 3815: -
- 3816: S4,TD SP-000024: TR 26.901 v.4.0.0
- 3817: Some of N1 tasks: Indication of supported codecs by the MS, Bearer cap negociation, codec indication to MS... / One common set of codec negotiation procedures will be specified as in ID1657.
- 3818: CN4#11 30/11/01: No inputs to CN4 at this meeting / 14/02/02 work started 50% reached / 17 May work is done 100%

| ID | WBS | Task | Duration | Start | Finish | Predecessors | Complete | Baseline start | Baseline finish | Baseline duration | Constraint | Resources | Work | Actual work | Release | MCC resp | Acronym | Acronym_3GU_Export | Impacted TSs and TRs | TSG stopped | WI rapporteur name | WI rapporteur e-mail |
| --- | --- | --- | --- | --- | --- | --- | --- | --- | --- | --- | --- | --- | --- | --- | --- | --- | --- | --- | --- | --- | --- | --- |
| 3819 | 86.1.6 | **Codec issues** | 636d | 2000-01-03 A | 2002-06-07 A |  | 100% | 2000-01-03 | 2002-06-07 | 636d |  | S4 | 9496h | 9496h | Rel-5 | Paolo |  |  |  |  |  |  |
| 3820 | 86.1.6.1 | Codec qualification | 86d | 2000-02-02 A | 2000-05-31 A |  | 100% | 2000-02-02 | 2000-05-31 | 86d | finish no earlier than 2000-05-31 | S4 | 688h | 688h | Rel-5 | Paolo |  |  |  |  |  |  |
| 3821 | 86.1.6.2 | Codec selection tests | 102d | 2000-06-01 A | 2000-10-20 A | 3820 | 100% | 2000-06-01 | 2000-10-20 | 102d | finish no earlier than 2000-10-20 | S4 | 816h | 816h | Rel-5 | Paolo |  |  |  |  |  |  |
| 3822 | 86.1.6.3 | Codec selection | 5d | 2000-10-23 A | 2000-10-27 A | 3821 | 100% | 2000-10-23 | 2000-10-27 | 5d | finish no earlier than 2000-10-27 | S4 | 40h | 40h | Rel-5 | Paolo |  |  |  |  |  |  |
| 3823 | 86.1.6.4 | TFO AMR-WB | 63d | 2001-12-18 A | 2002-03-14 A |  | 100% | 2001-12-18 | 2002-03-14 | 63d | finish no earlier than 2002-03-14 | S4 | 504h | 504h | Rel-5 | Paolo | AMRWB-TFO | AMRWB-TFO |  |  |  |  |
| 3824 | 86.1.6.5 | Other codec issues (verif., characterization) | 441d | 2000-09-29 A | 2002-06-07 A |  | 100% | 2000-09-29 | 2002-06-07 | 441d | finish no earlier than 2002-06-07 | S4 | 3528h | 3528h | Rel-5 | Paolo |  |  | 26.976 |  |  |  |
| 3825 | 86.1.6.6 | AMR-WB and narrrowband interworking | 121d | 2001-09-27 A | 2002-03-14 A |  | 100% | 2001-09-27 | 2002-03-14 | 121d | finish no earlier than 2002-03-14 | S4 | 968h | 968h | Rel-5 | Paolo | AMRWB-IWG | AMRWB-IWG |  |  |  |  |
| 3826 | 86.1.6.7 | Interworking with fixed broadband networks | 121d | 2001-09-27 A | 2002-03-14 A |  | 100% | 2001-09-27 | 2002-03-14 | 121d | finish no earlier than 2002-03-14 | S4 | 968h | 968h | Rel-5 | Paolo |  |  |  |  |  |  |
| 3827 | 86.1.6.8 | Tones and announcements | 121d | 2001-09-27 A | 2002-03-14 A |  | 100% | 2001-09-27 | 2002-03-14 | 121d | finish no earlier than 2002-03-14 | S4 | 968h | 968h | Rel-5 | Paolo |  |  |  |  |  |  |
| 3828 | 86.1.6.9 | Deleted - WB Conferencing and WB Voice Group calls | 1d | 2000-01-03 A | 2000-01-03 A |  | 100% | 2000-01-03 | 2000-01-03 | 1d | finish no earlier than 2000-01-03 | S1 | 8h | 8h | Rel-5 | Alain |  |  |  | SP-07 |  |  |
| 3829 | 86.1.8 | **Conformance tests (CRs to 34 series)** | 74d | 2000-01-01 A | 2000-04-12 A |  | 100% | 2000-01-01 | 2000-04-12 | 74d |  | T1 | 1768h | 1768h | Rel-5 | Ingbert |  |  |  |  |  |  |
| 3830 | 86.1.8.1 | **Terminal Acoustic Characteristics** | 74d | 2000-01-01 A | 2000-04-12 A |  | 100% | 2000-01-01 | 2000-04-12 | 74d |  | S4 | 1176h | 1176h | Rel-5 | Paolo |  |  |  |  |  |  |
| 3831 | 86.1.8.1.1 | Definition for Terminal Acoustic Characteristics | 22d | 2000-01-01 A | 2000-01-31 A |  | 100% | 2000-01-01 | 2000-01-31 | 22d | finish no earlier than 2000-01-28 | S4 | 168h | 168h | Rel-5 | Paolo |  |  | 26.131 |  |  |  |
| 3832 | 86.1.8.1.2 | Test specification for Terminal Acoustic Characteristics | 52d | 2000-02-01 A | 2000-04-12 A | 3831 | 100% | 2000-02-01 | 2000-04-12 | 52d | finish no earlier than 2000-03-13 | S4 | 416h | 416h | Rel-5 | Paolo |  |  | 26.132 |  |  |  |
| 3833 | 86.2 | Floating-point ANSI-C code for the AMR-WB speech codec | 123d | 2001-09-25 A | 2002-03-14 A |  | 100% | 2001-09-25 | 2002-03-14 | 123d | finish no earlier than 2002-03-14 | S4 | 984h | 984h | Rel-5 | Paolo | AMRWB-FP | AMRWB-FP | 26.204 |  | Nokia | janne.m.vainio@nokia.com |
| 3834 | 86.3 | **Support of AMR-WB in GERAN: GMSK and 8PSK WB FR / HR** | 651d | 2000-01-03 A | 2002-06-28 A |  | 100% | 2000-01-03 | 2002-06-28 | 651d |  | GP | 23488h | 23488h | Rel-5 | Paolo | GAMRWB | GAMRWB |  |  |  |  |
| 3835 | 86.3.1 | Channel coding in 45.003 for Support of AMR-WB in GERAN: GMSK and 8PSK WB FR / HR | 591d | 2000-01-03 A | 2002-04-05 A |  | 100% | 2000-01-03 | 2002-04-05 | 591d |  | GP | 4720h | 4720h | Rel-5 | Paolo |  |  |  |  |  |  |
| 3836 | 86.3.2 | Signalling for the A interface | 391d | 2000-01-03 A | 2001-06-29 A |  | 100% | 2000-01-03 | 2001-06-29 | 391d | finish no earlier than 2001-06-29 | GP | 3120h | 3120h | Rel-5 | Paolo |  |  |  |  |  |  |
| 3837 | 86.3.3 | Signalling for Iu | 651d | 2000-01-03 A | 2002-06-28 A |  | 100% | 2000-01-03 | 2002-06-28 | 651d | finish no earlier than 2002-06-28 | GP | 5200h | 5200h | Rel-5 | Paolo |  |  |  |  |  |  |
| 3838 | 86.3.4 | Receiver performance in TS 45.005 | 325d | 2001-04-02 A | 2002-06-28 A |  | 100% | 2001-04-02 | 2002-06-28 | 325d | finish no earlier than 2002-06-28 | GP | 2600h | 2600h | Rel-5 | Paolo |  |  |  |  |  |  |
| 3839 | 86.3.5 | Link Adaptation in 45.009 | 330d | 2001-03-26 A | 2002-06-28 A |  | 100% | 2001-03-26 | 2002-06-28 | 330d | finish no earlier than 2002-06-28 | GP | 2640h | 2640h | Rel-5 | Paolo |  |  |  |  |  |  |
| 3840 | 86.4 | **Deleted - GERAN MS conformance test for AMR-WB** | 1036d | 2000-01-03 A | 2003-12-19 A |  | 100% | 2000-01-03 | 2003-12-19 | 1036d |  | GP | 16568h | 16568h | Rel-5 | Paolo |  |  |  |  |  |  |
| 3841 | 86.4.1 | Deleted - MS test for AMR-WB | 1036d | 2000-01-03 A | 2003-12-19 A |  | 100% | 2000-01-03 | 2003-12-19 | 1036d | finish no earlier than 2003-12-19 | GP | 8280h | 8280h | Rel-5 | Paolo |  |  |  | GP-17 |  |  |
| 3842 | 86.5 | GERAN BTS conformance test for AMR-WB | 762d | 2000-01-03 A | 2002-12-02 A |  | 100% | 2000-01-03 | 2002-12-02 | 762d |  | GP | 6096h | 6096h | Rel-5 | Paolo |  |  |  |  |  |  |

Notes:
- 3819: -
- 3820: -
- 3821: -
- 3822: -
- 3823: -
- 3824: ANSI C-Code , Test Sequences, Speech Transcoding Functions, Error Concealment of lost frames, Source Controlled Bit-Rate Operation, Voice Activity Detector, Frame Structure
- 3825: -
- 3826: -
- 3827: -
- 3828: -
- 3829: -
- 3830: -
- 3831: -
- 3832: -
- 3833: -
- 3834: -
- 3835: 50098 -> 50298
- 3836: -
- 3837: -
- 3838: -
- 3839: -
- 3840: Not started 02/2003. Marked as stopped 12/2008
- 3841: Marked as stopped 12/2008
- 3842: -

| ID | WBS | Task | Duration | Start | Finish | Complete | Baseline start | Baseline finish | Baseline duration | Constraint | Resources | Work | Actual work | Acronym | Release | MCC resp | Acronym_3GU_Export | WI rapporteur name | WI rapporteur e-mail |
| --- | --- | --- | --- | --- | --- | --- | --- | --- | --- | --- | --- | --- | --- | --- | --- | --- | --- | --- | --- |
| 3843 | 11 | **Rel-5 Terminal interfaces** | 223d | 2001-05-14 A | 2002-03-20 A | 100% | 2001-05-14 | 2002-03-20 | 223d |  | T2 | 3568h | 3568h | TI, TLM5 | Rel-5 | Kimmo | TI, TLM5 |  |  |
| 3844 | 87 | Terminal local model enhancements | 223d | 2001-05-14 A | 2002-03-20 A | 100% | 2001-05-14 | 2002-03-20 | 223d | finish no earlier than 2002-03-20 | T2 | 1784h | 1784h | TLM5 | Rel-5 |  | TLM5 |  |  |
| 3845 | 88 | **Rel-5 Location Services enhancements** | 845d | 2000-04-03 A | 2003-06-27 A | 100% | 2000-04-03 | 2003-06-27 | 845d |  | S2; S1; S3; S5; N4; R2; R3; GP | 237560h | 237560h | LCS1, Rel-5 | Rel-5 | Maurice | LCS1, Rel-5 | Nokia | Jan Kall |
| 3846 | 88.1 | **UE positioning for Rel-5 Location Services enhancements** | 315d | 2001-01-15 A | 2002-03-29 A | 100% | 2001-01-15 | 2002-03-29 | 315d |  | R2 | 6120h | 6120h | LCS1-Uepos, Rel-5 | Rel-5 | Issam | LCS1-Uepos, Rel-5 |  |  |
| 3847 | 88.1.1 | UE positioning enhancements for 1.28 Mcps TDD | 255d | 2001-04-09 A | 2002-03-29 A | 100% | 2001-04-09 | 2002-03-29 | 255d | finish no earlier than 2002-03-29 | R2 | 2040h | 2040h | LCS-128Pos | Rel-5 | Yong-Jun | LCS-128Pos | CATT | Xiaohua Mei |
| 3848 | 88.1.2 | Open SMLC-SRNC Interface within the UTRAN to support A-GPS Positioning | 195d | 2001-01-15 A | 2001-10-12 A | 100% | 2001-01-15 | 2001-10-12 | 195d |  | R2 | 1560h | 1560h | LCS-INTF | Rel-5 | Yong-Jun | LCS-INTF | Qualcomm | Kirk Burroughs |
| 3849 | 88.2 | **Event Based and Periodic LCS** | 535d | 2000-05-22 A | 2002-06-07 A | 100% | 2000-05-22 | 2002-06-07 | 535d |  | S1; S2; N4 | 14848h | 14848h | LCS1-EBP | Rel-5 | Alain | LCS1-EBP | Pacific Bell Wireless | Randolph Wohlert (rwohlert@tri.sbc.com) |
| 3850 | 88.2.1 | Stage 1 for Event based and Periodic LCS | 130d | 2000-05-22 A | 2000-11-17 A | 100% | 2000-05-22 | 2000-11-17 | 130d | finish no earlier than 2000-07-21 | S1 | 1040h | 1040h |  | Rel-5 | Alain |  | Pacific Bell Wireless | Randolph Wohlert (rwohlert@tri.sbc.com) |
| 3851 | 88.2.2 | Stage 2 for Event based and Periodic LCS | 60d | 2000-11-06 A | 2001-01-26 A | 100% | 2000-11-06 | 2001-01-26 | 60d | finish no earlier than 2001-01-26 | S2 | 480h | 480h |  | Rel-5 | Maurice |  |  |  |
| 3852 | 88.2.3 | Impact on MAP | 61d | 2002-03-15 A | 2002-06-07 A | 100% | 2002-03-15 | 2002-06-07 | 61d | finish no earlier than 2002-06-07 | N4 | 488h | 488h |  | Rel-5 | Kimmo |  |  |  |
| 3853 | 88.3 | **Location Services for GERAN in A/Gb Mode** | 485d | 2000-04-03 A | 2002-02-08 A | 100% | 2000-04-03 | 2002-02-08 | 485d |  | GP | 26400h | 26400h | LCS-GERAN | Rel-5 | Paolo | LCS-GERAN | Nokia | Margaret Livingston |
| 3854 | 88.3.1 | GERAN LCS Stage 2 (first release) | 485d | 2000-04-03 A | 2002-02-08 A | 100% | 2000-04-03 | 2002-02-08 | 485d | finish no earlier than 2002-02-08 | GP; S2; G1; G2 | 15520h | 15520h |  | Rel-5 | Paolo |  | Nokia | Margaret Livingston |
| 3855 | 88.3.2 | Gb interface support for LCS | 370d | 2000-04-03 A | 2001-08-31 A | 100% | 2000-04-03 | 2001-08-31 | 370d | finish no earlier than 2001-08-31 | GP | 2960h | 2960h |  | Rel-5 | Paolo |  | Nokia | Margaret Livingston |
| 3856 | 88.3.3 | L3 protocol support for LCS | 305d | 2000-04-03 A | 2001-06-01 A | 100% | 2000-04-03 | 2001-06-01 | 305d | finish no earlier than 2001-06-01 | GP | 2440h | 2440h |  | Rel-5 | Paolo |  | Nokia | Margaret Livingston |
| 3857 | 88.3.4 | Stage 3 for Location Services for GERAN in A/Gb Mode | 305d | 2000-04-03 A | 2001-06-01 A | 100% | 2000-04-03 | 2001-06-01 | 305d | finish no earlier than 2001-06-01 | GP | 2440h | 2440h |  | Rel-5 | Paolo |  | Nokia | Margaret Livingston |
| 3858 | 88.4 | **Location Services for GERAN in Iu Mode** | 585d | 2000-04-03 A | 2002-06-28 A | 100% | 2000-04-03 | 2002-06-28 | 585d |  | S2; G1; G2; R2; R3 | 64264h | 64264h |  | Rel-5 | Paolo |  | Nokia | Margaret Livingston |
| 3859 | 88.4.1 | GERAN LCS Stage 2 | 585d | 2000-04-03 A | 2002-06-28 A | 100% | 2000-04-03 | 2002-06-28 | 585d | finish no earlier than 2002-06-28 | S2; G1; G2 | 14040h | 14040h |  | Rel-5 | Paolo |  | Nokia | Margaret Livingston |
| 3860 | 88.4.2 | Iu-ps interface support for LCS | 585d | 2000-04-03 A | 2002-06-28 A | 100% | 2000-04-03 | 2002-06-28 | 585d | finish no earlier than 2002-06-28 | R2; R3 | 9360h | 9360h |  | Rel-5 | Paolo |  | Nokia | Margaret Livingston |
| 3861 | 88.4.3 | Iu-cs interface support for LCS | 585d | 2000-04-03 A | 2002-06-28 A | 100% | 2000-04-03 | 2002-06-28 | 585d | finish no earlier than 2002-06-28 | R2; R3 | 9360h | 9360h |  | Rel-5 | Paolo |  | Nokia | Margaret Livingston |
| 3862 | 88.4.4 | Iur-g interface support for LCS | 62.5d | 2002-01-23 A | 2002-04-19 A | 100% | 2002-01-23 | 2002-04-19 | 62.5d | finish no earlier than 2002-04-19 | G1; G2 | 1000h | 1000h |  | Rel-5 | Paolo |  | Nokia | Margaret Livingston |
| 3863 | 88.4.5 | RRC protocol support for LCS | 75d | 2001-08-20 A | 2001-11-30 A | 100% | 2001-08-20 | 2001-11-30 | 75d | finish no earlier than 2001-11-30 | G1; G2; R2; R3 | 2400h | 2400h |  | Rel-5 | Paolo |  | Nokia | Margaret Livingston |
| 3864 | 88.4.6 | Additional impacts on Broadcast of LCS data on packet channels | 77.5d | 2001-08-20 A | 2001-12-05 A | 100% | 2001-08-20 | 2001-12-05 | 77.5d | finish no earlier than 2001-12-05 | G1; G2; R2; R3 | 2480h | 2480h |  | Rel-5 | Paolo |  | Nokia | Margaret Livingston |
| 3865 | 88.4.7 | Stage 3 for Location Services for GERAN in Iu Mode | 69.5d | 2002-03-25 A | 2002-06-28 A | 100% | 2002-03-25 | 2002-06-28 | 69.5d | finish no earlier than 2002-06-28 | G1; G2; R2; R3 | 2224h | 2224h |  | Rel-5 | Paolo |  | Nokia | Margaret Livingston |
| 3866 | 88.5 | **GERAN MS Conformance test for LCS** | 280d | 2002-06-03 A | 2003-06-27 A | 100% | 2002-06-03 | 2003-06-27 | 280d |  | GP | 11200h | 11200h | LCS-GERAN-MSconf | Rel-5 | Paolo | LCS-GERAN-MSconf |  |  |
| 3867 | 88.5.1 | LCS MS test case work plan (Release 98/99/4) | 280d | 2002-06-03 A | 2003-06-27 A | 100% | 2002-06-03 | 2003-06-27 | 280d | finish no earlier than 2003-06-27 | G4; G5 | 4480h | 4480h |  | Rel-5 | Paolo |  |  |  |
| 3868 | 88.5.2 | LCS MS test cases | 280d | 2002-06-03 A | 2003-06-27 A | 100% | 2002-06-03 | 2003-06-27 | 280d | finish no earlier than 2003-06-27 | G4; G5 | 4480h | 4480h |  | Rel-5 | Paolo |  |  |  |

Notes:
- 3843: -
- 3844: - / Impacted TSs and TRs: 23.227
- 3845: -
- 3846: -
- 3847: - / Impacted TSs and TRs: 25.123, 25.224, 25.225, 25.302, 25.303, 25.304, 25.305, 25.331, 25.420, 25.423, 25.430, 25.433, New TR 25.859
- 3848: RP#13 completed
- 3849: -
- 3850: Evaluate Event based and Periodic LCS to be included in R00, corresponding Stage 1 description / Impacted TSs and TRs: 22.071
- 3851: Marked as closed 12/2008 (was marked 51% complete)
- 3852: Possible impact on UTRAN of LCS quality level request / 17 May No stage 2 for event-based & periodic LCS. Work 100% completefor current stage 2
- 3853: -
- 3854: -
- 3855: -
- 3856: -
- 3857: -
- 3858: -
- 3859: -
- 3860: -
- 3861: -
- 3862: FFS
- 3863: -
- 3864: -
- 3865: -
- 3866: -
- 3867: Marked as closed 12/2008 (was marked 60% complete)
- 3868: Marked as closed 12/2008 (was marked 60% complete)

| ID | WBS | Task | Duration | Start | Finish | Predecessors | Complete | Baseline start | Baseline finish | Baseline duration | Constraint | Resources | Work | Actual work | Acronym | Release | MCC resp | TSG stopped | Acronym_3GU_Export | Impacted TSs and TRs | WI rapporteur name | WI rapporteur e-mail |
| --- | --- | --- | --- | --- | --- | --- | --- | --- | --- | --- | --- | --- | --- | --- | --- | --- | --- | --- | --- | --- | --- | --- |
| 3869 | 88.6 | **Deleted - GERAN BTS Conformance test for LCS** | 280d | 2002-06-03 A | 2003-06-27 A |  | 100% | 2002-06-03 | 2003-06-27 | 280d |  | GP | 11200h | 11200h | LCS-GERAN-BTSconf | Rel-5 | Paolo | GP-15 | LCS-GERAN-BTSconf |  |  |  |
| 3870 | 88.6.1 | Deleted - LCS BTS test case work plan (Release 98/99/4) | 280d | 2002-06-03 A | 2003-06-27 A |  | 100% | 2002-06-03 | 2003-06-27 | 280d | finish no earlier than 2003-06-27 | G4; G5 | 4480h | 4480h |  | Rel-5 | Paolo | GP-15 |  |  |  |  |
| 3871 | 88.6.2 | Deleted - LCS BTS test cases | 280d | 2002-06-03 A | 2003-06-27 A |  | 100% | 2002-06-03 | 2003-06-27 | 280d | finish no earlier than 2003-06-27 | G4; G5 | 4480h | 4480h |  | Rel-5 | Paolo | GP-15 |  |  |  |  |
| 3872 | 88.7 | LCS interoperation stage 2 aspects | 480d | 2000-08-28 A | 2002-06-28 A |  | 100% | 2000-08-28 | 2002-06-28 | 480d |  | S2 | 3840h | 3840h |  | Rel-5 | Maurice |  |  |  |  |  |
| 3873 | 88.8 | **LCS interoperability aspects to GERAN (LCS-GERAN)** | 480d | 2000-08-28 A | 2002-06-28 A |  | 100% | 2000-08-28 | 2002-06-28 | 480d |  | GP; S5 | 34560h | 34560h |  | Rel-5 | Paolo |  |  |  |  |  |
| 3874 | 88.8.1 | Co-ordinated development of GSM LCS Phase 2 and UMTS LCS, S2 and GERAN | 480d | 2000-08-28 A | 2002-06-28 A |  | 100% | 2000-08-28 | 2002-06-28 | 480d | finish no earlier than 2002-06-28 | GP; S2; S5; R2; R3; G2; G1 | 26880h | 26880h |  | Rel-5 | Paolo |  |  |  |  |  |
| 3875 | 88.9 | FS on LCS support in the IMS | 90d | 2001-02-12 A | 2002-01-18 A |  | 100% | 2001-02-12 | 2002-01-18 | 90d | start no earlier than 2001-02-12 | S1 | 720h | 720h |  | Rel-5 | Alain |  |  |  |  |  |
| 3876 | 88.10 | Charging and OAM&P for LCS enhancements | 201d | 2001-09-21 A | 2002-06-28 A |  | 100% | 2001-09-21 | 2002-06-28 | 201d | finish no earlier than 2002-06-28 | S5 | 1608h | 1608h | LCS1-OAM | Rel-5 | Mirko |  | LCS1-OAM | 32.200-series |  |  |
| 3877 | 88.11 | New security aspects of LCS | 446d | 2000-04-14 A | 2001-12-28 A |  | 100% | 2000-04-14 | 2001-12-28 | 446d | finish no earlier than 2001-12-28 | S3; S2 | 7136h | 7136h | LCS1-SEC | Rel-5 | Mirko |  | LCS1-SEC | 23.271, 43.059 | Nokia | valtteri.niemi@nokia.com |
| 3878 | 88.12 | Specification for the Le interface | 45d | 2002-01-14 A | 2002-03-15 A |  | 100% | 2002-01-14 | 2002-03-15 | 45d | start no earlier than 2002-01-14 | S2 | 360h | 360h | LCS1-Le | Rel-5 | Maurice |  | LCS1-Le |  |  |  |
| 3879 | 88.13 | Deleted - CHECK STATUS - Inter-GMLC interface | 153d | 2002-05-30 A | 2002-12-30 A |  | 100% | 2002-05-30 | 2002-12-30 | 153d | finish no earlier than 2002-12-30 | S2 | 1224h | 1224h |  | Rel-5 | Maurice | SP-10 |  |  |  |  |
| 3880 | 89 | **Rel-5 Security enhancements (SEC1)** | 615d | 2000-02-21 A | 2002-06-28 A |  | 100% | 2000-02-21 | 2002-06-28 | 615d |  | S3 | 29974.9h | 29974.9h |  | Rel-5 | Mirko |  |  |  | Vodafone | Peter.Howard@vodafone.com |
| 3881 | 89.1 | **Rel-5 Network Domain Security (SEC1-NDS)** | 615d | 2000-02-21 A | 2002-06-28 A |  | 100% | 2000-02-21 | 2002-06-28 | 615d |  | S3 | 25054.9h | 25054.9h |  | Rel-5 | Mirko |  |  | New 33.200 (exists also for Rel-4) | Telenor | Geir-myrdahl.koien@telenor.com |
| 3882 | 89.1.3 | Rel-5 IP network layer security (NDS/IP) (SEC1-NDS-IP) | 457d | 2000-06-15 A | 2002-03-15 A |  | 100% | 2000-06-15 | 2002-03-15 | 457d | finish no earlier than 2002-03-15 | S3 | 3656h | 3656h |  | Rel-5 | Mirko |  |  | New 33.210 | Telenor | Geir-myrdahl.koien@telenor.com |
| 3883 | 89.1.1 | **Deleted - Control plane protection in core network (e.g., GTP, CAP, MAP/IP, provided by IPsec)** | 541d | 2000-05-12 A | 2002-06-07 A |  | 100% | 2000-05-12 | 2002-06-07 | 541d |  | S3 | 7118.9h | 7118.9h |  | Rel-5 | Mirko | SP-16 |  |  |  |  |
| 3884 | 89.1.1.1 | Deleted - Main aspects of User plane protection in core network (e.g., provided by IPsec) | 290d | 2000-05-12 A | 2001-06-21 A |  | 100% | 2000-05-12 | 2001-06-21 | 290d | finish no earlier than 2001-06-21 | S3 | 2320h | 2320h |  | Rel-5 | Mirko | SP-12 |  |  |  |  |
| 3885 | 89.1.1.2 | Deleted - Integration of GTP signalling security architecture - for User plane protection in core network (e.g., provided by IPsec) | 191d | 2001-09-14 A | 2002-06-07 A |  | 100% | 2001-09-14 | 2002-06-07 | 191d | finish no earlier than 2002-06-07 | N4 | 1528h | 1528h |  | Rel-5 | Kimmo | NP-16 |  |  |  |  |
| 3886 | 89.1.2 | **Deleted - User plane protection in core network (e.g., provided by IPsec)** | 615d | 2000-02-21 A | 2002-06-28 A |  | 100% | 2000-02-21 | 2002-06-28 | 615d |  | S3 | 9360h | 9360h |  | Rel-5 | Mirko | SP-16 |  |  |  |  |
| 3887 | 89.1.2.1 | Deleted -Main aspects of User plane protection in core network (e.g., provided by IPsec) | 349d | 2000-02-21 A | 2001-06-21 A |  | 100% | 2000-02-21 | 2001-06-21 | 349d | finish no earlier than 2001-06-21 | S3 | 2792h | 2792h |  | Rel-5 | Mirko | SP-12 |  |  |  |  |
| 3888 | 89.1.2.2 | Deleted - Integration of GTP signalling security architecture - for User plane protection in core network (e.g., provided by IPsec) | 206d | 2001-09-14 A | 2002-06-28 A |  | 100% | 2001-09-14 | 2002-06-28 | 206d | finish no earlier than 2002-06-28 | N4 | 1648h | 1648h |  | Rel-5 | Kimmo | NP-16 |  |  |  |  |
| 3889 | 90 | **Intra Domain Connection of RAN Nodes to Multiple CN Nodes** | 455d | 2000-10-02 A | 2002-06-28 A |  | 100% | 2000-10-02 | 2002-06-28 | 455d |  | S2; N1; N4; R3; GP | 30232h | 30232h | IUFLEX | Rel-5 | Alain |  | IUFLEX | 23.236 | Ericsson | stephen.terrill@ericsson.com |
| 3890 | 90.1 | Overall System Architecture for Intra Domain Connection of RAN Nodes to Multiple CN Nodes | 188d | 2001-01-03 A | 2001-09-21 A |  | 100% | 2001-01-03 | 2001-09-21 | 188d | finish no earlier than 2001-06-01 | S2 | 1504h | 1504h |  | Rel-5 | Maurice |  |  |  |  |  |
| 3891 | 90.2 | Stage 3: RAN node selecting CN node | 130d | 2001-09-24 A | 2002-03-22 A | 3890 | 100% | 2001-09-24 | 2002-03-22 | 130d | finish no earlier than 2002-03-22 | R3 | 1040h | 1040h |  | Rel-5 | Juha |  |  |  | Vodafone | Brendan.McWilliams@gb.vodafone.co.uk |
| 3892 | 90.3 | N1 work for Intra Domain Connection of RAN Nodes to Multiple CN Nodes | 205d | 2001-09-17 A | 2002-06-28 A |  | 100% | 2001-09-17 | 2002-06-28 | 205d | start no earlier than 2001-09-17 | N1 | 1640h | 1640h |  | Rel-5 | Frederic |  |  | 24.008 and check 29.018 |  |  |
| 3893 | 90.4 | N4 work for Intra Domain Connection of RAN Nodes to Multiple CN Nodes | 375d | 2000-10-02 A | 2002-03-08 A |  | 100% | 2000-10-02 | 2002-03-08 | 375d | finish no earlier than 2002-03-15 | N4 | 3000h | 3000h |  | Rel-5 | Kimmo |  |  |  |  |  |

Notes:
- 3869: Not started 02/3003. Marked as stopped 12/2008
- 3870: Marked as stopped 12/2008
- 3871: Marked as stopped 12/2008
- 3872: Marked as closed 12/2008 (was marked 17% complete)
- 3873: -
- 3874: -
- 3875: Marked as closed 12/2008 (was marked 75% complete)
- 3876: -
- 3877: SP#9 updated WID S3-000609 (Location services security)
- 3878: -
- 3879: Marked as stopped 12/2008
- 3880: Added BB UE authentication and rapporteur added. TO BE DELETED
- 3881: SP#9 approved WID SP-000420 (S3-000606 Network domain security). S3#17: All due in Rel5. (WI Update at S3#18). Replaced by NDS-IP and NDS-MAP. TO BE DELETED OR MOVED TO HISTORY FILE
- 3882: SP#12 WID updated SP-000420 (S3-000606) =>SP-010326 (S3-010286)
- 3883: Marked as stopped 12/2008
- 3884: TO BE DELETED. Marked as stopped 12/2008
- 3885: Waiting for input from SA3!.... Marked as stopped 12/2008
- 3886: TO BE DELETED. Marked as stopped 12/2008
- 3887: -
- 3888: 14/02/2002 requirements are not clear/not received...Marked as closed 12/2008 (was marked 95 complete)
- 3889: No clear indication on the end date. Put to Rel5 by AS.
- 3890: -
- 3891: Not identified
- 3892: -
- 3893: DAB 12.12.01 - % complete to 66% / 14/02/02 Work completed

| ID | WBS | Task | Duration | Start | Finish | Complete | Baseline start | Baseline finish | Baseline duration | Constraint | Resources | Work | Actual work | Acronym | WI rapporteur name | WI rapporteur e-mail | Release | MCC resp | Acronym_3GU_Export | TSG stopped | Impacted TSs and TRs |
| --- | --- | --- | --- | --- | --- | --- | --- | --- | --- | --- | --- | --- | --- | --- | --- | --- | --- | --- | --- | --- | --- |
| 3894 | 90.5 | **GERAN work for Intra Domain Connection of RAN Nodes to Multiple CN Nodes** | 101d | 2002-02-08 A | 2002-06-28 A | 100% | 2002-02-08 | 2002-06-28 | 101d |  | GP | 4848h | 4848h | IDCRAN-GERAN | Ericsson | ingemar.backlund@era.ericsson.se | Rel-5 | Paolo | IDCRAN-GERAN |  |  |
| 3895 | 90.5.1 | Stage 2 (changes to ) | 101d | 2002-02-08 A | 2002-06-28 A | 100% | 2002-02-08 | 2002-06-28 | 101d | finish no earlier than 2002-06-28 | G1 | 808h | 808h |  |  |  | Rel-5 | Paolo |  |  |  |
| 3896 | 90.5.2 | 43.051 Introduction of support for IDNNS in GERAN Iu mode | 101d | 2002-02-08 A | 2002-06-28 A | 100% | 2002-02-08 | 2002-06-28 | 101d | finish no earlier than 2002-06-28 | G1 | 808h | 808h |  |  |  | Rel-5 | Paolo |  |  |  |
| 3897 | 90.5.3 | Stage 3 (changes to ) | 101d | 2002-02-08 A | 2002-06-28 A | 100% | 2002-02-08 | 2002-06-28 | 101d | finish no earlier than 2002-06-28 | G2 | 808h | 808h |  |  |  | Rel-5 | Gert |  |  |  |
| 3898 | 90.5.4 | 48.016 Use of Gb interface concepts when a network applies IDNNS | 101d | 2002-02-08 A | 2002-06-28 A | 100% | 2002-02-08 | 2002-06-28 | 101d | finish no earlier than 2002-06-28 | G2 | 808h | 808h |  |  |  | Rel-5 | Gert |  |  |  |
| 3899 | 90.5.5 | 48.018 Include MSC/VLR identity in CS IMSI paging | 101d | 2002-02-08 A | 2002-06-28 A | 100% | 2002-02-08 | 2002-06-28 | 101d | finish no earlier than 2002-06-28 | G2 | 808h | 808h |  |  |  | Rel-5 | Gert |  |  |  |
| 3900 | 91 | **Deleted - GERAN improvements 3 (new transport layer on interface A)** | 446d | 2001-04-06 A | 2002-12-20 A | 100% | 2001-04-06 | 2002-12-20 | 446d |  | GP | 14272h | 14272h | GEIMP3 |  |  | Rel-5 | Paolo | GEIMP3 |  |  |
| 3901 | 91.1 | **Deleted - Evolution of the transport for A** | 446d | 2001-04-06 A | 2002-12-20 A | 100% | 2001-04-06 | 2002-12-20 | 446d |  | GP | 10704h | 10704h | GEIMP3-EtA |  |  | Rel-5 | Paolo | GEIMP3-EtA | GP-12 |  |
| 3902 | 91.1.1 | Deleted - Definition of a new A/Ater interface Transport Layer option based on the Iu Interface Transport Layer | 446d | 2001-04-06 A | 2002-12-20 A | 100% | 2001-04-06 | 2002-12-20 | 446d | finish no earlier than 2002-12-20 | GP | 3568h | 3568h |  |  |  | Rel-5 | Paolo |  | GP-12 |  |
| 3903 | 91.1.2 | Deleted - Adaptation of the Layer 3 BSSMAP procedures as required | 446d | 2001-04-06 A | 2002-12-20 A | 100% | 2001-04-06 | 2002-12-20 | 446d | finish no earlier than 2002-12-20 | GP | 3568h | 3568h |  |  |  | Rel-5 | Paolo |  | GP-12 |  |
| 3904 | 92 | **Rel-5 Charging Management & Operations, Administration, Maintenance and Provisioning (OAM&P)** | 264d | 2001-09-10 A | 2002-09-12 A | 100% | 2001-09-10 | 2002-09-12 | 264d |  | S5 | 9976h | 9976h | OAM5 |  |  | Rel-5 | Mirko | OAM5 |  |  |
| 3905 | 92.1 | Rel-5 Principles, high level Requirements and Architecture | 205d | 2001-09-17 A | 2002-06-28 A | 100% | 2001-09-17 | 2002-06-28 | 205d | finish no earlier than 2002-06-28 | S5 | 1640h | 1640h |  | Motorola |  | Rel-5 | Mirko |  |  | 32.101, 32.102 |
| 3906 | 92.2 | Rel-5 Performance Management | 259d | 2001-09-17 A | 2002-09-12 A | 100% | 2001-09-17 | 2002-09-12 | 259d | finish no earlier than 2002-09-12 | S5 | 2072h | 2072h |  | Nortel |  | Rel-5 | Mirko |  |  | 32.4xy, 52.402 |
| 3907 | 92.3 | Rel-5 Charging Management | 264d | 2001-09-10 A | 2002-09-12 A | 100% | 2001-09-10 | 2002-09-12 | 264d | finish no earlier than 2002-09-12 | S5 | 2112h | 2112h |  | T-Mobile | Karl-Heinz.Nenner@T-MOBILE.DE | Rel-5 | Mirko |  |  | 32.200, 32.205, 32.215, 32.225, 32.235 |
| 3908 | 92.4 | Rel-5 Network Infrastructure Management | 255d | 2001-09-21 A | 2002-09-12 A | 100% | 2001-09-21 | 2002-09-12 | 255d | finish no earlier than 2002-09-12 | S5 | 2040h | 2040h |  | Ericsson | thomas.tovinger@ericsson.com | Rel-5 | Mirko |  |  | 32.6xy, 32.3xy |
| 3909 | 93 | **GERAN enhancements for streaming services 1 (RLC enhancements)** | 430d | 2000-11-06 A | 2002-06-28 A | 100% | 2000-11-06 | 2002-06-28 | 430d |  | GP | 8944h | 8944h |  |  |  | Rel-5 | Paolo |  |  |  |
| 3910 | 93.1 | Concept for GERAN enhancements for streaming services 1 (RLC enhancements) | 258d | 2000-11-06 A | 2001-10-31 A | 100% | 2000-11-06 | 2001-10-31 | 258d | finish no earlier than 2001-10-31 | GP | 2064h | 2064h |  |  |  | Rel-5 | Paolo |  |  |  |
| 3911 | 93.2 | RLC protocol enhancement (SDU Discard) | 430d | 2000-11-06 A | 2002-06-28 A | 100% | 2000-11-06 | 2002-06-28 | 430d | finish no earlier than 2002-06-28 | GP | 3440h | 3440h |  |  |  | Rel-5 | Paolo |  |  |  |
| 3912 | 94 | **GERAN enhancements for streaming services 2 (usage of ECSD)** | 430d | 2000-11-06 A | 2002-06-28 A | 100% | 2000-11-06 | 2002-06-28 | 430d |  | GP | 19840h | 19840h |  | Ericsson | Frank Muller | Rel-5 | Paolo |  |  |  |
| 3913 | 94.1 | Usage of ECSD Concept | 380d | 2000-11-06 A | 2002-04-19 A | 100% | 2000-11-06 | 2002-04-19 | 380d | finish no earlier than 2002-04-19 | GP | 3040h | 3040h |  |  |  | Rel-5 | Paolo |  |  |  |
| 3914 | 94.2 | Stage 2 for GERAN enhancements for streaming services 2 (usage of ECSD) | 380d | 2000-11-06 A | 2002-04-19 A | 100% | 2000-11-06 | 2002-04-19 | 380d | finish no earlier than 2002-04-19 | GP | 3040h | 3040h |  |  |  | Rel-5 | Paolo |  |  |  |
| 3915 | 94.3 | Stage 3 for GERAN enhancements for streaming services 2 (usage of ECSD) | 430d | 2000-11-06 A | 2002-06-28 A | 100% | 2000-11-06 | 2002-06-28 | 430d | finish no earlier than 2002-06-28 | GP | 3440h | 3440h |  |  |  | Rel-5 | Paolo |  |  |  |
| 3916 | 94.4 | RLC PDU formats | 430d | 2000-11-06 A | 2002-06-28 A | 100% | 2000-11-06 | 2002-06-28 | 430d | finish no earlier than 2002-06-28 | GP | 3440h | 3440h |  |  |  | Rel-5 | Paolo |  |  |  |
| 3917 | 94.5 | MAC header | 430d | 2000-11-06 A | 2002-06-28 A | 100% | 2000-11-06 | 2002-06-28 | 430d | finish no earlier than 2002-06-28 | GP | 3440h | 3440h |  |  |  | Rel-5 | Paolo |  |  |  |

Notes:
- 3894: Accept changes Gb over IP
- 3895: -
- 3896: -
- 3897: -
- 3898: Closed, accept changes for Gb over IP
- 3899: -
- 3900: Terminated - not standardized. Marked as stopped 12/2008
- 3901: TERMINATED - NOT STANDARDIZED. Marked as stopped 12/2008
- 3902: TERMINATED - NOT STANDARDIZED. Marked as stopped 12/2008
- 3903: TERMINATED - NOT STANDARDIZED. Marked as stopped 12/2008
- 3904: -
- 3905: -
- 3906: -
- 3907: -
- 3908: -
- 3909: -
- 3910: -
- 3911: -
- 3912: AWS, Nokia, Ericsson, Nortel, Siemens, Motorola, Vodafone
- 3913: -
- 3914: -
- 3915: -
- 3916: -
- 3917: -

| ID | WBS | Task | Duration | Start | Finish | Predecessors | Complete | Baseline start | Baseline finish | Baseline duration | Constraint | Resources | Work | Actual work | Acronym | WI rapporteur name | WI rapporteur e-mail | Release | MCC resp | Acronym_3GU_Export |
| --- | --- | --- | --- | --- | --- | --- | --- | --- | --- | --- | --- | --- | --- | --- | --- | --- | --- | --- | --- | --- |
| 3918 | 95 | **GERAN/UTRAN interface evolution 1 (evolution of Iu PS)** | 476d | 2000-09-01 A | 2002-06-28 A |  | 100% | 2000-09-01 | 2002-06-28 | 476d |  | GP; R3 | 22848h | 22848h | GERUEV1 | SBC | Marc Grant | Rel-5 | Paolo | GERUEV1 |
| 3919 | 95.1 | **Evolution of Iu ps** | 476d | 2000-09-01 A | 2002-06-28 A |  | 100% | 2000-09-01 | 2002-06-28 | 476d |  | GP; R3 | 15232h | 15232h | GERUEV1-IuPS |  |  | Rel-5 | Paolo | GERUEV1-IuPS |
| 3920 | 95.1.1 | Identification of GERAN requirements on Iu ps | 326d | 2000-09-01 A | 2001-11-30 A |  | 100% | 2000-09-01 | 2001-11-30 | 326d | finish no earlier than 2001-11-30 | GP; R3 | 5216h | 5216h |  |  |  | Rel-5 | Paolo |  |
| 3921 | 95.1.2 | Update of Evolution of Iu ps specifications | 150d | 2001-12-03 A | 2002-06-28 A | 3920 | 100% | 2001-12-03 | 2002-06-28 | 150d | finish no earlier than 2002-06-28 | GP; R3 | 2400h | 2400h |  |  |  | Rel-5 | Paolo |  |
| 3922 | 96 | **GERAN/UTRAN interface evolution 2 (evolution of Iu CS)** | 522d | 2000-06-29 A | 2002-06-28 A |  | 100% | 2000-06-29 | 2002-06-28 | 522d |  | GP; R3 | 31872h | 31872h | GERUEV2 |  |  | Rel-5 | Paolo | GERUEV2 |
| 3923 | 96.1 | **Evolution of Iu cs** | 522d | 2000-06-29 A | 2002-06-28 A |  | 100% | 2000-06-29 | 2002-06-28 | 522d |  | GP; R3 | 23520h | 23520h | GERUEV2-IuCS | Lucent | Krishna Balachandran | Rel-5 | Paolo | GERUEV2-IuCS |
| 3924 | 96.1.1 | Identification of GERAN requirements on Iu cs | 472d | 2000-06-29 A | 2002-04-19 A |  | 100% | 2000-06-29 | 2002-04-19 | 472d | finish no earlier than 2002-04-19 | GP; R3 | 7552h | 7552h |  |  |  | Rel-5 | Paolo |  |
| 3925 | 96.1.2 | Update of Evolution of Iu cs specifications | 476d | 2000-09-01 A | 2002-06-28 A |  | 100% | 2000-09-01 | 2002-06-28 | 476d | finish no earlier than 2002-06-28 | GP; R3 | 7616h | 7616h |  |  |  | Rel-5 | Paolo |  |
| 3926 | 97 | **End to End QoS for PS Domain including IMS** | 480d | 2000-08-28 A | 2002-06-28 A |  | 100% | 2000-08-28 | 2002-06-28 | 480d |  | S2; S5; N3 | 18272h | 18272h | E2EQoS, Rel-5 | Ericsson | Johnson.oyama@era.ericcson.se | Rel-5 | Maurice | E2EQoS, Rel-5 |
| 3927 | 97.1 | E2E QoSConcept and Architecture | 178d | 2001-01-03 A | 2001-09-07 A |  | 100% | 2001-01-03 | 2001-09-07 | 178d | finish no earlier than 2001-09-07 | S2 | 1424h | 1424h |  |  |  | Rel-5 | Maurice |  |
| 3928 | 97.2 | E2E QoS interworking | 465d | 2000-08-28 A | 2002-06-07 A |  | 100% | 2000-08-28 | 2002-06-07 | 465d | finish no earlier than 2002-06-07 | N3 | 3720h | 3720h | E2EQoS-IW | Lucent | Daisuke Yokota (yokota@lucent.com) | Rel-5 | Gwiho | E2EQoS-IW |
| 3929 | 97.3 | QoS Management (Provisioning and Monitoring) | 201d | 2001-09-21 A | 2002-06-28 A |  | 100% | 2001-09-21 | 2002-06-28 | 201d | finish no earlier than 2002-06-28 | S5 | 1608h | 1608h | E2EQoS-OAM |  |  | Rel-5 | Mirko | E2EQoS-OAM |
| 3930 | 98 | **Rel-5 Messaging enhancements** | 467d | 2001-06-15 A | 2003-03-31 A |  | 100% | 2001-06-15 | 2003-03-31 | 467d |  | T2 | 19000h | 19000h | MESS5 |  |  | Rel-5 | Kimmo | MESS5 |
| 3931 | 98.1 | **Rel-5 Multimedia Messaging (MMS) enhancements** | 467d | 2001-06-15 A | 2003-03-31 A |  | 100% | 2001-06-15 | 2003-03-31 | 467d |  | T2 | 11688h | 11688h | MESS5-MMS | Siemens | Josef.Laumen@SAL.SIEMENS.DE | Rel-5 | Alain | MESS5-MMS |
| 3932 | 98.1.1 | Definition of service requirements for MESS5-MMS | 196d | 2001-06-15 A | 2002-03-15 A |  | 100% | 2001-06-15 | 2002-03-15 | 196d | finish no earlier than 2002-03-15 | S1 | 1568h | 1568h | MESS5-SR | Siemens | Josef.Laumen@SAL.SIEMENS.DE | Rel-5 | Alain | MESS5-SR |
| 3933 | 98.1.2 | Technical realization of MESS5-MMS | 256d | 2001-06-15 A | 2002-06-07 A |  | 100% | 2001-06-15 | 2002-06-07 | 256d | finish no earlier than 2002-06-07 | T2 | 2048h | 2048h |  | Siemens | Josef.Laumen@SAL.SIEMENS.DE | Rel-5 |  |  |
| 3934 | 98.1.3 | WAP Forum dependency: MM1 stage 3 | 467d | 2001-06-15 A | 2003-03-31 A |  | 100% | 2001-06-15 | 2003-03-31 | 467d | finish no earlier than 2003-03-31 | T2 | 3736h | 3736h |  |  |  | Rel-5 |  |  |
| 3935 | 98.1.4 | MMS formats and codecs for MESS5-MMS | 75d | 2001-12-03 A | 2002-03-15 A |  | 100% | 2001-12-03 | 2002-03-15 | 75d | finish no earlier than 2002-03-15 | S4 | 600h | 600h |  |  |  | Rel-5 | Paolo |  |
| 3936 | 98.2 | **Enhanced Messaging Service (EMS) enhancements** | 191d | 2001-06-15 A | 2002-03-08 A |  | 100% | 2001-06-15 | 2002-03-08 | 191d |  | T2 | 3584h | 3584h | MESS5-EMS | Ericsson | Alan.Baldwin@EML.ERICSSON.SE | Rel-5 | Kimmo | MESS5-EMS |
| 3937 | 98.2.1 | Definition of service requirements for Enhanced Messaging Service (EMS) enhancements | 66d | 2001-06-15 A | 2001-09-14 A |  | 100% | 2001-06-15 | 2001-09-14 | 66d | finish no earlier than 2001-09-14 | S1 | 528h | 528h |  | Ericsson | Alan.Baldwin@EML.ERICSSON.SE | Rel-5 | Alain |  |
| 3938 | 98.2.2 | Technical realization of Enhanced Messaging Service (EMS) enhancements | 191d | 2001-06-15 A | 2002-03-08 A |  | 100% | 2001-06-15 | 2002-03-08 | 191d | finish no earlier than 2002-03-08 | T2 | 1528h | 1528h |  | Ericsson | Alan.Baldwin@EML.ERICSSON.SE | Rel-5 | Kimmo |  |
| 3939 | 99 | **GERAN Inter BSC NACC improvements over the Gb Interface** | 215d | 2001-09-03 A | 2002-06-28 A |  | 100% | 2001-09-03 | 2002-06-28 | 215d |  | GP | 11184h | 11184h | GERNACC |  |  | Rel-5 | Paolo | GERNACC |
| 3940 | 99.1 | **Modification of core network protocols for GERAN Inter BSC NACC over Gb Interface** | 165d | 2001-09-03 A | 2002-04-19 A |  | 100% | 2001-09-03 | 2002-04-19 | 165d |  | N4; S2 | 7048h | 7048h | GERNACC-Cnmod |  |  | Rel-5 | Kimmo | GERNACC-Cnmod |
| 3941 | 99.1.1 | Stage 2 - Concept | 43d | 2001-09-03 A | 2001-10-31 A |  | 100% | 2001-09-03 | 2001-10-31 | 43d | finish no earlier than 2001-10-31 | N4; S2 | 688h | 688h |  |  |  | Rel-5 | Kimmo |  |
| 3942 | 99.1.2 | Stage 2 - 23.060 change - Definition of Inter BSC NACC | 165d | 2001-09-03 A | 2002-04-19 A |  | 100% | 2001-09-03 | 2002-04-19 | 165d | finish no earlier than 2002-04-19 | N4; S2 | 2640h | 2640h |  |  |  | Rel-5 | Kimmo |  |
| 3943 | 99.1.3 | Stage 3 (changes to TS 29.060) | 135d | 2001-09-03 A | 2002-03-08 A |  | 100% | 2001-09-03 | 2002-03-08 | 135d | finish no earlier than 2002-03-08 | N4 | 1080h | 1080h |  |  |  | Rel-5 | Kimmo |  |

Notes:
- 3918: SBC, Motorola, Nokia, Ericsson, Nortel
- 3919: -
- 3920: -
- 3921: -
- 3922: -
- 3923: Lucent, Ericsson, AWS, Nortel
- 3924: -
- 3925: -
- 3926: -
- 3927: - / Impacted TSs and TRs: 23.207
- 3928: [DAB - 30/07/02] - % complete to 95% (if we exclude Diffserv). Marked as closed 12/2008 (was marked 95% complete) / Impacted TSs and TRs: 29.208, 29.207, 27.060, 29.061, 24.008, 24.228, , 24.229, 29.060, 29.163
- 3929: - / Impacted TSs and TRs: 32-series
- 3930: support of UAProf, so this in my opinion is 100% complete
- 3931: -
- 3932: - / Impacted TSs and TRs: 22.140
- 3933: stage 3 MM7 is missing / Impacted TSs and TRs: 23.140
- 3934: Marked as closed 12/2008 (was marked 80% complete)
- 3935: - / Impacted TSs and TRs: 26.140
- 3936: - / Impacted TSs and TRs: 23.040
- 3937: -
- 3938: - / Impacted TSs and TRs: 23.040
- 3939: -
- 3940: -
- 3941: -
- 3942: -
- 3943: IP 30/11/01: Input awaited from GERAN2 to CN4 / 17 May Work complete 100%

| ID | WBS | Task | Duration | Start | Finish | Complete | Baseline start | Baseline finish | Baseline duration | Constraint | Resources | Work | Actual work | Acronym | Release | MCC resp | Acronym_3GU_Export | TSG stopped | WI rapporteur name | WI rapporteur e-mail |
| --- | --- | --- | --- | --- | --- | --- | --- | --- | --- | --- | --- | --- | --- | --- | --- | --- | --- | --- | --- | --- |
| 3944 | 99.2 | **Modification of Gb protocols for GERAN Inter BSC NACC over Gb Interface** | 151d | 2001-11-30 A | 2002-06-28 A | 100% | 2001-11-30 | 2002-06-28 | 151d |  | GP | 2416h | 2416h | GERNACC-Gbmod | Rel-5 | Paolo | GERNACC-Gbmod |  |  |  |
| 3945 | 99.2.1 | Stage 3 (changes to TS 48.018) | 151d | 2001-11-30 A | 2002-06-28 A | 100% | 2001-11-30 | 2002-06-28 | 151d | finish no earlier than 2002-06-28 | GP | 1208h | 1208h |  | Rel-5 | Paolo |  |  |  |  |
| 3946 | 100 | **Enhanced Power Control** | 540d | 2001-11-26 A | 2003-12-19 A | 100% | 2001-11-26 | 2003-12-19 | 540d |  | GP | 12840h | 12840h | EPC | Rel-5 | Paolo | EPC |  |  |  |
| 3947 | 100.1 | Realization of Enhanced power control and signalling support | 5d | 2001-11-26 A | 2001-11-30 A | 100% | 2001-11-26 | 2001-11-30 | 5d | finish no earlier than 2001-11-30 | GP | 40h | 40h |  | Rel-5 | Paolo |  |  |  |  |
| 3948 | 100.2 | Deleted - GERAN MS Conformance test for Enhanced Power Control | 530d | 2001-12-10 A | 2003-12-19 A | 100% | 2001-12-10 | 2003-12-19 | 530d | finish no earlier than 2003-12-19 | GP | 4240h | 4240h |  | Rel-5 | Paolo |  | GP-17 |  |  |
| 3949 | 100.3 | Deleted - GERAN BTS Conformance test for Enhanced Power Control | 530d | 2001-12-10 A | 2003-12-19 A | 100% | 2001-12-10 | 2003-12-19 | 530d | finish no earlier than 2003-12-19 | GP | 4240h | 4240h |  | Rel-5 | Paolo |  | GP-17 |  |  |
| 3950 | 101 | **8PSK AMR HR** | 530d | 2001-12-10 A | 2003-12-19 A | 100% | 2001-12-10 | 2003-12-19 | 530d |  | GP | 21080h | 21080h | 8PSK-AH | Rel-5 | Paolo | 8PSK-AH |  |  |  |
| 3951 | 101.1 | **Definition of channel coding, performance requirements and signalling support** | 145d | 2001-12-10 A | 2002-06-28 A | 100% | 2001-12-10 | 2002-06-28 | 145d |  | GP | 10440h | 10440h |  | Rel-5 | Paolo |  |  |  |  |
| 3952 | 101.1.1 | Concept | 145d | 2001-12-10 A | 2002-06-28 A | 100% | 2001-12-10 | 2002-06-28 | 145d | finish no earlier than 2002-06-28 | GP | 1160h | 1160h |  | Rel-5 | Paolo |  |  |  |  |
| 3953 | 101.1.2 | Changes to 44.018 | 145d | 2001-12-10 A | 2002-06-28 A | 100% | 2001-12-10 | 2002-06-28 | 145d | finish no earlier than 2002-06-28 | G2 | 1160h | 1160h |  | Rel-5 | Gert |  |  |  |  |
| 3954 | 101.1.3 | Changes to 45.001 | 145d | 2001-12-10 A | 2002-06-28 A | 100% | 2001-12-10 | 2002-06-28 | 145d | finish no earlier than 2002-06-28 | G1 | 1160h | 1160h |  | Rel-5 | Paolo |  |  |  |  |
| 3955 | 101.1.4 | Changes to 45.002 | 145d | 2001-12-10 A | 2002-06-28 A | 100% | 2001-12-10 | 2002-06-28 | 145d | finish no earlier than 2002-06-28 | G1 | 1160h | 1160h |  | Rel-5 | Paolo |  |  |  |  |
| 3956 | 101.1.5 | Changes to 45.003 | 145d | 2001-12-10 A | 2002-06-28 A | 100% | 2001-12-10 | 2002-06-28 | 145d | finish no earlier than 2002-06-28 | G1 | 1160h | 1160h |  | Rel-5 | Paolo |  |  |  |  |
| 3957 | 101.1.6 | Changes to 45.005 | 145d | 2001-12-10 A | 2002-06-28 A | 100% | 2001-12-10 | 2002-06-28 | 145d | finish no earlier than 2002-06-28 | G1 | 1160h | 1160h |  | Rel-5 | Paolo |  |  |  |  |
| 3958 | 101.1.7 | Changes to 24.008 | 145d | 2001-12-10 A | 2002-06-28 A | 100% | 2001-12-10 | 2002-06-28 | 145d | finish no earlier than 2002-06-28 | G2 | 1160h | 1160h |  | Rel-5 | Gert |  |  |  |  |
| 3959 | 101.1.8 | Changes to 48.058 | 145d | 2001-12-10 A | 2002-06-28 A | 100% | 2001-12-10 | 2002-06-28 | 145d | finish no earlier than 2002-06-28 | G2 | 1160h | 1160h |  | Rel-5 | Gert |  |  |  |  |
| 3960 | 101.2 | Deleted - GERAN MS Conformance test for 8PSK HR | 530d | 2001-12-10 A | 2003-12-19 A | 100% | 2001-12-10 | 2003-12-19 | 530d | finish no earlier than 2003-12-19 | GP | 4240h | 4240h |  | Rel-5 | Paolo |  | GP-17 |  |  |
| 3961 | 101.3 | GERAN BTS Conformance test for 8PSK HR | 270d | 2001-12-10 A | 2002-12-20 A | 100% | 2001-12-10 | 2002-12-20 | 270d | finish no earlier than 2002-12-20 | GP | 2160h | 2160h |  | Rel-5 | Paolo |  |  |  |  |
| 3962 | 102 | Service Change and UDI Fallback | 175d | 2001-10-08 A | 2002-06-07 A | 100% | 2001-10-08 | 2002-06-07 | 175d | finish no earlier than 2002-06-07 | N3 | 1400h | 1400h | SCUDIF | Rel-5 | Gwiho | SCUDIF |  | Ericsson | Rune.Werner.Wiik@ericsson.no |
| 3963 | 103 | **Rel-5 USIM toolkit enhancements** | 865d | 2000-06-05 A | 2003-09-26 A | 100% | 2000-06-05 | 2003-09-26 | 865d |  | T3; S1 | 36776h | 36776h | USAT1, USAT1-Interpr, USAT1LocLnk | Rel-5 | Xavier | USAT1, USAT1-Interpr, USAT1LocLnk |  | G & D | Michael Meyer |
| 3964 | 103.1 | Deleted - Test specification for USIM toolkit security mechanisms | 349d | 2002-05-28 A | 2003-09-26 A | 100% | 2002-05-28 | 2003-09-26 | 349d | finish no earlier than 2003-09-26 | T3 | 2792h | 2792h |  | Rel-5 | Xavier |  | TP-21 | Gemplus | Sophie Viallet |
| 3965 | 103.2 | **Protocol Standardisation of a SIM Toolkit Interpreter** | 688d | 2000-06-05 A | 2003-01-22 A | 100% | 2000-06-05 | 2003-01-22 | 688d |  | T3; T2 | 18016h | 18016h |  | Rel-5 | Xavier |  |  | G & D | Michael Meyer |
| 3966 | 103.2.1 | Stage 1 for Protocol Standardisation of a SIM Toolkit Interpreter | 205d | 2000-06-05 A | 2001-03-16 A | 100% | 2000-06-05 | 2001-03-16 | 205d | finish no earlier than 2001-03-16 | T3 | 1640h | 1640h |  | Rel-5 | Xavier |  |  |  |  |
| 3967 | 103.2.2 | Stage 2 and 3 | 308d | 2001-01-03 A | 2002-03-08 A | 100% | 2001-01-03 | 2002-03-08 | 308d | finish no earlier than 2002-03-08 | T3 | 2464h | 2464h |  | Rel-5 | Xavier |  |  |  |  |
| 3968 | 103.2.3 | Test specification for Protocol Standardisation of a SIM Toolkit Interpreter | 363d | 2001-09-03 A | 2003-01-22 A | 100% | 2001-09-03 | 2003-01-22 | 363d | finish no earlier than 2003-01-22 | T3 | 2904h | 2904h |  | Rel-5 | Xavier |  |  | Gemplus | Gérald MAUNIER |

Notes:
- 3944: -
- 3945: -
- 3946: -
- 3947: Completed 11/2001
- 3948: Not started. Marked as stopped 12/2008
- 3949: Not started. Marked as stopped 12/2008
- 3950: Completed for Rel-5
- 3951: -
- 3952: -
- 3953: -
- 3954: -
- 3955: -
- 3956: -
- 3957: -
- 3958: -
- 3959: -
- 3960: Marked as stopped 12/2008
- 3961: -
- 3962: - / Impacted TSs and TRs: 29.007, 27.001, 24.008
- 3963: - / Impacted TSs and TRs: 22.038, 31.111 (USAT1), 22.038, 03.19, 03.48 (USAT1LocLnk), 23.048 (USAT1SM), 43.019 (USAT1APIJAVA)
- 3964: Marked as stopped 12/2008
- 3965: 28/5/2001: T3-19 proposed that since the stage 2 and 3 will not be presented to TP-12 for approval as expected, the WI will be moved to rel-5, with completion expected at TP-13. / Impacted TSs and TRs: T2 27.103
- 3966: 5/10/2001: Stage one comepeted at TP-12. / Impacted TSs and TRs: 31.112, 31.113, 31.114
- 3967: 5/10/2001: TS 31.112 and 31.113 approved at TP-13. TS 31.114 to be presented to TP-14. / Impacted TSs and TRs: 31.112, 31.113, 31.114
- 3968: 5/10/2001: Work started on test specification. Marked as closed 12/2008 (was marked 12% complete)

| ID | WBS | Task | Type | Duration | Start | Finish | Complete | Baseline start | Baseline finish | Baseline duration | Constraint | Resources | Work | Actual work | Acronym | WI rapporteur name | WI rapporteur e-mail | Release | MCC resp | Acronym_3GU_Export | TSG stopped |
| --- | --- | --- | --- | --- | --- | --- | --- | --- | --- | --- | --- | --- | --- | --- | --- | --- | --- | --- | --- | --- | --- |
| 3969 | 103.4 | **(U)SIM API** |  | 133d | 2002-03-20 A | 2002-09-20 A | 100% | 2002-03-20 | 2002-09-20 | 133d |  | T3 | 2128h | 2128h | USAT1-API, TEI4 | Microelectrónica Española | Mario Pérez | Rel-5 | Xavier | USAT1-API, TEI4 |  |
| 3970 | 103.4.1 | Rel-5 Java API Test specification |  | 133d | 2002-03-20 A | 2002-09-20 A | 100% | 2002-03-20 | 2002-09-20 | 133d | finish no earlier than 2002-09-20 | T3 | 1064h | 1064h |  | Microelectrónica Española | Mario Pérez | Rel-5 | Xavier |  |  |
| 3971 | 104 | (Small) Technical Enhancements and Improvements for Rel-5 | milestone | 0d? | 2000-01-03 A | 2000-01-03 A | 100% | 2000-01-03 | 2000-01-03 | 0d? |  | SP; CP; RP; GP |  |  | TEI5 |  |  | Rel-5 | all | TEI5 |  |
| 3972 | 987 | Test - (Small) Technical Enhancements and Improvements for Rel-5 |  | 2349d? | 2000-01-03 A | 2008-12-31 A | 100% | 2000-01-03 | 2008-12-31 | 2349d? | finish no earlier than 2008-12-31 | R5; T1 | 37584h | 37584h | TEI5_Test |  |  | Rel-5 | Ingbert | TEI5_Test |  |
| 3973 | 105 | Technical Report on UE Functionality Split |  | 87d | 2000-01-03 A | 2000-05-01 A | 100% | 2000-01-03 | 2000-05-01 | 87d |  | S1 | 688h | 688h | UESPLIT | Motorola | jian.j.wu@motorola.com | Rel-5 | Alain | UESPLIT |  |
| 3974 | 106 | **User Equipment Management** |  | 267d | 2001-06-21 A | 2002-06-28 A | 100% | 2001-06-21 | 2002-06-28 | 267d |  | S5 | 3752h | 3752h | UEM | Vodafone | john.mudge@vf.vodafone.co.uk | Rel-5 | Mirko | UEM |  |
| 3975 | 106.1 | FS on User Equipment (UE) Management |  | 267d | 2001-06-21 A | 2002-06-28 A | 100% | 2001-06-21 | 2002-06-28 | 267d | finish no earlier than 2002-06-28 | S5 | 2136h | 2136h | OAM-UEM | Vodafone | john.mudge@vf.vodafone.co.uk | Rel-5 | Mirko | OAM-UEM |  |
| 3976 | 107 | **Flow control supporting an MS with multiple data flows with different QoS over the Gb interface** |  | 50d | 2002-06-24 A | 2002-08-30 A | 100% | 2002-06-24 | 2002-08-30 | 50d |  | GP | 1288h | 1288h | FlowCon | Ericsson | ingemar.backlund@era.ericsson.se | Rel-5 | Paolo | FlowCon |  |
| 3977 | 107.1 | **Update of stage 2 specifications** |  | 50d | 2002-06-24 A | 2002-08-30 A | 100% | 2002-06-24 | 2002-08-30 | 50d |  | GP | 808h | 808h |  |  |  | Rel-5 | Paolo |  |  |
| 3978 | 107.1.1 | Concept document 23.060 (changes to) |  | 46d | 2002-06-28 A | 2002-08-30 A | 100% | 2002-06-28 | 2002-08-30 | 46d | finish no earlier than 2002-08-30 | S2 | 368h | 368h |  |  |  | Rel-5 | Maurice |  |  |
| 3979 | 107.1.2 | Flow Control |  | 5d | 2002-06-24 A | 2002-06-28 A | 100% | 2002-06-24 | 2002-06-28 | 5d | finish no earlier than 2002-06-28 | GP | 40h | 40h |  |  |  | Rel-5 | Paolo |  |  |
| 3980 | 107.2 | **Modification of BSSGP protocol** |  | 5d | 2002-06-24 A | 2002-06-28 A | 100% | 2002-06-24 | 2002-06-28 | 5d |  | GP | 80h | 80h |  | Ericsson | ingemar.backlund@era.ericsson.se | Rel-5 | Paolo |  |  |
| 3981 | 107.2.1 | Stage 3 (changes to 48.018) |  | 5d | 2002-06-24 A | 2002-06-28 A | 100% | 2002-06-24 | 2002-06-28 | 5d | finish no earlier than 2002-06-28 | G2 | 40h | 40h |  |  |  | Rel-5 | Gert |  |  |
| 3982 | 108 | **Deleted - Multiple TBF in A/Gb mode - Phase 1 (MULTBF)** |  | 421d | 2002-04-19 A | 2003-11-28 A | 100% | 2002-04-19 | 2003-11-28 | 421d |  | GP | 17480h | 17480h |  | Ericsson | gunnar.mildh@era.ericsson.se | Rel-5 | Paolo |  | GP-17 |
| 3983 | 108.1 | **Deleted - Multiple TBF in A/Gb mode - Core (MULTBF-Agbmode)** |  | 351d | 2002-04-19 A | 2003-08-22 A | 100% | 2002-04-19 | 2003-08-22 | 351d |  | GP | 8112h | 8112h |  |  |  | Rel-5 | Paolo |  | GP-17 |
| 3984 | 108.1.1 | Deleted - Multiple TBF Concept paper |  | 351d | 2002-04-19 A | 2003-08-22 A | 100% | 2002-04-19 | 2003-08-22 | 351d | finish no earlier than 2003-08-22 | GP | 2808h | 2808h |  |  |  | Rel-5 | Paolo |  | GP-17 |
| 3985 | 108.1.2 | Deleted - Multiple TBF Stage 2 (43.064) CRs |  | 156d | 2002-04-19 A | 2002-11-22 A | 100% | 2002-04-19 | 2002-11-22 | 156d | finish no earlier than 2002-11-22 | G1 | 1248h | 1248h |  |  |  | Rel-5 | Paolo |  | GP-12 |
| 3986 | 108.1.3 | Deleted - Multiple TBF Stage 3 (44.060) CRs |  | 156d | 2002-04-19 A | 2002-11-22 A | 100% | 2002-04-19 | 2002-11-22 | 156d | finish no earlier than 2002-11-22 | G2 | 1248h | 1248h |  |  |  | Rel-5 | Gert |  | GP-12 |
| 3987 | 108.2 | **Deleted - Multiple TBF in A/Gb mode - Phase 1 – MS testing** |  | 375d | 2002-06-24 A | 2003-11-28 A | 100% | 2002-06-24 | 2003-11-28 | 375d |  | GP | 6000h | 6000h |  | Ericsson | ingemar.backlund@era.ericsson.se | Rel-5 | Paolo |  | GP-17 |
| 3988 | 108.2.1 | Deleted - MS conformance tests for Multiple TBF in A/Gb mode |  | 375d | 2002-06-24 A | 2003-11-28 A | 100% | 2002-06-24 | 2003-11-28 | 375d | finish no earlier than 2003-11-28 | G4 | 3000h | 3000h |  |  |  | Rel-5 | Paolo |  | GP-17 |
| 3989 | 109 | **Alignment of 3G functional split and Iu** |  | 922d | 2000-06-08 A | 2003-12-19 A | 100% | 2000-06-08 | 2003-12-19 | 922d |  | GP | 165704h | 165704h | GER3GAL | Ericsson | Frank Muller | Rel-5 | Paolo | GER3GAL |  |
| 3990 | 109.1 | **GERAN user / control plane** |  | 540d | 2000-08-07 A | 2002-08-30 A | 100% | 2000-08-07 | 2002-08-30 | 540d |  | GP | 36232h | 36232h | GER3GAL-GUCOPL | Ericsson | Frank Muller | Rel-5 | Paolo | GER3GAL-GUCOPL |  |
| 3991 | 109.1.1 | **Alignment with UMTS bearer concept** |  | 540d | 2000-08-07 A | 2002-08-30 A | 100% | 2000-08-07 | 2002-08-30 | 540d |  | GP | 24952h | 24952h |  |  |  | Rel-5 | Paolo |  |  |
| 3992 | 109.1.1.1 | Enhanced power control - for Alignment with UMTS bearer concept |  | 1d | 2001-08-31 A | 2001-08-31 A | 100% | 2001-08-31 | 2001-08-31 | 1d | finish no earlier than 2001-08-31 | GP | 8h | 8h |  |  |  | Rel-5 | Paolo |  |  |
| 3993 | 109.1.1.2 | Stage 2 - for Alignment with UMTS bearer concept |  | 235d | 2000-08-07 A | 2001-06-29 A | 100% | 2000-08-07 | 2001-06-29 | 235d | finish no earlier than 2001-06-29 | GP | 1880h | 1880h |  |  |  | Rel-5 | Paolo |  |  |
| 3994 | 109.1.1.3 | Adoption of the UTRAN PDCP |  | 295d | 2000-11-06 A | 2001-12-21 A | 100% | 2000-11-06 | 2001-12-21 | 295d | finish no earlier than 2001-12-21 | GP | 2360h | 2360h |  |  |  | Rel-5 | Paolo |  |  |
| 3995 | 109.1.1.4 | Development of RLC / MAC |  | 261d | 2001-08-31 A | 2002-08-30 A | 100% | 2001-08-31 | 2002-08-30 | 261d | finish no earlier than 2002-08-30 | GP | 2088h | 2088h |  |  |  | Rel-5 | Paolo |  |  |
| 3996 | 109.1.1.5 | Development of GERAN RRC |  | 266d | 2001-06-22 A | 2002-06-28 A | 100% | 2001-06-22 | 2002-06-28 | 266d | finish no earlier than 2002-06-28 | GP | 2128h | 2128h |  |  |  | Rel-5 | Paolo |  |  |
| 3997 | 109.1.1.6 | Ciphering and integrity protection concept paper |  | 166d | 2001-08-31 A | 2002-04-19 A | 100% | 2001-08-31 | 2002-04-19 | 166d | finish no earlier than 2002-04-19 | GP | 1328h | 1328h |  |  |  | Rel-5 | Paolo |  |  |
| 3998 | 109.1.1.7 | Multiple TBF or equivalent Concept paper |  | 116d | 2001-08-31 A | 2002-02-08 A | 100% | 2001-08-31 | 2002-02-08 | 116d | finish no earlier than 2002-02-08 | GP | 928h | 928h |  |  |  | Rel-5 | Paolo |  |  |
| 3999 | 109.1.1.8 | Paging concept |  | 166d | 2001-08-31 A | 2002-04-19 A | 100% | 2001-08-31 | 2002-04-19 | 166d | finish no earlier than 2002-04-19 | GP | 1328h | 1328h |  |  |  | Rel-5 | Paolo |  |  |
| 4000 | 109.1.1.9 | Dedicated Physical subchannels, includes traffic and control channels |  | 66d | 2001-08-31 A | 2001-11-30 A | 100% | 2001-08-31 | 2001-11-30 | 66d | finish no earlier than 2001-11-30 | GP | 528h | 528h |  |  |  | Rel-5 | Paolo |  |  |
| 4001 | 109.1.1.10 | Iu support and broadcast concept |  | 166d | 2001-08-31 A | 2002-04-19 A | 100% | 2001-08-31 | 2002-04-19 | 166d | finish no earlier than 2002-04-19 | GP | 1328h | 1328h |  |  |  | Rel-5 | Paolo |  |  |
| 4002 | 109.1.1.11 | Impact of using RLC instead of LAPDm concept |  | 116d | 2001-08-31 A | 2002-02-08 A | 100% | 2001-08-31 | 2002-02-08 | 116d | finish no earlier than 2002-02-08 | GP | 928h | 928h |  |  |  | Rel-5 | Paolo |  |  |
| 4003 | 109.1.1.12 | Contention resolution, mobile station identity, and access concept |  | 66d | 2001-08-31 A | 2001-11-30 A | 100% | 2001-08-31 | 2001-11-30 | 66d | finish no earlier than 2001-11-30 | GP | 528h | 528h |  |  |  | Rel-5 | Paolo |  |  |
| 4004 | 109.1.1.13 | PDCP concept |  | 166d | 2001-08-31 A | 2002-04-19 A | 100% | 2001-08-31 | 2002-04-19 | 166d | finish no earlier than 2002-04-19 | GP | 1328h | 1328h |  |  |  | Rel-5 | Paolo |  |  |
| 4005 | 109.1.1.14 | Downlink delayed TBF release |  | 261d | 2001-08-31 A | 2002-08-30 A | 100% | 2001-08-31 | 2002-08-30 | 261d | finish no earlier than 2002-08-30 | GP | 2088h | 2088h |  |  |  | Rel-5 | Paolo |  |  |
| 4006 | 109.1.1.15 | Add transparent RLC Concept |  | 116d | 2001-08-31 A | 2002-02-08 A | 100% | 2001-08-31 | 2002-02-08 | 116d | finish no earlier than 2002-02-08 | GP | 928h | 928h |  |  |  | Rel-5 | Paolo |  |  |
| 4007 | 109.1.1.16 | Handover concept |  | 116d | 2001-08-31 A | 2002-02-08 A | 100% | 2001-08-31 | 2002-02-08 | 116d | finish no earlier than 2002-02-08 | GP | 928h | 928h |  |  |  | Rel-5 | Paolo |  |  |

Notes:
- 3969: 8/3/2001: test spec is based on R99 core spec, so deleted from Workplan
- 3970: - / Impacted TSs and TRs: 51.013
- 3971: "Joker" WI, to be used for a Rel 5 CR not related to any feature and with very limited impact on the system
- 3972: "Joker" WI, to be used for small modifications applicable to Rel 5 conformance testing. Moved in from Stoyan/testing WP. / Impacted TSs and TRs: 34.108, 34.109, 34.121-1, 34.121-2, 34.122, 34.123-1, 34.123-2, 34.123-3, 34.171, 34.229-1, 34.229-2, 34.229-3
- 3973: - / Impacted TSs and TRs: New TR 22.944
- 3974: - / Impacted TSs and TRs: 32.802
- 3975: - / Impacted TSs and TRs: 32.802
- 3976: 50101 -> 50201
- 3977: 50102 -> 50202
- 3978: -
- 3979: 50103 -> 50203
- 3980: 50104 -> 50204
- 3981: -
- 3982: GP#17 Nov 2003 Moved to Rel-6 as UID_50600 MULTBF (Only Multiple TBF Concept paper produced in Rel-5)
- 3983: Marked as closed 12/2008 (was marked 26% complete)
- 3984: Marked as closed 12/2008 (was marked 50% complete)
- 3985: Marked as stopped 12/2008
- 3986: Marked as stopped 12/2008
- 3987: 08/08: duplicate UID_50106=-> 50206. Marked as stopped 12/2008
- 3988: Not started. Marked as stopped 12/2008
- 3989: AWS, Nokia, Ericsson, Nortel, Siemens, Vodafone
- 3990: AWS, Nokia, Ericsson, Nortel, Siemens, Vodafone
- 3991: -
- 3992: -
- 3993: -
- 3994: Responsible is GERAN; RAN WG2 help may be needed.
- 3995: -
- 3996: -
- 3997: -
- 3998: -
- 3999: -
- 4000: -
- 4001: -
- 4002: -
- 4003: -
- 4004: -
- 4005: -
- 4006: -
- 4007: -

| ID | WBS | Task | Duration | Start | Finish | Complete | Baseline start | Baseline finish | Baseline duration | Constraint | Resources | Work | Actual work | Release | MCC resp | Acronym | WI rapporteur name | WI rapporteur e-mail | Acronym_3GU_Export |
| --- | --- | --- | --- | --- | --- | --- | --- | --- | --- | --- | --- | --- | --- | --- | --- | --- | --- | --- | --- |
| 4008 | 109.1.2 | **Physical layer alignment with UMTS bearer concept** | 280d | 2000-11-06 A | 2001-11-30 A | 100% | 2000-11-06 | 2001-11-30 | 280d |  | GP | 6960h | 6960h | Rel-5 | Paolo |  |  |  |  |
| 4009 | 109.1.2.1 | PDTCH/TCH in 45.003 | 155d | 2000-11-06 A | 2001-06-08 A | 100% | 2000-11-06 | 2001-06-08 | 155d | finish no earlier than 2001-06-08 | GP | 1240h | 1240h | Rel-5 | Paolo |  |  |  |  |
| 4010 | 109.1.2.2 | Control channels in 45.003 | 155d | 2000-11-06 A | 2001-06-08 A | 100% | 2000-11-06 | 2001-06-08 | 155d | finish no earlier than 2001-06-08 | GP | 1240h | 1240h | Rel-5 | Paolo |  |  |  |  |
| 4011 | 109.1.2.3 | Receiver performance in 45.005 for PDTCH/TCH and control channels | 280d | 2000-11-06 A | 2001-11-30 A | 100% | 2000-11-06 | 2001-11-30 | 280d | finish no earlier than 2001-11-30 | GP | 2240h | 2240h | Rel-5 | Paolo |  |  |  |  |
| 4012 | 109.2 | **Iu rg interface** | 430d | 2000-11-06 A | 2002-06-28 A | 100% | 2000-11-06 | 2002-06-28 | 430d |  | GP; RP | 61920h | 61920h | Rel-5 | Paolo | GER3GAL-Iurg | Ericsson | Frank Muller | GER3GAL-Iurg |
| 4013 | 109.2.1 | **Inter BSS interface** | 430d | 2000-11-06 A | 2002-06-28 A | 100% | 2000-11-06 | 2002-06-28 | 430d |  | GP; RP | 24080h | 24080h | Rel-5 | Paolo |  |  |  |  |
| 4014 | 109.2.1.1 | Identification of requirements for Inter BSS interface | 430d | 2000-11-06 A | 2002-06-28 A | 100% | 2000-11-06 | 2002-06-28 | 430d | finish no earlier than 2002-06-28 | GP | 3440h | 3440h | Rel-5 | Paolo |  |  |  |  |
| 4015 | 109.2.1.2 | Stage 2 for Inter BSS interface | 430d | 2000-11-06 A | 2002-06-28 A | 100% | 2000-11-06 | 2002-06-28 | 430d | finish no earlier than 2002-06-28 | GP | 3440h | 3440h | Rel-5 | Paolo |  |  |  |  |
| 4016 | 109.2.1.3 | Adoption of relevant parts from Iur - for Inter BSS interface | 430d | 2000-11-06 A | 2002-06-28 A | 100% | 2000-11-06 | 2002-06-28 | 430d | finish no earlier than 2002-06-28 | GP | 3440h | 3440h | Rel-5 | Paolo |  |  |  |  |
| 4017 | 109.2.1.4 | Complementation with GERAN specifics - for Inter BSS interface | 430d | 2000-11-06 A | 2002-06-28 A | 100% | 2000-11-06 | 2002-06-28 | 430d | finish no earlier than 2002-06-28 | GP | 3440h | 3440h | Rel-5 | Paolo |  |  |  |  |
| 4018 | 109.2.1.5 | Stage 3 for Inter BSS interface | 430d | 2000-11-06 A | 2002-06-28 A | 100% | 2000-11-06 | 2002-06-28 | 430d | finish no earlier than 2002-06-28 | GP | 3440h | 3440h | Rel-5 | Paolo |  |  |  |  |
| 4019 | 109.2.2 | **Inter BSS-RNS interface** | 430d | 2000-11-06 A | 2002-06-28 A | 100% | 2000-11-06 | 2002-06-28 | 430d |  | GP; RP | 30960h | 30960h | Rel-5 | Paolo |  |  |  |  |
| 4020 | 109.2.2.1 | Identification of requirements for Inter BSS-RNS interface | 430d | 2000-11-06 A | 2002-06-28 A | 100% | 2000-11-06 | 2002-06-28 | 430d | start no earlier than 2000-11-06 | GP; R3 | 6880h | 6880h | Rel-5 | Paolo |  |  |  |  |
| 4021 | 109.2.2.2 | Stage 2 for Inter BSS-RNS interface | 430d | 2000-11-06 A | 2002-06-28 A | 100% | 2000-11-06 | 2002-06-28 | 430d | finish no earlier than 2002-06-28 | GP; R3 | 6880h | 6880h | Rel-5 | Paolo |  |  |  |  |
| 4022 | 109.2.2.3 | Adoption of relevant parts from Iur - for Inter BSS-RNS interface | 430d | 2000-11-06 A | 2002-06-28 A | 100% | 2000-11-06 | 2002-06-28 | 430d | finish no earlier than 2002-06-28 | GP; R3 | 6880h | 6880h | Rel-5 | Paolo |  |  |  |  |
| 4023 | 109.2.2.4 | Complementation with GERAN specifics - for Inter BSS-RNS interface | 107.5d | 2002-01-30 A | 2002-06-28 A | 100% | 2002-01-30 | 2002-06-28 | 107.5d | finish no earlier than 2002-06-28 | GP; R3 | 1720h | 1720h | Rel-5 | Paolo |  |  |  |  |
| 4024 | 109.2.2.5 | Stage 3 for Inter BSS-RNS interface | 107.5d | 2002-01-30 A | 2002-06-28 A | 100% | 2002-01-30 | 2002-06-28 | 107.5d | finish no earlier than 2002-06-28 | GP; R3 | 1720h | 1720h | Rel-5 | Paolo |  |  |  |  |
| 4025 | 109.3 | **Voice over GERAN PS and CS concept** | 430d | 2000-11-06 A | 2002-06-28 A | 100% | 2000-11-06 | 2002-06-28 | 430d |  | GP; R3 | 35200h | 35200h | Rel-5 | Paolo |  |  |  |  |
| 4026 | 109.3.1 | Architecture for A, Iu cs and Iu ps | 430d | 2000-11-06 A | 2002-06-28 A | 100% | 2000-11-06 | 2002-06-28 | 430d | finish no earlier than 2002-06-28 | GP; R3 | 6880h | 6880h | Rel-5 | Paolo |  |  |  |  |
| 4027 | 109.3.2 | Transcoder position/operation | 115d | 2000-11-06 A | 2001-04-13 A | 100% | 2000-11-06 | 2001-04-13 | 115d | finish no earlier than 2001-04-13 | GP | 920h | 920h | Rel-5 | Paolo |  |  |  |  |
| 4028 | 109.3.3 | Handover for Voice over GERAN PS and CS | 430d | 2000-11-06 A | 2002-06-28 A | 100% | 2000-11-06 | 2002-06-28 | 430d | finish no earlier than 2002-06-28 | GP; R3 | 6880h | 6880h | Rel-5 | Paolo |  |  |  |  |
| 4029 | 109.3.4 | RTP payload | 430d | 2000-11-06 A | 2002-06-28 A | 100% | 2000-11-06 | 2002-06-28 | 430d | finish no earlier than 2002-06-28 | GP; R3 | 6880h | 6880h | Rel-5 | Paolo |  |  |  |  |
| 4030 | 109.3.5 | Codec renegotiation concept | 365d | 2000-11-06 A | 2002-03-29 A | 100% | 2000-11-06 | 2002-03-29 | 365d | finish no earlier than 2002-03-29 | GP; R3 | 5840h | 5840h | Rel-5 | Paolo |  |  |  |  |
| 4031 | 109.3.6 | LA | 115d | 2000-11-06 A | 2001-04-13 A | 100% | 2000-11-06 | 2001-04-13 | 115d | finish no earlier than 2001-04-13 | GP | 920h | 920h | Rel-5 | Paolo |  |  |  |  |

Notes:
- 4008: -
- 4009: -
- 4010: -
- 4011: -
- 4012: AWS, Nokia, Ericsson, Nortel, Siemens, Vodafone
- 4013: -
- 4014: -
- 4015: -
- 4016: -
- 4017: -
- 4018: -
- 4019: -
- 4020: -
- 4021: -
- 4022: -
- 4023: -
- 4024: -
- 4025: -
- 4026: -
- 4027: -
- 4028: -
- 4029: -
- 4030: -
- 4031: -

| ID | WBS | Task | Duration | Start | Finish | Complete | Baseline start | Baseline finish | Baseline duration | Constraint | Resources | Work | Actual work | Release | MCC resp | TSG stopped | Acronym | WI rapporteur name | WI rapporteur e-mail | Acronym_3GU_Export | Impacted TSs and TRs |
| --- | --- | --- | --- | --- | --- | --- | --- | --- | --- | --- | --- | --- | --- | --- | --- | --- | --- | --- | --- | --- | --- |
| 4032 | 109.4 | **Deleted - GERAN MS Conformance test for GERAN interface evolution** | 660d | 2001-06-11 A | 2003-12-19 A | 100% | 2001-06-11 | 2003-12-19 | 660d |  | GP | 10560h | 10560h | Rel-5 | Paolo | GP-17 |  |  |  |  |  |
| 4033 | 109.4.1 | Deleted - MS test for GERAN interface evolution | 660d | 2001-06-11 A | 2003-12-19 A | 100% | 2001-06-11 | 2003-12-19 | 660d | finish no earlier than 2003-12-19 | GP | 5280h | 5280h | Rel-5 | Paolo | GP-17 |  |  |  |  |  |
| 4034 | 109.5 | **GERAN BSS Conformance test for GERAN interface evolution** | 922d | 2000-06-08 A | 2003-12-19 A | 100% | 2000-06-08 | 2003-12-19 | 922d |  | GP | 14752h | 14752h | Rel-5 | Paolo |  |  |  |  |  |  |
| 4035 | 109.5.1 | Deleted - BSS test | 922d | 2000-06-08 A | 2003-12-19 A | 100% | 2000-06-08 | 2003-12-19 | 922d | finish no earlier than 2003-12-19 | GP | 7376h | 7376h | Rel-5 | Paolo | GP-17 |  |  |  |  |  |
| 4036 | 110 | **GERAN support for IMS** | 690d | 2000-05-01 A | 2002-12-20 A | 100% | 2000-05-01 | 2002-12-20 | 690d |  | GP | 83939.6h | 83939.6h | Rel-5 | Paolo |  | GERIMS | Nokia | Shkumbin Hamiti | GERIMS |  |
| 4037 | 110.1 | **GERAN Header adaptation** | 690d | 2000-05-01 A | 2002-12-20 A | 100% | 2000-05-01 | 2002-12-20 | 690d |  | GP; S2; RP | 40011.6h | 40011.6h | Rel-5 | Paolo |  | GERIMS-HEADAPT | Nokia | Shkumbin Hamiti | GERIMS-HEADAPT |  |
| 4038 | 110.1.1 | Definition of compression and removal modes for PDCP protocol | 29.15d | 2000-07-24 A | 2000-09-01 A | 100% | 2000-07-24 | 2000-09-01 | 29.15d | finish no earlier than 2000-09-01 | GP; S2; RP | 699.6h | 699.6h | Rel-5 | Paolo |  |  |  |  |  |  |
| 4039 | 110.1.2 | Conceptual description in stage 2 | 393d | 2000-05-01 A | 2001-10-31 A | 100% | 2000-05-01 | 2001-10-31 | 393d | finish no earlier than 2001-10-31 | GP; S2; RP | 9432h | 9432h | Rel-5 | Paolo |  |  |  |  |  |  |
| 4040 | 110.1.3 | Necessary changes on stage 3 regarding header removal | 555d | 2000-11-06 A | 2002-12-20 A | 100% | 2000-11-06 | 2002-12-20 | 555d | finish no earlier than 2002-12-20 | GP; S2; RP | 13320h | 13320h | Rel-5 | Paolo |  |  |  |  |  |  |
| 4041 | 110.2 | **Deleted - GERAN Radio access bearer design for IMS** | 430d | 2000-11-06 A | 2002-06-28 A | 100% | 2000-11-06 | 2002-06-28 | 430d |  | GP; S2; RP | 29520h | 29520h | Rel-5 | Paolo | GP-10 | GERIMS-RABDES | Nokia | Shkumbin Hamiti | GERIMS-RABDES |  |
| 4042 | 110.2.1 | **Deleted - MuM control signalling for conversational multimedia services** | 430d | 2000-11-06 A | 2002-06-28 A | 100% | 2000-11-06 | 2002-06-28 | 430d |  | GP; S2; RP | 19200h | 19200h | Rel-5 | Paolo | GP-10 |  |  |  |  |  |
| 4043 | 110.2.1.1 | Deleted - Identification of requirements for MuM control signalling for conversational multimedia services | 330d | 2000-11-06 A | 2002-02-08 A | 100% | 2000-11-06 | 2002-02-08 | 330d | finish no earlier than 2002-02-08 | GP; S2; RP | 7920h | 7920h | Rel-5 | Paolo | GP-08 |  |  |  |  |  |
| 4044 | 110.2.1.2 | Deleted - Necessary modifications due to SIP | 40d | 2002-05-06 A | 2002-06-28 A | 100% | 2002-05-06 | 2002-06-28 | 40d | finish no earlier than 2002-06-28 | GP; S2; RP | 960h | 960h | Rel-5 | Paolo | GP-10 |  |  |  |  |  |
| 4045 | 110.3 | **Deleted - GERAN MS Conformance test for support of IMS** | 400d | 2001-06-11 A | 2002-12-20 A | 100% | 2001-06-11 | 2002-12-20 | 400d |  | GP | 6400h | 6400h | Rel-5 | Paolo | GP-12 | GERIMS-MSconf | Nokia | Shkumbin Hamiti | GERIMS-MSconf |  |
| 4046 | 110.3.1 | Deleted - MS test for support of IMS | 400d | 2001-06-11 A | 2002-12-20 A | 100% | 2001-06-11 | 2002-12-20 | 400d | finish no earlier than 2002-12-20 | G4 | 3200h | 3200h | Rel-5 | Paolo | GP-12 |  |  |  |  |  |
| 4047 | 110.4 | Deleted - GERAN BTS Conformance test for support of IMS | 400d | 2001-06-11 A | 2002-12-20 A | 100% | 2001-06-11 | 2002-12-20 | 400d |  | GP | 3200h | 3200h | Rel-5 | Paolo | GP-12 | GERIMS-BTSconf | Nokia | Shkumbin Hamiti | GERIMS-BTSconf |  |
| 4048 | 994 | MS Conformance Testing of Dual Transfer Mode | 65d? | 2002-11-11 A | 2003-02-07 A | 100% | 2002-11-11 | 2003-02-07 | 65d? | finish no earlier than 2003-02-07 | G4; G5 | 1040h | 1040h | Rel-5 | Paolo |  | MSCTDTM | Vodafone | Dave Fox | MSCTDTM |  |
| 4049 | 995 | **Handling of early Ues** | 911d? | 2000-01-03 A | 2003-06-27 A | 100% | 2000-01-03 | 2003-06-27 | 911d? |  | S2 | 4488h | 4488h | Rel-5 | Maurice |  | LATE_UE |  |  | LATE_UE |  |
| 4050 | 995.1 | Feasibility Study on Handling of early Ues | 50d? | 2002-10-07 A | 2002-12-13 A | 100% | 2002-10-07 | 2002-12-13 | 50d? | finish no earlier than 2002-12-13 | S2 | 400h | 400h | Rel-5 | Maurice |  |  |  |  |  |  |
| 4051 | 995.2 | Stage 2 for Handling of early Ues | 125d? | 2003-01-06 A | 2003-06-27 A | 100% | 2003-01-06 | 2003-06-27 | 125d? | start no earlier than 2003-01-06 | S2 | 1000h | 1000h | Rel-5 | Maurice |  |  |  |  |  |  |
| 4052 | 995.3 | FS for the Early Mobile Handling in UTRAN | 195d | 2002-09-09 A | 2003-06-06 A | 100% | 2002-09-09 | 2003-06-06 | 195d | finish no earlier than 2003-06-06 | R2 | 1560h | 1560h | Rel-5 | Yong-Jun |  | FSEarlyUE | Vodafone | alan.law@vodafone.com | FSEarlyUE |  |
| 4053 | 995.4 | Note: Stage 3 RAN part not shown | 1d | 2000-01-03 A | 2000-01-03 A | 100% | 2000-01-03 | 2000-01-03 | 1d |  | RP | 8h | 8h | Rel-5 |  |  |  |  |  |  |  |
| 4054 | 996 | Release 4 Features | 326d? | 2000-01-03 A | 2001-03-30 A | 100% | 2000-01-03 | 2001-03-30 | 326d? |  | NP; GP; RP; SP; TP | 13040h | 13040h | Rel-4 | All |  |  |  |  |  |  |
| 4055 | 15 | **Miscellaneous UE Conformance Testing Activities** | 958d | 2001-04-02 A | 2004-12-01 A | 100% | 2001-04-02 | 2004-12-01 | 958d |  | T1 | 36360h | 36360h | Rel-4 | Ingbert |  | MISTST1 |  |  | MISTST1 |  |
| 4056 | 15.1 | Optimization of Test Time, RF Aspects (FDD) | 508d | 2001-09-24 A | 2003-09-03 A | 100% | 2001-09-24 | 2003-09-03 | 508d | finish no earlier than 2003-09-03 | T1 | 4064h | 4064h | Rel-4 | Ingbert |  | MISTST1-OpFDD |  |  | MISTST1-OpFDD | 34.121 |
| 4057 | 15.2 | Optimization of Test Time, RF Aspects (TDD) | 508d | 2001-09-24 A | 2003-09-03 A | 100% | 2001-09-24 | 2003-09-03 | 508d | finish no earlier than 2003-09-03 | T1 | 4064h | 4064h | Rel-4 | Ingbert |  | MISTST1-OpTDD |  |  | MISTST1-OpTDD | 34.122 |
| 4058 | 15.3 | Extensions to R99 Test cases | 139.4w | 2001-04-02 A | 2003-12-02 A | 100% | 2001-04-02 | 2003-12-02 | 139.4w | finish no earlier than 2003-12-02 | T1 | 5576h | 5576h | Rel-4 | Ingbert |  | MISTST1-Ext |  |  | MISTST1-Ext | 34.123 p 1,2 |
| 4059 | 15.4 | Extension to R99 Test cases - TTCN | 439d | 2002-06-28 A | 2004-03-03 A | 100% | 2002-06-28 | 2004-03-03 | 439d | finish no earlier than 2004-03-03 | T1 | 3512h | 3512h | Rel-4 | Ingbert |  |  |  |  |  |  |
| 4060 | 15.5 | Creation of R99 TCs for TDD - prose | 719d | 2001-10-01 A | 2004-07-01 A | 100% | 2001-10-01 | 2004-07-01 | 719d | finish no earlier than 2004-07-01 | T1 | 5752h | 5752h | Rel-4 | Ingbert |  | MISTST1-TDD |  |  | MISTST1-TDD | 34.123-1 |
| 4061 | 15.6 | Deleted - Creation of R99 TCs for TDD - TTCN | 587d | 2002-09-03 A | 2004-12-01 A | 100% | 2002-09-03 | 2004-12-01 | 587d | finish no earlier than 2004-12-01 | T1 | 4696h | 4696h | Rel-4 | Ingbert | TP-26 |  |  |  |  |  |
| 4062 | 15.7 | Deleted - Review all other work items for impact on new or exiting 34 series specs. | 25.8w | 2002-07-02 A | 2002-12-27 A | 100% | 2002-07-02 | 2002-12-27 | 25.8w | finish no earlier than 2002-12-27 | T1 | 1032h | 1032h | Rel-4 | Ingbert | TP-18 |  |  |  |  | 34.121,122,123,125 |

Notes:
- 4032: Not started. Marked as stopped 12/2008
- 4033: Not started. Marked as stopped 12/2008
- 4034: Not started. Marked as stopped 12/2008
- 4035: Not started. Marked as stopped 12/2008
- 4036: AWS, Nokia, Ericsson, Nortel, Siemens, Motorola
- 4037: AWS, Nokia, Ericsson, Nortel, Siemens, Motorola
- 4038: -
- 4039: -
- 4040: -
- 4041: TERMINATED - NOT STANDARDIZED. Marked as stopped 12/2008
- 4042: TERMINATED - NOT STANDARDIZED. Marked as stopped 12/2008
- 4043: TERMINATED - NOT STANDARDIZED
- 4044: TERMINATED - NOT STANDARDIZED
- 4045: TERMINATED - NOT STANDARDIZED. Marked as stopped 12/2008
- 4046: TERMINATED - NOT STANDARDIZED. Marked as stopped 12/2008
- 4047: TERMINATED - NOT STANDARDIZED. Marked as stopped 12/2008
- 4048: Needed to complete DTM (R99)
- 4049: -
- 4050: -
- 4051: -
- 4052: -
- 4053: -
- 4054: -
- 4055: -
- 4056: It is believed that the current R99 test spec. can be optimised for faster overall test times. Marked as stopped 12/2008 (was 70% complete)
- 4057: It is believed that the current R99 test spec. can be optimised for faster overall test times
- 4058: Further test coverage of the R99 specification to cover supplementry services. Marked as stopped 12/2008 (was 70% complete)
- 4059: Marked as closed 12/2008 (was marked 50% complete)
- 4060: Marked as closed 12/2008 (was marked 50% complete)
- 4061: Marked as stopped 12/2008
- 4062: Marked as stopped 12/2008

| ID | WBS | Task | Duration | Start | Finish | Predecessors | Complete | Baseline start | Baseline finish | Baseline duration | Constraint | Resources | Work | Actual work | Acronym | Release | MCC resp | Acronym_3GU_Export | Impacted TSs and TRs | WI rapporteur name | WI rapporteur e-mail |
| --- | --- | --- | --- | --- | --- | --- | --- | --- | --- | --- | --- | --- | --- | --- | --- | --- | --- | --- | --- | --- | --- |
| 4063 | 46 | **Real Time Facsimile** | 89d | 2000-02-22 A | 2000-06-23 A |  | 100% | 2000-02-22 | 2000-06-23 | 89d |  | S1 | 4376h | 4376h | FAX-RT | Rel-4 | Alain | FAX-RT |  |  |  |
| 4064 | 46.1 | **Real Time Fax** | 89d | 2000-02-22 A | 2000-06-23 A |  | 100% | 2000-02-22 | 2000-06-23 | 89d |  | S2 | 3664h | 3664h |  | Rel-4 | Maurice |  |  |  |  |
| 4065 | 46.1.1 | Terminal capabilities, AT commands | 89d | 2000-02-22 A | 2000-06-23 A |  | 100% | 2000-02-22 | 2000-06-23 | 89d | finish no earlier than 2000-06-23 | T2 | 712h | 712h |  | Rel-4 |  |  | 21.904, 27.007 |  |  |
| 4066 | 46.1.2 | Signalling aspects (e.g. ICM) | 89d | 2000-02-22 A | 2000-06-23 A |  | 100% | 2000-02-22 | 2000-06-23 | 89d | start no earlier than 2000-02-22 | N1 | 712h | 712h |  | Rel-4 | Frederic |  |  |  |  |
| 4067 | 46.1.3 | Service provision | 89d | 2000-02-22 A | 2000-06-23 A |  | 100% | 2000-02-22 | 2000-06-23 | 89d | finish no earlier than 2000-06-23 | N3 | 712h | 712h |  | Rel-4 | Gwiho |  | 23.146 |  |  |
| 4068 | 46.1.4 | Review whether service/stage 1 aspects need to be aligned | 51d | 2000-04-14 A | 2000-06-23 A |  | 100% | 2000-04-14 | 2000-06-23 | 51d | finish no earlier than 2000-12-14 | S1 | 408h | 408h |  | Rel-4 | Alain |  |  |  |  |
| 4069 | 46.1.5 | Review whether architecture/stage 2 aspects need to be aligned | 51d | 2000-04-14 A | 2000-06-23 A |  | 100% | 2000-04-14 | 2000-06-23 | 51d | finish no earlier than 2000-12-14 | S2 | 408h | 408h |  | Rel-4 | Maurice |  |  |  |  |
| 4070 | 47 | Transparent End-to-End PS mobile streaming application | 253d | 2000-04-03 A | 2001-03-21 A |  | 100% | 2000-04-03 | 2001-03-21 | 253d | finish no earlier than 2000-12-29 | S4 | 2024h | 2024h | PSTREAM | Rel-4 | Paolo | PSTREAM | 26.233, 26.234 |  |  |
| 4071 | 48 | **Multimedia Messaging** | 277d | 2000-02-22 A | 2001-03-14 A |  | 100% | 2000-02-22 | 2001-03-14 | 277d |  | T2; S1 | 14424h | 14424h | MMS, Rel-4 | Rel-4 | Kimmo | MMS, Rel-4 | 22.140, 23.140 | Siemens | Josef.Laumen@SAL.SIEMENS.DE |
| 4072 | 48.1 | Definition of service requirements for Multimedia Messaging | 72d | 2000-02-22 A | 2000-05-31 A |  | 100% | 2000-02-22 | 2000-05-31 | 72d | start no earlier than 2000-02-22 | S1 | 576h | 576h |  | Rel-4 | Alain |  |  |  |  |
| 4073 | 48.2 | Review of definition of service requirements | 205d | 2000-06-01 A | 2001-03-14 A | 4072 | 100% | 2000-06-01 | 2001-03-14 | 205d | finish no earlier than 2000-09-08 | T2 | 1640h | 1640h |  | Rel-4 | Kimmo |  | 22.140, 23.140 | Siemens |  |
| 4074 | 48.3 | **Technical Realisation** | 243d | 2000-04-10 A | 2001-03-14 A |  | 100% | 2000-04-10 | 2001-03-14 | 243d |  | T2 | 7776h | 7776h |  | Rel-4 | Kimmo |  | 22.140, 23.140 | Siemens | Josef.Laumen@SAL.SIEMENS.DE |
| 4075 | 48.3.1 | Review of definition of reference Achitecture model | 243d | 2000-04-10 A | 2001-03-14 A |  | 100% | 2000-04-10 | 2001-03-14 | 243d | finish no earlier than 2001-03-14 | T2 | 1944h | 1944h |  | Rel-4 | Kimmo |  | 22.140, 23.140 | Siemens | Josef.Laumen@SAL.SIEMENS.DE |
| 4076 | 48.3.2 | Fulfill Requirements of Stage 1 | 243d | 2000-04-10 A | 2001-03-14 A |  | 100% | 2000-04-10 | 2001-03-14 | 243d | finish no earlier than 2001-03-14 | T2 | 1944h | 1944h |  | Rel-4 | Kimmo |  | 22.140, 23.140 | Siemens | Josef.Laumen@SAL.SIEMENS.DE |
| 4077 | 48.3.3 | Definition of MMS primitives in Stage 2 | 243d | 2000-04-10 A | 2001-03-14 A |  | 100% | 2000-04-10 | 2001-03-14 | 243d | finish no earlier than 2001-03-14 | T2 | 1944h | 1944h |  | Rel-4 | Kimmo |  | 22.140, 23.140 | Siemens | Josef.Laumen@SAL.SIEMENS.DE |
| 4078 | 49 | **Transcoder-Free Operation** | 326d | 2000-01-03 A | 2001-03-30 A |  | 100% | 2000-01-03 | 2001-03-30 | 326d |  | N4; S2; N1 | 18272h | 18272h | TrFO | Rel-4 | Kimmo | TrFO |  |  |  |
| 4079 | 49.1 | **Out-of-Band Transcoder Control solution** | 326d | 2000-01-03 A | 2001-03-30 A |  | 100% | 2000-01-03 | 2001-03-30 | 326d |  | N4 | 8448h | 8448h | TrFO-OoBTC | Rel-4 | Kimmo | TrFO-OoBTC |  | NEC | Toshiyuki Tamura (tamurato@aj.jp.nec.com) |
| 4080 | 49.1.1 | implementation in UTRAN | 145d | 2000-09-11 A | 2001-03-30 A |  | 100% | 2000-09-11 | 2001-03-30 | 145d | finish no earlier than 2001-03-30 | R3 | 1160h | 1160h | TrFO-OoBTC-UTRAN | Rel-4 | Juha | TrFO-OoBTC-UTRAN | 25.401, 25.410, 25.413, 25.415, 23.153 | Siemens | Alexander Vesely |
| 4081 | 49.1.2 | Impact on architecture, Principles and Terminology | 211d | 2000-01-03 A | 2000-10-20 A |  | 100% | 2000-01-03 | 2000-10-20 | 211d | finish no earlier than 2000-10-20 | S2 | 1680h | 1680h |  | Rel-4 | Maurice |  |  |  |  |
| 4082 | 49.1.3 | Codec Negotiation between UE and MSC | 125d | 2000-08-14 A | 2001-02-02 A |  | 100% | 2000-08-14 | 2001-02-02 | 125d | finish no earlier than 2001-02-02 | N1 | 1000h | 1000h |  | Rel-4 | Frederic |  | 24.008, 23.009, 23.108, (29.002) | Motorola | Andrew Howell |
| 4083 | 49.1.4 | Codec Negotiation inter MSC | 125d | 2000-07-03 A | 2000-12-22 A |  | 100% | 2000-07-03 | 2000-12-22 | 125d | finish no earlier than 2000-12-22 | N4 | 1000h | 1000h |  | Rel-4 | Kimmo |  |  |  |  |
| 4084 | 49.1.5 | Bearer establishment inter MSC | 125d | 2000-07-03 A | 2000-12-22 A |  | 100% | 2000-07-03 | 2000-12-22 | 125d | finish no earlier than 2000-12-22 | N4 | 1000h | 1000h |  | Rel-4 | Kimmo |  | 23.153 |  |  |
| 4085 | 49.2 | **Speech Transcoder: Location and Control at the UMTS Core Network Border** | 125d | 2000-04-10 A | 2000-09-29 A |  | 100% | 2000-04-10 | 2000-09-29 | 125d |  | S2 | 2000h | 2000h | TrFO-STLC | Rel-4 | Maurice | TrFO-STLC |  |  |  |
| 4086 | 49.2.1 | Transcoder at Edge | 125d | 2000-04-10 A | 2000-09-29 A |  | 100% | 2000-04-10 | 2000-09-29 | 125d | finish no earlier than 2000-09-29 | NP | 1000h | 1000h |  | Rel-4 | Kimmo |  |  |  |  |

Notes:
- 4063: -
- 4064: postponed from R99 to R00, SP-000169
- 4065: -
- 4066: -
- 4067: -
- 4068: -
- 4069: -
- 4070: -
- 4071: -
- 4072: -
- 4073: -
- 4074: -
- 4075: -
- 4076: e.g. minimum set of media formats, media format conversion, personalization of MMS.
- 4077: -
- 4078: Lead given to CN4 from CN / [DAB 28/11/00]
- 4079: -
- 4080: moved according to NP-000575
- 4081: e.g. study cascading TrFO/TFO/TrFO
- 4082: the link to NP-000085has been deleted because refering to a R99 status sheet / One common set of codec negotiation procedures will be specified as in ID1656.
- 4083: Bearer establishment inter MSC. TS 23.153 R99 part complete. capabilities moved to annex + list of open issues
- 4084: Bearer establishment inter MSC. TS 23.153 R99 part complete. capabilities moved to annex. / See NP-000127 / Open issues: / Handling of Conference Calls; / Handling of Multi Party Supplementary Services; / Handling of Handover UMTS to GSM; / Handling of Sending a ...
- 4085: WI description and Tdoc S2-99352 / Speech Transcoder: Location and Control at the UMTS Core Network Border
- 4086: WI description and Tdoc S2-99352...

| ID | WBS | Task | Duration | Start | Finish | Complete | Baseline start | Baseline finish | Baseline duration | Constraint | Resources | Work | Actual work | Acronym | Release | MCC resp | Acronym_3GU_Export | WI rapporteur name | WI rapporteur e-mail |
| --- | --- | --- | --- | --- | --- | --- | --- | --- | --- | --- | --- | --- | --- | --- | --- | --- | --- | --- | --- |
| 4087 | 50 | **GERAN improvements 1 (Gb over IP)** | 225d | 2000-05-09 A | 2001-03-19 A | 100% | 2000-05-09 | 2001-03-19 | 225d |  | GP | 6472h | 6472h | GEIMP1 | Rel-4 | Paolo | GEIMP1 |  |  |
| 4088 | 50.1 | **Gb over IP (Ip-fication of Gb)** | 225d | 2000-05-09 A | 2001-03-19 A | 100% | 2000-05-09 | 2001-03-19 | 225d |  | GP | 4672h | 4672h | GbIP | Rel-4 | Paolo | GbIP |  |  |
| 4089 | 50.1.1 | Concept of Gb over IP (Ip-fication of Gb) | 134d | 2000-05-09 A | 2000-11-10 A | 100% | 2000-05-09 | 2000-11-10 | 134d |  | GP | 1072h | 1072h |  | Rel-4 | Paolo |  |  |  |
| 4090 | 50.1.2 | Changes to 08.16, 08.18 | 225d | 2000-05-09 A | 2001-03-19 A | 100% | 2000-05-09 | 2001-03-19 | 225d |  | GP | 1800h | 1800h |  | Rel-4 | Paolo |  |  |  |
| 4091 | 51 | **GERAN improvements 2 (NACC)** | 677d | 2000-11-06 A | 2003-06-10 A | 100% | 2000-11-06 | 2003-06-10 | 677d |  | GP | 22408h | 22408h | GEIMP2 | Rel-4 | Paolo | GEIMP2 |  |  |
| 4092 | 51.1 | **Gb enhancements** | 155d | 2000-11-06 A | 2001-06-08 A | 100% | 2000-11-06 | 2001-06-08 | 155d |  | GP | 7440h | 7440h | Gben | Rel-4 | Paolo | Gben |  |  |
| 4093 | 51.1.1 | **Intra BSC NACC (Network Assisted Cell Change)** | 155d | 2000-11-06 A | 2001-06-08 A | 100% | 2000-11-06 | 2001-06-08 | 155d |  | GP | 6200h | 6200h |  | Rel-4 | Paolo |  |  |  |
| 4094 | 51.1.1.1 | Concept | 155d | 2000-11-06 A | 2001-06-08 A | 100% | 2000-11-06 | 2001-06-08 | 155d | finish no earlier than 2001-06-08 | GP | 1240h | 1240h |  | Rel-4 | Paolo |  |  |  |
| 4095 | 51.1.1.2 | Changes in 03.64 | 155d | 2000-11-06 A | 2001-06-08 A | 100% | 2000-11-06 | 2001-06-08 | 155d | finish no earlier than 2001-06-08 | GP | 1240h | 1240h |  | Rel-4 | Paolo |  |  |  |
| 4096 | 51.1.1.3 | Changes in 04.60 | 155d | 2000-11-06 A | 2001-06-08 A | 100% | 2000-11-06 | 2001-06-08 | 155d | finish no earlier than 2001-06-08 | GP | 1240h | 1240h |  | Rel-4 | Paolo |  |  |  |
| 4097 | 51.1.1.4 | Changes in 44.008 | 155d | 2000-11-06 A | 2001-06-08 A | 100% | 2000-11-06 | 2001-06-08 | 155d | finish no earlier than 2001-06-08 | GP | 1240h | 1240h |  | Rel-4 | Paolo |  |  |  |
| 4098 | 51.3 | **MS conformance test for Intra BSC NACC** | 398d | 2001-11-30 A | 2003-06-10 A | 100% | 2001-11-30 | 2003-06-10 | 398d |  | GP | 9552h | 9552h | GEIMP2-Msconf | Rel-4 | Paolo | GEIMP2-Msconf |  |  |
| 4099 | 51.3.1 | Changes in 51.010 | 398d | 2001-11-30 A | 2003-06-10 A | 100% | 2001-11-30 | 2003-06-10 | 398d | finish no earlier than 2003-12-19 | G5; G4 | 6368h | 6368h |  | Rel-4 | Paolo |  |  |  |
| 4100 | 52 | **GERAN improvements 4 (Delayed TBF)** | 105d | 2001-01-15 A | 2001-06-08 A | 100% | 2001-01-15 | 2001-06-08 | 105d |  | GP | 3960h | 3960h | GEIMP4 | Rel-4 | Paolo | GEIMP4 |  |  |
| 4101 | 52.1 | **Gb enhancements 2** | 105d | 2001-01-15 A | 2001-06-08 A | 100% | 2001-01-15 | 2001-06-08 | 105d |  | GP | 3120h | 3120h | GEIMP4-Gben2 | Rel-4 | Paolo | GEIMP4-Gben2 |  |  |
| 4102 | 52.1.1 | Stage 2 for Gb enhancements 2 | 105d | 2001-01-15 A | 2001-06-08 A | 100% | 2001-01-15 | 2001-06-08 | 105d | finish no earlier than 2001-06-08 | GP | 840h | 840h |  | Rel-4 | Paolo |  |  |  |
| 4103 | 52.1.2 | **Stage 3 (changes in 44.060)** | 60d | 2001-01-15 A | 2001-04-06 A | 100% | 2001-01-15 | 2001-04-06 | 60d |  | G2 | 1440h | 1440h |  | Rel-4 | Gert |  |  |  |
| 4104 | 52.1.2.1 | Definition of enhanced countdown procedure | 60d | 2001-01-15 A | 2001-04-06 A | 100% | 2001-01-15 | 2001-04-06 | 60d | finish no earlier than 2001-04-06 | G2 | 480h | 480h |  | Rel-4 | Gert |  |  |  |
| 4105 | 52.1.2.2 | Definition of enhanced TBF release procedure | 60d | 2001-01-15 A | 2001-04-06 A | 100% | 2001-01-15 | 2001-04-06 | 60d | finish no earlier than 2001-04-06 | G2 | 480h | 480h |  | Rel-4 | Gert |  |  |  |
| 4106 | 52.1.2.3 | Definition of USF=FREE type polling mechanism on PDCH | 60d | 2001-01-15 A | 2001-04-06 A | 100% | 2001-01-15 | 2001-04-06 | 60d | finish no earlier than 2001-04-06 | G2 | 480h | 480h |  | Rel-4 | Gert |  |  |  |
| 4107 | 53 | **Low Chip Rate TDD option** | 880d | 2000-07-19 A | 2003-12-02 A | 100% | 2000-07-19 | 2003-12-02 | 880d |  | R1 | 27488h | 27488h | LCRTDD | Rel-4 | Patrick | LCRTDD | CWTS | G. Yang |
| 4108 | 53.1 | Physical layer for Low Chip Rate TDD option | 183d | 2000-07-19 A | 2001-03-30 A | 100% | 2000-07-19 | 2001-03-30 | 183d | finish no earlier than 2001-03-30 | R1 | 1464h | 1464h | LCRTDD-Phys | Rel-4 | Patrick | LCRTDD-Phys | CWTS | G. Yang |
| 4109 | 53.2 | Layer 2 and layer 3 protocol aspects | 183d | 2000-07-19 A | 2001-03-30 A | 100% | 2000-07-19 | 2001-03-30 | 183d | finish no earlier than 2001-03-30 | R2 | 1464h | 1464h | LCRTDD-L23 | Rel-4 | Yong-Jun | LCRTDD-L23 | CWTS | Y. Liu |
| 4110 | 53.3 | RF radio transmission/reception, system performance requirements and conformance testing | 165d | 2000-08-14 A | 2001-03-30 A | 100% | 2000-08-14 | 2001-03-30 | 165d | finish no earlier than 2001-03-30 | R4 | 1320h | 1320h | LCRTDD-RF | Rel-4 | Issam | LCRTDD-RF | CWTS | D. Zhang |
| 4111 | 53.4 | UE radio access capability | 165d | 2000-08-14 A | 2001-03-30 A | 100% | 2000-08-14 | 2001-03-30 | 165d | finish no earlier than 2001-03-30 | R2 | 1320h | 1320h | LCRTDD-UErac | Rel-4 | Yong-Jun | LCRTDD-UErac | CWTS | Y. Liu |
| 4112 | 53.5 | Iub/Iur protocol aspects - for Low Chip Rate TDD option | 165d | 2000-08-14 A | 2001-03-30 A | 100% | 2000-08-14 | 2001-03-30 | 165d | finish no earlier than 2001-03-30 | R3 | 1320h | 1320h | LCRTDD-IubIur | Rel-4 | Juha | LCRTDD-IubIur | CWTS | Y. Liu |

Notes:
- 4087: -
- 4088: -
- 4089: -
- 4090: -
- 4091: -
- 4092: -
- 4093: -
- 4094: -
- 4095: -
- 4096: -
- 4097: -
- 4098: -
- 4099: az 05/08: duplicated UID_50099 => 50299. Marked as closed 12/2008 (was marked 50% complete)
- 4100: -
- 4101: -
- 4102: -
- 4103: -
- 4104: -
- 4105: -
- 4106: -
- 4107: -
- 4108: -
- 4109: -
- 4110: -
- 4111: -
- 4112: -

| ID | WBS | Task | Duration | Start | Finish | Predecessors | Complete | Baseline start | Baseline finish | Baseline duration | Constraint | Resources | Work | Actual work | Release | MCC resp | Impacted TSs and TRs | TSG stopped | Acronym | WI rapporteur name | WI rapporteur e-mail | Acronym_3GU_Export |
| --- | --- | --- | --- | --- | --- | --- | --- | --- | --- | --- | --- | --- | --- | --- | --- | --- | --- | --- | --- | --- | --- | --- |
| 4113 | 53.6 | **Low chiprate TDD interworking with GERAN** | 101d | 2000-09-01 A | 2001-01-19 A | 4112 | 100% | 2000-09-01 | 2001-01-19 | 101d |  | GP | 1616h | 1616h | Rel-4 | Paolo |  |  |  |  |  |  |
| 4114 | 53.6.1 | Handover and Cell Selection / Reselection to UTRA 1.28 Mcps TDD | 101d | 2000-09-01 A | 2001-01-19 A |  | 100% | 2000-09-01 | 2001-01-19 | 101d | finish no earlier than 2001-01-19 | GP | 808h | 808h | Rel-4 | Paolo |  |  |  |  |  |  |
| 4115 | 53.8 | **Conformance Test Aspects - Low Chip Rate TDD** | 577d | 2001-09-17 A | 2003-12-02 A | 4113 | 100% | 2001-09-17 | 2003-12-02 | 577d |  | T1 | 12088h | 12088h | Rel-4 | Ingbert |  |  |  |  |  |  |
| 4116 | 53.8.1 | Testing Layer 2 and layer 3 protocol aspects | 468d | 2001-09-17 A | 2003-07-02 A |  | 100% | 2001-09-17 | 2003-07-02 | 468d | finish no earlier than 2003-07-02 | T1 | 3744h | 3744h | Rel-4 | Ingbert | 34.123-1, 34.123-2 |  |  |  |  |  |
| 4117 | 53.8.2 | Deleted - Testing Layer 2 and layer 3 protocol aspects - TTCN | 261d | 2002-12-03 A | 2003-12-02 A |  | 100% | 2002-12-03 | 2003-12-02 | 261d | finish no earlier than 2003-12-02 | T1 | 2088h | 2088h | Rel-4 | Ingbert | 34.123-3 | TP-22 |  |  |  |  |
| 4118 | 53.8.3 | Testing RF Radio Transmission and Reception | 205d | 2001-09-17 A | 2002-06-28 A |  | 100% | 2001-09-17 | 2002-06-28 | 205d | finish no earlier than 2002-06-28 | T1 | 1640h | 1640h | Rel-4 | Ingbert |  |  |  |  |  |  |
| 4119 | 54 | **Enable bearer independent CS architecture** | 566d | 2000-01-03 A | 2002-03-01 A |  | 100% | 2000-01-03 | 2002-03-01 | 566d |  | S2; N3; N4 | 28008h | 28008h | Rel-4 | Maurice |  |  | CSSPLIT | Siemens | Alexander Milinski | CSSPLIT |
| 4120 | 54.1 | **Enable bearer-independent call control** | 425d | 2000-01-03 A | 2001-08-16 A |  | 100% | 2000-01-03 | 2001-08-16 | 425d |  | N4 | 12344h | 12344h | Rel-4 | Kimmo |  |  |  | Ericsson | Heinz-Peter.Keutmann@eed.ericsson.se |  |
| 4121 | 54.1.1 | Architecture and Stage 2 description | 181d | 2000-01-03 A | 2000-09-08 A |  | 100% | 2000-01-03 | 2000-09-08 | 181d | finish no earlier than 2000-09-08 | S2 | 1440h | 1440h | Rel-4 | Maurice | 23.002 |  |  |  |  |  |
| 4122 | 54.1.2 | Standardisation of protocols (control & user planes) over Nb interface | 64d | 2001-01-02 A | 2001-03-30 A |  | 100% | 2001-01-02 | 2001-03-30 | 64d | finish no earlier than 2001-03-30 | N3 | 512h | 512h | Rel-4 | Gwiho |  |  |  |  |  |  |
| 4123 | 54.1.3 | Standardisation of protocols over reference points between MSC server and Gateway MSC server | 130d | 2000-09-25 A | 2001-03-23 A |  | 100% | 2000-09-25 | 2001-03-23 | 130d | finish no earlier than 2001-03-23 | N4 | 1040h | 1040h | Rel-4 | Kimmo |  |  |  |  |  |  |
| 4124 | 54.1.4 | Standardisation of detailed stage 2 description | 180d | 2000-07-17 A | 2001-03-23 A |  | 100% | 2000-07-17 | 2001-03-23 | 180d | finish no earlier than 2001-03-23 | N4 | 1440h | 1440h | Rel-4 | Kimmo |  |  |  |  |  |  |
| 4125 | 54.1.5 | **Bearer control between MSC server and MGW** | 250d | 2000-09-01 A | 2001-08-16 A |  | 100% | 2000-09-01 | 2001-08-16 | 250d |  | N4 | 4512h | 4512h | Rel-4 | Kimmo |  |  |  |  |  |  |
| 4126 | 54.1.5.1 | stage 3 - protocol issues | 250d | 2000-09-01 A | 2001-08-16 A |  | 100% | 2000-09-01 | 2001-08-16 | 250d | finish no earlier than 2001-08-16 | N4 | 2000h | 2000h | Rel-4 | Kimmo |  |  |  |  |  |  |
| 4127 | 54.1.5.2 | stage 3 - parameter value issues | 64d | 2001-01-02 A | 2001-03-30 A |  | 100% | 2001-01-02 | 2001-03-30 | 64d | finish no earlier than 2001-03-30 | N3 | 512h | 512h | Rel-4 | Gwiho |  |  |  |  |  |  |
| 4128 | 54.4 | Deleted - Conformance Test Aspects - Enable bearer independent CS architecture | 260d | 2001-03-05 A | 2002-03-01 A |  | 100% | 2001-03-05 | 2002-03-01 | 260d |  | T1 | 2080h | 2080h | Rel-4 | Ingbert |  | TP-15 | CSSPLIT-TEST |  |  | CSSPLIT-TEST |
| 4129 | 55 | **MExE enhancements Rel-4** | 511d | 2000-01-03 A | 2001-12-14 A |  | 100% | 2000-01-03 | 2001-12-14 | 511d |  | T2; S3 | 26912h | 26912h | Rel-4 | Kimmo |  |  | MEXE |  |  | MEXE |
| 4130 | 55.1 | **MExE Security Analysis Activity** | 474d | 2000-02-22 A | 2001-12-14 A |  | 100% | 2000-02-22 | 2001-12-14 | 474d |  | S3; T2 | 12256h | 12256h | Rel-4 | Mirko |  |  | MEXE-SEC | BT | Andrew.Myers@bt.com | MEXE-SEC |
| 4131 | 55.1.1 | Stage 3 for MExE Security | 370d | 2000-07-17 A | 2001-12-14 A |  | 100% | 2000-07-17 | 2001-12-14 | 370d | finish no earlier than 2001-12-14 | S3 | 2960h | 2960h | Rel-4 | Mirko | 21.133, 33.102 |  |  | BT | Andrew.Myers@bt.com |  |
| 4132 | 55.1.2 | Terminal aspects for MExE Security | 214d | 2000-02-22 A | 2000-12-15 A |  | 100% | 2000-02-22 | 2000-12-15 | 214d | finish no earlier than 2000-12-15 | T2 | 1712h | 1712h | Rel-4 |  | 23.057 |  |  | BT | Andrew.Myers@bt.com |  |
| 4133 | 55.2 | **MExE Rel-4 Improvements and Investigations** | 251d | 2000-01-03 A | 2000-12-15 A |  | 100% | 2000-01-03 | 2000-12-15 | 251d |  | T2 | 6480h | 6480h | Rel-4 | Kimmo | 22.057, 23.057 |  | MEXE-ENHANC | Motorola | Mark Cataldo | MEXE-ENHANC |
| 4134 | 55.2.1 | 3rd MExE classmark | 251d | 2000-01-03 A | 2000-12-15 A |  | 100% | 2000-01-03 | 2000-12-15 | 251d | finish no earlier than 2000-12-15 | T2 | 2000h | 2000h | Rel-4 | Kimmo | 22.057, 23.057 |  |  | Motorola | Mark Cataldo |  |
| 4135 | 55.2.2 | FS on Secure download mechanism and capabilities to support SDR concepts | 225d | 2000-02-07 A | 2000-12-15 A |  | 100% | 2000-02-07 | 2000-12-15 | 225d | finish no earlier than 2000-12-15 | T2 | 1800h | 1800h | Rel-4 | Kimmo | 22.057, 23.057 |  |  | Motorola | Mark Cataldo |  |
| 4136 | 55.2.3 | FS on Support of MP3/MPEG4 content | 225d | 2000-02-07 A | 2000-12-15 A |  | 100% | 2000-02-07 | 2000-12-15 | 225d | finish no earlier than 2000-12-15 | T2 | 1800h | 1800h | Rel-4 | Kimmo | 22.057, 23.057 |  |  | Motorola | Mark Cataldo |  |

Notes:
- 4113: -
- 4114: -
- 4115: -
- 4116: Marked as closed 12/2008 (was marked 60% complete)
- 4117: Marked as stopped 12/2008
- 4118: duration set to 6 months (was 0), finish date set
- 4119: -
- 4120: DAB 12.12.01 should be 100% hence closed
- 4121: R00 stage 2 at least 80 % complete in TSGS #8 21.-23.6.2000
- 4122: -
- 4123: -
- 4124: -
- 4125: -
- 4126: -
- 4127: -
- 4128: Marked as stopped 12/2008
- 4129: -
- 4130: SP#12 updated WID
- 4131: -
- 4132: -
- 4133: -
- 4134: Additional features for MExE R2000
- 4135: -
- 4136: -

| ID | WBS | Task | Duration | Start | Finish | Complete | Baseline start | Baseline finish | Baseline duration | Constraint | Resources | Work | Actual work | Acronym | Release | MCC resp | Acronym_3GU_Export | Impacted TSs and TRs | WI rapporteur name | WI rapporteur e-mail |
| --- | --- | --- | --- | --- | --- | --- | --- | --- | --- | --- | --- | --- | --- | --- | --- | --- | --- | --- | --- | --- |
| 4137 | 56 | **Tandem Free aspects for 3G and between 2G and 3G systems** | 344d | 2000-02-22 A | 2001-06-15 A | 100% | 2000-02-22 | 2001-06-15 | 344d |  | S4 | 9696h | 9696h | TFO | Rel-4 | Paolo | TFO |  |  |  |
| 4138 | 56.1 | **Tandem Free AMR** | 344d | 2000-02-22 A | 2001-06-15 A | 100% | 2000-02-22 | 2001-06-15 | 344d |  | S4 | 6944h | 6944h | TFO-AMR | Rel-4 | Paolo | TFO-AMR |  |  |  |
| 4139 | 56.1.1 | Specification of Tandem Free AMR | 284d | 2000-02-22 A | 2001-03-23 A | 100% | 2000-02-22 | 2001-03-23 | 284d | start no earlier than 2000-02-22 | S4 | 2272h | 2272h |  | Rel-4 | Paolo |  | 28.062 |  |  |
| 4140 | 56.1.2 | **Impact of Tandem Free AMR on:** | 115d | 2001-01-08 A | 2001-06-15 A | 100% | 2001-01-08 | 2001-06-15 | 115d |  | NP | 1920h | 1920h |  | Rel-4 | Kimmo |  |  |  |  |
| 4141 | 56.1.2.1 | CN | 60d | 2001-03-26 A | 2001-06-15 A | 100% | 2001-03-26 | 2001-06-15 | 60d | finish no earlier than 2001-06-15 | NP | 480h | 480h |  | Rel-4 | Kimmo |  |  |  |  |
| 4142 | 56.1.2.2 | GERAN | 65d | 2001-01-08 A | 2001-04-06 A | 100% | 2001-01-08 | 2001-04-06 | 65d | finish no earlier than 2001-04-06 | GP | 520h | 520h |  | Rel-4 | Paolo |  |  |  |  |
| 4143 | 57 | **Advanced Speech Call Items enhancements_Rel-4** | 334d | 2000-12-03 A | 2002-03-14 A | 100% | 2000-12-03 | 2002-03-14 | 334d |  | N1 | 5925.6h | 5925.6h | ASCI, Rel-4 | Rel-4 | Frederic | ASCI, Rel-4 |  | Nortel | sonia.garapaty@nortelnetworks.com |
| 4144 | 57.1 | Stage 2 for Advanced Speech Call Items enhancements_Rel-4 (ASCI) | 326.7d | 2000-12-03 A | 2002-03-14 A | 100% | 2000-12-03 | 2002-03-14 | 326.7d | finish no earlier than 2002-03-14 | N4 | 2613.6h | 2613.6h |  | Rel-4 | Kimmo |  | 23.067, 24.067 | Sagem | Vivien Perlic |
| 4145 | 57.2 | Stages 2 and 3 on A interface | 80d | 2000-12-03 A | 2001-03-23 A | 100% | 2000-12-03 | 2001-03-23 | 80d | finish no earlier than 2001-03-23 | N1 | 640h | 640h |  | Rel-4 | Frederic |  | 44.068, 44.069, 24.008 | Nortel | sonia.garapaty@nortelnetworks.com |
| 4146 | 58 | **700 MHz spectrum support** | 776d | 2000-01-03 A | 2002-12-20 A | 100% | 2000-01-03 | 2002-12-20 | 776d |  | GP | 20016h | 20016h | 700SS | Rel-4 | Paolo | 700SS |  |  |  |
| 4147 | 58.1 | **GERAN support for the 700 MHz band** | 276d | 2000-01-03 A | 2001-01-19 A | 100% | 2000-01-03 | 2001-01-19 | 276d |  | GP | 8808h | 8808h |  | Rel-4 | Paolo |  |  |  |  |
| 4148 | 58.1.1 | Signalling support | 276d | 2000-01-03 A | 2001-01-19 A | 100% | 2000-01-03 | 2001-01-19 | 276d | finish no earlier than 2001-01-19 | GP | 2200h | 2200h |  | Rel-4 | Paolo |  |  |  |  |
| 4149 | 58.1.2 | Physical layer definitions - for GERAN support for the 700 MHz band | 276d | 2000-01-03 A | 2001-01-19 A | 100% | 2000-01-03 | 2001-01-19 | 276d | finish no earlier than 2001-01-19 | GP | 2200h | 2200h |  | Rel-4 | Paolo |  |  |  |  |
| 4150 | 58.1.3 | Receiver performance and RF budget | 276d | 2000-01-03 A | 2001-01-19 A | 100% | 2000-01-03 | 2001-01-19 | 276d | finish no earlier than 2001-01-19 | GP | 2200h | 2200h |  | Rel-4 | Paolo |  |  |  |  |
| 4151 | 58.2 | GERAN MS Conformance test for 700 MHz band | 175d | 2001-04-02 A | 2001-11-30 A | 100% | 2001-04-02 | 2001-11-30 | 175d |  | GP | 1400h | 1400h |  | Rel-4 | Paolo |  |  |  |  |
| 4152 | 58.3 | GERAN BTS Conformance test for 700 MHz band | 450d | 2001-04-02 A | 2002-12-20 A | 100% | 2001-04-02 | 2002-12-20 | 450d |  | GP | 3600h | 3600h |  | Rel-4 | Paolo |  |  |  |  |
| 4153 | 59 | Operator Determined Barring for Packet Oriented Services | 208d | 2000-06-01 A | 2001-03-19 A | 100% | 2000-06-01 | 2001-03-19 | 208d | finish no earlier than 2001-03-19 | NP | 1664h | 1664h | ODB | Rel-4 | Kimmo | ODB |  | NEC | Toshiyuki Tamura (tamurato@aj.jp.nec.com) |
| 4154 | 60 | **UMTS QoS Architecture for PS Domain** | 759d | 2000-01-03 A | 2002-11-27 A | 100% | 2000-01-03 | 2002-11-27 | 759d |  | S2; S5; R3; GP | 72848h | 72848h | QoSPS | Rel-4 | Maurice | QoSPS |  | Ericsson | Ina.widegren@era.ericsson.se |
| 4155 | 60.1 | Architecture | 153d | 2000-06-05 A | 2001-01-03 A | 100% | 2000-06-05 | 2001-01-03 | 153d | finish no earlier than 2001-01-03 | S2 | 1224h | 1224h |  | Rel-4 | Maurice |  | 23.107 |  |  |
| 4156 | 60.2 | Charging and OAM&P for QoS Management | 201d | 2001-09-21 A | 2002-06-28 A | 100% | 2001-09-21 | 2002-06-28 | 201d | finish no earlier than 2002-06-28 | S5 | 1608h | 1608h | QoSPS-OAM | Rel-4 | Mirko | QoSPS-OAM | 32-series |  |  |
| 4157 | 60.3 | **RAB Quality of Service (re)Negotiation over Iu** | 155d | 2000-08-21 A | 2001-03-23 A | 100% | 2000-08-21 | 2001-03-23 | 155d |  | R3 | 3648h | 3648h | QoSPS-MAPEND-RABQoS | Rel-4 | Juha | QoSPS-MAPEND-RABQoS | 25.413 | Ericsson | anders.molander@ericsson.com |
| 4158 | 60.3.1 | RAB Quality of Service Negotiation over Iu | 155d | 2000-08-21 A | 2001-03-23 A | 100% | 2000-08-21 | 2001-03-23 | 155d | finish no earlier than 2001-03-23 | R3 | 1240h | 1240h | QoSPS-MAPEND-RABQoS-Negot | Rel-4 | Juha | QoSPS-MAPEND-RABQoS-Negot |  | Ericsson | anders.molander@ericsson.com |
| 4159 | 60.3.2 | RAB Quality of Service Negotiation over Iu during relocation | 16d | 2001-03-02 A | 2001-03-23 A | 100% | 2001-03-02 | 2001-03-23 | 16d | start no earlier than 2001-03-02 | R3 | 128h | 128h | QoSPS-MAPEND-RABQoS-NegotReloc | Rel-4 | Juha | QoSPS-MAPEND-RABQoS-NegotReloc |  |  |  |
| 4160 | 60.3.3 | RAB Quality of Service Re-Negotiation over Iu | 130d | 2000-09-25 A | 2001-03-23 A | 100% | 2000-09-25 | 2001-03-23 | 130d | finish no earlier than 2001-03-23 | R3 | 1040h | 1040h | QoSPS-MAPEND-RABQoS-ReNegot | Rel-4 | Juha | QoSPS-MAPEND-RABQoS-ReNegot |  | Motorola | S. Irwin |

Notes:
- 4137: RAN and CN to verify no problems for GSM terminals roaming in 3G R99
- 4138: RAN and CN to verify UMTS_AMR_2 support
- 4139: -
- 4140: "Implementation" changed to "Impact on:" by A. Sultan (for better wording)
- 4141: RAN and CN to verify UMTS_AMR_2 support
- 4142: End date Modified from June to March to have it in Rel4
- 4143: Approved at CN#10
- 4144: CN4#11 30/11/02: no inputs received in CN4
- 4145: -
- 4146: -
- 4147: -
- 4148: -
- 4149: -
- 4150: -
- 4151: -
- 4152: -
- 4153: Completed WI missing from the P-plan Added for tracking
- 4154: -
- 4155: -
- 4156: -
- 4157: -
- 4158: -
- 4159: -
- 4160: -

| ID | WBS | Task | Type | Duration | Start | Finish | Complete | Baseline start | Baseline finish | Baseline duration | Constraint | Resources | Work | Actual work | Acronym | Release | MCC resp | Acronym_3GU_Export | TSG stopped | WI rapporteur name | WI rapporteur e-mail | Impacted TSs and TRs |
| --- | --- | --- | --- | --- | --- | --- | --- | --- | --- | --- | --- | --- | --- | --- | --- | --- | --- | --- | --- | --- | --- | --- |
| 4161 | 60.4 | **GERAN QoS Aspects - Handovers: maintenance of real-time QoS while moving between cells in the PLMN including inter-SGSN and SRNS relocation or possibly other mechanisms** |  | 501d | 2000-01-03 A | 2001-11-30 A | 100% | 2000-01-03 | 2001-11-30 | 501d |  | GP | 14456h | 14456h | GERQoS | Rel-4 | Paolo | GERQoS |  |  |  |  |
| 4162 | 60.4.1 | **Handover Concept for the PS domain** |  | 501d | 2000-01-03 A | 2001-11-30 A | 100% | 2000-01-03 | 2001-11-30 | 501d |  | GP | 10448h | 10448h |  | Rel-4 | Paolo |  |  |  |  |  |
| 4163 | 60.4.1.1 | Stable RT handover report 25.936 including header removal |  | 14d | 2000-01-03 A | 2000-01-19 A | 100% | 2000-01-03 | 2000-01-19 | 14d | start no earlier than 2000-01-03 | GP | 104h | 104h |  | Rel-4 | Paolo |  |  |  |  |  |
| 4164 | 60.4.1.2 | Update of stage 2 |  | 293d | 2000-01-03 A | 2001-02-13 A | 100% | 2000-01-03 | 2001-02-13 | 293d | finish no earlier than 2001-02-13 | GP | 2336h | 2336h |  | Rel-4 | Paolo |  |  |  |  |  |
| 4165 | 60.4.1.3 | Update of relevant stage 3 specs -> RRC |  | 501d | 2000-01-03 A | 2001-11-30 A | 100% | 2000-01-03 | 2001-11-30 | 501d | finish no earlier than 2001-11-30 | G2 | 4000h | 4000h |  | Rel-4 | Gert |  |  |  |  |  |
| 4166 | 60.5 | **Deleted - GERAN MS Conformance test for inter-system and intra-system Packet data real-time Handover** |  | 324d | 2001-08-31 A | 2002-11-27 A | 100% | 2001-08-31 | 2002-11-27 | 324d |  | G4; R3 | 25920h | 25920h | GERQoS-Mstest | Rel-4 | Paolo | GERQoS-Mstest | GP-12 |  |  |  |
| 4167 | 60.5.1 | **Deleted - Handover for the PS domain** |  | 324d | 2001-08-31 A | 2002-11-27 A | 100% | 2001-08-31 | 2002-11-27 | 324d |  | G4; R3 | 20736h | 20736h |  | Rel-4 | Paolo |  | GP-12 |  |  |  |
| 4168 | 60.5.1.1 | Deleted - Stable RT handover report 25.936 including header removal |  | 324d | 2001-08-31 A | 2002-11-27 A | 100% | 2001-08-31 | 2002-11-27 | 324d | finish no earlier than 2002-11-27 | G4; R3 | 5184h | 5184h |  | Rel-4 | Paolo |  | GP-12 |  |  |  |
| 4169 | 60.5.1.2 | Deleted - Update of stage 2 |  | 324d | 2001-08-31 A | 2002-11-27 A | 100% | 2001-08-31 | 2002-11-27 | 324d | finish no earlier than 2002-11-27 | G4; R3 | 5184h | 5184h |  | Rel-4 | Paolo |  | GP-12 |  |  |  |
| 4170 | 60.5.1.3 | Deleted - Update of relevant stage 3 specs |  | 324d | 2001-08-31 A | 2002-11-27 A | 100% | 2001-08-31 | 2002-11-27 | 324d | finish no earlier than 2002-11-27 | G4; R3 | 5184h | 5184h |  | Rel-4 | Paolo |  | GP-12 |  |  |  |
| 4171 | 60.6 | PS-domain handover for real-time services |  | 155d | 2000-08-28 A | 2001-03-30 A | 100% | 2000-08-28 | 2001-03-30 | 155d | finish no earlier than 2001-03-30 | R3 | 1240h | 1240h | QoSPS-PSdoRTS | Rel-4 | Juha | QoSPS-PSdoRTS |  | Nokia | atte.lansisalmi@nokia.com |  |
| 4172 | 60.7 | Deleted - RAB QoS Renegotiation at Relocation |  | 58d | 2001-01-03 A | 2001-03-23 A | 100% | 2001-01-03 | 2001-03-23 | 58d | finish no earlier than 2001-03-23 | R3 | 464h | 464h |  | Rel-4 | Juha |  | RP-11 |  |  | 25.851, 25.946 |
| 4173 | 61 | (Small) Technical Enhancements and Improvements for Rel-4 | milestone | 0d? | 2000-01-03 A | 2000-01-03 A | 100% | 2000-01-03 | 2001-03-30 | 326d? |  | SP; CP; RP; GP |  |  | TEI4 | Rel-4 | all | TEI4 |  |  |  |  |
| 4174 | 1014 | Test - (Small) Technical Enhancements and Improvements for Rel-4 |  | 326d? | 2000-01-03 A | 2001-03-30 A | 100% | 2000-01-03 | 2001-03-30 | 326d? | finish no earlier than 2008-12-31 | R5; T1 | 5216h | 5216h | TEI4_Test | Rel-4 | Ingbert | TEI4_Test |  |  |  |  |
| 4175 | 62 | **Rel-4 Evolutions of the transport in the UTRAN** |  | 525d | 2000-08-21 A | 2002-08-23 A | 100% | 2000-08-21 | 2002-08-23 | 525d |  | RP | 8600h | 8600h | ETRAN | Rel-4 | Issam | ETRAN |  | Alcatel | Francois Courau |  |
| 4176 | 62.1 | QoS optimization for AAL2 connections over Iub and Iur interfaces |  | 160d | 2000-08-21 A | 2001-03-30 A | 100% | 2000-08-21 | 2001-03-30 | 160d | finish no earlier than 2001-03-30 | R3 | 1280h | 1280h | ETRAN-QoSAAL2 | Rel-4 | Juha | ETRAN-QoSAAL2 |  | Japan Telecom | T. Yoshimura |  |
| 4177 | 62.2 | Transport bearer modification procedure on Iub, Iur, and Iu |  | 130d | 2000-10-02 A | 2001-03-30 A | 100% | 2000-10-02 | 2001-03-30 | 130d | finish no earlier than 2001-03-30 | R3 | 1040h | 1040h | ETRAN-MigrMod | Rel-4 | Juha | ETRAN-MigrMod |  | Japan Telecom | T. Yoshimura |  |
| 4178 | 62.3 | **Deleted - Conformance Test Aspects of Rel-4 evolutions of the transport in UTRAN** |  | 130d | 2002-02-25 A | 2002-08-23 A | 100% | 2002-02-25 | 2002-08-23 | 130d |  | T1 | 2080h | 2080h |  | Rel-4 | Ingbert |  | TP-17 |  |  |  |
| 4179 | 62.3.1 | Deleted - Testing RAB support enhancements |  | 130d | 2002-02-25 A | 2002-08-23 A | 100% | 2002-02-25 | 2002-08-23 | 130d | finish no earlier than 2002-08-23 | T1 | 1040h | 1040h | CT-RABS? | Rel-4 | Ingbert | CT-RABS? | TP-17 |  |  | 34.108, 34. 121, 34.122, 34.123 p 1,2, 34.123 pt 3 |
| 4180 | 63 | **Rel-4 Evolutions of the transport in the CN** |  | 215d | 2000-05-29 A | 2001-03-23 A | 100% | 2000-05-29 | 2001-03-23 | 215d |  | N4; N1; N2; S2 | 13128h | 13128h | CNTRSP | Rel-4 | Kimmo | CNTRSP |  |  |  |  |
| 4181 | 63.1 | **IP Transport of CN protocols (e.g. CAP, MAP)** |  | 77d | 2000-12-07 A | 2001-03-23 A | 100% | 2000-12-07 | 2001-03-23 | 77d |  | N4 | 2808h | 2808h | SS7IP | Rel-4 | Kimmo | SS7IP |  |  |  |  |
| 4182 | 63.1.1 | **Stage 3 for IP Transport of CN protocols (e.g. CAP, MAP)** |  | 77d | 2000-12-07 A | 2001-03-23 A | 100% | 2000-12-07 | 2001-03-23 | 77d |  | N4 | 2192h | 2192h |  | Rel-4 | Kimmo |  |  |  |  |  |
| 4183 | 63.1.1.1 | CAP |  | 77d | 2000-12-07 A | 2001-03-23 A | 100% | 2000-12-07 | 2001-03-23 | 77d | finish no earlier than 2001-03-23 | N2 | 616h | 616h |  | Rel-4 | Kimmo |  |  |  |  |  |
| 4184 | 63.1.1.2 | MAP |  | 77d | 2000-12-07 A | 2001-03-23 A | 100% | 2000-12-07 | 2001-03-23 | 77d | finish no earlier than 2001-03-23 | N4 | 616h | 616h |  | Rel-4 | Kimmo |  |  |  |  | 29.202 |
| 4185 | 63.1.1.3 | BSSAP+ |  | 43d | 2001-01-15 A | 2001-03-14 A | 100% | 2001-01-15 | 2001-03-14 | 43d | finish no earlier than 2001-03-14 | N1 | 344h | 344h | SS7IP-BSSAP+ | Rel-4 | Frederic | SS7IP-BSSAP+ |  |  |  |  |

Notes:
- 4161: -
- 4162: -
- 4163: -
- 4164: -
- 4165: -
- 4166: Still exist? To be clarified by GERAN4/5. Marked as stopped 12/2008
- 4167: Marked as stopped 12/2008
- 4168: Marked as stopped 12/2008
- 4169: Marked as stopped 12/2008
- 4170: Marked as stopped 12/2008
- 4171: -
- 4172: Marked as stopped 12/2008
- 4173: "Joker" WI, to be used for a Rel 4 CR not related to any feature and with very limited impact on the system
- 4174: "Joker" WI, to be used for small modifications applicable to Rel 4 conformance testing. Moved in from the Stoyan/Testing WP
- 4175: -
- 4176: -
- 4177: -
- 4178: Marked as stopped 12/2008
- 4179: Marked as stopped 12/2008
- 4180: -
- 4181: -
- 4182: -
- 4183: -
- 4184: -
- 4185: -

| ID | WBS | Task | Duration | Start | Finish | Complete | Baseline start | Baseline finish | Baseline duration | Constraint | Resources | Work | Actual work | WI rapporteur name | WI rapporteur e-mail | Release | MCC resp | Acronym | Acronym_3GU_Export | Impacted TSs and TRs | TSG stopped |
| --- | --- | --- | --- | --- | --- | --- | --- | --- | --- | --- | --- | --- | --- | --- | --- | --- | --- | --- | --- | --- | --- |
| 4186 | 63.2 | **FS on Transport and control separation in the PS CN domain** | 215d | 2000-05-29 A | 2001-03-23 A | 100% | 2000-05-29 | 2001-03-23 | 215d |  | S2 | 3440h | 3440h | Ericsson | Juan-Antonio.Ibanez@eed.ericsson.se | Rel-4 | Maurice |  |  |  |  |
| 4187 | 63.2.1 | Architectural impacts | 215d | 2000-05-29 A | 2001-03-23 A | 100% | 2000-05-29 | 2001-03-23 | 215d | finish no earlier than 2001-03-23 | S2 | 1720h | 1720h |  |  | Rel-4 | Maurice |  |  |  |  |
| 4188 | 64 | **Rel-4 Improvements of Radio Interface** | 700d | 2000-07-10 A | 2003-03-14 A | 100% | 2000-07-10 | 2003-03-14 | 700d |  | RP | 28624h | 28624h |  |  | Rel-4 |  |  |  |  |  |
| 4189 | 64.1 | UTRA repeater specification (master) | 183d | 2000-07-10 A | 2001-03-21 A | 100% | 2000-07-10 | 2001-03-21 | 183d | finish no earlier than 2001-03-21 | R4 | 1464h | 1464h | Mikom, Allgon | T. Kummetz, Mikom; Alf Ahlström, Allgon | Rel-4 | Issam | RInImp-REP | RInImp-REP |  |  |
| 4190 | 64.2 | DSCH power control improvement in soft handover | 140d | 2000-09-11 A | 2001-03-23 A | 100% | 2000-09-11 | 2001-03-23 | 140d | finish no earlier than 2001-03-23 | R1 | 1120h | 1120h | Nokia | antti.toskala@nokia.com | Rel-4 | Patrick | RInImp-DSCHsho | RInImp-DSCHsho |  |  |
| 4191 | 64.3 | UMTS 1800 | 320d | 2000-09-25 A | 2001-12-14 A | 100% | 2000-09-25 | 2001-12-14 | 320d | finish no earlier than 2001-12-14 | R4 | 2560h | 2560h | Motorola | Howard Benn | Rel-4 | Issam | RInImp-UMTS18 | RInImp-UMTS18 |  |  |
| 4192 | 64.4 | UMTS 1900 | 195d | 2001-03-19 A | 2001-12-14 A | 100% | 2001-03-19 | 2001-12-14 | 195d | finish no earlier than 2001-12-14 | R4 | 1560h | 1560h | Motorola | Howard Benn | Rel-4 | Issam | RInImp-UMTS19 | RInImp-UMTS19 | 25.101 |  |
| 4193 | 64.5 | FS on High Speed downlink packet access | 155d | 2000-08-21 A | 2001-03-23 A | 100% | 2000-08-21 | 2001-03-23 | 155d | finish no earlier than 2001-03-23 | R2 | 1240h | 1240h | Motorola | Amitabha Ghosh (qa0047@email.mot.com) | Rel-4 | Yong-Jun | RInImp-HSDPA | RInImp-HSDPA |  |  |
| 4194 | 64.6 | Deleted - FS on improved common DL channel for Cell-FACH state | 340d | 2000-09-11 A | 2001-12-28 A | 100% | 2000-09-11 | 2001-12-28 | 340d | finish no earlier than 2001-12-28 | R2 | 2720h | 2720h | GBT | J. Kwak | Rel-4 | Yong-Jun | RInImp-DLCFACH | RInImp-DLCFACH |  | RP-14 |
| 4195 | 64.7 | **Conformance Test Spec. Rel-4 improvements in Radio Interface** | 375d | 2001-10-08 A | 2003-03-14 A | 100% | 2001-10-08 | 2003-03-14 | 375d |  | T1 | 12360h | 12360h |  |  | Rel-4 | Ingbert |  |  |  |  |
| 4196 | 64.7.1 | Deleted - Testing Improved usage of downlink resource in FDD for CCTrCHs of dedicated type | 140d | 2002-02-18 A | 2002-08-30 A | 100% | 2002-02-18 | 2002-08-30 | 140d | finish no earlier than 2002-08-30 | T1 | 1120h | 1120h |  |  | Rel-4 | Ingbert |  |  |  | TP-17 |
| 4197 | 64.7.2 | Deleted - Testing Terminal Power saving features | 140d | 2002-02-18 A | 2002-08-30 A | 100% | 2002-02-18 | 2002-08-30 | 140d | finish no earlier than 2002-08-30 | T1 | 1120h | 1120h |  |  | Rel-4 | Ingbert |  |  |  | TP-17 |
| 4198 | 64.7.3 | Deleted - Testing DSCH power control improvement in soft handover | 140d | 2002-02-18 A | 2002-08-30 A | 100% | 2002-02-18 | 2002-08-30 | 140d | finish no earlier than 2002-08-30 | T1 | 1120h | 1120h |  |  | Rel-4 | Ingbert |  |  |  | TP-17 |
| 4199 | 64.7.4 | Testing UMTS 1800 | 180d | 2001-10-08 A | 2002-06-14 A | 100% | 2001-10-08 | 2002-06-14 | 180d | finish no earlier than 2002-06-14 | T1 | 1440h | 1440h |  |  | Rel-4 | Ingbert |  |  | 34.108, 34,121, 34.122, 34.123-1 |  |
| 4200 | 64.7.5 | Testing UMTS 1900 | 180d | 2001-10-08 A | 2002-06-14 A | 100% | 2001-10-08 | 2002-06-14 | 180d | finish no earlier than 2002-06-14 | T1 | 1440h | 1440h |  |  | Rel-4 | Ingbert |  |  | 34.108, 34,121, 34.122, 34.123-1 |  |
| 4201 | 64.7.6 | Testing UMTS 1800 - TTCN | 195d | 2002-06-17 A | 2003-03-14 A | 100% | 2002-06-17 | 2003-03-14 | 195d | finish no earlier than 2003-03-14 | T1 | 1560h | 1560h |  |  | Rel-4 | Ingbert |  |  | 34.123-3 |  |
| 4202 | 64.7.7 | Testing UMTS 1900 - TTCN | 195d | 2002-06-17 A | 2003-03-14 A | 100% | 2002-06-17 | 2003-03-14 | 195d | finish no earlier than 2003-03-14 | T1 | 1560h | 1560h |  |  | Rel-4 | Ingbert |  |  | 34.123-3 |  |
| 4203 | 65 | **Rel-4 RAN improvements** | 938d? | 2000-08-14 A | 2004-03-17 A | 100% | 2000-08-14 | 2004-03-17 | 938d? |  | RP | 29336h | 29336h |  |  | Rel-4 |  |  |  |  |  |
| 4204 | 65.1 | Node B synchronization for TDD | 160d | 2000-08-14 A | 2001-03-23 A | 100% | 2000-08-14 | 2001-03-23 | 160d | finish no earlier than 2001-03-23 | R1 | 1280h | 1280h | Siemens | S. Oestreich | Rel-4 | Patrick | RANimp-NBsync | RANimp-NBsync |  |  |
| 4205 | 65.2 | RAB support enhancement for Rel-4 | 155d | 2000-08-21 A | 2001-03-23 A | 100% | 2000-08-21 | 2001-03-23 | 155d | finish no earlier than 2001-03-23 | R2 | 1240h | 1240h | Ericsson | M. Israelsson, A. Krishnarajah | Rel-4 | Yong-Jun | RANimp-RABSE | RANimp-RABSE |  |  |
| 4206 | 65.4 | **Deleted - Conformance Test Aspects - Rel-4 RAN Improvements** | 577d? | 2002-01-01 A | 2004-03-17 A | 100% | 2002-01-01 | 2004-03-17 | 577d? |  | T1 | 19312h | 19312h |  |  | Rel-4 | Ingbert |  |  |  | TP-23 |
| 4207 | 65.4.1 | Deleted - Testing Radio access bearer support enhancments | 175d | 2002-01-01 A | 2002-09-02 A | 100% | 2002-01-01 | 2002-09-02 | 175d | finish no earlier than 2002-09-02 | T1 | 1400h | 1400h |  |  | Rel-4 | Ingbert |  |  |  | TP-17 |
| 4208 | 65.4.2 | Deleted - Testing RAB support enhancements-Robust Header Compression | 332d | 2002-05-28 A | 2003-09-03 A | 100% | 2002-05-28 | 2003-09-03 | 332d | finish no earlier than 2003-09-03 | T1 | 2656h | 2656h |  |  | Rel-4 | Ingbert | RABimp-RoCH | RABimp-RoCH | 34.123-1, -2 | TP-21 |
| 4209 | 65.4.3 | Deleted - Testing RAB support enhancements-Robust Header Compression - TTCN | 472d | 2002-05-28 A | 2004-03-17 A | 100% | 2002-05-28 | 2004-03-17 | 472d | finish no earlier than 2004-03-17 | T1 | 3776h | 3776h |  |  | Rel-4 | Ingbert |  |  | 34.123-3 | TP-23 |
| 4210 | 65.4.4 | Testing of Extended Robut Header Compression | 270d | 2002-09-18 A | 2003-09-30 A | 100% | 2002-09-18 | 2003-09-30 | 270d | finish no earlier than 2003-09-30 | T1 | 2160h | 2160h |  |  | Rel-4 | Ingbert | Ext-RoHC | Ext-RoHC | 34.123-1, -2 |  |
| 4211 | 65.4.5 | Deleted - Testing of Extended Robut Header Compression - TTCN | 325d | 2002-09-18 A | 2003-12-16 A | 100% | 2002-09-18 | 2003-12-16 | 325d | finish no earlier than 2003-12-16 | T1 | 2600h | 2600h |  |  | Rel-4 | Ingbert |  |  | 34.123-3 | TP-22 |
| 4212 | 1018.3.6 | Deleted - General changes to TS34.121 corresponding to release 4 | 263d? | 2003-03-03 A | 2004-03-03 A | 100% | 2003-03-03 | 2004-03-03 | 263d? | finish no earlier than 2004-03-03 | T1 | 2104h | 2104h |  |  | Rel-4 | Ingbert | RANimp-test, TEI4 | RANimp-test, TEI4 | 34.108, 34.121 | TP-23 |

Notes:
- 4186: -
- 4187: -
- 4188: -
- 4189: -
- 4190: -
- 4191: -
- 4192: -
- 4193: -
- 4194: Stopped at RP#14
- 4195: -
- 4196: Marked as stopped 12/2008
- 4197: Marked as stopped 12/2008
- 4198: Marked as stopped 12/2008
- 4199: -
- 4200: -
- 4201: -
- 4202: -
- 4203: -
- 4204: -
- 4205: 29 Nov 2000: split into ROHC and non-ROHC part; 5 Mar 2001: splitting off of ROHC for Rel-4 agreed by R2
- 4206: Marked as stopped 12/2008
- 4207: Marked as stopped 12/2008
- 4208: UID changed. Marked as stopped 12/2008
- 4209: UID changed. Marked as stopped 12/2008
- 4210: Marked as closed 12/2008 (was marked 15% complete)
- 4211: Marked as stopped 12/2008
- 4212: Marked as stopped 12/2008

| ID | WBS | Task | Duration | Start | Finish | Complete | Baseline start | Baseline finish | Baseline duration | Constraint | Resources | Work | Actual work | Acronym | WI rapporteur name | Release | MCC resp | Special Focus Doc | Acronym_3GU_Export | TSG stopped | WI rapporteur e-mail | Status Report |
| --- | --- | --- | --- | --- | --- | --- | --- | --- | --- | --- | --- | --- | --- | --- | --- | --- | --- | --- | --- | --- | --- | --- |
| 4213 | 66 | **Rel-4 Emergency call enhancements** | 628d | 2000-01-03 A | 2002-05-28 A | 100% | 2000-01-03 | 2002-05-28 | 628d |  | N1; S1; T1 | 18672h | 18672h | EMC1, EMC1-CS | Ericsson | Rel-4 | Frederic | Public Safety (I-A) | EMC1, EMC1-CS |  |  |  |
| 4214 | 66.1 | **For CS based calls** | 628d | 2000-01-03 A | 2002-05-28 A | 100% | 2000-01-03 | 2002-05-28 | 628d |  | N1 | 3600h | 3600h | EMC1-CS | Ericsson | Rel-4 | Frederic | Public Safety (I-A) | EMC1-CS |  |  |  |
| 4215 | 66.1.1 | Distinction in CS domain of emergency call types to different emergency services | 40d | 2000-05-01 A | 2000-06-23 A | 100% | 2000-05-01 | 2000-06-23 | 40d | finish no earlier than 2000-06-23 | S1 | 320h | 320h |  |  | Rel-4 | Alain | Public Safety (I-A) |  |  |  |  |
| 4216 | 66.1.2 | Distinction in CS domain of emergency calls to different emergency types | 22d | 2000-08-24 A | 2000-09-22 A | 100% | 2000-08-24 | 2000-09-22 | 22d | finish no earlier than 2000-09-22 | N1 | 176h | 176h |  |  | Rel-4 | Frederic | Public Safety (I-A) |  |  |  |  |
| 4217 | 66.1.3 | Deleted - Conformance Test Aspects - Emergency call enhancements | 151d | 2000-01-03 A | 2000-07-28 A | 100% | 2000-01-03 | 2000-07-28 | 151d |  | T1 | 1200h | 1200h |  |  | Rel-4 | Ingbert | Public Safety (I-A) |  | TP-08 |  |  |
| 4218 | 66.1.4 | Testing CS based emergency calls | 67d | 2002-02-25 A | 2002-05-28 A | 100% | 2002-02-25 | 2002-05-28 | 67d | finish no earlier than 2002-05-28 | T1 | 536h | 536h |  |  | Rel-4 | Ingbert | Public Safety (I-A) |  |  |  |  |
| 4219 | 66.1.5 | Testing CS based emergency calls - TTCN | 134d | 2001-11-22 A | 2002-05-28 A | 100% | 2001-11-22 | 2002-05-28 | 134d | finish no earlier than 2002-05-28 | T1 | 1072h | 1072h |  |  | Rel-4 | Ingbert | Public Safety (I-A) |  |  |  |  |
| 4220 | 67 | **Rel-4 Terminal interfaces** | 315d | 2000-01-03 A | 2001-03-15 A | 100% | 2000-01-03 | 2001-03-15 | 315d |  | T2 | 14296h | 14296h | TI |  | Rel-4 | Kimmo |  | TI |  |  |  |
| 4221 | 67.1 | **AT commands enhancements** | 314d | 2000-01-03 A | 2001-03-14 A | 100% | 2000-01-03 | 2001-03-14 | 314d |  | T2 | 5016h | 5016h | TI-ATC |  | Rel-4 | Kimmo |  | TI-ATC |  |  |  |
| 4222 | 67.1.1 | Specification of AT commands for new services | 314d | 2000-01-03 A | 2001-03-14 A | 100% | 2000-01-03 | 2001-03-14 | 314d | finish no earlier than 2001-03-14 | T2 | 2504h | 2504h |  |  | Rel-4 | Kimmo |  |  |  |  |  |
| 4223 | 67.2 | **Wide Area Data Synchronization** | 314d | 2000-01-03 A | 2001-03-14 A | 100% | 2000-01-03 | 2001-03-14 | 314d |  | T2 | 5016h | 5016h | TI-WADS |  | Rel-4 | Kimmo |  | TI-WADS |  |  |  |
| 4224 | 67.2.1 | Continues evolution of Synchronization protocol | 314d | 2000-01-03 A | 2001-03-14 A | 100% | 2000-01-03 | 2001-03-14 | 314d | finish no earlier than 2001-03-14 | T2 | 2504h | 2504h | TI-SYNC-EVOL |  | Rel-4 | Kimmo |  | TI-SYNC-EVOL |  |  |  |
| 4225 | 67.3 | Terminal local model | 218d | 2000-05-16 A | 2001-03-15 A | 100% | 2000-05-16 | 2001-03-15 | 218d | finish no earlier than 2001-03-15 | T2 | 1744h | 1744h | TLM | Ericsson | Rel-4 | Kimmo |  | TLM |  | Olga.Tome@ECS.ERICSSON.SE |  |
| 4226 | 68 | **Rel-4 Location Services enhancements** | 455d | 2000-04-03 A | 2001-12-28 A | 100% | 2000-04-03 | 2001-12-28 | 455d |  | S2; S1; T2; N1; N4; R3; R2 | 67671.2h | 67671.2h | LCS1 | Nokia | Rel-4 | Maurice |  | LCS1 |  | Jan Kall |  |
| 4227 | 68.1 | CBS interactions | 455d | 2000-04-03 A | 2001-12-28 A | 100% | 2000-04-03 | 2001-12-28 | 455d | finish no earlier than 2001-12-28 | T2 | 3640h | 3640h | LCS1-CBS |  | Rel-4 |  |  | LCS1-CBS |  |  |  |
| 4228 | 68.2 | LCS support in the CS domain | 180d | 2000-05-15 A | 2001-01-19 A | 100% | 2000-05-15 | 2001-01-19 | 180d | finish no earlier than 2001-01-19 | S2 | 1440h | 1440h | LCS1-CS |  | Rel-4 | Maurice |  | LCS1-CS |  |  |  |
| 4229 | 68.3 | **LCS support in the PS domain** | 435d | 2000-05-01 A | 2001-12-28 A | 100% | 2000-05-01 | 2001-12-28 | 435d |  | S2; S1; N1; N4 | 29880h | 29880h | LCS1-PS |  | Rel-4 | Maurice |  | LCS1-PS |  |  |  |
| 4230 | 68.3.1 | Stage 1 for LCS support in the PS domain | 40d | 2000-07-03 A | 2000-08-25 A | 100% | 2000-07-03 | 2000-08-25 | 40d | start no earlier than 2000-07-03 | S1 | 320h | 320h |  | Pacific Bell Wireless | Rel-4 | Alain |  |  |  | Randolph Wohlert (rwohlert@tri.sbc.com) |  |
| 4231 | 68.3.2 | Stage 2 for LCS support in the PS domain | 190d | 2000-05-01 A | 2001-01-19 A | 100% | 2000-05-01 | 2001-01-19 | 190d | finish no earlier than 2001-01-19 | S2; R2; G1 | 4560h | 4560h |  |  | Rel-4 | Maurice |  |  |  |  |  |
| 4232 | 68.3.3 | **Stage 3 for LCS support in the PS domain** | 355d | 2000-08-21 A | 2001-12-28 A | 100% | 2000-08-21 | 2001-12-28 | 355d |  | N1; N4 | 11080h | 11080h |  |  | Rel-4 | Frederic |  |  |  |  |  |
| 4233 | 68.3.3.1 | Layer 3 LCS signalling UE (MS) -SGSN (UMTS PS and and GSM-GPRS) | 355d | 2000-08-21 A | 2001-12-28 A | 100% | 2000-08-21 | 2001-12-28 | 355d | finish no earlier than 2001-12-28 | N1 | 2840h | 2840h |  | Nokia | Rel-4 | Frederic |  |  |  | Janne Muhonen |  |
| 4234 | 68.3.3.2 | MAP impacts of LCS | 160d | 2000-08-21 A | 2001-03-30 A | 100% | 2000-08-21 | 2001-03-30 | 160d | finish no earlier than 2001-03-30 | N4 | 1280h | 1280h |  |  | Rel-4 | Kimmo |  |  |  |  |  |
| 4235 | 68.3.3.3 | GTP signalling for LCS | 160d | 2000-08-21 A | 2001-03-30 A | 100% | 2000-08-21 | 2001-03-30 | 160d | finish no earlier than 2001-03-30 | N4 | 1280h | 1280h |  |  | Rel-4 | Kimmo |  |  |  |  |  |
| 4236 | 68.4 | **UE positioning Rel-4** | 260d | 2000-04-03 A | 2001-03-30 A | 100% | 2000-04-03 | 2001-03-30 | 260d |  | R3; R2 | 7231.2h | 7231.2h | LCS1-UEpos |  | Rel-4 | Issam |  | LCS1-UEpos |  |  | RP-010045 |
| 4237 | 68.4.1 | Iub/Iur interfaces for methods Rel 99 | 233.9d | 2000-04-03 A | 2001-03-30 A | 100% | 2000-04-03 | 2001-03-30 | 233.9d | finish no earlier than 2001-03-30 | R3 | 1871.2h | 1871.2h | LCS1-UEpos-IubIur | Ericsson | Rel-4 | Juha |  | LCS1-UEpos-IubIur |  | Yun-Chao Hu | RP-010045 |
| 4238 | 68.4.2 | UE positioning enhancements - IPDL for TDD | 150d | 2000-08-28 A | 2001-03-23 A | 100% | 2000-08-28 | 2001-03-23 | 150d | finish no earlier than 2001-03-23 | R2 | 1200h | 1200h | LCS1-UEpos-enh | Siemens | Rel-4 | Yong-Jun |  | LCS1-UEpos-enh |  | Armin Sitte | RP-010045 |

Notes:
- 4213: -
- 4214: WI approved in TSG_10
- 4215: -
- 4216: Calls to different emergency services such as ambulance, fire brigade, police, etc. can be routed to respective different emergency centres. / NP-000447 is the stage 3 changes for CS call control protocol. / Impacted TSs and TRs: 24.008
- 4217: UID changed. Marked as stopped 12/2008
- 4218: - / Impacted TSs and TRs: 34.123-1
- 4219: - / Impacted TSs and TRs: 34.123-3
- 4220: -
- 4221: - / Impacted TSs and TRs: 27.007
- 4222: goal not completely achieved because of missing input / Impacted TSs and TRs: 27.007
- 4223: AS: Rel5 changed to Rel4 according to SP#10 decision, milestone on testing added
- 4224: - / Impacted TSs and TRs: 27.903, 27.103
- 4225: - / Impacted TSs and TRs: 23.227
- 4226: -
- 4227: - / Impacted TSs and TRs: 23.041
- 4228: Only MAP impact foreseen so far. To be further split if needed.
- 4229: -
- 4230: To be also considered: External LCS client identity, and Privacy options when PDP-context and when no PDP-context is established / Impacted TSs and TRs: 22.071
- 4231: SP#10 completed / Impacted TSs and TRs: 25.305 (UTRAN part), new 23.271 (CN part by S2, 43.059 (GERAN part)
- 4232: -
- 4233: -
- 4234: -
- 4235: -
- 4236: -
- 4237: - / Impacted TSs and TRs: 25.401, 25.420, 25.423, 25.430, 25.433, new TR 25.850
- 4238: 5 Mar 2001: split of IPDL for TDD agreed by R2 / Impacted TSs and TRs: new TR 25.847

| ID | WBS | Task | Duration | Start | Finish | Complete | Remaining | Baseline start | Baseline finish | Baseline duration | Total slack | Constraint | Resources | Work | Actual work | Acronym | Release | MCC resp | Acronym_3GU_Export | Impacted TSs and TRs | WI rapporteur name | WI rapporteur e-mail | TSG stopped |
| --- | --- | --- | --- | --- | --- | --- | --- | --- | --- | --- | --- | --- | --- | --- | --- | --- | --- | --- | --- | --- | --- | --- | --- |
| 4239 | 69 | **Rel-4 UICC/(U)SIM enhancements and interworking** | 175d | 2000-07-24 A | 2001-03-23 A | 100% |  | 2000-07-24 | 2001-03-23 | 175d |  |  | T3 | 2800h | 2800h | UICC1, Rel-4 | Rel-4 | Xavier | UICC1, Rel-4 |  |  |  |  |
| 4240 | 69.1 | Common PCN Handset Specification (CPHS) | 175d | 2000-07-24 A | 2001-03-23 A | 100% |  | 2000-07-24 | 2001-03-23 | 175d |  | finish no earlier than 2001-03-23 | T3 | 1400h | 1400h | UICC1-CPHS | Rel-4 | Xavier | UICC1-CPHS | 27.103 | One2One |  |  |
| 4241 | 70 | **Rel-4 (U)SIM toolkit enhancements** | 210d | 2000-06-05 A | 2001-03-23 | 99% | 0d | 2000-06-05 | 2001-03-23 | 210d | 0d |  | T3; S1 | 6720h | 5040h | USAT1, USAT1-LocLnk, USAT1APIJAVA, USAT1SM | Rel-4 | Xavier | USAT1, USAT1-LocLnk, USAT1APIJAVA, USAT1SM | 23.048 (USAT1SM), 43.019 (USAT1APIJAVA) | Gemplus | Jean-Francois Rubon |  |
| 4242 | 70.1 | USAT local link | 210d | 2000-06-05 A | 2001-03-23 A | 100% |  | 2000-06-05 | 2001-03-23 | 210d |  | finish no earlier than 2001-03-23 | T3; S1 | 3360h | 3360h | USAT1-LocLnk | Rel-4 | Xavier | USAT1-LocLnk | 22.038, 31.111 | Gemplus | Jean-Francois Rubon |  |
| 4243 | 71 | **Rel-4 Security enhancements** | 576d | 2000-01-03 A | 2002-03-15 A | 100% |  | 2000-01-03 | 2002-03-15 | 576d |  |  | S3; N4; N1 | 38112h | 38112h | SEC1 | Rel-4 | Mirko | SEC1 |  | Vodafone | Peter.Howard@vodafone.com |  |
| 4244 | 54.2 | Rel-4 Lawful Interception | 155d | 2000-08-21 A | 2001-03-23 A | 100% |  | 2000-08-21 | 2001-03-23 | 155d |  | finish no earlier than 2001-03-23 | S3 | 1240h | 1240h | SEC1-LI | Rel-4 | Mirko | SEC1-LI | 33.107 |  |  |  |
| 4245 | 71.1 | Evolution of GSM CS algorithms (e.g. A5/3 development and deployment) | 272d | 2000-01-03 A | 2001-01-15 A | 100% |  | 2000-01-03 | 2001-01-15 | 272d |  | finish no earlier than 2001-01-15 | S3 | 2168h | 2168h | SEC1-CSALGO1 | Rel-4 | Mirko | SEC1-CSALGO1 | 33.102, 33.103, 33.105 | DTI, BIS | cbrookson@iee.org |  |
| 4246 | 71.2 | **Evolution of GSM PS algorithms (e.g. GEA 2 deployment)** | 219d | 2000-02-22 A | 2000-12-22 A | 100% |  | 2000-02-22 | 2000-12-22 | 219d |  |  | S3; N4; N1 | 9528h | 9528h | SEC1-PSALGO1 | Rel-4 | Mirko | SEC1-PSALGO1 | 33.102, 33.103, 33.105 | DTI, BIS | cbrookson@iee.org |  |
| 4247 | 71.2.1 | Deleted - Main aspects of Evolution of GSM PS algorithms (e.g. GEA 2 deployment) | 199d | 2000-02-22 A | 2000-11-24 A | 100% |  | 2000-02-22 | 2000-11-24 | 199d |  | finish no earlier than 2000-11-24 | S3 | 1592h | 1592h |  | Rel-4 | Mirko |  |  | DTI, BIS | cbrookson@iee.org |  |
| 4248 | 71.2.2 | Impact on GTP | 200d | 2000-03-20 A | 2000-12-22 A | 100% |  | 2000-03-20 | 2000-12-22 | 200d |  | finish no earlier than 2000-12-22 | N4 | 1600h | 1600h |  | Rel-4 | Kimmo |  |  | DTI, BIS | cbrookson@iee.org |  |
| 4249 | 71.2.3 | GEA capability indication in MS CM | 135d | 2000-06-19 A | 2000-12-22 A | 100% |  | 2000-06-19 | 2000-12-22 | 135d |  | finish no earlier than 2000-12-22 | N1 | 1080h | 1080h | SEC1-PSALGO1-GEACAP | Rel-4 | Frederic | SEC1-PSALGO1-GEACAP |  | Vodafone Airtouch | Duncan Mills |  |
| 4250 | 71.3 | **Deleted - MAP application layer security** | 576d | 2000-01-03 A | 2002-03-15 A | 100% |  | 2000-01-03 | 2002-03-15 | 576d |  |  | S3 | 11352h | 11352h | SEC1-MAPAL | Rel-4 | Mirko | SEC1-MAPAL |  |  |  | SP-15 |
| 4251 | 71.3.1 | Deleted - Main aspects of MAP application layer security | 199d | 2000-02-21 A | 2001-03-29 A | 100% |  | 2000-02-21 | 2001-03-29 | 199d |  | start no earlier than 2000-02-21 | S3 | 1592h | 1592h |  | Rel-4 | Mirko |  |  |  |  | SP-11 |
| 4252 | 71.3.2 | Deleted - Other stage 3 aspects | 199d | 2000-02-22 A | 2000-11-24 A | 100% |  | 2000-02-22 | 2000-11-24 | 199d |  | finish no earlier than 2000-11-24 | N4 | 1592h | 1592h |  | Rel-4 | Kimmo |  |  |  |  | CP-10 |
| 4253 | 71.3.3 | Deleted - Visibility and Configurability of security | 576d | 2000-01-03 A | 2002-03-15 A | 100% |  | 2000-01-03 | 2002-03-15 | 576d |  | finish no earlier than 2002-03-15 | S3 | 4600h | 4600h | SEC1-VCS | Rel-4 | Mirko | SEC1-VCS |  | France Telecom | Sebastien.nguyenngoc@rd.francetelecom.com | SP-15 |
| 4254 | 72 | **Rel-4 Charging and OAM&P** | 221d | 2000-12-01 A | 2001-10-05 A | 100% |  | 2000-12-01 | 2001-10-05 | 221d |  |  | S5 | 10472h | 10472h | OAM4 | Rel-4 | Mirko | OAM4 |  |  |  |  |
| 4255 | 72.1 | Rel-4 Principles, high level Requirements and Architecture | 145d | 2000-12-01 A | 2001-06-21 A | 100% |  | 2000-12-01 | 2001-06-21 | 145d |  | finish no earlier than 2001-06-21 | S5 | 1160h | 1160h |  | Rel-4 | Mirko |  | 32.101, 32.102 | Motorola, Telia | Michael.Truss@motorola.com, Tommy.R.Berggren@TELIA.SE |  |
| 4256 | 72.2 | Rel-4 Performance Management | 216d | 2000-12-01 A | 2001-09-28 A | 100% |  | 2000-12-01 | 2001-09-28 | 216d |  | finish no earlier than 2001-06-21 | S5 | 1728h | 1728h |  | Rel-4 | Mirko |  | 32.4xy, 52.402 | T-Mobile | karl-heinz.nenner@t-mobile.de |  |
| 4257 | 72.3 | Fault Management | 221d | 2000-12-01 A | 2001-10-05 A | 100% |  | 2000-12-01 | 2001-10-05 | 221d |  | finish no earlier than 2001-06-21 | S5 | 1768h | 1768h |  | Rel-4 | Mirko |  | 32.111-1/4 | Lucent |  |  |
| 4258 | 72.4 | Configuration Management | 145d | 2000-12-01 A | 2001-06-21 A | 100% |  | 2000-12-01 | 2001-06-21 | 145d |  | finish no earlier than 2001-06-21 | S5 | 1160h | 1160h |  | Rel-4 | Mirko |  | 32.106-1/8 | Ericsson | thomas.tovinger@ericsson.com |  |
| 4259 | 72.5 | Rel-4 Charging Management | 216d | 2000-12-01 A | 2001-09-28 A | 100% |  | 2000-12-01 | 2001-09-28 | 216d |  | finish no earlier than 2001-06-21 | S5 | 1728h | 1728h |  | Rel-4 | Mirko |  | 32.200, 32.205, 32.215, 32.235 | T-Mobile | karl-heinz.nenner@t-mobile.de |  |
| 4260 | 72.6 | UTRAN Operations and Maintenance procedures | 145d | 2000-12-01 A | 2001-06-21 A | 100% |  | 2000-12-01 | 2001-06-21 | 145d |  | finish no earlier than 2001-06-21 | S5 | 1160h | 1160h | UOAM | Rel-4 | Mirko | UOAM | 32.800 | Mannesmann Mobilfunk | bert.boden@d2mannesmann.de |  |
| 4261 | 73 | **Global Text Telephony** | 317d? | 2000-01-03 A | 2001-03-19 A | 100% |  | 2000-01-03 | 2009-09-18 | 2537d? |  |  | S1; S2; S4; T1; R5 | 18528h | 18528h | GTT | Rel-4 | Maurice | GTT |  | Ericsson | gunnar.hellstrom@omnitor.se |  |
| 4262 | 73.1 | Stage 1 for Global Text Telephony | 188d | 2000-04-05 A | 2000-12-22 A | 100% |  | 2000-04-05 | 2000-12-22 | 188d |  | finish no earlier than 2000-12-22 | S1 | 1504h | 1504h |  | Rel-4 | Alain |  | 22.226 |  |  |  |
| 4263 | 73.2 | Stage 2 for Global Text Telephony | 206d | 2000-01-03 A | 2000-10-13 A | 100% |  | 2000-01-03 | 2000-10-13 | 206d |  |  | S2 | 1640h | 1640h |  | Rel-4 | Maurice |  | 23.226 |  |  |  |

Notes:
- 4239: -
- 4240: 28/5/2001: CRs approved at TP-11. WI complete.
- 4241: -
- 4242: 25/5/2001:CR was approved at TP-11. WI is complete
- 4243: -
- 4244: Requirements capture: S3#14 (Aug 00), Feature specification: S3#15 (Sep 00), Definition of architecture. Should be included in general LI work mentioned above.
- 4245: SP#8 approved WID
- 4246: SP#8 approved WID
- 4247: Complete TSG#09 (09/2000). S3#17: Proposed for deletion. TO BE DELETED
- 4248: -
- 4249: -
- 4250: REPLACED BY NDS-MAP and NDS-IP. Completed Auto Key Management -> Rel-6. Marked as stopped 12/2008
- 4251: UID changed. Marked as stopped 12/2008
- 4252: UID changed. Marked as stopped 12/2008
- 4253: CR approved at SA3#21 awaiting comments from CN1. Marked as stopped 12/2008
- 4254: SP#13 approved WID
- 4255: -
- 4256: -
- 4257: -
- 4258: -
- 4259: -
- 4260: -
- 4261: SP#12 updated WID SP-000162=>SP-010340
- 4262: -
- 4263: -

| ID | WBS | Task | Type | Duration | Start | Finish | Complete | Baseline start | Baseline finish | Baseline duration | Constraint | Resources | Work | Actual work | Acronym | Release | MCC resp | Acronym_3GU_Export | PCG stopped | TSG stopped |
| --- | --- | --- | --- | --- | --- | --- | --- | --- | --- | --- | --- | --- | --- | --- | --- | --- | --- | --- | --- | --- |
| 4264 | 73.3 | **Specification of Cellular Text telephone Modem** |  | 136d | 2000-09-11 A | 2001-03-19 A | 100% | 2000-09-11 | 2001-03-19 | 136d |  | S4 | 2704h | 2704h | GTT-CTM | Rel-4 | Paolo | GTT-CTM |  |  |
| 4265 | 73.3.1 | General description and C-code |  | 66d | 2000-09-11 A | 2000-12-11 A | 100% | 2000-09-11 | 2000-12-11 | 66d | finish no earlier than 2000-12-11 | S4 | 528h | 528h |  | Rel-4 | Paolo |  |  |  |
| 4266 | 73.3.2 | Minimum Performance requirements |  | 136d | 2000-09-11 A | 2001-03-19 A | 100% | 2000-09-11 | 2001-03-19 | 136d | finish no earlier than 2001-03-19 | S4 | 1088h | 1088h |  | Rel-4 | Paolo |  |  |  |
| 4267 | 73.5 | Deleted - Conformance Test Aspects - Global Text Telephony | milestone | 0d? | 2000-09-21 A | 2000-09-21 A | 100% | 2000-09-21 | 2009-09-18 | 2348d? | finish no earlier than 2009-09-18 | R5; T1 |  |  | GTT_Test | Rel-4 | Ingbert | GTT_Test | PCG-23 | RP-45 |
| 4268 | 1027 | Release 1999 Features |  | 261d? | 2000-01-03 A | 2000-12-29 A | 100% | 2000-01-03 | 2000-12-29 | 261d? |  | NP; SP; TP; SMG | 8352h | 8352h |  | R99 | All |  |  |  |
| 4269 | 1028 | **UMTS Features** |  | 261d? | 1999-01-01 A | 1999-12-31 A | 100% | 1999-01-01 | 1999-12-31 | 261d? |  | S1; S2; S4; SMG; N3; N4; RP | 39672h | 39672h |  | R99 | Alain |  |  |  |
| 4270 | 1028.1 | UMTS_SERVICES |  | 261d? | 1999-01-01 A | 1999-12-31 A | 100% | 1999-01-01 | 1999-12-31 | 261d? | start no earlier than 1999-01-01 | S1 | 2088h | 2088h | UMTS_SERVICES | R99 | Alain | UMTS_SERVICES |  |  |
| 4271 | 1028.2 | UMTS phase 1 |  | 261d? | 1999-01-01 A | 1999-12-31 A | 100% | 1999-01-01 | 1999-12-31 | 261d? | start no earlier than 1999-01-01 | S1 | 2088h | 2088h | UMTS1 | R99 | Alain | UMTS1 |  |  |
| 4272 | 1028.3 | UMTS Capabilities |  | 261d? | 1999-01-01 A | 1999-12-31 A | 100% | 1999-01-01 | 1999-12-31 | 261d? | start no earlier than 1999-01-01 | S1 | 2088h | 2088h | UMTS_Capabil | R99 | Alain | UMTS_Capabil |  |  |
| 4273 | 1028.4 | Architecture of the GSM-UMTS platform |  | 261d? | 1999-01-01 A | 1999-12-31 A | 100% | 1999-01-01 | 1999-12-31 | 261d? | start no earlier than 1999-01-01 | S2; N4 | 4176h | 4176h |  | R99 | Maurice |  |  |  |
| 4274 | 1028.5 | UMTS Terrestrial Radio Access Network |  | 261d? | 1999-01-01 A | 1999-12-31 A | 100% | 1999-01-01 | 1999-12-31 | 261d? | start no earlier than 1999-01-01 | RP | 2088h | 2088h | UTRAN | R99 | Yong-Jun | UTRAN |  |  |
| 4275 | 1028.6 | UMTS 1800, UMTS 1900 |  | 261d? | 1999-01-01 A | 1999-12-31 A | 100% | 1999-01-01 | 1999-12-31 | 261d? | start no earlier than 1999-01-01 | R2 | 2088h | 2088h | Rlnlmp19, Rlnlmp18 | R99 | Yong-Jun | Rlnlmp19, Rlnlmp18 |  |  |
| 4276 | 1028.7 | Mandatory speech codec for narrowband telephony service |  | 261d? | 1999-01-01 A | 1999-12-31 A | 100% | 1999-01-01 | 1999-12-31 | 261d? | start no earlier than 1999-01-01 | S4 | 2088h | 2088h | Mandatory_Speech_Codec, AMR-NB, AMR | R99 | Paolo | Mandatory_Speech_Codec, AMR-NB, AMR |  |  |
| 4277 | 1028.8 | Codec for low bitrate multimedia telephony service |  | 261d? | 1999-01-01 A | 1999-12-31 A | 100% | 1999-01-01 | 1999-12-31 | 261d? | start no earlier than 1999-01-01 | S4 | 2088h | 2088h | Low_bit_rate_codec_for_MM_Tel., H.324M | R99 | Paolo | Low_bit_rate_codec_for_MM_Tel., H.324M |  |  |
| 4278 | 1028.9 | 3G Audio-Visual Terminal characteristics |  | 261d? | 1999-01-01 A | 1999-12-31 A | 100% | 1999-01-01 | 1999-12-31 | 261d? | start no earlier than 1999-01-01 | S4 | 2088h | 2088h | WI5TAC, 3G-AVT, Terminal_Acoustic_Characteristics | R99 | Paolo | WI5TAC, 3G-AVT, Terminal_Acoustic_Characteristics |  |  |
| 4279 | 1028.10 | Updates_for_UMTS |  | 261d? | 1999-01-01 A | 1999-12-31 A | 100% | 1999-01-01 | 1999-12-31 | 261d? | start no earlier than 1999-01-01 | N3 | 2088h | 2088h | Updates_for_UMTS | R99 | Gwiho | Updates_for_UMTS |  |  |
| 4280 | 1028.11 | UMTS |  | 261d? | 1999-01-01 A | 1999-12-31 A | 100% | 1999-01-01 | 1999-12-31 | 261d? | start no earlier than 1999-01-01 | N3 | 2088h | 2088h | UMTS | R99 | Gwiho | UMTS |  |  |
| 4281 | 1029 | **UMTS and GSM Features** |  | 261d? | 1999-01-01 A | 1999-12-31 A | 100% | 1999-01-01 | 1999-12-31 | 261d? |  | S1; S2; SMG; T2; N1; N2; N3; N4; R2; R3 | 219240h | 219240h |  | R99 | Alain |  |  |  |
| 4282 | 1029.1 | Multimedia Messaging Service |  | 261d? | 1999-01-01 A | 1999-12-31 A | 100% | 1999-01-01 | 1999-12-31 | 261d? | start no earlier than 1999-01-01 | T2 | 2088h | 2088h | MMS | R99 |  | MMS |  |  |
| 4283 | 1029.2 | Location Services |  | 261d? | 1999-01-01 A | 1999-12-31 A | 100% | 1999-01-01 | 1999-12-31 | 261d? | start no earlier than 1999-01-01 | S1; S2; S3; SMG1; SMG2; SMG12; N1; N2; N4; R2; R3 | 22968h | 22968h | LCS | R99 | Alain | LCS |  |  |
| 4284 | 1029.3 | **Customised Application for Mobile network Enhanced Logic Phase 3** |  | 261d? | 1999-01-01 A | 1999-12-31 A | 100% | 1999-01-01 | 1999-12-31 | 261d? |  | S1; S2; N2; N4 | 18792h | 18792h | CAMEL3 | R99 | Alain | CAMEL3 |  |  |
| 4285 | 1029.3.1 | Global view |  | 261d? | 1999-01-01 A | 1999-12-31 A | 100% | 1999-01-01 | 1999-12-31 | 261d? | start no earlier than 1999-01-01 | S1; S2; N2; N4 | 8352h | 8352h |  | R99 | Alain |  |  |  |
| 4286 | 1029.3.2 | Multiple Subscriber Profile (MSP) based on CAMEL phase 3 |  | 261d? | 1999-01-01 A | 1999-12-31 A | 100% | 1999-01-01 | 1999-12-31 | 261d? | start no earlier than 1999-01-01 | S1 | 2088h | 2088h |  | R99 | Alain |  |  |  |
| 4287 | 1029.4 | Short Message Service enhancements / Enhanced Messaging Service (EMS) |  | 261d? | 1999-01-01 A | 1999-12-31 A | 100% | 1999-01-01 | 1999-12-31 | 261d? | start no earlier than 1999-01-01 | T2 | 2088h | 2088h | EMS | R99 |  | EMS |  |  |
| 4288 | 1029.5 | Mobile Station Execution Environment |  | 261d? | 1999-01-01 A | 1999-12-31 A | 100% | 1999-01-01 | 1999-12-31 | 261d? | start no earlier than 1999-01-01 | S1; SMG1; T2 | 6264h | 6264h | MExE | R99 | Alain | MExE |  |  |
| 4289 | 1029.6 | MS_Classmark |  | 261d? | 1999-01-01 A | 1999-12-31 A | 100% | 1999-01-01 | 1999-12-31 | 261d? | start no earlier than 1999-01-01 | N1 | 2088h | 2088h | MS_Classmark | R99 | Frederic | MS_Classmark |  |  |

Notes:
- 4264: -
- 4265: - / Impacted TSs and TRs: 26.226, 26.230
- 4266: - / Impacted TSs and TRs: 26.231
- 4267: RP#45 work item abandoned/closed (it was never really started)
- 4268: -
- 4269: -
- 4270: - / Impacted TSs and TRs: 22.101
- 4271: - / Impacted TSs and TRs: 22.100
- 4272: Requirement for high quality speech in UMTS Phase 1 but not in R99 / Impacted TSs and TRs: 22.105
- 4273: wid Architecture overview of the GSM-UMTS System, Architecture the GSM-UMTS Platform and New Access Network to Core Network (BSS-NSS) interface / Impacted TSs and TRs: 23.002, 23.008, 23.060, 23.101, 23.110
- 4274: - / Impacted TSs and TRs: 22.011, 22.038, 22.060, 22.078, 22.100, 22.101, 22.105, 22.115, 22.129, 23.002, 23.060, 24.007, 24.008, 25.101, 25.102, 25.104, 25.105, 25.113, 25.123, 25.133, 25.141, 25.142, 25.201, 25.211, 25.212, 25.213, 25.214, 25.215, 25.221, 25.222, 25.223, 25.224,
- 4275: - / Impacted TSs and TRs: 25.307 CR#0002, 0003 Inclusion of release independent RF related information
- 4276: Define the default speech codec for UMTS (both for FDD and TDD). Definition limited to selection of one codec among several existing ones/proposed codecs: GSM AMR, IS127 EVRC, ITU G.729 and MPEG-4 speech codec. / Impacted TSs and TRs: 04.08, 05.01, 05.02, 05.03, 05.05, 05.08, 05.09, 05.09, 05.50, 08.60, 08.61, 11.21, 26.071, 26.073, 26.074, 26.090, 26.091, 26.092, 26.093, 26.094, 26.101, 26.102, 26.103, 26.104, 26.975
- 4277: - / Impacted TSs and TRs: 26.104, 26.110, 26.111, 26.911, 26.912, 26.915
- 4278: - / Impacted TSs and TRs: 26.131, 26.132
- 4279: - / Impacted TSs and TRs: 24.022, 27.001, 29.007
- 4280: - / Impacted TSs and TRs: 27.060, 29.061
- 4281: -
- 4282: MMS allows users to send/receive messages e.g. almost unlimited text length, images, audio and video clips and new content types. R99 only includes the concept. MMS stage 3 is not included in 23.140. Rel-4 adds detailed architecture and protocols. / Impacted TSs and TRs: 22.140, 23.040, 23.140
- 4283: LCS provide ability to localize a terminal / Impacted TSs and TRs: 02.07, 03.71, 04.31, 04.35, 04.71, 05.05, 08.08, 08.31, 08.71, 09.31, 22.071, 23.002, 23.003, 23.007, 23.008, 23.016, 23.018, 23.032, 23.171, 24.007, 24.008, 24.030, 24.080, 25.305, 25.306, 25.331, 25.413, 25.423, 29.002, 29.010
- 4284: CAMEL is a network feature providing mechanisms to support services of operators which are not covered by standardised services, even when roaming outside the HPLMN. / Impacted TSs and TRs: 22.101, 23.008, 23.012, 23.016, 23.018, 23.060, 23.072, 23.078, 23.079, 23.082, 23.093, 29.002, 29.078
- 4285: - / Impacted TSs and TRs: 22.078, 23.078, 29.078
- 4286: MSP is an optional service enabling mobile subscribers to have several profiles associated with a single IMSI, with each profile being a subscription option. Each profile may be used for mobile originated and mobile terminated calls. / Impacted TSs and TRs: 22.097 (Advanced Addressing)
- 4287: SMS for 3G terminals compatible with GSM SMS. Added Enhanced Messaging Service (EMS) allowing small pictures, sounds, animations to be transferred via SMS. / Impacted TSs and TRs: 23.038, 23.039, 23.040, 23.042
- 4288: MExE provides a standardized MS execution environment and ability to negotiate its supported capabilities with a MExE SP. R99 enhances SIM MExE certificate management, security clarifications, QoS and defines two MExE classmarks WAP/Personal-Java based. / Impacted TSs and TRs: 02.57, 22.057, 22.101, 23.057
- 4289: MExE classmark identifies a category of MExE UE supporting MExE functionality with a minimum level of processing, memory, display, and interactive capabilities. Several MExE classmarks may be defined. / Impacted TSs and TRs: 24.008

| ID | WBS | Task | Duration | Start | Finish | Complete | Baseline start | Baseline finish | Baseline duration | Constraint | Resources | Work | Actual work | Acronym | Release | MCC resp | Acronym_3GU_Export | TSG stopped |
| --- | --- | --- | --- | --- | --- | --- | --- | --- | --- | --- | --- | --- | --- | --- | --- | --- | --- | --- |
| 4290 | 1029.7 | **MultiCall** | 261d? | 1999-01-01 A | 1999-12-31 A | 100% | 1999-01-01 | 1999-12-31 | 261d? |  | S1; N1; N2; N4 | 10440h | 10440h | Multicall | R99 | Alain | Multicall |  |
| 4291 | 1029.7.1 | Stage 1 for Multicall | 261d? | 1999-01-01 A | 1999-12-31 A | 100% | 1999-01-01 | 1999-12-31 | 261d? | start no earlier than 1999-01-01 | S1 | 2088h | 2088h |  | R99 | Alain |  |  |
| 4292 | 1029.8 | Virtual Home Environment | 261d? | 1999-01-01 A | 1999-12-31 A | 100% | 1999-01-01 | 1999-12-31 | 261d? | start no earlier than 1999-01-01 | S1; SMG1; S2 | 6264h | 6264h | VHE | R99 | Alain | VHE |  |
| 4293 | 1029.9 | Open Service Access | 261d? | 1999-01-01 A | 1999-12-31 A | 100% | 1999-01-01 | 1999-12-31 | 261d? | start no earlier than 1999-01-01 | S1; S2; N5 | 6264h | 6264h | OSA | R99 | Alain | OSA |  |
| 4294 | 1029.10 | Super Charger mechanism for signalling traffic associated with mobility | 261d? | 1999-01-01 A | 1999-12-31 A | 100% | 1999-01-01 | 1999-12-31 | 261d? | start no earlier than 1999-01-01 | N2; N4 | 4176h | 4176h | Super_Charger | R99 | Kimmo | Super_Charger |  |
| 4295 | 1029.11 | Follow_Me service | 261d? | 1999-01-01 A | 1999-12-31 A | 100% | 1999-01-01 | 1999-12-31 | 261d? | start no earlier than 1999-01-01 | S1; N2; N4 | 6264h | 6264h | Follow_Me | R99 | Alain | Follow_Me |  |
| 4296 | 1029.12 | Wide area network Synchronization and object exchange | 261d? | 1999-01-01 A | 1999-12-31 A | 100% | 1999-01-01 | 1999-12-31 | 261d? | start no earlier than 1999-01-01 | T2 | 2088h | 2088h | SYNC | R99 |  | SYNC |  |
| 4297 | 1029.13 | **R99 Terminal Interfaces** | 261d? | 1999-01-01 A | 1999-12-31 A | 100% | 1999-01-01 | 1999-12-31 | 261d? |  | T2 | 8352h | 8352h |  | R99 |  |  |  |
| 4298 | 1029.13.1 | AT commands for 3GPP | 261d? | 1999-01-01 A | 1999-12-31 A | 100% | 1999-01-01 | 1999-12-31 | 261d? | start no earlier than 1999-01-01 | T2 | 2088h | 2088h |  | R99 |  |  |  |
| 4299 | 1029.13.2 | Physical interfaces | 261d? | 1999-01-01 A | 1999-12-31 A | 100% | 1999-01-01 | 1999-12-31 | 261d? | start no earlier than 1999-01-01 | T2 | 2088h | 2088h |  | R99 |  |  |  |
| 4300 | 1029.13.3 | Multiplexer | 261d? | 1999-01-01 A | 1999-12-31 A | 100% | 1999-01-01 | 1999-12-31 | 261d? | start no earlier than 1999-01-01 | T2 | 2088h | 2088h | MUX MS-TE | R99 |  | MUX MS-TE |  |
| 4301 | 1029.14 | **Bearer Services** | 261d? | 1999-01-01 A | 1999-12-31 A | 100% | 1999-01-01 | 1999-12-31 | 261d? |  | S1; T2; N1; N3 | 41760h | 41760h |  | R99 | Alain |  |  |
| 4302 | 1029.14.1 | **Circuit Switched Bearer Services** | 261d? | 1999-01-01 A | 1999-12-31 A | 100% | 1999-01-01 | 1999-12-31 | 261d? |  | S1; N3 | 16704h | 16704h | Circuit_switched_Bearer_Services | R99 | Alain | Circuit_switched_Bearer_Services |  |
| 4303 | 1029.14.1.1 | Stage 1 for Circuit Switched Bearer Services | 261d? | 1999-01-01 A | 1999-12-31 A | 100% | 1999-01-01 | 1999-12-31 | 261d? | start no earlier than 1999-01-01 | S1 | 2088h | 2088h | CS_Bearerss_in_UMTS | R99 | Alain | CS_Bearerss_in_UMTS |  |
| 4304 | 1029.14.1.2 | CS_Bearers | 261d? | 1999-01-01 A | 1999-12-31 A | 100% | 1999-01-01 | 1999-12-31 | 261d? | start no earlier than 1999-01-01 | N3 | 2088h | 2088h | CS_Bearers | R99 | Gwiho | CS_Bearers |  |
| 4305 | 1029.14.1.3 | CS_Bearerss | 261d? | 1999-01-01 A | 1999-12-31 A | 100% | 1999-01-01 | 1999-12-31 | 261d? | start no earlier than 1999-01-01 | N3 | 2088h | 2088h | CS_Bearerss | R99 | Gwiho | CS_Bearerss |  |
| 4306 | 1029.14.1.4 | CS_Data | 261d? | 1999-01-01 A | 1999-12-31 A | 100% | 1999-01-01 | 1999-12-31 | 261d? | start no earlier than 1999-01-01 | N3 | 2088h | 2088h | CS_Data | R99 | Gwiho | CS_Data |  |
| 4307 | 1029.14.1.5 | CS_Data_Bearers | 261d? | 1999-01-01 A | 1999-12-31 A | 100% | 1999-01-01 | 1999-12-31 | 261d? | start no earlier than 1999-01-01 | N3 | 2088h | 2088h | CS_Data_Bearers | R99 | Gwiho | CS_Data_Bearers |  |
| 4308 | 1029.14.1.6 | Deleted - CN3 poart of Circuit Switched Bearer Services | 261d? | 1999-01-01 A | 1999-12-31 A | 100% | 1999-01-01 | 1999-12-31 | 261d? | start no earlier than 1999-01-01 | N3 | 2088h | 2088h | CSBS | R99 | Gwiho | CSBS | NP-06 |
| 4309 | 1029.14.2 | Frame Tunnelling Mode | 261d? | 1999-01-01 A | 1999-12-31 A | 100% | 1999-01-01 | 1999-12-31 | 261d? | start no earlier than 1999-01-01 | T2; N1; N3 | 6264h | 6264h | FTM | R99 | Gwiho | FTM |  |
| 4310 | 1029.14.3 | Access to ISPs and Intranets – Wireless/Remote access to LANs | 261d? | 1999-01-01 A | 1999-12-31 A | 100% | 1999-01-01 | 1999-12-31 | 261d? | start no earlier than 1999-01-01 | N3 | 2088h | 2088h | Interworking with PDN (DHCP) | R99 | Gwiho | Interworking with PDN (DHCP) |  |
| 4311 | 1029.14.4 | **PHS Internet Access Forum Specification** | 261d? | 1999-01-01 A | 1999-12-31 A | 100% | 1999-01-01 | 1999-12-31 | 261d? |  | S1; N3 | 8352h | 8352h | PIAFS | R99 | Alain | PIAFS |  |
| 4312 | 1029.14.4.1 | Personal Handyphone System Internet Access Forum Standard (PIAFS) | 261d? | 1999-01-01 A | 1999-12-31 A | 100% | 1999-01-01 | 1999-12-31 | 261d? | start no earlier than 1999-01-01 | S1 | 2088h | 2088h |  | R99 | Alain |  |  |
| 4313 | 1029.14.4.2 | Support_of_PIAFS_in_UMTS | 261d? | 1999-01-01 A | 1999-12-31 A | 100% | 1999-01-01 | 1999-12-31 | 261d? | start no earlier than 1999-01-01 | N3 | 2088h | 2088h | Support_of_PIAFS_in_UMTS | R99 | Gwiho | Support_of_PIAFS_in_UMTS |  |

Notes:
- 4290: Multicall allows several simultaneous CS calls with dedicated bearers of independent traffic and performance characteristics. R99 Multicall was defined as a supplementary service limited to one CS bearer to be used for speech at any time. / Impacted TSs and TRs: 22.030, 22.083, 22.087, 23.008, 23.009, 23.016, 23.018, 23.108, 23.135, 24.008, 24.080, 24.135, 29.002, 29.010
- 4291: - / Impacted TSs and TRs: 22.030, 22.083, 22.087
- 4292: Information exists in SP#5-8 reports & in SP-99416,SP-000095,SP 000155. OSA allows service development by operators and 3rd parties by making use of network functionality through open, standardised, secure, extensible and scalable interfaces. / Impacted TSs and TRs: 02.01, 22.105, 22.121,23.127
- 4293: Open Service Architecture became in later Releases Open Service Access. Produced by Parlay, ETSI SPAN (TISPAN), 3GPP SA1 (Stage 1), SA2 (Stage 2) and CN5 (Stage 3), resulting in a single set of standard OSA APIs for the whole development community. / Impacted TSs and TRs: 22.121, 23.127, 29.198, 29.998
- 4294: Super Charger reduces mobility management cost by reducing the volume of location update signalling. It changes subscriber data management associated with inter-VLR and SGSN location updates. It also applies to packet services (SGSN replaces VLR and … / Impacted TSs and TRs: 21.905, 23.007, 23.008, 23.012, 23.016, 23.018, 23.040, 23.060, 23.116, 23.912, 29.002
- 4295: Follow Me enables a mobile subscriber A to manipulate the Follow Me data of a party B in such a way that - under certain conditions - subsequent calls directed to party B will be forwarded to subscriber A. It is PLMN-specific and control based on USSD / Impacted TSs and TRs: 21.905, 22.004, 22.030, 22.082, 22.090, 22.094, 23.090, 24.090, 22.094, 23.011, 23.015, 23.082, 29.002
- 4296: Allows data stored in ME/USIM to be synchronized with the outside world. TS 27.103 defines protocols based upon IrMC level 4 and will evaluate new technologies (XML) for inclusion. From Rel-4 IrMC was replaced by SyncML in 27.103. / Impacted TSs and TRs: 27.103, 27.903
- 4297: -
- 4298: AT commands to control a 3G ME via an external Terminal Equipment (TE), fully compatible with GSM AT commands. R99 adds new AT commands e.g. to control Advanced Speech Call Items (ASCI) services. / Impacted TSs and TRs: 27.005, 27.007
- 4299: Conclusion: 3GPP should not produce any technical specification for terminal interfaces other than radio interface and USIM interface. SDOs could develop own optional physical connector specification based on market requirements / Impacted TSs and TRs: 27.901
- 4300: Multiplexing protocol allowing a number of simultaneous sessions between a MS and a terminal; used to send any data (voice, SMS, USSD, fax etc.). 27.010 describes the protocol, but not the commands or data transported with it. / Impacted TSs and TRs: 27.010
- 4301: -
- 4302: CS and real-time data services provided for interworking with PSTN/ISDN so that user is unaware of access network used (UMTS, GSM or handover between ANs). Transparent(constant delay) & non-transparent(zero error with flow control) services are supported / Impacted TSs and TRs: 22.002, 23.910, 27.001, 29.007
- 4303: CS and real-time data services provided for interworking with PSTN/ISDN so that user is unaware of access network used (UMTS, GSM or handover between ANs). Transparent(constant delay) & non-transparent(zero error with flow control) services are supported / Impacted TSs and TRs: 22.002
- 4304: - / Impacted TSs and TRs: 29.007
- 4305: - / Impacted TSs and TRs: 04.21, 23.910, 27.001, 29.007
- 4306: - / Impacted TSs and TRs: 27.001, 27.002, 27.003, 29.007
- 4307: - / Impacted TSs and TRs: 23.910, 27.001, 29.007
- 4308: No CR or new TS/TR approved under this WI / Impacted TSs and TRs: 23.910, 27.001, 29.007
- 4309: FTM is a type of async non-transparent CS bearer service (22.002). Generic term for HDLC and HDLC-related transmission protocols. Converts async non-transp data stream towards mobile side & sync data stream using X.31 flag stuffing on fixed network side. / Impacted TSs and TRs: 22.002, 27.001, 27.007, 29.007
- 4310: Access to an Intranet or ISP by running DHCP between the TE and a server in the Intranet/ISP domain. / Impacted TSs and TRs: 29.061
- 4311: PIAFS is one type of CS bearer data service (22.002). It refers to async CS tx protocol over ISDN 64 kbit/s unrestricted digital line. Facilitates interworking between PHS-MS and UMTS-UE & UMTS-UE and existing PIAFS TA (Terminal Adapter). / Impacted TSs and TRs: 22.002, 27.001, 27.007, 29.007
- 4312: PIAFS was originally standardised by the PHS Internet Access Forum in Japan. More information can be found at: http://www.infopro.or.jp/piaf / Impacted TSs and TRs: 22.002
- 4313: - / Impacted TSs and TRs: 27.001, 27.007, 29.007

| ID | WBS | Task | Duration | Start | Finish | Complete | Baseline start | Baseline finish | Baseline duration | Constraint | Resources | Work | Actual work | Acronym | Release | MCC resp | Acronym_3GU_Export | TSG stopped |
| --- | --- | --- | --- | --- | --- | --- | --- | --- | --- | --- | --- | --- | --- | --- | --- | --- | --- | --- |
| 4314 | 1029.15 | **Universal Integrated Circuit Card (UICC) and Universal Subscriber Identity Module (USIM)** | 261d? | 1999-01-01 A | 1999-12-31 A | 100% | 1999-01-01 | 1999-12-31 | 261d? |  | T3 | 31320h | 31320h | UICC, USIM | R99 | Xavier | UICC, USIM |  |
| 4315 | 1029.15.1 | UICC / Terminal interface; Physical and logical characteristics | 261d? | 1999-01-01 A | 1999-12-31 A | 100% | 1999-01-01 | 1999-12-31 | 261d? | start no earlier than 1999-01-01 | T3 | 2088h | 2088h | UICC | R99 | Xavier | UICC |  |
| 4316 | 1029.15.2 | UICC/(U)SIM enhancements and interworking | 261d? | 1999-01-01 A | 1999-12-31 A | 100% | 1999-01-01 | 1999-12-31 | 261d? | start no earlier than 1999-01-01 | T3 | 2088h | 2088h | UICC1 | R99 | Xavier | UICC1 |  |
| 4317 | 1029.15.3 | Characteristics of the USIM application | 261d? | 1999-01-01 A | 1999-12-31 A | 100% | 1999-01-01 | 1999-12-31 | 261d? | start no earlier than 1999-01-01 | T3 | 2088h | 2088h | USIM | R99 | Xavier | USIM |  |
| 4318 | 1029.15.4 | UICC Application Identifiers | 261d? | 1999-01-01 A | 1999-12-31 A | 100% | 1999-01-01 | 1999-12-31 | 261d? | start no earlier than 1999-01-01 | T3 | 2088h | 2088h | AID, Application_Identifiers | R99 | Xavier | AID, Application_Identifiers |  |
| 4319 | 1029.15.5 | SIM Application Toolkit | 261d? | 1999-01-01 A | 1999-12-31 A | 100% | 1999-01-01 | 1999-12-31 | 261d? | start no earlier than 1999-01-01 | S1; T3 | 4176h | 4176h | SAT | R99 | Alain | SAT |  |
| 4320 | 1029.15.6 | USIM Application Toolkit | 261d? | 1999-01-01 A | 1999-12-31 A | 100% | 1999-01-01 | 1999-12-31 | 261d? | start no earlier than 1999-01-01 | T3 | 2088h | 2088h | USAT | R99 | Xavier | USAT |  |
| 4321 | 1029.15.7 | Bearer Independent Protocol for SAT applications to exchange data over the GSM network | 261d? | 1999-01-01 A | 1999-12-31 A | 100% | 1999-01-01 | 1999-12-31 | 261d? | start no earlier than 1999-01-01 | T3 | 2088h | 2088h | BIP | R99 | Xavier | BIP |  |
| 4322 | 1029.15.8 | Administrative commands and functions for IC cards | 261d? | 1999-01-01 A | 1999-12-31 A | 100% | 1999-01-01 | 1999-12-31 | 261d? | start no earlier than 1999-01-01 | T3 | 2088h | 2088h |  | R99 | Xavier |  |  |
| 4323 | 1029.15.9 | USIM and UICC requirements | 261d? | 1999-01-01 A | 1999-12-31 A | 100% | 1999-01-01 | 1999-12-31 | 261d? | start no earlier than 1999-01-01 | T3 | 2088h | 2088h |  | R99 | Xavier |  |  |
| 4324 | 1029.15.10 | SIM_API | 261d? | 1999-01-01 A | 1999-12-31 A | 100% | 1999-01-01 | 1999-12-31 | 261d? | start no earlier than 1999-01-01 | T3 | 2088h | 2088h | SIM_API | R99 | Xavier | SIM_API |  |
| 4325 | 1029.15.11 | SIM_toolkit_API | 261d? | 1999-01-01 A | 1999-12-31 A | 100% | 1999-01-01 | 1999-12-31 | 261d? | start no earlier than 1999-01-01 | SMG9; T3 | 4176h | 4176h | SIM_toolkit | R99 | Xavier | SIM_toolkit |  |
| 4326 | 1029.15.12 | Deleted - 1.8 Volt SIM ME interface | 261d? | 1999-01-01 A | 1999-12-31 A | 100% | 1999-01-01 | 1999-12-31 | 261d? | start no earlier than 1999-01-01 | SMG9 | 2088h | 2088h | SMIME_1.8V | R99 | Xavier | SMIME_1.8V | TP-06 |
| 4327 | 1029.16 | **USIM/UICC Testing** | 261d? | 1999-01-01 A | 1999-12-31 A | 100% | 1999-01-01 | 1999-12-31 | 261d? |  | T3 | 10440h | 10440h |  | R99 | Xavier |  |  |
| 4328 | 1029.16.1 | Terminal tests for the UICC Interface | 261d? | 1999-01-01 A | 1999-12-31 A | 100% | 1999-01-01 | 1999-12-31 | 261d? | start no earlier than 1999-01-01 | T3 | 2088h | 2088h |  | R99 | Xavier |  |  |
| 4329 | 1029.16.2 | USIM application test specification | 261d? | 1999-01-01 A | 1999-12-31 A | 100% | 1999-01-01 | 1999-12-31 | 261d? | start no earlier than 1999-01-01 | T3 | 2088h | 2088h |  | R99 | Xavier |  |  |
| 4330 | 1029.16.3 | USIM conformance test specification | 261d? | 1999-01-01 A | 1999-12-31 A | 100% | 1999-01-01 | 1999-12-31 | 261d? | start no earlier than 1999-01-01 | T3 | 2088h | 2088h |  | R99 | Xavier |  |  |
| 4331 | 1029.16.4 | SIM toolkit test specification | 261d? | 1999-01-01 A | 1999-12-31 A | 100% | 1999-01-01 | 1999-12-31 | 261d? | start no earlier than 1999-01-01 | T3 | 2088h | 2088h |  | R99 | Xavier |  |  |
| 4332 | 1029.17 | **Security for UMTS and GSM Features** | 261d? | 1999-01-01 A | 1999-12-31 A | 100% | 1999-01-01 | 1999-12-31 | 261d? |  | S3; N2; N4 | 16704h | 16704h | Security | R99 | Mirko | Security |  |
| 4333 | 1029.17.1 | Fraud Information Gathering Service (for connection-orientated services) | 261d? | 1999-01-01 A | 1999-12-31 A | 100% | 1999-01-01 | 1999-12-31 | 261d? | start no earlier than 1999-01-01 | S3 | 2088h | 2088h | FIGS | R99 | Mirko | FIGS |  |
| 4334 | 1029.17.2 | Immediate Service Termination / SECurity Immediate Service Termination | 261d? | 1999-01-01 A | 1999-12-31 A | 100% | 1999-01-01 | 1999-12-31 | 261d? | start no earlier than 1999-01-01 | S3; N2; N4 | 6264h | 6264h | IST, SECIST | R99 | Mirko | IST, SECIST |  |
| 4335 | 1029.17.3 | Core_Network_Security | 261d? | 1999-01-01 A | 1999-12-31 A | 100% | 1999-01-01 | 1999-12-31 | 261d? | start no earlier than 1999-01-01 | N4 | 2088h | 2088h | Core_Network_Security | R99 | Kimmo | Core_Network_Security |  |
| 4336 | 1030 | **GSM Features** | 261d? | 1999-01-01 A | 1999-12-31 A | 100% | 1999-01-01 | 1999-12-31 | 261d? |  | S1; S2; SMG; T2; N1; N2; N3; N4 | 164952h | 164952h |  | R99 | Alain |  |  |
| 4337 | 1030.1 | **Dual Transfer Mode within GSM and GPRS** | 261d? | 1999-01-01 A | 1999-12-31 A | 100% | 1999-01-01 | 1999-12-31 | 261d? |  | SMG; N1 | 10440h | 10440h | DTM | R99 | Frederic | DTM |  |
| 4338 | 1030.1.1 | Class A Dual Transfer Mode | 261d? | 1999-01-01 A | 1999-12-31 A | 100% | 1999-01-01 | 1999-12-31 | 261d? | start no earlier than 1999-01-01 | SMG | 2088h | 2088h | Class_A_Dual_Transfer_Mode_(DTM) | R99 | Frederic | Class_A_Dual_Transfer_Mode_(DTM) |  |
| 4339 | 1030.1.2 | Dual Transfer Mode | 261d? | 1999-01-01 A | 1999-12-31 A | 100% | 1999-01-01 | 1999-12-31 | 261d? | start no earlier than 1999-01-01 | SMG; N1 | 4176h | 4176h |  | R99 | Frederic |  |  |

Notes:
- 4314: For 3G, GSM 11.11 was divided into two parts: a platform comprised of basic physical, electrical and logical specification (31.101) and an application specification (31.102)
- 4315: Defines a generic Terminal/Integrated Circuit Card (ICC) interface. Is independent of 3G USIM application => platform for any IC card application. Ensures interoperability between ICC and terminal independently of manufacturer, card issuer or operator. / Impacted TSs and TRs: 31.101 (Since 10/2000, ETSI EP SCP is responsible for the generic Terminal/Integrated Circuit Card (ICC) interface TS 102 221)
- 4316: - / Impacted TSs and TRs: 31.102, 31.900
- 4317: Defines Universal Subscriber Identity Module (USIM) application for 3G telecom network operation & resides on UICC, an IC card specified in 31.101. UICC can be used as a multi-application card: several USIMs and/or other applications can co-exist / Impacted TSs and TRs: 31.102
- 4318: Defines and administers Application IDentifiers (AID) for UICC. AID is used to address an application in the card. Consists of Registered application provider ID (RID) & Proprietary application ID exception (PIX - according to ISO/IEC 7816-5). / Impacted TSs and TRs: 21.111, 31.110
- 4319: - / Impacted TSs and TRs: 11.14, 22.030, 22.100, 22.101
- 4320: Defines UICC - ME interface, and mandatory ME procedures for USAT. Based on GSM 11.14 (SIM Application Toolkit). Commands and procedures defined in USIM and 3G Terminal for using USAT. Service and security requirements defined in 22.100 and 22.101. / Impacted TSs and TRs: 31.111
- 4321: Defines at SIM-ME interface a basic protocol allowing SIM Toolkit applications to determine available bearers and to exchange data by selecting using the most appropriate bearer available (CS data, GPRS, SMS, Unstructured Supplementary Service Data (USSD) / Impacted TSs and TRs: 03.48, 11.10, 11.14
- 4322: Defines function and syntax of administrative commands for telecommunication IC Card used during installation, activation and de-activation of applications. Compliant to ISO/IEC 7816 series. Handed over to ETSI Project Smart Card Platform (SCP) in 2000. / Impacted TSs and TRs: ETSI TS 102 222
- 4323: High level requirements for 3GPP IC card and its interface to 3GPP terminal (USIM&UICC reqs). Service&security reqs in 322.01,22.00. USIM is a 3GPP application on an IC card. Inter-operates with 3GPP terminals and provides access to 3GPP services / Impacted TSs and TRs: 21.111
- 4324: - / Impacted TSs and TRs: 03.19
- 4325: - / Impacted TSs and TRs: 03.48, 11.11, 11.14
- 4326: No CR or new TS/TR approved under this WI / Impacted TSs and TRs: 11.18
- 4327: -
- 4328: Test spec for the interface between UICC and terminal (originally based GSM 11.10-1 clause 27). Ensures UICC - terminal interoperability independently of manufacturer, card issuer or operator. Tests for applications residing on UICC are in 31.121 / Impacted TSs and TRs: 31.120
- 4329: Application test spec originally based on GSM 11.17. Aspects related to UICC administrative management phase are not defined. Any internal technical realisation of either UICC or terminal is only specified where these are reflected over the interface. / Impacted TSs and TRs: 31.121
- 4330: Conformance Test specification for UICC defined in 31.101 with USIM defined in 31.102. / Impacted TSs and TRs: 31.122
- 4331: SIM Application Toolkit (SAT) has major impact on ME design and enhances SIM/ME interface. Contains tests for SIM/ME interface optional features (no network related signalling issues involved). Doesn't form basis for any type approval or regulatory tests. / Impacted TSs and TRs: 11.10-4
- 4332: - / Impacted TSs and TRs: 02.09, 03.20, 21.133, 22.022, 23.003, 23.007, 23.008, 23.012, 23.018, 24.007, 24.008, 24.010, 24.011, 29.002, 29.060, New (33.102, 33.103, 33.105, 33.107, 35.201)
- 4333: HPLMN can monitor its subscribers in VPLMN, which collects info on a defined set of monitored subscribers activities & sends it to HPLMN, which can perform service limitation control eg Operator Determined Barring (ODB) and IST to limit financial exposure / Impacted TSs and TRs: New 22.031, 23.031
- 4334: HPLMN can terminate all activities of its subscriber in VPLMN, if decides (based on info via eg FIGS) that a roaming subscriber is behaving in fraudulent/suspicious way. HPLMN can terminate all subscriber activities including calls in progress. / Impacted TSs and TRs: 03.35, 22.032, 23.008, 23.016, 23.035, 29.002
- 4335: - / Impacted TSs and TRs: 29.002
- 4336: -
- 4337: 2-99-1780 (2-99-H80 from SMG2#32) WID on BSS co-ordination of Radio Resource allocation for class A GPRS services - GSM Radio Access (R99) / Impacted TSs and TRs: 03.55, 03.64, 04.18, 04.60, 05.01, 05.02, 05.08, 08.08, 23.060, 24.007, 24.008
- 4338: - / Impacted TSs and TRs: 05.10
- 4339: - / Impacted TSs and TRs: 03.55, 03.64, 04.18, 05.01, 05.02, 05.08, 24.008

| ID | WBS | Task | Duration | Start | Finish | Complete | Baseline start | Baseline finish | Baseline duration | Constraint | Resources | Work | Actual work | Acronym | Release | MCC resp | Acronym_3GU_Export | TSG stopped | WI rapporteur name | WI rapporteur e-mail |
| --- | --- | --- | --- | --- | --- | --- | --- | --- | --- | --- | --- | --- | --- | --- | --- | --- | --- | --- | --- | --- |
| 4340 | 1030.2 | **General Packet Radio Service enahancements** | 261d? | 1999-01-01 A | 1999-12-31 A | 100% | 1999-01-01 | 1999-12-31 | 261d? |  | S1; S2; SMG1; SMG2; SMG7; N1; N2; N3; N4; T2 | 50112h | 50112h | GPRS enhancements | R99 | Alain | GPRS enhancements |  |  |  |
| 4341 | 1030.2.1 | General Packet Radio Service | 261d? | 1999-01-01 A | 1999-12-31 A | 100% | 1999-01-01 | 1999-12-31 | 261d? | start no earlier than 1999-01-01 | S1; S2; SMG1; SMG2; SMG7; N1; N2; N3; N4; T2 | 20880h | 20880h | GPRS | R99 | Alain | GPRS |  |  |  |
| 4342 | 1030.2.2 | GPRS2 | 261d? | 1999-01-01 A | 1999-12-31 A | 100% | 1999-01-01 | 1999-12-31 | 261d? | start no earlier than 1999-01-01 | SMG1; N2 | 4176h | 4176h | GPRS2 | R99 |  | GPRS2 |  |  |  |
| 4343 | 1030.2.3 | GPRS Tunnelling Protocol enhancement | 261d? | 1999-01-01 A | 1999-12-31 A | 100% | 1999-01-01 | 1999-12-31 | 261d? | start no earlier than 1999-01-01 | N4; N2 | 4176h | 4176h | GTP_enhancement | R99 | Kimmo | GTP_enhancement |  |  |  |
| 4344 | 1030.3 | **Enhanced Data rates for GSM Evolution - Phase 1** | 261d? | 1999-01-01 A | 1999-12-31 A | 100% | 1999-01-01 | 1999-12-31 | 261d? |  | SMG2; SMG1; SMG3; SMG4; SMG7; SMG9; SMG10; N1; N3; T2 | 73080h | 73080h | EDGE - Phase 1 | R99 | Maurice | EDGE - Phase 1 |  |  |  |
| 4345 | 1030.3.1 | Enhanced Data rates for GSM Evolution | 261d? | 1999-01-01 A | 1999-12-31 A | 100% | 1999-01-01 | 1999-12-31 | 261d? | start no earlier than 1999-01-01 | SMG2; SMG1; SMG3; SMG4; SMG7; SMG9; SMG10; N1; N3; T2 | 20880h | 20880h | EDGE | R99 | Maurice | EDGE |  |  |  |
| 4346 | 1030.3.2 | EDGE-Layer1 | 261d? | 1999-01-01 A | 1999-12-31 A | 100% | 1999-01-01 | 1999-12-31 | 261d? | start no earlier than 1999-01-01 | SMG2 | 2088h | 2088h | EDGE-Layer1 | R99 |  | EDGE-Layer1 |  |  |  |
| 4347 | 1030.3.3 | High Speed Circuit Switched Data | 261d? | 1999-01-01 A | 1999-12-31 A | 100% | 1999-01-01 | 1999-12-31 | 261d? | start no earlier than 1999-01-01 | SMG1; SMG2; SMG7 | 6264h | 6264h | HSCSD | R99 |  | HSCSD |  |  |  |
| 4348 | 1030.3.4 | Enhanced Circuit Switched Data - Phase 1 | 261d? | 1999-01-01 A | 1999-12-31 A | 100% | 1999-01-01 | 1999-12-31 | 261d? | start no earlier than 1999-01-01 | S1; SMG | 4176h | 4176h | ECSD | R99 | Alain | ECSD |  |  |  |
| 4349 | 1030.3.5 | EDGE-Enhanced Circuit Switched Data | 261d? | 1999-01-01 A | 1999-12-31 A | 100% | 1999-01-01 | 1999-12-31 | 261d? | start no earlier than 1999-01-01 | SMG2 | 2088h | 2088h | EDGE-ECSD | R99 |  | EDGE-ECSD |  |  |  |
| 4350 | 1030.3.6 | Enhanced GPRS - Phase 1 | 261d? | 1999-01-01 A | 1999-12-31 A | 100% | 1999-01-01 | 1999-12-31 | 261d? | start no earlier than 1999-01-01 | SMG; N1 | 4176h | 4176h | EGPRS | R99 |  | EGPRS |  |  |  |
| 4351 | 1030.3.7 | EDGE-EGPRS | 261d? | 1999-01-01 A | 1999-12-31 A | 100% | 1999-01-01 | 1999-12-31 | 261d? | start no earlier than 1999-01-01 | SMG2 | 2088h | 2088h | EDGE-EGPRS | R99 |  | EDGE-EGPRS |  |  |  |
| 4352 | 1030.3.8 | Packet Flow Context (PFC) | 261d? | 1999-01-01 A | 1999-12-31 A | 100% | 1999-01-01 | 1999-12-31 | 261d? | start no earlier than 1999-01-01 | SMG2 | 2088h | 2088h | PFC | R99 |  | PFC |  |  |  |
| 4353 | 1030.3.9 | Support for EGPRS in ANSI-136 networks and EDGE COMPACT | 261d? | 1999-01-01 A | 1999-12-31 A | 100% | 1999-01-01 | 1999-12-31 | 261d? | start no earlier than 1999-01-01 | SMG | 2088h | 2088h | EDGE-Compact | R99 |  | EDGE-Compact |  |  |  |
| 4354 | 1030.3.10 | EGPRS COMPACT | 261d? | 1999-01-01 A | 1999-12-31 A | 100% | 1999-01-01 | 1999-12-31 | 261d? | start no earlier than 1999-01-01 | SMG | 2088h | 2088h | EGPRS-Compact | R99 |  | EGPRS-Compact |  |  |  |
| 4355 | 1030.3.11 | COMPACT | 261d? | 1999-01-01 A | 1999-12-31 A | 100% | 1999-01-01 | 1999-12-31 | 261d? | start no earlier than 1999-01-01 | SMG; N1 | 4176h | 4176h | COMPACT | R99 |  | COMPACT |  |  |  |
| 4356 | 1030.4 | GSM_400 | 261d? | 1999-01-01 A | 1999-12-31 A | 100% | 1999-01-01 | 1999-12-31 | 261d? | start no earlier than 1999-01-01 | SMG2; SMG7; T2 | 6264h | 6264h | GSM_400 | R99 | Paolo | GSM_400 |  |  |  |
| 4357 | 1030.5 | GSM_450 | 261d? | 1999-01-01 A | 1999-12-31 A | 100% | 1999-01-01 | 1999-12-31 | 261d? | start no earlier than 1999-01-01 | SMG2 | 2088h | 2088h | GSM_450 | R99 |  | GSM_450 |  |  |  |
| 4358 | 1030.6 | GSM_700 | 261d? | 1999-01-01 A | 1999-12-31 A | 100% | 1999-01-01 | 1999-12-31 | 261d? | start no earlier than 1999-01-01 | SMG2 | 2088h | 2088h | GSM_700 | R99 |  | GSM_700 |  |  |  |
| 4359 | 1030.7 | Deleted - GERAN | 261d? | 1999-01-01 A | 1999-12-31 A | 100% | 1999-01-01 | 1999-12-31 | 261d? | start no earlier than 1999-01-01 | SMG2; S2 | 4176h | 4176h | GERAN | R99 | Maurice | GERAN | SP-06 |  |  |
| 4360 | 1031 | **GSM Features transposed to UMTS** | 261d? | 1999-01-01 A | 1999-12-31 A | 100% | 1999-01-01 | 1999-12-31 | 261d? |  | S1; S3; T2; N2; N4 | 31320h | 31320h |  | R99 | Alain |  |  |  |  |
| 4361 | 1031.1 | Cell Broadcast Service | 261d? | 1999-01-01 A | 1999-12-31 A | 100% | 1999-01-01 | 1999-12-31 | 261d? | start no earlier than 1999-01-01 | T2 | 2088h | 2088h | CBS | R99 |  | CBS |  |  |  |
| 4362 | 1031.2 | **GSM mobile number portability euro MNP / North American MNP** | 261d? | 1999-01-01 A | 1999-12-31 A | 100% | 1999-01-01 | 1999-12-31 | 261d? |  | S1; N2; N4 | 10440h | 10440h | MNP | R99 | Alain | MNP |  |  |  |
| 4363 | 1031.2.1 | Mobile Number Portability | 261d? | 1999-01-01 A | 1999-12-31 A | 100% | 1999-01-01 | 1999-12-31 | 261d? | start no earlier than 1999-01-01 | N2; N4 | 4176h | 4176h |  | R99 | Kimmo |  |  |  |  |
| 4364 | 1031.3 | Automatic establishment of roaming relations | 261d? | 1999-01-01 A | 1999-12-31 A | 100% | 1999-01-01 | 1999-12-31 | 261d? | start no earlier than 1999-01-01 | S1 | 2088h | 2088h |  | R99 | Alain |  |  | Telecom Italia | enrico.scarrone@telecomitalia.it |
| 4365 | 1031.4 | Advanced addressing | 261d? | 1999-01-01 A | 1999-12-31 A | 100% | 1999-01-01 | 1999-12-31 | 261d? | start no earlier than 1999-01-01 | S1 | 2088h | 2088h |  | R99 | Alain |  |  |  |  |
| 4366 | 1031.5 | UMTS numbering, addressing and identities | 261d? | 1999-01-01 A | 1999-12-31 A | 100% | 1999-01-01 | 1999-12-31 | 261d? | start no earlier than 1999-01-01 | S1 | 2088h | 2088h |  | R99 | Alain |  |  |  |  |
| 4367 | 1031.6 | Lawful Interception for GSM Features transposed to UMTS | 261d? | 1999-01-01 A | 1999-12-31 A | 100% | 1999-01-01 | 1999-12-31 | 261d? | start no earlier than 1999-01-01 | S3 | 2088h | 2088h | LI | R99 | Mirko | LI |  |  |  |

Notes:
- 4340: GPRS was introduced in Release 97. Release 99 brings a number of essential corrections e.g. on Downlink Power Control, Timing Advance procedure, Cell reselection delay time, PBCCH scheduling, PTCCH mapping, etc. / Impacted TSs and TRs: 05.02, 05.05, 05.08, 05.10, 05.50, 11.21, 23.064, 24.008, 24.060
- 4341: - / Impacted TSs and TRs: 02.60, 03.22, 03.64, 04.18, 04.60, 04.64, 04.65, 05.01, 05.02, 05.05, 05.08, 05.10, 08.08, 08.18, 11.10-1, 11.21, 22.041, 22.060, 23.003, 23.007, 23.060, 23.107, 23.122, 24.007, 24.008, 27.007, 27.060, 29.002, 29.016, 29.018, 29.060, 29.061
- 4342: Introduction of EGPRS (S1) + Introduction of Reserved Service Labels in the APN (N2) / Impacted TSs and TRs: 02.60, 23.003
- 4343: - / Impacted TSs and TRs: 23.003, 23.008, 29.060
- 4344: EDGE is independent of the frequency bands, so it can be deployed e.g. in 900 and 1900 MHz bands. The new physical layer based on 8-PSK modulation is introduced and EGPRS and ECSD facilitate the new modulation in single and multi slot constellation. / Impacted TSs and TRs: 10.59, 02.34, 02.60, 03.30, 05.10, 05.50, 11.26
- 4345: WID in SMG2 331/97, SMG 1147/97, SMG 1148/97 / Impacted TSs and TRs: 02.34, 03.10, 03.20, 03.64, 04.03, 04.04, 04.06, 04.08, 04.18, 04.21, 04.22, 04.60, 04.64, 05.01, 05.02, 05.03, 05.04, 05.05, 05.08, 05.10, 05.50, 07.01, 07.02, 07.03, 08.08, 08.20, 08.58, 08.60, 09.07, 09.18, 11.10-1, 11.11, 11.21, 11.26, 23.034, 24.008,
- 4346: WID in SMG2 331/97, SMG 1147/97, SMG 1148/97 / Impacted TSs and TRs: 05.05, 05.10, 05.50
- 4347: No additional features for R99. / Impacted TSs and TRs: 02.34, 04.18, 11.10-1
- 4348: ECSD supports both transparent and non-transparent services, up to 64 kbit/s and 57.6 kbit/s respectively. See Tdoc SMG2 670/99 ECSD Concept Evaluation for more info / Impacted TSs and TRs: 05.02, 08.58, 22.034
- 4349: - / Impacted TSs and TRs: 05.03
- 4350: - / Impacted TSs and TRs: 02.07, 03.64, 04.14, 04.18, 04.60, 05.05, 05.08, 24.008
- 4351: - / Impacted TSs and TRs: 05.03, 05.05, 05.08
- 4352: - / Impacted TSs and TRs: 04.18
- 4353: Support for EGPRS in ANSI-136 networks and EDGE Compact (for ANSI-136 networks only). COMPACT = Deployment of services in spectrum below 1 MHz / Impacted TSs and TRs: 03.22, 03.30, 03.64, 05.01, 05.02, 05.03, 05.05, 05.08, 05.10
- 4354: COMPACT = Deployment of services in spectrum below 1 MHz / Impacted TSs and TRs: 04.18, 05.02
- 4355: COMPACT = Deployment of services in spectrum below 1 MHz / Impacted TSs and TRs: 03.22, 04.18, 04.60, 05.08, 23.122, 24.008
- 4356: GSM in the 400 MHz bands allows to deploy GSM within frequency bands in the range 450 to 500 MHz, previously used for analogue cellular systems. See Tdoc SMG2 190/99 and 595/99 for further info. / Impacted TSs and TRs: 02.17, 03.22, 03.30, 04.04, 04.18, 04.60, 05.01, 05.02, 05.05, 05.08, 05.10, 05.50, 08.18, 08.58, 11.21, 24.008, 27.007
- 4357: - / Impacted TSs and TRs: 03.22, 03.30, 05.01, 05.05, 05.08
- 4358: - / Impacted TSs and TRs: 05.05
- 4359: No CR or new TS/TR approved under this WI / Impacted TSs and TRs: G2: 04.18 CR#A248 , 04.60 CR#B090
- 4360: -
- 4361: Moved to CT1 at TSG-T closure. Applicability of the Cell Broadcast Service (as defined for GSM network) to 3G networks / Impacted TSs and TRs: 23.041
- 4362: R98 MNP: mobile subscriber ability to change PLMN operator within the same country whilst retaining its original MS ISDN number (MSISDN). IMSI is changed, only MSISDN is kept. R99 adds requirements for North American Service Provider Number Portability. / Impacted TSs and TRs: 22.066
- 4363: - / Impacted TSs and TRs: 23.018, 23.066, 29.002
- 4364: framework for commercial and technical interworking between UMTS Home Environments and Serving Networks who have no direct prior commercial agreements with each other. / Impacted TSs and TRs: 22.101, 22.971
- 4365: - / Impacted TSs and TRs: 22.101, 22.75U, 22.975
- 4366: Also new requirements for Single and Multiple Numbering scheme was added (CR#20 and 21). Deleted the term International Mobile User Identifier (IMUI) and changed IMSI (International Mobile Station Identifier=>International Mobile Subscriber Identity. / Impacted TSs and TRs: 22.101
- 4367: Defines an interception system in UMTS that supports a number of regional interception regulations. Regional interception requirements shall be met in using specific (regional) mediation functions allowing only required information to be transported. / Impacted TSs and TRs: New 33.106, 33.107

| ID | WBS | Task | Duration | Start | Finish | Complete | Baseline start | Baseline finish | Baseline duration | Constraint | Resources | Work | Actual work | Release | MCC resp | Acronym | Acronym_3GU_Export |
| --- | --- | --- | --- | --- | --- | --- | --- | --- | --- | --- | --- | --- | --- | --- | --- | --- | --- |
| 4368 | 1032 | **Charging** | 261d? | 1999-01-01 A | 1999-12-31 A | 100% | 1999-01-01 | 1999-12-31 | 261d? |  | S1; S5 | 8352h | 8352h | R99 | Alain |  |  |
| 4369 | 1032.1 | R99 Charging | 261d? | 1999-01-01 A | 1999-12-31 A | 100% | 1999-01-01 | 1999-12-31 | 261d? | start no earlier than 1999-01-01 | S1 | 2088h | 2088h | R99 | Alain | Charging | Charging |
| 4370 | 1032.2 | R99 OAM Charging Management | 261d? | 1999-01-01 A | 1999-12-31 A | 100% | 1999-01-01 | 1999-12-31 | 261d? | start no earlier than 1999-01-01 | S5 | 2088h | 2088h | R99 | Mirko | OAMCH, CH | OAMCH, CH |
| 4371 | 1033 | **Operations, Administration, Maintenance and Provisioning (OAM&P)** | 261d? | 1999-01-01 A | 1999-12-31 A | 100% | 1999-01-01 | 1999-12-31 | 261d? |  | S5 | 12528h | 12528h | R99 | Mirko | OAM1999 | OAM1999 |
| 4372 | 1033.1 | OAM Principles and High-level Requirements | 261d? | 1999-01-01 A | 1999-12-31 A | 100% | 1999-01-01 | 1999-12-31 | 261d? | start no earlier than 1999-01-01 | S5 | 2088h | 2088h | R99 | Mirko | PR, Princs_&_Reqs_(PR) | PR, Princs_&_Reqs_(PR) |
| 4373 | 1033.2 | OAM Architecture | 261d? | 1999-01-01 A | 1999-12-31 A | 100% | 1999-01-01 | 1999-12-31 | 261d? | start no earlier than 1999-01-01 | S5 | 2088h | 2088h | R99 | Mirko | OAMAR, AR, Telecom_Management_Arch_(AR) | OAMAR, AR, Telecom_Management_Arch_(AR) |
| 4374 | 1033.3 | OAM Configuration Management | 261d? | 1999-01-01 A | 1999-12-31 A | 100% | 1999-01-01 | 1999-12-31 | 261d? | start no earlier than 1999-01-01 | S5 | 2088h | 2088h | R99 | Mirko | OAMCM, CM | OAMCM, CM |
| 4375 | 1033.4 | OAM Fault Management | 261d? | 1999-01-01 A | 1999-12-31 A | 100% | 1999-01-01 | 1999-12-31 | 261d? | start no earlier than 1999-01-01 | S5 | 2088h | 2088h | R99 | Mirko | OAMFM | OAMFM |
| 4376 | 1033.5 | OAM Performance Management | 261d? | 1999-01-01 A | 1999-12-31 A | 100% | 1999-01-01 | 1999-12-31 | 261d? | start no earlier than 1999-01-01 | S5 | 2088h | 2088h | R99 | Mirko | OAMPM, PM | OAMPM, PM |
| 4377 | 1034 | Vocabulary | 261d? | 1999-01-01 A | 1999-12-31 A | 100% | 1999-01-01 | 1999-12-31 | 261d? | start no earlier than 1999-01-01 | S1 | 2088h | 2088h | R99 | Alain | Vocabulary | Vocabulary |
| 4378 | 1035 | Emergency | 261d? | 1999-01-01 A | 1999-12-31 A | 100% | 1999-01-01 | 1999-12-31 | 261d? | start no earlier than 1999-01-01 | S1 | 2088h | 2088h | R99 | Alain | Emergency | Emergency |
| 4379 | 1036 | GSM General Bearer Services (GBS) and interworking scenarios support in UMTS | 261d? | 1999-01-01 A | 1999-12-31 A | 100% | 1999-01-01 | 1999-12-31 | 261d? | start no earlier than 1999-01-01 | S1 | 2088h | 2088h | R99 | Alain | GSM_to_UMTS_Evol | GSM_to_UMTS_Evol |
| 4380 | 1037 | GPRS_Mobile_IP_interworking | 261d? | 1999-01-01 A | 1999-12-31 A | 100% | 1999-01-01 | 1999-12-31 | 261d? | start no earlier than 1999-01-01 | N3 | 2088h | 2088h | R99 |  | GPRS_Mobile_IP_interworking | GPRS_Mobile_IP_interworking |
| 4381 | 1038 | GSM/UMTS interworking | 261d? | 1999-01-01 A | 1999-12-31 A | 100% | 1999-01-01 | 1999-12-31 | 261d? | start no earlier than 1999-01-01 | N1; N2; N4; R3; S1; SMG | 12528h | 12528h | R99 | Frederic | 2G3Ginterworking | 2G3Ginterworking |
| 4382 | 1039 | Handover | 261d? | 1999-01-01 A | 1999-12-31 A | 100% | 1999-01-01 | 1999-12-31 | 261d? | start no earlier than 1999-01-01 | S1; SMG2; N1; N2; N4 | 10440h | 10440h | R99 | Alain | Handover | Handover |
| 4383 | 1040 | 2G3Ghandover | 261d? | 1999-01-01 A | 1999-12-31 A | 100% | 1999-01-01 | 1999-12-31 | 261d? | start no earlier than 1999-01-01 | SMG2 | 2088h | 2088h | R99 |  | 2G3Ghandover | 2G3Ghandover |
| 4384 | 1041 | Service Provider Name Indication | 261d? | 1999-01-01 A | 1999-12-31 A | 100% | 1999-01-01 | 1999-12-31 | 261d? | start no earlier than 1999-01-01 | S1 | 2088h | 2088h | R99 | Alain | SPANME | SPANME |
| 4385 | 1042 | Data & Data_CleanUp | 261d? | 1999-01-01 A | 1999-12-31 A | 100% | 1999-01-01 | 1999-12-31 | 261d? | start no earlier than 1999-01-01 | SMG1 | 2088h | 2088h | R99 |  | Data, Data_CleanUp | Data, Data_CleanUp |
| 4386 | 1043 | Unstructured Supplementary Service Data (USSD) | 261d? | 1999-01-01 A | 1999-12-31 A | 100% | 1999-01-01 | 1999-12-31 | 261d? | start no earlier than 1999-01-01 | SMG1; N4 | 4176h | 4176h | R99 | Kimmo | USSD | USSD |
| 4387 | 1044 | Man-Machine Interface (MMI) of the User Equipment (UE) | 261d? | 1999-01-01 A | 1999-12-31 A | 100% | 1999-01-01 | 1999-12-31 | 261d? | start no earlier than 1999-01-01 | S1 | 2088h | 2088h | R99 | Alain | MMI | MMI |
| 4388 | 1045 | Network Identity and Timezone (NITZ) | 261d? | 1999-01-01 A | 1999-12-31 A | 100% | 1999-01-01 | 1999-12-31 | 261d? | start no earlier than 1999-01-01 | SMG1; SMG3 | 4176h | 4176h | R99 | Alain | NITZ | NITZ |
| 4389 | 1046 | Deleted - Operator Determined Barring for Packet Oriented Services | 261d? | 1999-01-01 A | 1999-12-31 A | 100% | 1999-01-01 | 1999-12-31 | 261d? | start no earlier than 1999-01-01 | S1 | 2088h | 2088h | R99 | Alain | ODB_Enh. | ODB_Enh. |
| 4390 | 1047 | Packet Flow Management | 261d? | 1999-01-01 A | 1999-12-31 A | 100% | 1999-01-01 | 1999-12-31 | 261d? | start no earlier than 1999-01-01 | SMG2 | 2088h | 2088h | R99 |  | Packet_Flow_Management | Packet_Flow_Management |
| 4391 | 1048 | GPRS_Point-To-Multipoint Group call | 261d? | 1999-01-01 A | 1999-12-31 A | 100% | 1999-01-01 | 1999-12-31 | 261d? | start no earlier than 1999-01-01 | SMG1 | 2088h | 2088h | R99 |  | GPRS_PTMG | GPRS_PTMG |

Notes:
- 4368: -
- 4369: - / Impacted TSs and TRs: 22.115, 23.121
- 4370: - / Impacted TSs and TRs: 32.005, 32.015
- 4371: -
- 4372: - / Impacted TSs and TRs: 32.101
- 4373: - / Impacted TSs and TRs: 32.101, 32.102
- 4374: - / Impacted TSs and TRs: 32.106, 32.106-1, 32.106-2, 32.106-3, 32.106-4, 32.106-5, 32.106-6, 32.106-7, 32.106-8
- 4375: - / Impacted TSs and TRs: 32.111, 32.111-1, 32.111-2, 32.111-3, 32.111-4
- 4376: - / Impacted TSs and TRs: 12.04, 32.104
- 4377: - / Impacted TSs and TRs: 21.905
- 4378: - / Impacted TSs and TRs: 22.101
- 4379: UMTS shall support GSM General Bearer Services (GBS) and interworking scenarios as specified in 02.02 / Impacted TSs and TRs: 22.105
- 4380: - / Impacted TSs and TRs: 29.061
- 4381: - / Impacted TSs and TRs: 03.22, 04.18, 04.60, 05.02, 05.08, 05.10, 08.08, 08.18, 08.58, 09.08, 22.011, 23.003, 23.009, 23.014, 23.034, 23.122, 24.007, 24.008, 24.011, 24.080, 29.108
- 4382: - / Impacted TSs and TRs: 04.18, 08.08, 08.58, 22.129, 23.009, 29.002, 29.010
- 4383: - / Impacted TSs and TRs: 04.18, 04.60, 05.02, 05.08, 05.10, 08.08, 29.010
- 4384: Service Provider Name Indication included in R98 (02.07) was not carried into R99 (22.101), but is in the SIM/USIM specification for R99 / Impacted TSs and TRs: 22.101
- 4385: - / Impacted TSs and TRs: 02.01, 02.02, 02.04, 02.34
- 4386: No additional features for R99. / Impacted TSs and TRs: 02.04, 02.90, 23.090, 29.002
- 4387: Data services streamlining + Support for Anonymous Call Rejection / Impacted TSs and TRs: 22.030
- 4388: - / Impacted TSs and TRs: 02.42, 04.08
- 4389: Remove ODB for Packet Oriented Services from R99 / Impacted TSs and TRs: 22.041
- 4390: - / Impacted TSs and TRs: 08.18
- 4391: - / Impacted TSs and TRs: 02.60

| ID | WBS | Task | Duration | Start | Finish | Complete | Baseline start | Baseline finish | Baseline duration | Constraint | Resources | Work | Actual work | Release | MCC resp | Acronym | Acronym_3GU_Export |
| --- | --- | --- | --- | --- | --- | --- | --- | --- | --- | --- | --- | --- | --- | --- | --- | --- | --- |
| 4392 | 1049 | **Call Forwarding** | 261d? | 1999-01-01 A | 1999-12-31 A | 100% | 1999-01-01 | 1999-12-31 | 261d? |  | SMG1; N2; N4 | 16704h | 16704h | R99 | Kimmo |  |  |
| 4393 | 1049.1 | Call Forwarding enhancements | 261d? | 1999-01-01 A | 1999-12-31 A | 100% | 1999-01-01 | 1999-12-31 | 261d? | start no earlier than 1999-01-01 | N4; N2 | 4176h | 4176h | R99 | Kimmo | CF_enhancements | CF_enhancements |
| 4394 | 1049.2 | Call_Forwarding | 261d? | 1999-01-01 A | 1999-12-31 A | 100% | 1999-01-01 | 1999-12-31 | 261d? | start no earlier than 1999-01-01 | SMG1; N2 | 4176h | 4176h | R99 | Kimmo | Call_Forwarding | Call_Forwarding |
| 4395 | 1049.3 | Call_Forwarding_Enhancements | 261d? | 1999-01-01 A | 1999-12-31 A | 100% | 1999-01-01 | 1999-12-31 | 261d? | start no earlier than 1999-01-01 | N4 | 2088h | 2088h | R99 | Kimmo | Call_Forwarding_Enhancements | Call_Forwarding_Enhancements |
| 4396 | 1050 | **Quality of Service** | 261d? | 1999-01-01 A | 1999-12-31 A | 100% | 1999-01-01 | 1999-12-31 | 261d? |  | S2; T2; N1; N2; N4 | 31320h | 31320h | R99 | Maurice |  |  |
| 4397 | 1050.1 | End-to-end UMTS Quality of Service management | 261d? | 1999-01-01 A | 1999-12-31 A | 100% | 1999-01-01 | 1999-12-31 | 261d? | start no earlier than 1999-01-01 | S2; T2; N1; N2; N4 | 10440h | 10440h | R99 | Maurice | QoS | QoS |
| 4398 | 1050.2 | End-to-end QoS for PS Domain including IMS | 261d? | 1999-01-01 A | 1999-12-31 A | 100% | 1999-01-01 | 1999-12-31 | 261d? | start no earlier than 1999-01-01 | S2 | 2088h | 2088h | R99 | Maurice | E2EQoS | E2EQoS |
| 4399 | 1050.3 | GPRS-enhanced_QoS | 261d? | 1999-01-01 A | 1999-12-31 A | 100% | 1999-01-01 | 1999-12-31 | 261d? | start no earlier than 1999-01-01 | T2 | 2088h | 2088h | R99 |  | GPRS-enhanced_QoS | GPRS-enhanced_QoS |
| 4400 | 1050.4 | QoS_enhancements | 261d? | 1999-01-01 A | 1999-12-31 A | 100% | 1999-01-01 | 1999-12-31 | 261d? | start no earlier than 1999-01-01 | N2; N1; N4 | 6264h | 6264h | R99 | Kimmo | QoS_enhancements | QoS_enhancements |
| 4401 | 1051 | Support of Localised Service Area | 261d? | 1999-01-01 A | 1999-12-31 A | 100% | 1999-01-01 | 1999-12-31 | 261d? | start no earlier than 1999-01-01 | SMG2; SMG3; SMG7; N2 | 8352h | 8352h | R99 | Maurice | SoLSA | SoLSA |
| 4402 | 1052 | Transcoder_location | 261d? | 1999-01-01 A | 1999-12-31 A | 100% | 1999-01-01 | 1999-12-31 | 261d? | start no earlier than 1999-01-01 | S2 | 2088h | 2088h | R99 | Maurice | Transcoder_location | Transcoder_location |
| 4403 | 1053 | Antenna_test_methods | 261d? | 1999-01-01 A | 1999-12-31 A | 100% | 1999-01-01 | 1999-12-31 | 261d? | start no earlier than 1999-01-01 | SMG2 | 2088h | 2088h | R99 |  | Antenna_test_methods | Antenna_test_methods |
| 4404 | 1054 | WBAMR / high quality speech in UMTS Phase 1 but not in R99 | 261d? | 1999-01-01 A | 1999-12-31 A | 100% | 1999-01-01 | 1999-12-31 | 261d? | start no earlier than 1999-01-01 | S1 | 2088h | 2088h | R99 | Alain | WBAMR | WBAMR |
| 4405 | 1055 | **Codec** | 261d? | 1999-01-01 A | 1999-12-31 A | 100% | 1999-01-01 | 1999-12-31 | 261d? |  | S4 | 27144h | 27144h | R99 | Paolo |  |  |
| 4406 | 1055.1 | **Codecs for Multimedia Telephony Service** | 261d? | 1999-01-01 A | 1999-12-31 A | 100% | 1999-01-01 | 1999-12-31 | 261d? |  | S4 | 14616h | 14616h | R99 | Paolo | Codec_for_Multimedia_Telephony | Codec_for_Multimedia_Telephony |
| 4407 | 1055.1.1 | Codecs for Multimedia Telephony Service | 261d? | 1999-01-01 A | 1999-12-31 A | 100% | 1999-01-01 | 1999-12-31 | 261d? | start no earlier than 1999-01-01 | S4 | 2088h | 2088h | R99 | Paolo | Multimedia_Codec | Multimedia_Codec |
| 4408 | 1055.1.2 | Codecs for Multimedia Telephony Service | 261d? | 1999-01-01 A | 1999-12-31 A | 100% | 1999-01-01 | 1999-12-31 | 261d? | start no earlier than 1999-01-01 | S4 | 2088h | 2088h | R99 | Paolo | CSM | CSM |
| 4409 | 1055.1.3 | Codecs for Multimedia Telephony Service | 261d? | 1999-01-01 A | 1999-12-31 A | 100% | 1999-01-01 | 1999-12-31 | 261d? | start no earlier than 1999-01-01 | S4 | 2088h | 2088h | R99 | Paolo | WI2MMC | WI2MMC |
| 4410 | 1055.1.4 | Codecs for Multimedia Telephony Service | 261d? | 1999-01-01 A | 1999-12-31 A | 100% | 1999-01-01 | 1999-12-31 | 261d? | start no earlier than 1999-01-01 | S4 | 2088h | 2088h | R99 | Paolo | Codec(s)_for_CS_MM_Tel._Serv | Codec(s)_for_CS_MM_Tel._Serv |
| 4411 | 1055.1.5 | Codecs for Multimedia Telephony Service | 261d? | 1999-01-01 A | 1999-12-31 A | 100% | 1999-01-01 | 1999-12-31 | 261d? | start no earlier than 1999-01-01 | S4 | 2088h | 2088h | R99 | Paolo | Codec(s)_for_MM_Tel_Service | Codec(s)_for_MM_Tel_Service |
| 4412 | 1055.1.6 | Codecs for Multimedia Telephony Service | 261d? | 1999-01-01 A | 1999-12-31 A | 100% | 1999-01-01 | 1999-12-31 | 261d? | start no earlier than 1999-01-01 | S4 | 2088h | 2088h | R99 | Paolo |  |  |
| 4413 | 1055.2 | QoS for Speech and Multimedia Codec | 261d? | 1999-01-01 A | 1999-12-31 A | 100% | 1999-01-01 | 1999-12-31 | 261d? | start no earlier than 1999-01-01 | S4 | 2088h | 2088h | R99 | Paolo | QoS_for_Speech_&_MM_Codecs_/_AMR | QoS_for_Speech_&_MM_Codecs_/_AMR |
| 4414 | 1055.3 | Tandem Free Operation - Adaptive Multi-Rate codec types | 261d? | 1999-01-01 A | 1999-12-31 A | 100% | 1999-01-01 | 1999-12-31 | 261d? | start no earlier than 1999-01-01 | S4 | 2088h | 2088h | R99 | Paolo | TFOAMR | TFOAMR |
| 4415 | 1055.4 | Noise Suppression for AMR | 261d? | 1999-01-01 A | 1999-12-31 A | 100% | 1999-01-01 | 1999-12-31 | 261d? | start no earlier than 1999-01-01 | S4 | 2088h | 2088h | R99 | Paolo | AMRNS | AMRNS |
| 4416 | 1055.5 | Out-of-Band Transcoder | 261d? | 1999-01-01 A | 1999-12-31 A | 100% | 1999-01-01 | 1999-12-31 | 261d? | start no earlier than 1999-01-01 | N1 | 2088h | 2088h | R99 | Frederic | OoBT | OoBT |
| 4417 | 1055.6 | Out-of-Band Transcoder Control | 261d? | 1999-01-01 A | 1999-12-31 A | 100% | 1999-01-01 | 1999-12-31 | 261d? | start no earlier than 1999-01-01 | N1 | 2088h | 2088h | R99 | Frederic | OoBTC | OoBTC |
| 4418 | 1056 | Advanced Speech Call Items enhancements | 261d? | 1999-01-01 A | 1999-12-31 A | 100% | 1999-01-01 | 1999-12-31 | 261d? | start no earlier than 1999-01-01 | SMG1; SMG2; SMG3; SMG7; SMG9; N1; N4; S1; T2 | 18792h | 18792h | R99 | Alain | ASCI | ASCI |
| 4419 | 1057 | Call Control improvements | 261d? | 1999-01-01 A | 1999-12-31 A | 100% | 1999-01-01 | 1999-12-31 | 261d? | start no earlier than 1999-01-01 | N1 | 2088h | 2088h | R99 | Frederic | CC_Related_items | CC_Related_items |
| 4420 | 1058 | Multimedia | 261d? | 1999-01-01 A | 1999-12-31 A | 100% | 1999-01-01 | 1999-12-31 | 261d? | start no earlier than 1999-01-01 | N1; N3 | 4176h | 4176h | R99 | Frederic | Multimedia | Multimedia |
| 4421 | 1059 | Sub-System Number allocation for RANAP, RNSAP | 261d? | 1999-01-01 A | 1999-12-31 A | 100% | 1999-01-01 | 1999-12-31 | 261d? | start no earlier than 1999-01-01 | N2 | 2088h | 2088h | R99 | Frederic | SSN_allocation | SSN_allocation |
| 4422 | 1060 | Intranet / ISP access with DHCP end-to-end | 261d? | 1999-01-01 A | 1999-12-31 A | 100% | 1999-01-01 | 1999-12-31 | 261d? | start no earlier than 1999-01-01 | N3 | 2088h | 2088h | R99 | Gwiho | ISPaccess | ISPaccess |
| 4423 | 1061 | Point_to_Multipoint_Services | 261d? | 1999-01-01 A | 1999-12-31 A | 100% | 1999-01-01 | 1999-12-31 | 261d? | start no earlier than 1999-01-01 | N3 | 2088h | 2088h | R99 | Gwiho | Point_to_Multipoint_Services | Point_to_Multipoint_Services |
| 4424 | 1062 | Facsimile | 261d? | 1999-01-01 A | 1999-12-31 A | 100% | 1999-01-01 | 1999-12-31 | 261d? | start no earlier than 1999-01-01 | S1 | 2088h | 2088h | R99 | Alain | FAX | FAX |
| 4425 | 1063 | Realtime_NT_FAX_in_UMTS | 261d? | 1999-01-01 A | 1999-12-31 A | 100% | 1999-01-01 | 1999-12-31 | 261d? | start no earlier than 1999-01-01 | N3 | 2088h | 2088h | R99 | Gwiho | Realtime_NT_FAX_in_UMTS | Realtime_NT_FAX_in_UMTS |
| 4426 | 1064 | Gateway Location Register (GLR) - Mobile Application Part (MAP) specification | 261d? | 1999-01-01 A | 1999-12-31 A | 100% | 1999-01-01 | 1999-12-31 | 261d? | start no earlier than 1999-01-01 | N4 | 2088h | 2088h | R99 | Kimmo | GLR | GLR |
| 4427 | 1065 | Multiple Subscriber Profile phase 2 | 261d? | 1999-01-01 A | 1999-12-31 A | 100% | 1999-01-01 | 1999-12-31 | 261d? | start no earlier than 1999-01-01 | S1; N4 | 4176h | 4176h | R99 | Alain | MSP2 | MSP2 |
| 4428 | 1066 | Prepaging | 261d? | 1999-01-01 A | 1999-12-31 A | 100% | 1999-01-01 | 1999-12-31 | 261d? | start no earlier than 1999-01-01 | N2; N4 | 4176h | 4176h | R99 | Kimmo | Prepaging | Prepaging |
| 4429 | 1067 | Re-definition of channel quality measure used for AMR link adaptation for Downlink Advanced Receiver Performance (DARP) MS | 261d? | 1999-01-01 A | 1999-12-31 A | 100% | 1999-01-01 | 1999-12-31 | 261d? | start no earlier than 1999-01-01 | SMG | 2088h | 2088h | R99 |  |  |  |
| 4430 | 1068 | Harmonized Standard | 261d? | 1999-01-01 A | 1999-12-31 A | 100% | 1999-01-01 | 1999-12-31 | 261d? | start no earlier than 1999-01-01 | SMG2 | 2088h | 2088h | R99 |  | HS | HS |
| 4431 | 1069 | Streamlining of specifications | 261d? | 1999-01-01 A | 1999-12-31 A | 100% | 1999-01-01 | 1999-12-31 | 261d? | start no earlier than 1999-01-01 | N3 | 2088h | 2088h | R99 | Gwiho | Streamlining | Streamlining |
| 4432 | 1070 | R99_Service_Clean_up | 261d? | 1999-01-01 A | 1999-12-31 A | 100% | 1999-01-01 | 1999-12-31 | 261d? | start no earlier than 1999-01-01 | N3 | 2088h | 2088h | R99 | Gwiho | R99_Service_Clean_up | R99_Service_Clean_up |

Notes:
- 4392: -
- 4393: No additional features for R99. / Impacted TSs and TRs: 23.078, 23.079, 23.082, 29.002, 29.078
- 4394: - / Impacted TSs and TRs: 02.82, 29.002
- 4395: - / Impacted TSs and TRs: 23.082
- 4396: WID SMG 98-0781 End To End UMTS QoS Management
- 4397: WID SMG 98-0781 End To End UMTS QoS Management / Impacted TSs and TRs: 23.107, 23.907, 24.008
- 4398: - / Impacted TSs and TRs: 23.060, 23.170
- 4399: AT-commands for Enhanced QoS Support management / Impacted TSs and TRs: 27.007
- 4400: - / Impacted TSs and TRs: 23.008, 23.016, 24.008, 29.002, 29.060
- 4401: Mechanism which can be used as a platform for providing special tariffs and/or special set of service features for certain subscribers within a regionally restricted area or areas. No additional features for R99. / Impacted TSs and TRs: 04.08, 04.18, 08.08, 11.10-1, 29.002
- 4402: UE location identification: background information and associated primitives 2. Transcoder location at the core network and source depending coding belonging to the non-access stratum. / Impacted TSs and TRs: 23.110
- 4403: - / Impacted TSs and TRs: 03.30
- 4404: Add requirement for high quality speech in UMTS Phase 1 but not in R99 / Impacted TSs and TRs: 22.105
- 4405: -
- 4406: -
- 4407: - / Impacted TSs and TRs: 26.911, 26.104, 26.111
- 4408: - / Impacted TSs and TRs: 26.911, 26.104, 26.111
- 4409: - / Impacted TSs and TRs: 26.911, 26.104, 26.111
- 4410: - / Impacted TSs and TRs: 26.911, 26.104, 26.111
- 4411: - / Impacted TSs and TRs: 26.911, 26.104, 26.111
- 4412: - / Impacted TSs and TRs: 26.911, 26.104, 26.111
- 4413: - / Impacted TSs and TRs: 26.102, 26.912
- 4414: UMTS_AMR2 is default Codec Type in R99 dual_mode terminals / Impacted TSs and TRs: 26.103
- 4415: Combination of the AMR speech codec and the Noise Suppression function. TS 06.77 and TR 06.78 only apply to GSM. They apply to UMTS from Rel-4 onwards, when they were converted to TS 26.077 and TR 26.078. / Impacted TSs and TRs: 06.77, 06.78
- 4416: Transcoder handling in the CN at inter-system handover and relocation + Introduction of UMTS AMR / Impacted TSs and TRs: 23.009, 24.008
- 4417: 24.008 CR#0572 in NP-020220 was approved under this WI / Impacted TSs and TRs: 24.008 CR#0572 in NP-020220
- 4418: - / Impacted TSs and TRs: 02.30, 02.68, 03.68, 03.69, 04.18, 08.08, 11.10-1, 11.11, 23.067, 23.094, 24.008, 24.067, 27.007, 29.002
- 4419: Minor improvements to 24.007 and 24.008 to increase the number of simultaneous calls/sessions from the present 7: the TI value is increased (NP-99441). / Impacted TSs and TRs: 24.007, 24.008
- 4420: - / Impacted TSs and TRs: 24.008, 27.001, 29.007
- 4421: Sub-System Number allocation for Radio Access Network Application Part, Radio Network Subsystem Application Part / Impacted TSs and TRs: 23.003
- 4422: Access to an Intranet/ISP with DHCP end to end / Impacted TSs and TRs: 29.061
- 4423: Support for the IP-Multicast protocol / Impacted TSs and TRs: 29.061
- 4424: - / Impacted TSs and TRs: 22.003, 22.100
- 4425: Asynchronous Interface for real-time NT Fax + Introduction of Asynchronous interface for Real-time non-transparent FAX / Impacted TSs and TRs: 27.001, 27.003
- 4426: - / Impacted TSs and TRs: 29.120
- 4427: - / Impacted TSs and TRs: 22.097, 23.072, 23.083, 23.084, 23.091, 23.093, 23.097
- 4428: - / Impacted TSs and TRs: 23.018, 23.082, 29.002
- 4429: Re-definition of channel quality measure used for AMR link adaptation for DARP MS / Impacted TSs and TRs: 05.09
- 4430: - / Impacted TSs and TRs: 13.21
- 4431: - / Impacted TSs and TRs: 27.060, 29.061
- 4432: - / Impacted TSs and TRs: 03.10, 27.001, 27.002, 27.003, 27.060, 29.007, 29.061

| ID | WBS | Task | Type | Duration | Start | Finish | Complete | Baseline start | Baseline finish | Baseline duration | Constraint | Resources | Work | Actual work | Acronym | Release | MCC resp | Acronym_3GU_Export | Impacted TSs and TRs | TSG stopped | WI rapporteur name | WI rapporteur e-mail |
| --- | --- | --- | --- | --- | --- | --- | --- | --- | --- | --- | --- | --- | --- | --- | --- | --- | --- | --- | --- | --- | --- | --- |
| 4433 | 1071 | **(Small) Technical Enhancements and Improvements for R99** |  | 261d? | 1999-01-01 A | 1999-12-31 A | 100% | 1999-01-01 | 1999-12-31 | 261d? |  | N3 | 6264h | 6264h | TEI | R99 | Gwiho | TEI |  |  |  |  |
| 4434 | 1071.1 | TEI_[CS_Data] |  | 261d? | 1999-01-01 A | 1999-12-31 A | 100% | 1999-01-01 | 1999-12-31 | 261d? | start no earlier than 1999-01-01 | N3 | 2088h | 2088h | TEI_[CS_Data] | R99 | Gwiho | TEI_[CS_Data] |  |  |  |  |
| 4435 | 1071.2 | TEI_[GPRS] |  | 261d? | 1999-01-01 A | 1999-12-31 A | 100% | 1999-01-01 | 1999-12-31 | 261d? | start no earlier than 1999-01-01 | N3 | 2088h | 2088h | TEI_[GPRS] | R99 | Gwiho | TEI_[GPRS] |  |  |  |  |
| 4436 | 1072 | **R99 UE Conformance Testing** |  | 261d? | 1999-01-01 A | 1999-12-31 A | 100% | 1999-01-01 | 1999-12-31 | 261d? |  | R5; T1 | 6264h | 6264h | TEI_Test | R99 | Ingbert | TEI_Test | 34.108, 34.121, 34.122, 34.123-1, 34.123-2, 34.123-3 |  |  |  |
| 4437 | 1072.1 | Deleted - RTEI |  | 261d? | 1999-01-01 A | 1999-12-31 A | 100% | 1999-01-01 | 1999-12-31 | 261d? | start no earlier than 1999-01-01 | T1 | 2088h | 2088h | RTEI | R99 | Ingbert | RTEI | 34.123-1 CR#0650, 0651, 34.123-3 CR#0148, 0149, 0150 | TP-06 |  |  |
| 4438 | 1072.2 | Common test environments for User Equipment (UE); Conformance testing | milestone | 0d? | 1999-01-01 A | 1999-01-01 A | 100% | 1999-01-01 | 1999-01-01 | 0d? | start no earlier than 1999-01-01 | R5; T1 |  |  |  | R99 | Ingbert |  | 34.108 |  |  |  |
| 4439 | 1072.3 | Terminal conformance specification, Radio transmission and reception (FDD) | milestone | 0d? | 1999-01-01 A | 1999-01-01 A | 100% | 1999-01-01 | 1999-01-01 | 0d? | start no earlier than 1999-01-01 | R5; T1 |  |  |  | R99 | Ingbert |  | 34.121 |  |  |  |
| 4440 | 1072.4 | Terminal conformance specification, Radio transmission and reception (TDD) | milestone | 0d? | 1999-01-01 A | 1999-01-01 A | 100% | 1999-01-01 | 1999-01-01 | 0d? | start no earlier than 1999-01-01 | R5; T1 |  |  |  | R99 | Ingbert |  | 34.122 |  |  |  |
| 4441 | 1072.5 | UE conformance specification; Part 1: Protocol conformance specification | milestone | 0d? | 1999-01-01 A | 1999-01-01 A | 100% | 1999-01-01 | 1999-01-01 | 0d? | start no earlier than 1999-01-01 | R5; T1 |  |  |  | R99 | Ingbert |  | 34.123-1 |  |  |  |
| 4442 | 1072.6 | UE conformance specification; Part 2: Implementation Conformance Statement (ICS) specification | milestone | 0d? | 1999-01-01 A | 1999-01-01 A | 100% | 1999-01-01 | 1999-01-01 | 0d? | start no earlier than 1999-01-01 | R5; T1 |  |  |  | R99 | Ingbert |  | 34.123-2 |  |  |  |
| 4443 | 1072.7 | UE conformance specification; Part 3: Abstract test suites (ATSs) | milestone | 0d? | 1999-01-01 A | 1999-01-01 A | 100% | 1999-01-01 | 1999-01-01 | 0d? | start no earlier than 1999-01-01 | R5; T1 |  |  |  | R99 | Ingbert |  | 34.123-3 |  |  |  |
| 4444 | 1073 | Deleted - Dual Tone Multi-Frequency signalling : Support in the whole 3GPP system |  | 261d? | 1999-01-01 A | 1999-12-31 A | 100% | 1999-01-01 | 1999-12-31 | 261d? | start no earlier than 1999-01-01 | N1 | 2088h | 2088h | DTMF | R99 | Frederic | DTMF | 23.014 CR#0004 | NP-06 |  |  |
| 4445 | 1074 | Deleted - Intersystem_Change |  | 261d? | 1999-01-01 A | 1999-12-31 A | 100% | 1999-01-01 | 1999-12-31 | 261d? | start no earlier than 1999-01-01 | SMG | 2088h | 2088h | Intersystem_Change | R99 |  | Intersystem_Change | 04.18 CR#A243 | SMG |  |  |
| 4446 | 1075 | Deleted - Long_Forwardedto_Numbers |  | 261d? | 1999-01-01 A | 1999-12-31 A | 100% | 1999-01-01 | 1999-12-31 | 261d? | start no earlier than 1999-01-01 | N2 | 2088h | 2088h | Long_Forwardedto_Numbers | R99 | Kimmo | Long_Forwardedto_Numbers | 29.002 | NP-06 |  |  |
| 4447 | 1076 | Deleted - RANimp-FSEarlyUE |  | 261d? | 1999-01-01 A | 1999-12-31 A | 100% | 1999-01-01 | 1999-12-31 | 261d? | start no earlier than 1999-01-01 | R3 | 2088h | 2088h | RANimp-FSEarlyUE | R99 | Juha | RANimp-FSEarlyUE | 25.413 CR#0520, 0538, 0565, 0563, 0541, 0540, 0539, 0547 | RP-06 |  |  |
| 4448 | 1077 | Release 1999 Studies |  | 261d? | 1999-01-01 A | 1999-12-31 A | 100% | 1999-01-01 | 1999-12-31 | 261d? |  | S1; T2 | 4176h | 4176h |  | R99 | Alain |  |  |  |  |  |
| 4449 | 1078 | Advanced Addressing/Numbering |  | 261d? | 1999-01-01 A | 1999-12-31 A | 100% | 1999-01-01 | 1999-12-31 | 261d? | start no earlier than 1999-01-01 | S1 | 2088h | 2088h | Numbering | R99 | Alain | Numbering | 22.975 |  | Vodafone | mona.mustapha@vodafone.com |
| 4450 | 1079 | Combined GSM and Mobile IP mobility handling in UMTS IP CN |  | 261d? | 1999-01-01 A | 1999-12-31 A | 100% | 1999-01-01 | 1999-12-31 | 261d? | start no earlier than 1999-01-01 | S2 | 2088h | 2088h |  | R99 | Maurice |  | 23.923 |  |  |  |
| 4451 | 1080 | UE Capabilities Requirements |  | 261d? | 1999-01-01 A | 1999-12-31 A | 100% | 1999-01-01 | 1999-12-31 | 261d? | start no earlier than 1999-01-01 | T2 | 2088h | 2088h | UCR | R99 |  | UCR | 21.904 |  |  |  |
| 4452 | 1081 | Electrical safety requirements and regulations |  | 261d? | 1999-01-01 A | 1999-12-31 A | 100% | 1999-01-01 | 1999-12-31 | 261d? | start no earlier than 1999-01-01 | T2 | 2088h | 2088h |  | R99 |  |  | 34.907 |  |  |  |
| 4453 | 1082 | Specific Absorbtion Rate (SAR) requirements and regulations in different regions |  | 261d? | 1999-01-01 A | 1999-12-31 A | 100% | 1999-01-01 | 1999-12-31 | 261d? | start no earlier than 1999-01-01 | T2 | 2088h | 2088h |  | R99 |  |  | 34.925 |  |  |  |
| 4454 | 1083 | Multi-mode UE issues |  | 261d? | 1999-01-01 A | 1999-12-31 A | 100% | 1999-01-01 | 1999-12-31 | 261d? | start no earlier than 1999-01-01 | T2 | 2088h | 2088h |  | R99 |  |  | 21.810, 21.910 |  |  |  |
| 4455 | 1084 | Provision of fax service in GSM and UMTS |  | 261d? | 1999-01-01 A | 1999-12-31 A | 100% | 1999-01-01 | 1999-12-31 | 261d? | start no earlier than 1999-01-01 | T2 | 2088h | 2088h |  | R99 |  |  | 22.945 |  | Ericsson | peter.bleckert@ericsson.com |
| 4456 | 1085 | Separating Radio Resources and Mobility Management specific parts of the MS Classmark |  | 261d | 1999-01-01 A | 1999-12-31 A | 100% | 1999-01-01 | 1999-12-31 | 261d |  | T2 | 2088h | 2088h |  | R99 |  |  | 23.814 |  |  |  |

Notes:
- 4433: -
- 4434: -
- 4435: -
- 4436: Specifies Conformance Tests for a 3G UE to be recognised as 3GPP-standard compliant. A 3GPP-external body, GCF (Global Certification Forum), delivers certificates to prove that a UE has correctly passed tests and is then conform to the 3GPP standard.
- 4437: No CR or new TS/TR approved under this WI
- 4438: -
- 4439: measurement procedures for the conformance test of the UE that contain transmitting characteristics, receiving characteristics and performance requirements in addition to requirements for support of RRM (Radio Resource Management) in FDD mode.
- 4440: measurement procedures for the conformance test of the UE that contain transmitting characteristics, receiving characteristics and performance requirements in addition to requirements for support of RRM (Radio Resource Management) in TDD mode.
- 4441: TS 34.123, composed of three parts, actually specifies the protocol conformance testing for the 3G UE. Part 1 describes the overall test structure.
- 4442: Part 2 contains the applicability of each test case defined as the Implementation Conformance Statement (ICS) proforma, in compliance with the relevant requirements, and in accordance with the relevant guidance given in ISO/IEC 9646-7 and ETS 300 406.
- 4443: Part 3 specifies the protocol conformance testing in TTCN for the 3G UE at the Uu interface. It defines the TTCN test specification and design considerations in Abstract Test Suites based on the test cases specified in prose in part 1.
- 4444: No CR or new TS/TR approved under this WI
- 4445: No CR or new TS/TR approved under this WI
- 4446: -
- 4447: No CR or new TS/TR approved under this WI
- 4448: -
- 4449: Study on requirements for numbering and addressing for UMTS
- 4450: -
- 4451: Moved to CT1 at TSG-T closure
- 4452: Moved to RAN4 at TSG-T closure. TR summarizes differences between international and national standards relevant to IEC60950 and refers to regulations for conformity assessment due to different regulatory environments in different countries / regions.
- 4453: Moved to RAN4 at TSG-T closure.
- 4454: Moved to CT1 at TSG-T closure. Consequences on roaming capabilities and service availability (e.g. handover) of multi-mode UEs while roaming in various regions with various network configurations. Case studies for each of the possible scenarios in specs
- 4455: CP#27: Moved to C1 on closure of T2; see TP-050062. CP#28: C1->C3
- 4456: CP#27: change of WG as a result of closure of CN and T.
